# Outline ELEXON Plan_kc

How a schedule from MS Project changed from version to version. A marks actual dates.

## Version 1 (data date 2024-08-23, saved 2024-10-18, file MHHS-DEL1139 - MHHS Plan v6.1.mpp)

| ID | WBS | Task | Duration | Start | Finish | Predecessors | Complete | Total float | Constraint |
| --- | --- | --- | --- | --- | --- | --- | --- | --- | --- |
| 1 | 1 | **PROGRAMME PLAN.** | 1344d? | 2022-10-31 A | 2027-12-23 |  | 51% | 0d |  |
| 2 |  | MHHS Programme Start | 0d | 2022-10-31 A | 2022-10-31 A |  | 100% |  |  |
| 3 | 1.2 | **PROGRAMME MANAGEMENT** | 1089d | 2022-10-31 A | 2026-12-31 |  | 44% | 255d |  |
| 4 | 1.2.1 | **Programme Management** | 1089d | 2022-10-31 A | 2026-12-31 |  | 43% | 255d |  |
| 5 |  | Sprint-based prioritisation planning and execution | 1089d | 2022-10-31 A | 2026-12-31 |  | 43% | 255d | finish no earlier than 2026-12-31 |
| 6 |  | Programme governance secretariat | 1089d | 2022-10-31 A | 2026-12-31 |  | 43% | 255d |  |
| 7 |  | RAID management and reporting | 1089d | 2022-10-31 A | 2026-12-31 |  | 43% | 255d |  |
| 8 |  | Tracking against Programme outcomes and KPIs | 1089d | 2022-10-31 A | 2026-12-31 |  | 43% | 255d |  |
| 9 |  | Change control and reporting | 1089d | 2022-10-31 A | 2026-12-31 |  | 43% | 255d |  |
| 10 |  | Ongoing identification of lessons learned relating to the PMO and implementation of improvements | 1089d | 2022-10-31 A | 2026-12-31 |  | 43% | 255d |  |
| 11 | 1.2.2 | **Programme Internal Assurance Reviews** | 1089d | 2022-10-31 A | 2026-12-31 |  | 43% | 255d |  |
| 12 |  | Programme Internal Assurance Reviews | 1089d | 2022-10-31 A | 2026-12-31 |  | 43% | 255d |  |
| 13 | 1.2.3 | **Engagement with PPs** | 1089d | 2022-10-31 A | 2026-12-31 |  | 43% | 255d |  |
| 14 |  | Ongoing PP liaison activities | 1089d | 2022-10-31 A | 2026-12-31 |  | 43% | 255d |  |
| 15 |  | Milestone and Control Point objective setting | 1089d | 2022-10-31 A | 2026-12-31 |  | 43% | 255d |  |
| 16 |  | Reporting | 1089d | 2022-10-31 A | 2026-12-31 |  | 43% | 255d |  |
| 17 | 1.2.3.4 | **PP Engagement Events** | 1089d | 2022-10-31 A | 2026-12-31 |  | 43% | 255d |  |
| 18 |  | Bilateral meetings | 1089d | 2022-10-31 A | 2026-12-31 |  | 43% | 255d |  |
| 19 |  | Monthly webinars | 1089d | 2022-10-31 A | 2026-12-31 |  | 43% | 255d |  |
| 20 |  | Open days | 1089d | 2022-10-31 A | 2026-12-31 |  | 43% | 255d |  |
| 21 | 1.2.3.5 | **PP Communications** | 1088d | 2022-10-31 A | 2026-12-30 |  | 43% | 256d |  |
| 22 |  | The Clock updates (weekly) | 1088d | 2022-10-31 A | 2026-12-30 |  | 43% | 256d |  |
| 23 |  | Maintain and update content on public-facing Portal (and ongoing feedback reviews to identify and implement Portal improvements) | 1088d | 2022-10-31 A | 2026-12-30 |  | 43% | 256d |  |
| 24 | 1.2.4 | **Code Change Support / Other Programme Alignment** | 1089d | 2022-10-31 A | 2026-12-31 |  | 43% | 255d |  |
| 25 |  | Support DCC/BEIS on SEC change | 1089d | 2022-10-31 A | 2026-12-31 |  | 43% | 255d |  |
| 26 |  | Support on Smart Meters Act changes | 1089d | 2022-10-31 A | 2026-12-31 |  | 43% | 255d |  |
| 27 |  | Support DCC/RECCo on CSS change | 1089d | 2022-10-31 A | 2026-12-31 |  | 43% | 255d |  |
| 28 |  | Support Elexon on BSC change | 1089d | 2022-10-31 A | 2026-12-31 |  | 43% | 255d |  |
| 29 |  | Support code change inside & outside CCIAG | 1089d | 2022-10-31 A | 2026-12-31 |  | 43% | 255d |  |
| 30 |  | Support code change inside & outside CCAG | 1089d | 2022-10-31 A | 2026-12-31 |  | 43% | 255d |  |
| 31 | 1.2.5 | **Programme Replan Baseline** | 163d | 2022-10-31 A | 2023-06-14 A |  | 100% |  |  |
| 32 |  | Round 3 consultation preparation | 32d | 2022-10-31 A | 2022-12-13 A |  | 100% |  |  |
| 33 |  | PSG decision to launch Round 3 consultation | 0d | 2022-12-07 A | 2022-12-07 A | 32FS-5d | 100% |  |  |
| 34 |  | Round 3 consultation (incl. walkthroughs and Q&A) | 35d | 2022-12-14 A | 2023-01-31 A | 33FS+5d | 100% |  |  |
| 35 |  | Review and uplift of foundational testing documents to align with replan approach | 92d | 2022-12-14 A | 2023-04-20 A | 34SS | 100% |  |  |
| 36 |  | Round 3 consultation responses analysis (incl. identification of SIT volunteers) | 10d | 2023-02-01 A | 2023-02-14 A | 34 | 100% |  |  |
| 37 |  | Replan re-drafting and supporting artefact updates (incl. engagement with Ofgem) | 26d | 2023-02-15 A | 2023-03-22 A | 36 | 100% |  |  |
| 38 |  | Draft Replan Change Request | 31d | 2023-02-15 A | 2023-03-29 A | 36 | 100% |  |  |
| 39 |  | PSG decision to issue CR for industry impact assessment | 0d | 2023-04-05 A | 2023-04-05 A | 38FS+5d | 100% |  |  |
| 40 |  | Industry impact assessment | 10d | 2023-04-06 A | 2023-04-19 A | 39 | 100% |  |  |
| 41 |  | Replan playbacks (to assist PPs in impact assessment) | 5d | 2023-04-11 A | 2023-04-17 A | 40SS+3d | 100% |  |  |
| 42 |  | Industry impact assessment responses analysis | 5d | 2023-04-20 A | 2023-04-26 A | 40 | 100% |  |  |
| 43 |  | Extraordinary PSG decision to agree baseline recommendation | 0d | 2023-05-03 A | 2023-05-03 A | 42FS+5d | 100% |  |  |
| 44 |  | Programme Replan playbacks and drop-in sessions | 5d | 2023-06-08 A | 2023-06-14 A |  | 100% |  |  |
| 45 | 1.3 | **DESIGN, BUILD & TEST (PIT)** | 1221d? | 2022-10-31 A | 2027-07-05 |  | 78% | 123d |  |
| 46 | 1.3.1 | **Design Baseline & Enduring PP Support** | 1101d | 2022-10-31 A | 2027-01-18 |  | 71% | 243d |  |
| 47 |  | Physical design baselined (M5) | 0d | 2022-10-31 A | 2022-10-31 A |  | 100% |  |  |
| 48 | 1.3.1.2 | **M5 Design Work-Off Plan Implementation & Approval** | 79d | 2022-10-31 A | 2023-02-16 A |  | 100% |  |  |
| 49 |  | Implementation of M5 design Work-Off Plan | 74d | 2022-10-31 A | 2023-02-09 A | 47 | 100% |  |  |
| 50 |  | M5 design Work-Off Plan completion approved | 0d | 2023-02-16 A | 2023-02-16 A | 49FS+5d | 100% |  |  |
| 51 | 1.3.1.3 | **Enduring PP Design Support** | 1089d | 2022-10-31 A | 2026-12-31 A |  | 100% |  |  |
| 52 |  | Design playbacks and drop-in sessions | 45d | 2022-10-31 A | 2022-12-30 A | 47 | 100% |  |  |
| 53 |  | Support participants on E2E MHHS Design | 1089d | 2022-10-31 A | 2026-12-31 A | 47 | 100% |  |  |
| 54 |  | DIP Onboarding Support | 70d | 2022-11-14 A | 2023-02-17 A |  | 100% |  | must start on 2022-11-14 |
| 55 |  | iServer Launch | 0d | 2023-02-16 A | 2023-02-16 A | 50 | 100% |  |  |
| 56 | 1.3.1.4 | **Establish Design Change Management Processes** | 1101d | 2022-10-31 A | 2027-01-18 |  | 36% | 243d |  |
| 57 |  | Internal review of internal change management processes | 35d | 2022-10-31 A | 2022-12-16 A |  | 100% |  |  |
| 58 |  | SRO approval of internal change management processes | 0d | 2022-12-16 A | 2022-12-16 A | 57FF | 100% |  |  |
| 59 |  | Change Process Webinar | 0d | 2023-01-16 A | 2023-01-16 A |  | 100% |  | must start on 2023-01-16 |
| 60 |  | Enduring change management process approved | 0d | 2023-02-16 A | 2023-02-16 A | 50FF | 100% |  |  |
| 61 |  | Maintain E2E MHHS Design (post-M5 design change management processes operational) | 1022d | 2023-02-17 A | 2027-01-18 | 60 | 34% | 243d |  |
| 62 | 1.3.1.5 | **Design Authority Mobilisation** | 29d | 2022-12-14 A | 2023-01-23 A |  | 100% |  |  |
| 63 |  | Design Authority ToR approved | 0d | 2022-12-14 A | 2022-12-14 A |  | 100% |  | must start on 2022-12-14 |
| 64 |  | Inaugural Design Authority | 0d | 2023-01-23 A | 2023-01-23 A | 63FS+29d | 100% |  |  |
| 65 | 1.3.1.6 | **Network Operation Services Adaptor Procurement** | 0d | 2023-05-23 A | 2023-05-23 A |  | 100% |  |  |
| 66 |  | All SIT LDSOs have procured their adapter providers | 0d | 2023-05-23 A | 2023-05-23 A | 581SS | 100% |  |  |
| 67 | 1.3.2 | **PP Mobilisation** | 67d | 2022-10-31 A | 2023-01-31 A |  | 100% |  |  |
| 68 |  | Set up governance | 67d | 2022-10-31 A | 2023-01-31 A |  | 100% |  |  |
| 69 |  | Set up reporting | 67d | 2022-10-31 A | 2023-01-31 A |  | 100% |  |  |
| 70 |  | Obtain funding | 67d | 2022-10-31 A | 2023-01-31 A |  | 100% |  |  |

| ID | WBS | Task | Duration | Start | Finish | Predecessors | Complete | Total float | Constraint |
| --- | --- | --- | --- | --- | --- | --- | --- | --- | --- |
| 71 |  | Earmark resources | 67d | 2022-10-31 A | 2023-01-31 A |  | 100% |  |  |
| 72 |  | Mobilise initial team | 67d | 2022-10-31 A | 2023-01-31 A |  | 100% |  |  |
| 73 | 1.3.3 | **PIT Stub Specification and Delivery** | 435d | 2022-10-31 A | 2024-06-28 A |  | 100% |  |  |
| 74 | 1.3.3.1 | **DIP Simulator** | 108d | 2022-10-31 A | 2023-03-29 A |  | 100% |  |  |
| 75 |  | Build & Test | 95d | 2022-10-31 A | 2023-03-10 A | 47 | 100% |  |  |
| 76 |  | UAT | 85d | 2022-11-14 A | 2023-03-10 A | 75SS+10d | 100% |  |  |
| 77 |  | Beta test | 95d | 2022-10-31 A | 2023-03-10 A | 75SS | 100% |  |  |
| 78 |  | Prepare for release | 18d | 2023-03-06 A | 2023-03-29 A | 77FS-5d | 100% |  |  |
| 79 |  | DIP Simulator released | 0d | 2023-03-29 A | 2023-03-29 A | 78FF | 100% |  | start no earlier than 2023-01-30 |
| 80 | 1.3.3.2 | **DIP Simulator Uplifts** | 257d | 2023-07-06 A | 2024-06-28 A |  | 100% |  |  |
| 81 |  | DIP Simulator uplifted to align with design releases - design/build/test | 27d | 2023-07-06 A | 2023-08-11 A | 117 | 100% |  |  |
| 82 |  | DIP Simulator uplifted to align with Interim Release 2 | 0d | 2023-08-11 A | 2023-08-11 A | 81 | 100% |  |  |
| 83 |  | DIP Simulator uplifted to align with design releases - design/build/test | 20d | 2023-10-09 A | 2023-11-03 A | 126FS+2d | 100% |  |  |
| 84 |  | DIP Simulator uplifted to align with Interim Release 5 | 0d | 2023-11-03 A | 2023-11-03 A | 83 | 100% |  |  |
| 85 |  | DIP Simulator uplifted to align with design releases - design/build/test | 37d | 2024-02-01 A | 2024-03-22 A | 134 | 100% |  |  |
| 86 |  | DIP Simulator uplifted to align with Interim Release 7 | 0d | 2024-03-22 A | 2024-03-22 A | 85 | 100% |  |  |
| 87 |  | DIP Simulator uplifted to align with design releases - design/build/test | 57d | 2024-04-04 A | 2024-06-21 A | 138 | 100% |  |  |
| 88 |  | DIP Simulator uplifted to align with Interim Release 8 | 0d | 2024-06-28 A | 2024-06-28 A | 87FS+5d | 100% |  |  |
| 89 | 1.3.3.3 | **Data Generator** | 130d | 2022-12-01 A | 2023-05-31 A |  | 100% |  |  |
| 90 |  | Design | 15d | 2022-12-01 A | 2022-12-21 A |  | 100% |  |  |
| 91 |  | Build & Test | 50d | 2023-02-16 A | 2023-04-26 A | 90FS+40d | 100% |  |  |
| 92 |  | UAT | 10d | 2023-04-27 A | 2023-05-10 A | 91 | 100% |  |  |
| 93 |  | Beta test | 45d | 2023-03-30 A | 2023-05-31 A | 91FS-20d, 95FF | 100% |  |  |
| 94 |  | Prepare for release | 24d | 2023-04-27 A | 2023-05-30 A | 92SS | 100% |  |  |
| 95 |  | Data Generator released | 0d | 2023-05-31 A | 2023-05-31 A | 94FS+1d | 100% |  |  |
| 96 | 1.3.4 | **Design Artefact Releases** | 451d | 2023-02-22 A | 2024-11-13 |  | 99% | 811d |  |
| 97 | 1.3.4.1 | **Interim release 1** | 79d | 2023-02-22 A | 2023-06-12 A |  | 100% |  |  |
| 98 |  | Prioritise DINs and CR | 1d | 2023-02-22 A | 2023-02-22 A |  | 100% |  | must start on 2023-02-22 |
| 99 | 1.3.4.1.2 | **Industry input session** | 7d | 2023-02-23 A | 2023-03-03 A |  | 100% |  |  |
| 100 |  | Raise a CR covering prioritized assessment cluster | 1d | 2023-02-23 A | 2023-02-23 A | 98 | 100% |  |  |
| 101 |  | Organize Industry Input session to go through significant items to reach consensus | 1d | 2023-02-23 A | 2023-02-23 A | 100SS | 100% |  |  |
| 102 |  | Conduct Meeting | 1d | 2023-03-03 A | 2023-03-03 A | 101FS+5d | 100% |  |  |
| 103 |  | Update baselined artefacts | 10d | 2023-03-24 A | 2023-04-06 A |  | 100% |  |  |
| 104 | 1.3.4.1.4 | **Participant review and impact assess changes** | 18d | 2023-04-14 A | 2023-05-09 A |  | 100% |  |  |
| 105 |  | Issue Redline Version of documents | 1d | 2023-04-14 A | 2023-04-14 A | 103FS+5d | 100% |  |  |
| 106 |  | Participants provide review comments to common log | 17d | 2023-04-17 A | 2023-05-09 A | 105 | 100% |  |  |
| 107 | 1.3.4.1.5 | **Assurance review** | 19d | 2023-05-10 A | 2023-06-05 A |  | 100% |  |  |
| 108 |  | SI Design Review and Respond to Comments | 5d | 2023-05-10 A | 2023-05-16 A | 106 | 100% |  |  |
| 109 |  | Prep for Assurance Review Meeting | 7d | 2023-05-17 A | 2023-05-25 A | 108 | 100% |  |  |
| 110 |  | Conduct Assurance Review Meeting | 1d | 2023-05-26 A | 2023-05-26 A | 109 | 100% |  |  |
| 111 |  | Update Artefacts following Assurance Review | 6d | 2023-05-29 A | 2023-06-05 A | 110 | 100% |  |  |
| 112 |  | PSG Approval of interim release plan | 1d | 2023-06-08 A | 2023-06-08 A |  | 100% |  | must start on 2023-06-08 |
| 113 |  | Publish updated baselined artefacts | 0d | 2023-06-06 A | 2023-06-12 A | 111 | 100% |  |  |
| 114 |  | Interim release 1 Go live | 0d | 2023-06-12 A | 2023-06-12 A | 113 | 100% |  |  |
| 115 | 1.3.4.2 | **Interim release 2** | 27d | 2023-05-30 A | 2023-07-05 A |  | 100% |  |  |
| 116 |  | Update baselined artefacts | 27d | 2023-05-30 A | 2023-07-05 A |  | 100% |  | must start on 2023-05-30 |
| 117 |  | Interim release 2 Go live | 0d | 2023-07-05 A | 2023-07-05 A | 116 | 100% |  |  |
| 118 | 1.3.4.3 | **Interim release 3** | 35d | 2023-06-15 A | 2023-08-02 A |  | 100% |  |  |
| 119 |  | Update baselined artefacts | 35d | 2023-06-15 A | 2023-08-02 A |  | 100% |  | must start on 2023-06-15 |
| 120 |  | Interim release 3 Go live | 0d | 2023-08-02 A | 2023-08-02 A | 119 | 100% |  |  |
| 121 | 1.3.4.4 | **Interim release 4** | 36d | 2023-07-12 A | 2023-08-30 A |  | 100% |  |  |
| 122 |  | Update baselined artefacts | 36d | 2023-07-12 A | 2023-08-30 A |  | 100% |  | must start on 2023-07-12 |
| 123 |  | Interim release 4 Go live | 0d | 2023-08-30 A | 2023-08-30 A | 122 | 100% |  |  |
| 124 | 1.3.4.5 | **Interim release 5** | 147d | 2023-08-17 A | 2024-03-08 A |  | 100% |  |  |
| 125 |  | Update baselined artefacts | 35d | 2023-08-17 A | 2023-10-04 A |  | 100% |  | must start on 2023-08-17 |
| 126 |  | Interim release 5 Go live | 0d | 2023-10-04 A | 2023-10-04 A | 125 | 100% |  |  |
| 127 |  | Interim Release 5 Deployed to SIT | 10d | 2024-02-26 A | 2024-03-08 A | 126FS+102d | 100% |  |  |
| 128 | 1.3.4.6 | **Interim release 6** | 192d | 2023-09-14 A | 2024-06-07 A |  | 100% |  |  |
| 129 |  | Update baselined artefacts | 35d | 2023-09-14 A | 2023-11-01 A |  | 100% |  | must start on 2023-09-14 |
| 130 |  | Interim release 6 Go live | 0d | 2023-11-01 A | 2023-11-01 A | 129 | 100% |  |  |
| 131 |  | Interim Release 6 Deployed to SIT | 10d | 2024-05-27 A | 2024-06-07 A | 130FS+147d | 100% |  |  |
| 132 | 1.3.4.7 | **Interim release 7** | 168d | 2023-10-18 A | 2024-06-07 A |  | 100% |  |  |
| 133 |  | Update baselined artefacts | 76d | 2023-10-18 A | 2024-01-31 A |  | 100% |  | start no earlier than 2023-10-18 |
| 134 |  | Interim release 7 Go live | 0d | 2024-01-31 A | 2024-01-31 A | 133 | 100% |  |  |
| 135 |  | Interim Release 7 Deployed to SIT | 10d | 2024-05-27 A | 2024-06-07 A | 134FS+82d | 100% |  |  |
| 136 | 1.3.4.8 | **Interim release 8** | 196d | 2024-02-14 A | 2024-11-13 |  | 99% | 811d |  |
| 137 |  | Update baselined artefacts | 36d | 2024-02-14 A | 2024-04-03 A |  | 100% |  | start no earlier than 2024-02-14 |
| 138 |  | Interim release 8 Go live | 0d | 2024-04-03 A | 2024-04-03 A | 137 | 100% |  | start no earlier than 2024-01-10 |
| 139 | 1.3.4.8.3 | **Interim Release 8.3 - Maintenance Window** | 11d | 2024-10-07 | 2024-10-21 |  |  | 16d |  |
| 140 |  | Interim Release 8.3 'effective from date' to SIT A | 0d | 2024-10-21 | 2024-10-21 | 138FS+143d |  | 5d |  |

| ID | WBS | Task | Duration | Start | Finish | Predecessors | Complete | Total float | Constraint |
| --- | --- | --- | --- | --- | --- | --- | --- | --- | --- |
| 141 |  | Interim Release 8.3 'effective from date' to SIT B | 0d | 2024-10-07 | 2024-10-07 | 140SS-11d |  | 38d |  |
| 142 | 1.3.4.8.4 | **Interim Release 8.4** | 36d | 2024-09-25 A | 2024-11-13 |  | 99% | 811d |  |
| 143 |  | Update baselined artefacts | 8d | 2024-09-25 A | 2024-10-04 A |  | 100% |  | start no earlier than 2024-09-25 |
| 144 |  | Interim release 8.4 Published | 0d | 2024-10-16 | 2024-10-16 | 143FS+8d |  | 811d | start no earlier than 2024-10-09 |
| 145 |  | Interim Release 8.4 Deployed to SIT by Participants | 0d | 2024-11-13 | 2024-11-13 | 144FS+20d |  | 811d |  |
| 146 | 1.3.5 | **Queries Support / Knowledgebase & Tool Roll-Out (Systems)** | 325d | 2023-01-03 A | 2024-04-01 A |  | 100% |  |  |
| 147 | 1.3.5.1 | **Query Management** | 325d | 2023-01-03 A | 2024-04-01 A |  | 100% |  |  |
| 148 |  | Respond to Participant Queries | 325d | 2023-01-03 A | 2024-04-01 A |  | 100% |  | must start on 2023-01-03 |
| 149 |  | Respond to Programme Queries | 325d | 2023-01-03 A | 2024-04-01 A | 148SS | 100% |  |  |
| 150 | 1.3.5.2 | **Query Support tooling (FreshDesk)** | 23d | 2023-06-01 A | 2023-07-03 A |  | 100% |  |  |
| 151 |  | Migrate to Standalone Freshdesk | 10d | 2023-06-01 A | 2023-06-14 A |  | 100% |  | must start on 2023-06-01 |
| 152 |  | Develop reporting dashboard | 5d | 2023-06-15 A | 2023-06-21 A | 151 | 100% |  |  |
| 153 |  | Issue to SRO for Review | 5d | 2023-06-22 A | 2023-06-28 A | 152 | 100% |  |  |
| 154 |  | Update following review | 2d | 2023-06-29 A | 2023-06-30 A | 153 | 100% |  |  |
| 155 |  | Sign off | 1d | 2023-07-03 A | 2023-07-03 A | 154 | 100% |  |  |
| 156 | 1.3.5.3 | **KnowledgeBase Development** | 72d | 2023-06-01 A | 2023-09-08 A |  | 100% |  |  |
| 157 |  | Define Scope of KB | 1d | 2023-06-01 A | 2023-06-01 A | 151SS | 100% |  |  |
| 158 |  | Capture Existing KB artefacts | 20d | 2023-06-02 A | 2023-06-29 A | 157 | 100% |  |  |
| 159 |  | Tag artefacts | 5d | 2023-06-30 A | 2023-07-06 A | 158 | 100% |  |  |
| 160 |  | Develop Participant Interfaces | 20d | 2023-07-07 A | 2023-08-03 A | 159 | 100% |  |  |
| 161 |  | Promote to Collaboration Portal | 21d | 2023-08-04 A | 2023-09-01 A | 160 | 100% |  |  |
| 162 |  | Link into FreshDesk | 5d | 2023-09-04 A | 2023-09-08 A | 161 | 100% |  |  |
| 163 | 1.3.6 | **PP Design, Build & Test (DBT)** | 1221d? | 2022-10-31 A | 2027-07-05 |  | 82% | 123d |  |
| 164 | 1.3.6.1 | **PP Impact Assessment, Planning & Procurement** | 110d | 2022-10-31 A | 2023-03-31 A |  | 100% |  |  |
| 165 | 1.3.6.1.1 | **PP Impact Assessment** | 67d | 2022-10-31 A | 2023-01-31 A |  | 100% |  |  |
| 166 |  | Develop heatmap for impact of MHHS | 67d | 2022-10-31 A | 2023-01-31 A | 47 | 100% |  |  |
| 167 |  | Develop detailed impact assessment | 67d | 2022-10-31 A | 2023-01-31 A | 47 | 100% |  |  |
| 168 | 1.3.6.1.2 | **PP Planning** | 67d | 2022-10-31 A | 2023-01-31 A |  | 100% |  |  |
| 169 |  | Develop detailed short-term plan | 23d | 2022-10-31 A | 2022-11-30 A | 47 | 100% |  |  |
| 170 |  | Develop overall project plan for implementation | 67d | 2022-10-31 A | 2023-01-31 A | 47 | 100% |  |  |
| 171 |  | Develop procurement plan | 67d | 2022-10-31 A | 2023-01-31 A | 47 | 100% |  |  |
| 172 | 1.3.6.1.3 | **PP Software/Service Procurement** | 110d | 2022-10-31 A | 2023-03-31 A |  | 100% |  |  |
| 173 |  | Run tender process | 67d | 2022-10-31 A | 2023-01-31 A | 47 | 100% |  |  |
| 174 |  | Select provider & sign commercials | 43d | 2023-02-01 A | 2023-03-31 A | 173 | 100% |  |  |
| 175 | 1.3.6.2 | **Design Handover** | 741d? | 2024-09-02 A | 2027-07-05 |  | 2% | 123d |  |
| 176 | 1.3.6.2.1 | **Creation of the Configuration Management Database** | 14d | 2024-09-02 | 2024-09-19 |  |  | 850d |  |
| 177 |  | Identify all baselined design artefacts | 9d | 2024-09-02 | 2024-09-12 |  |  | 850d | start no earlier than 2024-09-02 |
| 178 |  | Create CMBD | 5d | 2024-09-13 | 2024-09-19 | 177 |  | 850d |  |
| 179 | 1.3.6.2.2 | **Knowledge Transfer** | 41d? | 2024-09-02 | 2024-10-28 |  |  | 823d |  |
| 180 |  | Elexon to document knowledge transfer requirements | 9d? | 2024-09-02 | 2024-09-12 |  |  | 834d | start no earlier than 2024-09-02 |
| 181 |  | Review Requirements | 5d | 2024-09-13 | 2024-09-19 | 180 |  | 834d |  |
| 182 |  | Agree Success Criteria | 10d | 2024-09-20 | 2024-10-03 | 181 |  | 834d |  |
| 183 |  | Identify Key personel with Elexon | 3d | 2024-10-04 | 2024-10-08 | 182 |  | 834d |  |
| 184 |  | Draft Agenda for initial meeting | 1d? | 2024-10-09 | 2024-10-09 | 183 |  | 834d |  |
| 185 |  | Define cadence for handover sessions | 2d | 2024-10-10 | 2024-10-11 | 184 |  | 834d |  |
| 186 |  | Share Design Information | 20d | 2024-09-02 | 2024-09-27 |  |  | 844d | start no earlier than 2024-09-02 |
| 187 |  | Conduct Initial Handover Session | 20d? | 2024-10-01 | 2024-10-28 |  |  | 823d | start no earlier than 2024-10-01 |
| 188 | 1.3.6.2.3 | **Triage Sessions** | 131d? | 2024-10-01 | 2025-04-01 |  |  | 712d |  |
| 189 |  | Design Triage Sessions | 131d? | 2024-10-01 | 2025-04-01 |  |  | 712d | start no earlier than 2024-10-01 |
| 190 |  | Test Triage Sessions | 131d? | 2024-10-01 | 2025-04-01 |  |  | 712d | finish no earlier than 2025-04-01 |
| 191 | 1.3.6.2.4 | **Knowledge Base** | 9d | 2024-09-02 A | 2024-09-12 A |  | 100% |  |  |
| 192 |  | Document Knowledge base update process | 4d | 2024-09-02 A | 2024-09-05 A |  | 100% |  | start no earlier than 2024-09-02 |
| 193 |  | Document Design updates to Collaboration Base | 5d | 2024-09-06 A | 2024-09-12 A |  | 100% |  | start no earlier than 2024-09-06 |
| 194 | 1.3.6.2.5 | **FreshDesk** | 30d? | 2025-02-03 | 2025-03-14 |  |  | 724d |  |
| 195 |  | Agree Indicative Handover of FreshDesk Calls to Service Now | 4d | 2025-02-03 | 2025-02-06 |  |  | 750d | start no earlier than 2025-02-03 |
| 196 |  | Prepare Comms to Industry | 10d | 2025-02-07 | 2025-02-20 |  |  | 740d | start no earlier than 2025-02-07 |
| 197 |  | Issue Comms to Industry | 1d? | 2025-02-21 | 2025-02-21 |  |  | 739d | start no earlier than 2025-02-21 |
| 198 |  | Redirect Design Mailbox to Service Now | 1d? | 2025-03-03 | 2025-03-03 |  |  | 733d | start no earlier than 2025-03-03 |
| 199 |  | Archive Freshdesk calls | 5d | 2025-03-03 | 2025-03-07 |  |  | 729d | start no earlier than 2025-03-03 |
| 200 |  | Decommission FreshDesk | 5d | 2025-03-10 | 2025-03-14 |  |  | 724d | start no earlier than 2025-03-10 |
| 201 | 1.3.6.2.6 | **Iserver** | 611d? | 2025-03-03 A | 2027-07-05 |  | 5% |  |  |
| 202 |  | Gather Licensing information | 1d? | 2025-03-03 A | 2025-03-03 A |  | 100% |  | start no earlier than 2025-03-03 |
| 203 |  | Clear down old information | 5d | 2025-03-03 | 2025-03-07 |  |  | 715d |  |
| 204 |  | Clear down accounts | 2d | 2025-03-10 | 2025-03-11 | 203 |  | 715d | start no earlier than 2025-03-10 |
| 205 |  | Identify Collaboration Base Design Dependencies on iServer | 2d | 2025-04-01 | 2025-04-02 | 204 |  | 701d | start no earlier than 2025-04-01 |
| 206 |  | Remove Design dependencies | 5d | 2025-04-03 | 2025-04-09 | 205 |  | 701d | start no earlier than 2025-04-03 |
| 207 |  | Close down iServer | 5d | 2025-04-10 | 2025-04-16 | 206 |  | 701d | start no earlier than 2025-04-10 |
| 208 | 1.3.6.3 | **Central Systems DBT** | 325d | 2022-10-31 A | 2024-01-26 A |  | 100% |  |  |
| 209 | 1.3.6.3.1 | **Elexon Central Systems DBT CIT (Entering at Interval 1)** | 248d | 2022-10-31 A | 2023-10-11 A |  | 100% |  |  |
| 210 | 1.3.6.3.1.1 | **Design and Build** | 235d | 2022-10-31 A | 2023-09-22 A |  | 100% |  |  |

| ID | WBS | Task | Duration | Start | Finish | Predecessors | Complete | Constraint |
| --- | --- | --- | --- | --- | --- | --- | --- | --- |
| 211 |  | Helix Design and Build | 235d | 2022-10-31 A | 2023-09-22 A | 2 | 100% |  |
| 212 | 1.3.6.3.1.2 | **Test Approach & Plan** | 235d | 2022-10-31 A | 2023-09-22 A |  | 100% |  |
| 213 |  | Develop Test Approach & Plan | 180d | 2022-10-31 A | 2023-07-07 A |  | 100% |  |
| 214 |  | Elexon Central Systems Test Approach & Plan (PIT) submitted to Programme for assurance | 0d | 2023-07-13 A | 2023-07-13 A | 213FF+4d | 100% |  |
| 215 |  | Elexon Central Systems Test Approach & Plan (PIT) V2 resubmitted to Programme for assurance | 0d | 2023-07-27 A | 2023-07-27 A | 214FS+9d | 100% |  |
| 216 |  | Elexon Central Systems Test Approach & Plan (PIT) V3 resubmitted to Programme for assurance | 0d | 2023-08-18 A | 2023-08-18 A | 215FS+17d | 100% |  |
| 217 |  | Elexon Central Systems Test approach and plan MHHS Review Completed | 0d | 2023-09-22 A | 2023-09-22 A | 216FS+25d | 100% |  |
| 218 | 1.3.6.3.1.3 | **Test Readiness Report** | 16d | 2023-07-28 A | 2023-08-18 A |  | 100% |  |
| 219 |  | Test readiness reporting | 16d | 2023-07-28 A | 2023-08-18 A | 214FS+10d | 100% |  |
| 220 | 1.3.6.3.1.4 | **Requirements to test Traceability Matrix (RTTM)** | 35d | 2023-08-04 A | 2023-09-22 A |  | 100% |  |
| 221 |  | Elexon Central Systems RTTM submitted to Programme for assurance | 0d | 2023-08-04 A | 2023-08-04 A | 214 | 100% | start no earlier than 2023-04-28 |
| 222 |  | Elexon Central Systems RTTM MHHS Review Completed | 0d | 2023-09-22 A | 2023-09-22 A | 221FS+35d | 100% |  |
| 223 | 1.3.6.3.1.5 | **Test Scenarios** | 35d | 2023-08-04 A | 2023-09-22 A |  | 100% |  |
| 224 |  | Elexon Central Systems test scenarios submitted to Programme for assurance | 0d | 2023-08-04 A | 2023-08-04 A | 214 | 100% |  |
| 225 |  | Elexon Central Systems Test scenarios MHHS Review Completed | 0d | 2023-09-22 A | 2023-09-22 A | 224FS+35d | 100% |  |
| 226 | 1.3.6.3.1.6 | **PIT Execution** | 38d | 2023-08-21 A | 2023-10-11 A |  | 100% |  |
| 227 |  | PIT Test Execution Progress Report | 18d | 2023-09-04 A | 2023-09-27 A | 219FS+10d | 100% |  |
| 228 |  | Elexon Central Systems PIT Execution | 28d | 2023-08-21 A | 2023-09-27 A | 219 | 100% |  |
| 229 |  | Elexon Central Systems PIT Completion Report submitted to Programme for assurance | 0d | 2023-09-27 A | 2023-09-27 A | 228 | 100% |  |
| 230 |  | Elexon Central Systems PIT Completion Report MHHS Review Completed | 0d | 2023-10-11 A | 2023-10-11 A | 222, 225, 227, 229FS+10d, 217 | 100% |  |
| 231 | 1.3.6.3.2 | **DIP DBT CIT (Entering at Interval 1)** | 221d | 2023-01-02 A | 2023-11-06 A |  | 100% |  |
| 232 |  | Design | 80d | 2023-01-02 A | 2023-04-21 A |  | 100% | must start on 2023-01-02 |
| 233 |  | Build | 155d | 2023-01-09 A | 2023-08-11 A | 232SS+5d | 100% |  |
| 234 | 1.3.6.3.2.3 | **Test Approach & Plan** | 9d | 2023-07-07 A | 2023-07-20 A |  | 100% |  |
| 235 |  | DIP Test Approach & Plan (PIT) submitted to Programme for assurance | 0d | 2023-07-07 A | 2023-07-07 A |  | 100% |  |
| 236 |  | DIP Test Approach & Plan (PIT) MHHS Review Completed | 0d | 2023-07-20 A | 2023-07-20 A | 235FS+9d | 100% |  |
| 237 | 1.3.6.3.2.4 | **PIT Test Readiness Report** | 31d | 2023-07-21 A | 2023-09-01 A |  | 100% |  |
| 238 |  | Test readiness reporting | 31d | 2023-07-21 A | 2023-09-01 A | 235FS+9d | 100% |  |
| 239 | 1.3.6.3.2.5 | **Requirements to test Traceability Matrix (RTTM)** | 18d | 2023-08-04 A | 2023-08-30 A |  | 100% |  |
| 240 |  | DIP RTTM submitted to Programme for assurance | 0d | 2023-08-04 A | 2023-08-04 A | 235FS+15d | 100% |  |
| 241 |  | DIP RTTM MHHS Review Completed | 0d | 2023-08-30 A | 2023-08-30 A | 240FS+18d | 100% |  |
| 242 | 1.3.6.3.2.6 | **Test Scenarios** | 22d | 2023-07-31 A | 2023-08-30 A |  | 100% |  |
| 243 |  | DIP PIT test scenarios submitted to Programme for assurance | 0d | 2023-07-31 A | 2023-07-31 A | 235FS+15d | 100% |  |
| 244 |  | DIP Test scenarios MHHS Review Completed | 0d | 2023-08-30 A | 2023-08-30 A | 243FS+22d | 100% |  |
| 245 | 1.3.6.3.2.7 | **PIT execution** | 50d | 2023-08-29 A | 2023-11-06 A |  | 100% |  |
| 246 |  | PIT Test Execution Progress Report | 37d | 2023-09-01 A | 2023-10-23 A | 247FF, 238 | 100% | start no earlier than 2023-08-29 |
| 247 |  | PIT Execution (Interim Release 1) | 30d | 2023-08-29 A | 2023-10-09 A |  | 100% | start no earlier than 2023-08-29 |
| 248 |  | PIT Execution (Interim Release 2) | 10d | 2023-10-10 A | 2023-10-23 A | 247 | 100% |  |
| 249 |  | DIP PIT Completion Report (Interim Release 1) submitted to Programme for assurance | 0d | 2023-10-09 A | 2023-10-09 A | 247 | 100% |  |
| 250 |  | DIP PIT Completion Report (Interim Release 1) MHHS Review Completed | 0d | 2023-10-23 A | 2023-10-23 A | 249FS+10d | 100% |  |
| 251 |  | DIP PIT Completion Report (Interim Release 2) submitted to Programme for assurance | 0d | 2023-10-23 A | 2023-10-23 A | 248, 246 | 100% |  |
| 252 |  | DIP PIT Completion Report (Interim Release 2) MHHS Review Completed | 0d | 2023-11-06 A | 2023-11-06 A | 251FS+10d | 100% |  |
| 253 | 1.3.6.3.3 | **DCC (DSP) DBT SIT Functional (Entering at SIT Functional)** | 325d | 2022-10-31 A | 2024-01-26 A |  | 100% |  |
| 254 |  | Design | 67d | 2022-10-31 A | 2023-01-31 A |  | 100% |  |
| 255 | 1.3.6.3.3.2 | **Test Approach & Plan** | 20d | 2023-11-17 A | 2023-12-15 A |  | 100% |  |
| 256 |  | DCC Test Approach & Plan (PIT) submitted to Programme for assurance | 0d | 2023-11-17 A | 2023-11-17 A | 254FS+208d | 100% |  |
| 257 |  | DCC Test Approach & Plan (PIT) MHHS Review Completed | 0d | 2023-12-15 A | 2023-12-15 A | 256FS+20d | 100% |  |
| 258 | 1.3.6.3.3.3 | **Test Readiness Report** | 22d | 2023-12-04 A | 2024-01-02 A |  | 100% |  |
| 259 |  | Test readiness reporting | 22d | 2023-12-04 A | 2024-01-02 A | 256FS+10d | 100% |  |
| 260 | 1.3.6.3.3.4 | **Requirements to test Traceability Matrix (RTTM)** | 30d | 2023-12-15 A | 2024-01-26 A |  | 100% |  |
| 261 |  | DCC RTTM submitted to Programme for assurance | 0d | 2023-12-15 A | 2023-12-15 A | 256FS+20d | 100% | start no earlier than 2023-04-28 |
| 262 |  | DCC RTTM MHHS Review Completed | 0d | 2024-01-26 A | 2024-01-26 A | 261FS+30d | 100% |  |
| 263 | 1.3.6.3.3.5 | **Test Scenarios** | 30d | 2023-12-15 A | 2024-01-26 A |  | 100% |  |
| 264 |  | DCC test scenarios submitted to Programme for assurance | 0d | 2023-12-15 A | 2023-12-15 A | 256FS+20d | 100% |  |
| 265 |  | DCC Test Scenarios MHHS Review Completed | 0d | 2024-01-26 A | 2024-01-26 A | 264FS+30d | 100% |  |
| 266 | 1.3.6.3.4 | **RECCo (EES) DBT CIT (Entering at Interval 6)** | 71d | 2023-10-13 A | 2024-01-19 A |  | 100% |  |
| 267 | 1.3.6.3.4.1 | **Test Approach & Plan** | 20d | 2023-10-13 A | 2023-11-09 A |  | 100% |  |
| 268 |  | EES Test Approach & Plan (PIT) submitted to Programme for assurance | 0d | 2023-10-13 A | 2023-10-13 A |  | 100% | start no earlier than 2023-10-13 |
| 269 |  | EES Test approach and plan (PIT) MHHS Review Completed | 0d | 2023-11-09 A | 2023-11-09 A | 268FS+20d | 100% |  |
| 270 | 1.3.6.3.4.2 | **Test Readiness Report** | 10d | 2023-10-27 A | 2023-11-09 A |  | 100% |  |
| 271 |  | Test readiness reporting | 10d | 2023-10-27 A | 2023-11-09 A | 268FS+10d | 100% |  |
| 272 | 1.3.6.3.4.3 | **Requirements to test Traceability Matrix (RTTM)** | 20d | 2023-11-02 A | 2023-11-30 A |  | 100% |  |
| 273 |  | EES RTTM submitted to Programme for assurance | 0d | 2023-11-02 A | 2023-11-02 A | 268FS+15d | 100% |  |
| 274 |  | EES RTTM MHHS Review Completed | 0d | 2023-11-30 A | 2023-11-30 A | 273FS+20d | 100% |  |
| 275 | 1.3.6.3.4.4 | **Test Scenarios** | 20d | 2023-11-02 A | 2023-11-30 A |  | 100% |  |
| 276 |  | EES test scenarios submitted to Programme for assurance | 0d | 2023-11-02 A | 2023-11-02 A | 268FS+15d | 100% |  |
| 277 |  | EES Test scenarios MHHS Review Completed | 0d | 2023-11-30 A | 2023-11-30 A | 276FS+20d | 100% |  |
| 278 | 1.3.6.3.4.5 | **PIT execution** | 51d | 2023-11-10 A | 2024-01-19 A |  | 100% |  |
| 279 |  | PIT Test Execution Progress Report | 41d | 2023-11-10 A | 2024-01-05 A | 271 | 100% |  |
| 280 |  | PIT Execution | 41d | 2023-11-10 A | 2024-01-05 A | 276FS+5d | 100% |  |

| ID | WBS | Task | Duration | Start | Finish | Predecessors | Complete | Total float | Constraint |
| --- | --- | --- | --- | --- | --- | --- | --- | --- | --- |
| 281 |  | EES PIT Completion Report submitted to Programme for assurance | 0d | 2024-01-05 A | 2024-01-05 A | 279, 280 | 100% |  |  |
| 282 |  | EES PIT Completion Report MHHS Review Completed | 0d | 2024-01-19 A | 2024-01-19 A | 269, 274, 277, 281FS+10d | 100% |  |  |
| 283 | 1.3.6.3.5 | **Registration Services DBT CIT (Entering at Interval 2)** | 70d | 2023-07-28 A | 2023-11-03 A |  | 100% |  |  |
| 284 | 1.3.6.3.5.1 | **Test Approach & Plan** | 40d | 2023-07-28 A | 2023-09-22 A |  | 100% |  |  |
| 285 |  | Registration Services Test Approach & Plan (PIT) submitted to Programme for assurance | 0d | 2023-07-28 A | 2023-07-28 A |  | 100% |  |  |
| 286 |  | Registration Services Test approach and plan MHHS Review Completed | 0d | 2023-09-22 A | 2023-09-22 A | 285FS+40d | 100% |  |  |
| 287 | 1.3.6.3.5.2 | **Test Readiness Report** | 20d | 2023-08-14 A | 2023-09-08 A |  | 100% |  |  |
| 288 |  | Test readiness reporting | 20d | 2023-08-14 A | 2023-09-08 A | 285FS+10d | 100% |  |  |
| 289 | 1.3.6.3.5.3 | **Requirements to test Traceability Matrix (RTTM)** | 20d | 2023-09-01 A | 2023-09-29 A |  | 100% |  |  |
| 290 |  | Registration Services RTTM submitted to Programme for assurance | 0d | 2023-09-01 A | 2023-09-01 A | 285FS+15d | 100% |  | start no earlier than 2023-04-28 |
| 291 |  | Registration Services RTTM MHHS Review Completed | 0d | 2023-09-29 A | 2023-09-29 A | 290FS+20d | 100% |  |  |
| 292 | 1.3.6.3.5.4 | **Test Scenarios** | 20d | 2023-09-01 A | 2023-09-29 A |  | 100% |  |  |
| 293 |  | Registration Services test scenarios submitted to Programme for assurance | 0d | 2023-09-01 A | 2023-09-01 A | 285FS+15d | 100% |  |  |
| 294 |  | Registration Services Test scenarios MHHS Review Completed | 0d | 2023-09-29 A | 2023-09-29 A | 293FS+20d | 100% |  |  |
| 295 | 1.3.6.3.5.5 | **PIT execution** | 40d | 2023-09-11 A | 2023-11-03 A |  | 100% |  |  |
| 296 |  | PIT Test Execution Progress Report | 33d | 2023-09-11 A | 2023-10-25 A | 288 | 100% |  |  |
| 297 |  | PIT Execution | 30d | 2023-09-11 A | 2023-10-20 A | 293FS+5d | 100% |  |  |
| 298 |  | Registration Services PIT (CIT interval 2) Completion Report submitted to Programme for assurance | 0d | 2023-10-25 A | 2023-10-25 A | 296, 297 | 100% |  |  |
| 299 |  | Registration Services PIT (CIT interval 2) Completion Report MHHS Review Completed | 0d | 2023-11-03 A | 2023-11-03 A | 286, 291, 294, 298FS+7d | 100% |  |  |
| 300 | 1.3.6.4 | **SIT Participants DBT** | 356d | 2023-08-11 A | 2024-12-20 |  | 89% | 125d |  |
| 301 | 1.3.6.4.1 | **All Data Services DBT CIT (Entering at Interval 3)** | 71d | 2023-08-11 A | 2023-11-17 A |  | 100% |  |  |
| 302 | 1.3.6.4.1.1 | **Test Approach & Plan** | 30d | 2023-08-11 A | 2023-09-21 A |  | 100% |  |  |
| 303 |  | All Data Services Test Approach & Plans (PIT) submitted to Programme for assurance | 0d | 2023-08-11 A | 2023-08-11 A |  | 100% |  | start no earlier than 2023-08-11 |
| 304 |  | All Data Services Test approach and plans MHHS Review Completed | 0d | 2023-09-21 A | 2023-09-21 A | 303FS+30d | 100% |  |  |
| 305 | 1.3.6.4.1.2 | **Test Readiness Report** | 11d | 2023-08-25 A | 2023-09-08 A |  | 100% |  |  |
| 306 |  | Test readiness reporting | 11d | 2023-08-25 A | 2023-09-08 A | 303FS+10d | 100% |  |  |
| 307 | 1.3.6.4.1.3 | **Requirements to test Traceability Matrix (RTTM)** | 7d | 2023-09-20 A | 2023-09-29 A |  | 100% |  |  |
| 308 |  | All Data Services RTTMs submitted to Programme for assurance | 0d | 2023-09-20 A | 2023-09-20 A | 303FS+29d | 100% |  |  |
| 309 |  | All Data Services RTTMs MHHS Review Completed | 0d | 2023-09-29 A | 2023-09-29 A | 308FS+7d | 100% |  |  |
| 310 | 1.3.6.4.1.4 | **Test Scenarios** | 6d | 2023-09-20 A | 2023-09-28 A |  | 100% |  |  |
| 311 |  | All Data Services test scenarios' submitted to Programme for assurance | 0d | 2023-09-20 A | 2023-09-20 A | 303FS+29d | 100% |  |  |
| 312 |  | All Data Services Test scenarios' MHHS Review Completed | 0d | 2023-09-28 A | 2023-09-28 A | 311FS+6d | 100% |  |  |
| 313 | 1.3.6.4.1.5 | **PIT execution** | 50d | 2023-09-11 A | 2023-11-17 A |  | 100% |  |  |
| 314 |  | PIT Test Execution Progress Report | 40d | 2023-09-11 A | 2023-11-03 A | 306 | 100% |  |  |
| 315 |  | PIT Execution | 27d | 2023-09-28 A | 2023-11-03 A | 311FS+5d | 100% |  |  |
| 316 |  | All Data Services PIT Completion Reports submitted to Programme for assurance | 0d | 2023-11-03 A | 2023-11-03 A | 314, 315 | 100% |  |  |
| 317 |  | All Data Services PIT Completion Reports MHHS Review Completed | 0d | 2023-11-17 A | 2023-11-17 A | 304, 309, 312, 316FS+10d | 100% |  |  |
| 318 | 1.3.6.4.2 | **All Metering Services DBT CIT (Entering at Interval 4)** | 70d | 2023-08-25 A | 2023-12-01 A |  | 100% |  |  |
| 319 | 1.3.6.4.2.1 | **Test Approach & Plan** | 40d | 2023-08-25 A | 2023-10-20 A |  | 100% |  |  |
| 320 |  | All Metering Services Test Approach & Plans (PIT) submitted to Programme for assurance | 0d | 2023-08-25 A | 2023-08-25 A |  | 100% |  |  |
| 321 |  | All Metering Services Test approach and plans MHHS Review Completed | 0d | 2023-10-20 A | 2023-10-20 A | 320FS+40d | 100% |  |  |
| 322 | 1.3.6.4.2.2 | **Test Readiness Report** | 11d | 2023-09-11 A | 2023-09-25 A |  | 100% |  |  |
| 323 |  | Test readiness reporting | 11d | 2023-09-11 A | 2023-09-25 A | 320FS+10d | 100% |  |  |
| 324 | 1.3.6.4.2.3 | **Requirements to test Traceability Matrix (RTTM)** | 30d | 2023-09-15 A | 2023-10-27 A |  | 100% |  |  |
| 325 |  | All Metering Services RTTMs submitted to Programme for assurance | 0d | 2023-09-15 A | 2023-09-15 A | 320FS+15d | 100% |  |  |
| 326 |  | All Metering Services MHHS Reviews Completed | 0d | 2023-10-27 A | 2023-10-27 A | 325FS+30d | 100% |  |  |
| 327 | 1.3.6.4.2.4 | **Test Scenarios** | 30d | 2023-09-15 A | 2023-10-27 A |  | 100% |  |  |
| 328 |  | All Metering Services test scenarios' submitted to Programme for assurance | 0d | 2023-09-15 A | 2023-09-15 A | 320FS+15d | 100% |  |  |
| 329 |  | All Metering Services Test scenarios' MHHS Review Completed | 0d | 2023-10-27 A | 2023-10-27 A | 328FS+30d | 100% |  |  |
| 330 | 1.3.6.4.2.5 | **PIT execution** | 50d | 2023-09-25 A | 2023-12-01 A |  | 100% |  |  |
| 331 |  | PIT Test Execution Progress Report | 39d | 2023-09-26 A | 2023-11-17 A | 323 | 100% |  |  |
| 332 |  | PIT Execution | 40d | 2023-09-25 A | 2023-11-17 A | 328FS+5d | 100% |  |  |
| 333 |  | All Metering Services PIT Completion Reports submitted to Programme for assurance | 0d | 2023-11-17 A | 2023-11-17 A | 331, 332 | 100% |  |  |
| 334 |  | All Metering Services PIT Completion Reports MHHS Review Completed | 0d | 2023-12-01 A | 2023-12-01 A | 321, 326, 329, 333FS+10d | 100% |  |  |
| 335 | 1.3.6.4.3 | **All SIT Programme Participants PIT (SIT Functional)** | 286d | 2023-11-17 A | 2024-12-20 |  | 77% | 125d |  |
| 336 | 1.3.6.4.3.1 | **Test Approach & Plans** | 40d | 2023-11-17 A | 2024-01-11 A |  | 100% |  |  |
| 337 |  | SIT Functional PIT Test Approach & Plan (PIT) submitted to Programme for assurance | 0d | 2023-11-17 A | 2023-11-17 A |  | 100% |  | start no earlier than 2023-11-17 |
| 338 |  | All SIT Functional Test approach and plans MHHS Reviews Completed | 0d | 2024-01-11 A | 2024-01-11 A | 337FS+40d | 100% |  |  |
| 339 | 1.3.6.4.3.2 | **Test Readiness Reports** | 11d | 2023-12-01 A | 2023-12-15 A |  | 100% |  |  |
| 340 |  | Test readiness reporting | 11d | 2023-12-01 A | 2023-12-15 A | 337FS+10d | 100% |  |  |
| 341 | 1.3.6.4.3.3 | **Requirements to test Traceability Matrices (RTTM)** | 30d | 2023-12-07 A | 2024-01-18 A |  | 100% |  |  |
| 342 |  | SIT Functional PIT RTTM submitted to Programme for assurance | 0d | 2023-12-07 A | 2023-12-07 A | 337FS+15d | 100% |  |  |
| 343 |  | All SIT Functional RTTMs MHHS Reviews Completed | 0d | 2024-01-18 A | 2024-01-18 A | 342FS+30d | 100% |  |  |
| 344 | 1.3.6.4.3.4 | **Test Scenarios** | 30d | 2023-12-07 A | 2024-01-18 A |  | 100% |  |  |
| 345 |  | SIT Functional PIT test scenarios submitted to Programme for assurance | 0d | 2023-12-07 A | 2023-12-07 A | 337FS+15d | 100% |  |  |
| 346 |  | All SIT Functional Test scenarios' MHHS Reviews Completed | 0d | 2024-01-18 A | 2024-01-18 A | 345FS+30d | 100% |  |  |
| 347 | 1.3.6.4.3.5 | **PIT execution** | 51d | 2023-12-15 A | 2024-02-23 A |  | 100% |  |  |
| 348 |  | PIT Test Execution Progress Reports | 40d | 2023-12-18 A | 2024-02-09 A | 340 | 100% |  |  |
| 349 |  | PIT Execution | 41d | 2023-12-15 A | 2024-02-09 A | 345FS+5d | 100% |  |  |
| 350 |  | All SIT Functional PIT Completion Reports submitted to Programme for Assurance | 0d | 2024-02-09 A | 2024-02-09 A | 348, 349 | 100% |  |  |

| ID | WBS | Task | Duration | Start | Finish | Predecessors | Complete | Total float | Constraint |
| --- | --- | --- | --- | --- | --- | --- | --- | --- | --- |
| 351 |  | All SIT Functional PIT Completion Reports MHHS Review Completed | 0d | 2024-02-23 A | 2024-02-23 A | 338, 343, 346, 350FS+10d | 100% |  |  |
| 352 | 1.3.6.4.3.6 | **All SIT Programme Participants PIT (SIT Migration)** | 71d | 2024-02-16 A | 2024-05-24 A |  | 100% |  |  |
| 353 | 1.3.6.4.3.6.1 | **Test Approach & Plans** | 40d | 2024-02-16 A | 2024-04-11 A |  | 100% |  |  |
| 354 |  | All SIT Migration PIT Test Approach & Plans submitted to Programme for assurance | 0d | 2024-02-16 A | 2024-02-16 A |  | 100% |  | start no earlier than 2024-02-16 |
| 355 |  | All SIT Migration PIT Test approach and plans MHHS Reviews Completed | 0d | 2024-04-11 A | 2024-04-11 A | 354FS+40d | 100% |  |  |
| 356 | 1.3.6.4.3.6.2 | **Test Readiness Reports** | 11d | 2024-03-01 A | 2024-03-15 A |  | 100% |  |  |
| 357 |  | Test readiness reporting | 11d | 2024-03-01 A | 2024-03-15 A | 354FS+10d | 100% |  |  |
| 358 | 1.3.6.4.3.6.3 | **Requirements to test Traceability Matrices (RTTM)** | 30d | 2024-03-07 A | 2024-04-18 A |  | 100% |  |  |
| 359 |  | All SIT Migration PIT RTTMs submitted to Programme for assurance | 0d | 2024-03-07 A | 2024-03-07 A | 354FS+15d | 100% |  |  |
| 360 |  | All SIT Migration RTTMs MHHS Reviews Completed | 0d | 2024-04-18 A | 2024-04-18 A | 359FS+30d | 100% |  |  |
| 361 | 1.3.6.4.3.6.4 | **Test Scenarios** | 30d | 2024-03-07 A | 2024-04-18 A |  | 100% |  |  |
| 362 |  | All SIT Migration PIT test scenarios submitted to Programme for assurance | 0d | 2024-03-07 A | 2024-03-07 A | 354FS+15d | 100% |  |  |
| 363 |  | All SIT Migration Test scenarios MHHS Reviews Completed | 0d | 2024-04-18 A | 2024-04-18 A | 362FS+30d | 100% |  |  |
| 364 | 1.3.6.4.3.6.5 | **PIT execution** | 51d | 2024-03-15 A | 2024-05-24 A |  | 100% |  |  |
| 365 |  | PIT Test Execution Progress Reports | 40d | 2024-03-18 A | 2024-05-10 A | 357 | 100% |  |  |
| 366 |  | PIT Execution | 41d | 2024-03-15 A | 2024-05-10 A | 362FS+5d | 100% |  |  |
| 367 |  | All SIT Migration PIT Completion Reports submitted to Programme for assurance | 0d | 2024-05-10 A | 2024-05-10 A | 365, 366 | 100% |  |  |
| 368 |  | All SIT Migration PIT Completion Reports MHHS Review Completed | 0d | 2024-05-24 A | 2024-05-24 A | 355, 360, 363, 367FS+10d | 100% |  |  |
| 369 | 1.3.6.4.3.7 | **All SIT Programme Participants PIT (SIT Non Functional)** | 116d | 2024-07-12 A | 2024-12-20 |  | 63% | 125d |  |
| 370 | 1.3.6.4.3.7.1 | **Test Approach & Plan** | 41d | 2024-09-27 A | 2024-11-22 |  |  | 145d |  |
| 371 |  | SIT Non-Functional PIT Test Approach & Plan (PIT) submitted to Programme for assurance | 0d | 2024-09-27 A | 2024-09-27 |  | 75% | 0d | start no earlier than 2024-05-10 |
| 372 |  | SIT Non-Functional Test approach and plan MHHS Review Completed | 1d | 2024-11-21 A | 2024-11-22 | 371FS+40d |  | 145d |  |
| 373 | 1.3.6.4.3.7.2 | **Test Readiness Report** | 13d | 2024-10-04 A | 2024-10-22 |  | 85% | 0d |  |
| 374 |  | Test readiness reporting | 13d | 2024-10-04 A | 2024-10-22 | 371FS+10d | 85% | 0d |  |
| 375 | 1.3.6.4.3.7.3 | **Requirements to test Traceability Matrix (RTTM)** | 20d | 2024-11-01 A | 2024-11-29 |  |  | 140d |  |
| 376 |  | SIT Non-Functional PIT RTTM submitted to Programme for assurance | 0d | 2024-11-01 A | 2024-11-01 | 371FS+26d | 75% | 140d |  |
| 377 |  | SIT Non-Functional RTTM MHHS Review Completed | 0d | 2024-11-29 | 2024-11-29 | 376FS+20d |  | 140d | start no earlier than 2024-11-29 |
| 378 | 1.3.6.4.3.7.4 | **Test Scenarios** | 20d | 2024-11-01 | 2024-11-29 |  |  | 0d |  |
| 379 |  | SIT Non-Functional PIT test scenarios submitted to Programme for assurance | 0d | 2024-11-01 | 2024-11-01 | 371FS+26d |  | 0d |  |
| 380 |  | SIT Non-Functional Test scenarios MHHS Review Completed | 0d | 2024-11-29 | 2024-11-29 | 379FS+20d |  | 140d |  |
| 381 | 1.3.6.4.3.7.5 | **PIT execution** | 116d | 2024-07-12 A | 2024-12-20 |  | 61% | 125d |  |
| 382 |  | PIT Test Execution Progress Report | 50d | 2024-07-15 A | 2024-11-21 | 374 | 56% | 131d | finish no earlier than 2024-11-21 |
| 383 |  | PIT Execution | 44d | 2024-07-12 A | 2024-11-29 | 379FS+5d | 66% | 125d | finish no earlier than 2024-11-29 |
| 384 |  | SIT Non-Functional PIT Completion Report submitted to Programme for assurance | 0d | 2024-11-29 | 2024-11-29 | 382, 383 |  | 125d |  |
| 385 |  | SIT Non-Functional PIT Completion Report MHHS Review Completed | 0d | 2024-12-20 | 2024-12-20 | 372, 377, 380, 384FS+15d |  | 125d |  |
| 386 | 1.3.6.4.3.8 | **All SIT Programme Participants PIT (SIT Operational)** | 116d | 2024-07-12 A | 2024-12-20 |  | 46% | 87d |  |
| 387 | 1.3.6.4.3.8.1 | **Test Approach & Plan** | 40d | 2024-09-27 | 2024-11-21 |  |  | 0d |  |
| 388 |  | SIT Operational PIT Test Approach & Plan (PIT) submitted to Programme for assurance | 0d | 2024-09-27 | 2024-09-27 |  |  | 0d | start no earlier than 2024-09-27 |
| 389 |  | SIT Operational Test approach and plan MHHS Review Completed | 0d | 2024-11-21 | 2024-11-21 | 388FS+40d |  | 108d |  |
| 390 | 1.3.6.4.3.8.2 | **Test Readiness Report** | 13d | 2024-10-04 A | 2024-10-22 |  | 42% | 0d |  |
| 391 |  | Test readiness reporting | 13d | 2024-10-04 A | 2024-10-22 | 388FS+10d | 42% | 0d |  |
| 392 | 1.3.6.4.3.8.3 | **Requirements to test Traceability Matrix (RTTM)** | 20d | 2024-11-01 | 2024-11-29 |  |  | 102d |  |
| 393 |  | SIT Operational PIT RTTM submitted to Programme for assurance | 0d | 2024-11-01 | 2024-11-01 | 388FS+26d |  | 102d |  |
| 394 |  | SIT Operational RTTM MHHS Review Completed | 0d | 2024-11-29 | 2024-11-29 | 393FS+20d |  | 102d |  |
| 395 | 1.3.6.4.3.8.4 | **Test Scenarios** | 20d | 2024-11-01 | 2024-11-29 |  |  | 0d |  |
| 396 |  | SIT Operational PIT test scenarios submitted to Programme for assurance | 0d | 2024-11-01 | 2024-11-01 | 388FS+26d |  | 0d |  |
| 397 |  | SIT Operational Test scenarios MHHS Review Completed | 0d | 2024-11-29 | 2024-11-29 | 396FS+20d |  | 102d |  |
| 398 | 1.3.6.4.3.8.5 | **PIT execution** | 116d | 2024-07-12 A | 2024-12-20 |  | 47% | 87d |  |
| 399 |  | PIT Test Execution Progress Report | 40d | 2024-07-15 A | 2024-11-21 | 391 | 45% | 93d |  |
| 400 |  | PIT Execution | 39d | 2024-07-12 A | 2024-11-29 | 396 | 49% | 87d |  |
| 401 |  | SIT Operational PIT Completion Report submitted to Programme for assurance | 0d | 2024-11-29 | 2024-11-29 | 399, 400 |  | 87d |  |
| 402 |  | SIT Operational PIT Completion Report MHHS Review Completed | 0d | 2024-12-20 | 2024-12-20 | 389, 394, 397, 401FS+15d |  | 87d |  |
| 403 | 1.3.6.4.4 | **All Suppliers DBT CIT (Entering at Interval 5)** | 71d | 2023-09-15 A | 2023-12-22 A |  | 100% |  |  |
| 404 | 1.3.6.4.4.1 | **Test Approach & Plan** | 20d | 2023-09-15 A | 2023-10-12 A |  | 100% |  |  |
| 405 |  | All SIT Suppliers Test Approach & Plans (PIT) submitted to Programme for assurance | 0d | 2023-09-15 A | 2023-09-15 A |  | 100% |  | start no earlier than 2023-09-15 |
| 406 |  | All SIT Suppliers Test Approach & Plans MHHS Review Completed | 0d | 2023-10-12 A | 2023-10-12 A | 405FS+20d | 100% |  |  |
| 407 | 1.3.6.4.4.2 | **Test Readiness Report** | 11d | 2023-09-29 A | 2023-10-13 A |  | 100% |  |  |
| 408 |  | Test readiness reporting | 11d | 2023-09-29 A | 2023-10-13 A | 405FS+10d | 100% |  |  |
| 409 | 1.3.6.4.4.3 | **Requirements to test Traceability Matrix (RTTM)** | 20d | 2023-10-06 A | 2023-11-03 A |  | 100% |  |  |
| 410 |  | All SIT Suppliers RTTMs submitted to Programme for assurance | 0d | 2023-10-06 A | 2023-10-06 A | 405FS+16d | 100% |  |  |
| 411 |  | All SIT Suppliers RTTMs MHHS Review Completed | 0d | 2023-11-03 A | 2023-11-03 A | 410FS+20d | 100% |  |  |
| 412 | 1.3.6.4.4.4 | **Test Scenarios** | 20d | 2023-10-05 A | 2023-11-02 A |  | 100% |  |  |
| 413 |  | All SIT Suppliers test scenarios' submitted to Programme for assurance | 0d | 2023-10-05 A | 2023-10-05 A | 405FS+15d | 100% |  |  |
| 414 |  | All SIT Suppliers Test scenarios' MHHS Review Completed | 0d | 2023-11-02 A | 2023-11-02 A | 413FS+20d | 100% |  |  |
| 415 | 1.3.6.4.4.5 | **PIT execution** | 51d | 2023-10-13 A | 2023-12-22 A |  | 100% |  |  |
| 416 |  | PIT Test Execution Progress Report | 40d | 2023-10-16 A | 2023-12-08 A | 413FS+5d, 408 | 100% |  |  |
| 417 |  | PIT Execution | 41d | 2023-10-13 A | 2023-12-08 A | 413FS+5d | 100% |  |  |
| 418 |  | All SIT Suppliers PIT Completion Reports submitted to Programme for assurance | 0d | 2023-12-08 A | 2023-12-08 A | 417, 416 | 100% |  |  |
| 419 |  | All SIT Suppliers PIT Completion Reports MHHS Review Completed | 0d | 2023-12-22 A | 2023-12-22 A | 418FS+10d, 406, 411, 414 | 100% |  |  |
| 420 | 1.3.6.4.5 | **All LDSO Network Operations DBT CIT (Entering at Interval 5)** | 71d | 2023-09-15 A | 2023-12-22 A |  | 100% |  |  |

| ID | WBS | Task | Duration | Start | Finish | Predecessors | Complete | Total float | Constraint |
| --- | --- | --- | --- | --- | --- | --- | --- | --- | --- |
| 421 | 1.3.6.4.5.1 | **Test Approach & Plan** | 71d | 2023-09-15 A | 2023-12-22 A |  | 100% |  |  |
| 422 |  | All Network Operation Test Approach & Plans (PIT) submitted to Programme for assurance | 0d | 2023-09-15 A | 2023-09-15 A |  | 100% |  | start no earlier than 2023-09-15 |
| 423 |  | All Network Operation Test Approach & Plans MHHS Review Completed | 0d | 2023-10-12 A | 2023-10-12 A | 422FS+20d | 100% |  |  |
| 424 | 1.3.6.4.5.1.3 | **Test Readiness Report** | 11d | 2023-09-29 A | 2023-10-13 A |  | 100% |  |  |
| 425 |  | Test readiness reporting | 11d | 2023-09-29 A | 2023-10-13 A | 422FS+10d | 100% |  |  |
| 426 | 1.3.6.4.5.1.4 | **Requirements to test Traceability Matrix (RTTM)** | 20d | 2023-10-05 A | 2023-11-02 A |  | 100% |  |  |
| 427 |  | All Network Operation RTTMs submitted to Programme for assurance | 0d | 2023-10-05 A | 2023-10-05 A | 422FS+15d | 100% |  | start no earlier than 2023-04-28 |
| 428 |  | All Network Operation RTTMs MHHS Review Completed | 0d | 2023-11-02 A | 2023-11-02 A | 427FS+20d | 100% |  |  |
| 429 | 1.3.6.4.5.1.5 | **Test Scenarios** | 20d | 2023-10-05 A | 2023-11-02 A |  | 100% |  |  |
| 430 |  | All Network Operation test scenarios' submitted to Programme for assurance | 0d | 2023-10-05 A | 2023-10-05 A | 422FS+15d | 100% |  |  |
| 431 |  | All Network Operation test scenarios' MHHS Review Completed | 0d | 2023-11-02 A | 2023-11-02 A | 430FS+20d | 100% |  |  |
| 432 | 1.3.6.4.5.1.6 | **PIT execution** | 51d | 2023-10-13 A | 2023-12-22 A |  | 100% |  |  |
| 433 |  | PIT Test Execution Progress Report | 40d | 2023-10-16 A | 2023-12-08 A | 430FS+5d, 425 | 100% |  |  |
| 434 |  | PIT Execution | 41d | 2023-10-13 A | 2023-12-08 A | 430FS+5d | 100% |  |  |
| 435 |  | All Network Operation PIT (CIT interval 5) Completion Reports submitted to Programme for assurance | 0d | 2023-12-08 A | 2023-12-08 A | 434, 433 | 100% |  |  |
| 436 |  | All Network Operation PIT (CIT interval 5) Completion Reports MHHS Review Completed | 0d | 2023-12-22 A | 2023-12-22 A | 435FS+10d, 423, 428, 431 | 100% |  |  |
| 437 | 1.3.6.4.6 | **All UMSO DBT CIT (Entering at Interval 6)** | 81d | 2023-09-29 | 2024-01-19 A |  | 100% |  |  |
| 438 | 1.3.6.4.6.1 | **Test Approach & Plan** | 20d | 2023-10-13 A | 2023-11-09 A |  | 100% |  |  |
| 439 |  | All UMSO Test Approach & Plans (PIT) submitted to Programme for assurance | 0d | 2023-10-13 A | 2023-10-13 A |  | 100% |  | start no earlier than 2023-10-13 |
| 440 |  | All UMSO Test Approach & Plans MHHS Review Completed | 0d | 2023-11-09 A | 2023-11-09 A | 439FS+20d | 100% |  |  |
| 441 | 1.3.6.4.6.2 | **Test Readiness Report** | 11d | 2023-09-29 | 2023-10-13 |  | 100% |  |  |
| 442 |  | Test readiness reporting | 11d | 2023-10-27 A | 2023-11-10 A | 439FS+10d | 100% |  |  |
| 443 | 1.3.6.4.6.3 | **Requirements to test Traceability Matrix (RTTM)** | 20d | 2023-10-05 | 2023-11-01 |  | 100% |  |  |
| 444 |  | All UMSO RTTMs submitted to Programme for assurance | 0d | 2023-11-02 A | 2023-11-02 A | 439FS+15d | 100% |  |  |
| 445 |  | All UMSO RTTMs MHHS Review Completed | 0d | 2023-11-30 A | 2023-11-30 A | 444FS+20d | 100% |  |  |
| 446 | 1.3.6.4.6.4 | **Test Scenarios** | 20d | 2023-10-05 | 2023-11-01 |  | 100% |  |  |
| 447 |  | All UMSO test scenarios' submitted to Programme for assurance | 0d | 2023-11-02 A | 2023-11-02 A | 439FS+15d | 100% |  |  |
| 448 |  | All UMSO Test scenarios' MHHS Review Completed | 0d | 2023-11-30 A | 2023-11-30 A | 447FS+20d | 100% |  |  |
| 449 | 1.3.6.4.6.5 | **PIT execution** | 51d | 2023-11-10 A | 2024-01-19 A |  | 100% |  |  |
| 450 |  | PIT Test Execution Progress Report | 40d | 2023-11-13 A | 2024-01-05 A | 447FS+5d, 442 | 100% |  |  |
| 451 |  | PIT Execution | 40d | 2023-11-10 A | 2024-01-04 A | 447FS+5d | 100% |  |  |
| 452 |  | All UMSO PIT (CIT interval 6) Completion Reports submitted to Programme for assurance | 0d | 2024-01-05 A | 2024-01-05 A | 451, 450 | 100% |  |  |
| 453 |  | All UMSO PIT (CIT interval 6) Completion Reports MHHS Review Completed | 0d | 2024-01-19 A | 2024-01-19 A | 440, 445, 448, 452FS+10d | 100% |  |  |
| 454 | 1.3.7 | **DBT Monitoring and Assurance** | 842d | 2022-10-31 A | 2026-01-20 |  | 64% | 502d |  |
| 455 | 1.3.7.1 | **Planning and DBT Progress Monitoring of PPs** | 696d | 2022-10-31 A | 2025-06-30 |  | 67% | 648d |  |
| 456 |  | Monitor Non-SIT PPs Planning and DBT1 progress (to inform confirmation of Qualification Testing Tranche participants milestones) | 696d | 2022-10-31 A | 2025-06-30 | 169SS | 67% | 648d |  |
| 457 | 1.3.7.2 | **DBT Progress Monitoring of Consequential Change** | 774d | 2023-02-02 A | 2026-01-20 |  | 51% | 502d |  |
| 458 |  | Monitor & report data cleanse progress | 774d | 2023-02-02 A | 2026-01-20 |  | 51% | 502d |  |
| 459 | 1.3.7.3 | **Design Assurance** | 713d | 2022-11-14 A | 2025-08-06 |  | 71% | 621d |  |
| 460 | 1.3.7.3.1 | **Design Assurance Readiness Assessment Preparation** | 39d | 2023-02-28 A | 2023-04-21 A |  | 100% |  |  |
| 461 |  | Set up FTIG | 15d | 2023-04-03 A | 2023-04-21 A |  | 100% |  | must start on 2023-04-03 |
| 462 |  | Produce Draft Questions | 10d | 2023-02-28 A | 2023-03-13 A |  | 100% |  | must start on 2023-02-28 |
| 463 |  | Pilot with SRO | 1d | 2023-03-14 A | 2023-03-14 A | 462 | 100% |  |  |
| 464 |  | Finalise questions | 10d | 2023-03-15 A | 2023-03-28 A | 463 | 100% |  |  |
| 465 |  | Prepare on-line RA tooling | 10d | 2023-03-29 A | 2023-04-11 A | 464 | 100% |  |  |
| 466 |  | Prepare webinar content | 5d | 2023-03-20 A | 2023-03-24 A | 462FS+4d | 100% |  |  |
| 467 |  | Conduct webinar | 1d | 2023-03-30 A | 2023-03-30 A | 466FS+3d | 100% |  |  |
| 468 | 1.3.7.3.2 | **Participant Design Assurance Approach** | 43d | 2022-11-14 A | 2023-01-11 A |  | 100% |  |  |
| 469 |  | Develop document | 20d | 2022-11-14 A | 2022-12-09 A | 47FS+10d | 100% |  | start no earlier than 2022-11-14 |
| 470 |  | Review document | 18d | 2022-12-12 A | 2023-01-04 A | 469 | 100% |  |  |
| 471 |  | Participant Design Assurance Approach approved | 0d | 2023-01-11 A | 2023-01-11 A | 470FF+5d | 100% |  |  |
| 472 | 1.3.7.3.3 | **Phase 1 - SIT Volunteers (Core Providers)** | 145d | 2023-04-10 A | 2023-10-27 A |  | 100% |  |  |
| 473 |  | Send on-line questionnaire to core capability providers and current SIT volunteers (from Round 3 consultation) | 1d | 2023-04-10 A | 2023-04-10 A |  | 100% |  | must start on 2023-04-10 |
| 474 |  | Participants Provide Responses to questionnaires | 15d | 2023-04-11 A | 2023-05-01 A | 473 | 100% |  |  |
| 475 |  | Assess on-line responses and provided evidence | 5d | 2023-05-02 A | 2023-05-08 A | 474 | 100% |  |  |
| 476 |  | Bi-lateral meeting with each responder, to walk and navigate through provided materials | 31d | 2023-05-09 A | 2023-06-20 A | 475 | 100% |  |  |
| 477 |  | Plan for, create and execute deep dive assurance interviews based on agreed priorities (participants, design areas) | 62d | 2023-06-07 A | 2023-08-31 A | 476FS-10d | 100% |  |  |
| 478 |  | SI endorsement of participants’ design – assurance reports | 43d | 2023-08-02 A | 2023-09-29 A | 477FS-22d | 100% |  |  |
| 479 |  | Post-assurance review of recommendations take-up by assured participants | 44d | 2023-08-29 A | 2023-10-27 A | 478SS+19d | 100% |  |  |
| 480 |  | Phase 1 - SIT Volunteers (Core Providers) complete | 0d | 2023-10-27 A | 2023-10-27 A | 479 | 100% |  |  |
| 481 | 1.3.7.3.4 | **Phase 2 - SIT all other participants** | 143d | 2023-05-08 A | 2023-11-22 A |  | 100% |  |  |
| 482 |  | Send on-line questionnaire to core capability providers and current SIT volunteers (from Round 3 consultation) | 1d | 2023-05-08 A | 2023-05-08 A |  | 100% |  | must start on 2023-05-08 |
| 483 |  | Participants Provide Responses to questionnaires | 15d | 2023-05-09 A | 2023-05-29 A | 482 | 100% |  |  |
| 484 |  | Assess on-line responses and provided evidence | 5d | 2023-05-30 A | 2023-06-05 A | 483 | 100% |  |  |
| 485 |  | Bi-lateral meeting with each responder, to walk and navigate through provided materials | 84d | 2023-06-06 A | 2023-09-29 A | 484 | 100% |  |  |
| 486 |  | Plan for, create and execute deep dive assurance interviews based on agreed priorities (participants, design areas) | 69d | 2023-06-27 A | 2023-09-29 A | 485SS+15d | 100% |  |  |
| 487 |  | SI endorsement of participants’ design – assurance reports | 54d | 2023-07-18 A | 2023-09-29 A | 486SS+15d | 100% |  |  |
| 488 |  | Post-assurance review of recommendations take-up by assured participants | 73d | 2023-08-14 A | 2023-11-22 A | 487SS+19d | 100% |  |  |
| 489 |  | SIT PPs design assurance (excl Migration/Reverse Migration) complete | 0d | 2023-11-22 A | 2023-11-22 A | 488 | 100% |  |  |
| 490 | 1.3.7.3.5 | **Non-SIT PPs design assurance** | 445d | 2023-11-23 A | 2025-08-06 |  | 33% | 621d |  |

| ID | WBS | Task | Duration | Start | Finish | Predecessors | Complete | Total float | Constraint |
| --- | --- | --- | --- | --- | --- | --- | --- | --- | --- |
| 491 |  | Non-SIT PPs design assurance (risk-based sample) | 445d | 2023-11-23 A | 2025-08-06 | 489 | 33% | 621d |  |
| 492 | 1.3.7.4 | **Test Assurance** | 629d | 2023-02-01 A | 2025-06-30 |  | 63% | 648d |  |
| 493 |  | Non-SIT PPs test assurance | 629d | 2023-02-01 A | 2025-06-30 |  | 63% | 648d |  |
| 494 | 1.3.7.5 | **Pre-Qualification Guidance (PIT Guidance)** | 67d | 2022-10-31 A | 2023-01-31 A |  | 100% |  |  |
| 495 |  | Develop document (incl. collaboration with code bodies, as required) | 56d | 2022-10-31 A | 2023-01-16 A |  | 100% |  |  |
| 496 |  | Review, update and agree Pre-Qualification Guidance internally | 11d | 2023-01-17 A | 2023-01-31 A | 495 | 100% |  |  |
| 497 | 1.3.7.6 | **External Programme Dependency Management** | 0d | 2022-11-03 A | 2022-11-03 A |  | 100% |  |  |
| 498 | 1.3.7.6.1 | **SLC47** | 0d | 2022-11-03 A | 2022-11-03 A |  | 100% |  |  |
| 499 |  | SLC47 implementation date | 0d | 2022-11-03 A | 2022-11-03 A |  | 100% |  | start no earlier than 2022-11-03 |
| 500 | 1.4 | **SYSTEMS INTEGRATION TESTING (SIT)** | 910d? | 2022-10-31 A | 2026-04-24 |  | 62% |  |  |
| 501 | 1.4.1 | **SIT Preparation** | 665d? | 2022-10-31 A | 2025-05-16 |  | 81% | 679d |  |
| 502 | 1.4.1.1 | **Test Artefact Development** | 472d | 2022-10-31 A | 2024-08-21 |  | 99% | 872d |  |
| 503 | 1.4.1.1.1 | **Environment Approach & Plan** | 460d | 2022-11-16 A | 2024-08-21 A |  | 100% |  |  |
| 504 |  | Environment Approach & Plan approved | 0d | 2022-11-16 A | 2022-11-16 A |  | 100% |  | start no earlier than 2022-11-16 |
| 505 |  | Environment Approach & Plan - Work Off | 157d | 2022-11-17 A | 2023-06-23 A | 504FS+1d | 100% |  |  |
| 506 |  | Environment Approach & Plan - Work Off Approved | 0d | 2023-08-16 A | 2023-08-16 A | 505FS+5d | 100% |  | start no earlier than 2023-08-16 |
| 507 |  | Environment Approach and Plan - SIT Functional | 0d | 2023-11-20 A | 2023-11-20 A |  | 100% |  | start no earlier than 2023-11-20 |
| 508 |  | Define Approach to Simulator for Non-SIT LDSO | 0d | 2023-11-15 A | 2023-11-15 A |  | 100% |  | start no earlier than 2023-11-15 |
| 509 |  | Environment Approach and Plan - Non SIT LDSO Testing | 0d | 2024-04-17 A | 2024-04-17 A |  | 100% |  | start no earlier than 2024-04-17 |
| 510 |  | Environment Approach and Plan - S and A Testing | 0d | 2024-07-17 A | 2024-07-17 A |  | 100% |  | start no earlier than 2024-07-17 |
| 511 |  | Environment Approach and Plan - SIT Non Functional | 0d | 2024-06-19 A | 2024-06-19 A |  | 100% |  | start no earlier than 2024-06-19 |
| 512 |  | Environment Approach and Plan - Sandbox | 0d | 2024-08-21 A | 2024-08-21 A |  | 100% |  | start no earlier than 2024-08-21 |
| 513 | 1.4.1.1.2 | **Overarching Test Scope (for all stages)** | 65d | 2022-10-31 A | 2023-01-27 A |  | 100% |  |  |
| 514 | 1.4.1.1.2.1 | **Overarching Test Scope (excl. Migration/Reverse Migration, NFT and Ops components)** | 65d | 2022-10-31 A | 2023-01-27 A |  | 100% |  |  |
| 515 |  | Develop document (excl Migration/Reverse Migration, NFT and Ops components) | 55d | 2022-10-31 A | 2023-01-13 A | 47 | 100% |  |  |
| 516 |  | Review, update & agree document (excl Migration/Reverse Migration, NFT and Ops components) | 10d | 2023-01-16 A | 2023-01-27 A | 515 | 100% |  |  |
| 517 | 1.4.1.1.3 | **Configuration and Release Management Approach & Plan** | 164d | 2022-11-01 A | 2023-06-16 A |  | 100% |  |  |
| 518 |  | Develop document | 69d | 2022-11-01 A | 2023-06-16 A |  | 100% |  | start no earlier than 2022-11-01 |
| 519 |  | Review, update and agree Configuration and Release Management Approach & Plan internally | 63d | 2023-02-01 A | 2023-04-28 A | 518 | 100% |  |  |
| 520 | 1.4.1.1.4 | **Test Data Overarching Approach & Plan** | 179d | 2022-11-14 A | 2023-07-20 A |  | 100% |  |  |
| 521 |  | Develop document | 20d | 2022-11-14 A | 2022-12-09 A |  | 100% |  | start no earlier than 2022-11-14 |
| 522 |  | Document review and update | 155d | 2022-12-12 A | 2023-07-14 A | 521 | 100% |  |  |
| 523 |  | Test Data Overarching Approach & Plan approved by TMAG | 0d | 2023-07-19 A | 2023-07-19 A | 522FS+3d | 100% |  |  |
| 524 |  | Document publication final version | 1d | 2023-07-20 A | 2023-07-20 A | 523 | 100% |  |  |
| 525 | 1.4.1.1.5 | **Interface Code of Connection (dates subject to DIP Service Provider's plan)** | 48d | 2023-03-01 A | 2023-05-05 A |  | 100% |  |  |
| 526 |  | Develop Interface Code of Connection with DIP Service Provider | 43d | 2023-03-01 A | 2023-04-28 A |  | 100% |  | must start on 2023-03-01 |
| 527 |  | Interface Code of Connection approved at SDWG | 0d | 2023-05-05 A | 2023-05-05 A | 526FS+5d | 100% |  |  |
| 528 | 1.4.1.1.6 | **Test Traceability** | 165d | 2023-06-01 A | 2024-01-17 |  | 98% | 1026d |  |
| 529 |  | RTM containing Method Statement Implied Requirements into Azure DevOps | 22d | 2023-06-01 A | 2023-06-30 A |  | 100% |  | must start on 2023-06-01 |
| 530 |  | RTM Containing Interface Catalogue Implied Requirements | 27d | 2023-06-01 A | 2023-07-07 A |  | 100% |  | must start on 2023-06-01 |
| 531 |  | SIT CIT Full Traceability & Coverage complete | 118d | 2023-07-10 A | 2023-12-20 A | 530, 529 | 100% |  |  |
| 532 |  | SIT Functional Full Traceability & Coverage complete | 138d | 2023-07-10 A | 2024-01-17 | 530, 529 | 96% | 1026d |  |
| 533 | 1.4.1.2 | **Test Tool Development** | 256d? | 2022-10-31 A | 2023-10-23 A |  | 100% |  |  |
| 534 | 1.4.1.2.1 | **Test Management Tool** | 256d | 2022-10-31 A | 2023-10-23 A |  | 100% |  |  |
| 535 | 1.4.1.2.1.1 | **Test Management Tool Implementation** | 256d | 2022-10-31 A | 2023-10-23 A |  | 100% |  |  |
| 536 |  | Requirements identification | 40d | 2022-10-31 A | 2022-12-23 A |  | 100% |  |  |
| 537 |  | Development | 125d | 2023-01-02 A | 2023-06-23 A | 536FS+5d | 100% |  |  |
| 538 |  | Testing | 125d | 2023-01-02 A | 2023-06-23 A | 537FF | 100% |  |  |
| 539 |  | Accept tool | 0d | 2023-06-23 A | 2023-06-23 A | 538FF | 100% |  |  |
| 540 |  | Implementation | 1d | 2023-10-23 A | 2023-10-23 A | 539FS+85d | 100% |  |  |
| 541 | 1.4.1.2.1.2 | **Test Management Tool User Guide** | 115d | 2023-01-02 A | 2023-06-09 A |  | 100% |  |  |
| 542 |  | Develop document | 100d | 2023-01-02 A | 2023-05-19 A | 537SS, 538SS | 100% |  | start no earlier than 2023-01-02 |
| 543 |  | Review, update and agree Test Management Tool User Guide internally | 15d | 2023-05-22 A | 2023-06-09 A | 542 | 100% |  |  |
| 544 | 1.4.1.2.1.3 | **Test Management Tool Configuration Guide** | 60d | 2023-01-02 A | 2023-03-24 A |  | 100% |  |  |
| 545 |  | Develop document | 45d | 2023-01-02 A | 2023-03-03 A | 536 | 100% |  | start no earlier than 2023-01-02 |
| 546 |  | Review, update and agree Test Management Tool Configuration Guide internally | 15d | 2023-03-06 A | 2023-03-24 A | 545 | 100% |  |  |
| 547 | 1.4.1.2.2 | **Secure Volunteer SIT Participants** | 163d? | 2023-01-31 A | 2023-09-14 A |  | 100% |  |  |
| 548 |  | PPs decide whether to volunteer to participate in SIT and inform Programme of decision via Round 3 Replan consultation | 1d? | 2023-01-31 A | 2023-01-31 A |  | 100% |  | finish no earlier than 2023-01-31 |
| 549 |  | Assurance of SIT volunteers' plans (submitted via Round 3 Replan Consultation) | 1d? | 2023-02-14 A | 2023-02-14 A |  | 100% |  | finish no earlier than 2023-02-14 |
| 550 |  | SIT Participant Volunteers Identified | 1d? | 2023-02-14 A | 2023-02-14 A |  | 100% |  | start no earlier than 2023-02-14 |
| 551 |  | Engagement with SIT volunteers | 1d? | 2023-05-23 A | 2023-05-23 A |  | 100% |  | finish no earlier than 2023-05-23 |
| 552 |  | SIT Participants Agreed | 1d? | 2023-05-23 A | 2023-05-23 A |  | 100% |  | start no earlier than 2023-05-23 |
| 553 | 1.4.1.2.2.6 | **Data Protection Impact Assessment (DPIA)** | 11d? | 2023-06-30 A | 2023-07-14 A |  | 100% |  |  |
| 554 |  | Conduct DPIA on Overall Test Data Approach | 1d? | 2023-06-30 A | 2023-06-30 A |  | 100% |  | finish no earlier than 2023-06-30 |
| 555 |  | Revise Overarching Test Data Approach& plan for DPIA (if required), including engagement with DWG | 1d? | 2023-07-13 A | 2023-07-13 A |  | 100% |  | finish no earlier than 2023-07-13 |
| 556 |  | Review (internal), update and approve revised Overarching Test Data Approach& Plan (if required) | 1d? | 2023-07-14 A | 2023-07-14 A |  | 100% |  | start no earlier than 2023-07-14 |
| 557 | 1.4.1.2.2.7 | **Data Sharing Agreements** | 30d? | 2023-08-04 A | 2023-09-14 A |  | 100% |  |  |
| 558 |  | Produce Data Sharing Agreement for Industry Review | 1d? | 2023-08-04 A | 2023-08-04 A |  | 100% |  | finish no earlier than 2023-08-04 |
| 559 |  | Manage Participant Queries and Contract Agreement Execution | 1d? | 2023-09-14 A | 2023-09-14 A |  | 100% |  | finish no earlier than 2023-09-14 |
| 560 |  | Data Sharing Agreements Complete | 1d? | 2023-09-14 A | 2023-09-14 A |  | 100% |  | start no earlier than 2023-09-14 |

| ID | WBS | Task | Duration | Start | Finish | Predecessors | Complete | Total float | Constraint |
| --- | --- | --- | --- | --- | --- | --- | --- | --- | --- |
| 561 | 1.4.1.2.2.8 | **Production Data Cut & Data Obfuscation** | 55d? | 2023-06-19 A | 2023-09-01 A |  | 100% |  |  |
| 562 | 1.4.1.2.2.8.1 | **SI Data Cut Preparation& Infrastructure** | 45d? | 2023-06-19 A | 2023-08-18 A |  | 100% |  |  |
| 563 |  | SI Data Cut Planning activities (incl. pre-cut and post-cut cleansing and population approach) | 1d? | 2023-06-19 A | 2023-06-19 A |  | 100% |  | finish no earlier than 2023-06-19 |
| 564 |  | Set up SI database and transmission structure | 1d? | 2023-08-17 A | 2023-08-17 A |  | 100% |  | finish no earlier than 2023-08-17 |
| 565 |  | Mechanism for transfer of data in place | 1d? | 2023-08-18 A | 2023-08-18 A |  | 100% |  | start no earlier than 2023-08-18 |
| 566 |  | SI Data Cut Preparation& Infrastructure Complete | 1d? | 2023-08-18 A | 2023-08-18 A |  | 100% |  | start no earlier than 2023-08-18 |
| 567 | 1.4.1.2.2.8.2 | **Production Data Cut** | 55d? | 2023-06-19 A | 2023-09-01 A |  | 100% |  |  |
| 568 |  | Notification of Production Data Cut issued to relevant participants | 1d? | 2023-06-19 A | 2023-06-19 A |  | 100% |  | start no earlier than 2023-06-19 |
| 569 |  | Coordinate relevant participants taking data cut from production systems | 1d? | 2023-08-11 A | 2023-08-11 A |  | 100% |  | finish no earlier than 2023-08-11 |
| 570 |  | Production data cut GONG decision | 1d? | 2023-08-16 A | 2023-08-16 A |  | 100% |  | start no earlier than 2023-08-16 |
| 571 |  | Relevant participants take data cut from production systems (Saturday 19 August) | 1d? | 2023-08-21 A | 2023-08-21 A |  | 100% |  | start no earlier than 2023-08-21 |
| 572 |  | EES transmit request data to SI | 1d? | 2023-08-25 A | 2023-08-25 A |  | 100% |  | finish no earlier than 2023-08-25 |
| 573 |  | Check data alignment and integrity of data cut | 1d? | 2023-09-01 A | 2023-09-01 A |  | 100% |  | finish no earlier than 2023-09-01 |
| 574 |  | Data cut from relevant participants' production systems completed (Saturday 19 August) | 1d? | 2023-08-21 A | 2023-08-21 A |  | 100% |  | start no earlier than 2023-08-21 |
| 575 |  | Production Data Cut Complete | 1d? | 2023-08-21 A | 2023-08-21 A |  | 100% |  | start no earlier than 2023-08-21 |
| 576 | 1.4.1.3 | **SIT Participation** | 147d | 2022-10-31 A | 2023-05-23 A |  | 100% |  |  |
| 577 |  | PPs decide whether to volunteer to participate in SIT and inform Programme of decision via Round 3 Replan consultation | 67d | 2022-10-31 A | 2023-01-31 A | 34FF | 100% |  |  |
| 578 |  | Assurance of SIT volunteers' plans (submitted via Round 3 Replan Consultation) | 10d | 2023-02-01 A | 2023-02-14 A | 577, 34 | 100% |  |  |
| 579 |  | SIT Participant Volunteers Identified | 0d | 2023-02-14 A | 2023-02-14 A | 578FF | 100% |  |  |
| 580 |  | Engagement with SIT volunteers | 147d | 2022-10-31 A | 2023-05-23 A |  | 100% |  |  |
| 581 |  | SIT Participants Agreed | 0d | 2023-05-23 A | 2023-05-23 A | 580, 615FS-74d | 100% |  |  |
| 582 | 1.4.1.4 | **SIT Stage-Specific Preparation** | 665d? | 2022-10-31 A | 2025-05-16 |  | 77% | 679d |  |
| 583 | 1.4.1.4.1 | **SIT Component Integration Preparation** | 320d | 2022-10-31 A | 2024-01-19 A |  | 100% |  |  |
| 584 | 1.4.1.4.1.1 | **Test Approach & Plan** | 188d | 2022-10-31 A | 2023-07-19 A |  | 100% |  |  |
| 585 |  | Develop document with SITWG | 159d | 2022-10-31 A | 2023-06-08 A |  | 100% |  |  |
| 586 |  | Industry consultation | 10d | 2023-06-09 A | 2023-06-22 A | 585 | 100% |  |  |
| 587 |  | Artefact review (via TMAG) and updates | 19d | 2023-06-23 A | 2023-07-19 A | 586 | 100% |  | finish no earlier than 2023-07-06 |
| 588 |  | SIT Component Integration Testing Test Approach & Plan approved | 0d | 2023-07-19 A | 2023-07-19 A | 587 | 100% |  | finish no earlier than 2023-07-19 |
| 589 | 1.4.1.4.1.2 | **Test Data Approach & Plan** | 29d | 2023-06-09 A | 2023-07-19 A |  | 100% |  |  |
| 590 |  | Industry consultation | 10d | 2023-06-09 A | 2023-06-22 A | 586SS | 100% |  |  |
| 591 |  | Artefact review (via TMAG) and updates | 19d | 2023-06-23 A | 2023-07-19 A | 590 | 100% |  |  |
| 592 |  | SIT Component Integration Testing Test Data Approach & Plan approved | 0d | 2023-07-19 A | 2023-07-19 A | 591 | 100% |  |  |
| 593 | 1.4.1.4.1.3 | **Test scenarios** | 173d | 2023-01-02 A | 2023-08-30 A |  | 100% |  |  |
| 594 |  | Development of test scenarios | 0d | 2023-01-02 A | 2023-04-28 A | 585SS+45d | 100% |  |  |
| 595 |  | Review test scenarios with SIT Working Group | 11d | 2023-02-01 A | 2023-08-09 A | 594SS+22d | 100% |  |  |
| 596 |  | SIT Component Integration Testing Test scenarios approved | 0d | 2023-08-30 A | 2023-08-30 A | 595FS+15d | 100% |  |  |
| 597 | 1.4.1.4.1.4 | **Test cases** | 160d | 2023-05-01 A | 2023-12-08 A |  | 100% |  |  |
| 598 | 1.4.1.4.1.4.1 | **SI Test cases** | 160d | 2023-05-01 A | 2023-12-08 A |  | 100% |  |  |
| 599 | 1.4.1.4.1.4.1.1 | **Batch 1 (CIT Intervals 1 and 2)** | 110d | 2023-05-01 A | 2023-09-29 A |  | 100% |  |  |
| 600 |  | Develop Test cases | 100d | 2023-05-01 A | 2023-09-15 A | 594 | 100% |  |  |
| 601 |  | Review Test cases with SIT Working Group | 9d | 2023-09-18 A | 2023-09-28 A | 600 | 100% |  |  |
| 602 |  | SIT Component Integration Testing Test cases Batch 1 (CIT Intervals 1 and 2) approved at ETMAG | 0d | 2023-09-29 A | 2023-09-29 A | 601FS+1d | 100% |  |  |
| 603 | 1.4.1.4.1.4.1.2 | **Batch 2 (CIT Intervals 3 and 4)** | 25d | 2023-10-02 A | 2023-11-03 A |  | 100% |  |  |
| 604 |  | Develop Test cases | 15d | 2023-10-02 A | 2023-10-20 A | 602 | 100% |  |  |
| 605 |  | Review Test cases with SIT Working Group | 9d | 2023-10-23 A | 2023-11-02 A | 604 | 100% |  |  |
| 606 |  | SIT Component Integration Testing Test cases Batch 2 (CIT Intervals 3 and 4) approved at ETMAG | 0d | 2023-11-03 A | 2023-11-03 A | 605FS+1d | 100% |  |  |
| 607 | 1.4.1.4.1.4.1.3 | **Batch 3 (CIT Intervals 5 and 6)** | 25d | 2023-11-03 A | 2023-12-08 A |  | 100% |  |  |
| 608 |  | Develop Test cases | 15d | 2023-11-03 A | 2023-11-24 A | 606 | 100% |  |  |
| 609 |  | Review Test cases with SIT Working Group | 9d | 2023-11-27 A | 2023-12-07 A | 608 | 100% |  |  |
| 610 |  | SIT Component Integration Testing Test cases Batch 3 (CIT Intervals 5 and 6) approved at ETMAG | 0d | 2023-12-08 A | 2023-12-08 A | 609FS+1d | 100% |  |  |
| 611 | 1.4.1.4.1.5 | **CIT Interval 1 Preparation** | 283d | 2022-11-16 A | 2023-12-15 A |  | 100% |  |  |
| 612 | 1.4.1.4.1.5.1 | **Environments (SIT A)** | 246d | 2022-11-16 A | 2023-10-25 A |  | 100% |  |  |
| 613 |  | PPs register PKI Officers and request PKI certificates | 5d | 2023-10-09 A | 2023-10-13 A |  | 100% |  | start no earlier than 2023-10-09 |
| 614 |  | PPs register PKI Officers and request PKI certificates Complete - Interval 1 | 0d | 2023-10-25 A | 2023-10-25 A | 613FS+8d | 100% |  |  |
| 615 |  | PP SIT A environment preparation (incl. security certificates and security compliance) | 238d | 2022-11-16 A | 2023-10-13 A | 504 | 100% |  |  |
| 616 |  | SI coordinate SIT Participants' SIT A environment preparation | 238d | 2022-11-16 A | 2023-10-13 A | 615SS | 100% |  |  |
| 617 |  | PP submit self-declaration of environment preparation complete (incl. security certificates and security compliance) to Programme for assurance | 0d | 2023-10-13 A | 2023-10-13 A | 615FF | 100% |  | start no earlier than 2023-10-13 |
| 618 |  | SI assure PPs' self-declaration of environment preparation complete (incl. security certificates and security compliance) | 5d | 2023-10-16 A | 2023-10-20 A | 617FF+5d | 100% |  |  |
| 619 |  | SIT Participants' SIT A environments ready to start connectivity proving CIT Interval 1 | 0d | 2023-09-01 A | 2023-09-01 A | 617SS | 100% |  |  |
| 620 |  | PP SIT A environment connectivity proving | 10d | 2023-09-04 A | 2023-09-15 A | 619 | 100% |  |  |
| 621 |  | SI coordinate SIT Participants' SIT A environment connectivity proving | 10d | 2023-09-04 A | 2023-09-15 A | 620SS | 100% |  |  |
| 622 |  | PP deployment of MHHS solution code to SIT A environments | 10d | 2023-09-25 A | 2023-10-06 A | 663FF | 100% |  |  |
| 623 |  | SI coordinate deployment of MHHS solution code to SIT Participants' SIT A environments | 10d | 2023-09-25 A | 2023-10-06 A | 663FF | 100% |  |  |
| 624 |  | PP submit evidence of SIT A environment connectivity proving and code deployment completion to Programme for assurance | 30d | 2023-09-04 A | 2023-10-13 A | 620SS | 100% |  |  |
| 625 |  | SI assurance of SIT Participants' SIT A environment connectivity proving and code deployment completion | 25d | 2023-09-18 A | 2023-10-20 A | 624FF+5d | 100% |  |  |
| 626 | 1.4.1.4.1.5.2 | **Test Data - ISD Creation** | 9d | 2023-08-22 A | 2023-09-01 A |  | 100% |  |  |
| 627 |  | Set-up Market Participants and DIP ID Data | 8d | 2023-08-22 A | 2023-08-31 A |  | 100% |  |  |
| 628 |  | Distribute ISD Data to Participants | 1d | 2023-09-01 A | 2023-09-01 A | 627 | 100% |  |  |
| 629 |  | Test Data - ISD Creation Complete | 0d | 2023-09-01 A | 2023-09-01 A | 628 | 100% |  |  |
| 630 | 1.4.1.4.1.5.3 | **Test Data - SFTP Onboarding** | 70d | 2023-08-21 A | 2023-11-24 A |  | 100% |  |  |

| ID | WBS | Task | Duration | Start | Finish | Predecessors | Complete | Constraint |
| --- | --- | --- | --- | --- | --- | --- | --- | --- |
| 631 |  | Create Containers and Keys for Participants | 3d | 2023-08-21 A | 2023-08-23 A |  | 100% |  |
| 632 |  | Share SFTP Access with Participants | 5d | 2023-08-24 A | 2023-08-30 A | 631 | 100% |  |
| 633 |  | Test SFTP Connectivity | 5d | 2023-08-31 A | 2023-09-06 A | 632 | 100% |  |
| 634 |  | Test Data - SFTP Onboarding Complete | 0d | 2023-11-24 A | 2023-11-24 A | 633FS+57d | 100% |  |
| 635 | 1.4.1.4.1.5.4 | **Test Data - Provide Sample Files** | 10d | 2023-08-21 A | 2023-09-01 A |  | 100% |  |
| 636 |  | Generate Sample Files off IF Messages | 8d | 2023-08-21 A | 2023-08-30 A |  | 100% |  |
| 637 |  | Transmit Sample Files off IF Messages to Participants (More detail needs to be planned for a POC) | 2d | 2023-08-31 A | 2023-09-01 A | 636 | 100% |  |
| 638 |  | Test Data - Provide Sample Files Complete | 0d | 2023-09-01 A | 2023-09-01 A | 637 | 100% |  |
| 639 | 1.4.1.4.1.5.5 | **Test Data - Detailed SIT Data Load Guidance** | 65d | 2023-09-07 A | 2023-12-06 A |  | 100% |  |
| 640 |  | Document Guidance | 21d | 2023-09-07 A | 2023-10-05 A | 638FS+3d | 100% |  |
| 641 |  | Provide Guidance to PPs | 1d | 2023-10-06 A | 2023-10-06 A | 640 | 100% |  |
| 642 |  | Test Data - Detailed SIT Functional Data Load Guidance Complete | 0d | 2023-12-06 A | 2023-12-06 A | 641FS+43d | 100% |  |
| 643 | 1.4.1.4.1.5.6 | **Test Data - Population of Data Items for Testing Guidance - Draft** | 80d | 2023-08-17 A | 2023-12-06 A |  | 100% |  |
| 644 |  | Document Guidance - Draft | 11d | 2023-08-17 A | 2023-08-31 A | 833 | 100% |  |
| 645 |  | Provide Guidance to PPs - Draft | 1d | 2023-09-01 A | 2023-09-01 A | 644 | 100% |  |
| 646 |  | Test Data - Population of Data Items for Testing Guidance - Draft Complete | 0d | 2023-12-06 A | 2023-12-06 A | 645FS+68d | 100% |  |
| 647 | 1.4.1.4.1.5.7 | **Test Data - Population of Data Items for Testing Guidance - Final** | 87d | 2023-08-17 A | 2023-12-15 A |  | 100% |  |
| 648 |  | Update Document Guidance With PPS Feedback | 81d | 2023-08-17 A | 2023-12-07 A | 644SS | 100% |  |
| 649 |  | Provide Final Guidance to PPs | 1d | 2023-12-08 A | 2023-12-08 A | 648 | 100% |  |
| 650 |  | Test Data - Population of Data Items for Testing Guidance - Final Complete | 0d | 2023-12-15 A | 2023-12-15 A | 649FS+5d | 100% |  |
| 651 | 1.4.1.4.1.5.8 | **Test Data (SIT A) Interval 1** | 40d | 2023-09-04 A | 2023-10-27 A |  | 100% |  |
| 652 |  | Run data allocation | 4d | 2023-09-04 A | 2023-09-07 A | 592, 629 | 100% |  |
| 653 |  | Cleanse, anonymise and populate data post cut | 4d | 2023-09-08 A | 2023-09-13 A | 652 | 100% |  |
| 654 |  | Transmit data sets to PPs | 3d | 2023-09-15 A | 2023-09-19 A | 653 | 100% |  |
| 655 |  | PP - Load test data to test environments | 7d | 2023-09-20 A | 2023-09-28 A | 654, 638 | 100% |  |
| 656 |  | PP Check data integrity on test environment | 1d | 2023-09-29 A | 2023-09-29 A | 655 | 100% |  |
| 657 |  | PP submit self-declaration to Programme to confirm loading & verification of test data | 0d | 2023-09-29 A | 2023-09-29 A | 656FF | 100% |  |
| 658 |  | Test Data (SIT A) Interval 1 Complete | 0d | 2023-10-27 A | 2023-10-27 A | 657FS+20d | 100% |  |
| 659 | 1.4.1.4.1.5.9 | **Other Preparation** | 45d | 2023-07-03 A | 2023-09-01 A |  | 100% |  |
| 660 |  | Onboarding of Test Participants to Test Management Tool (Azure DevOps) | 45d | 2023-07-03 A | 2023-09-01 A | 619SF | 100% |  |
| 661 |  | Test Management Tool onboarding | 45d | 2023-07-03 A | 2023-09-01 A | 619SF | 100% |  |
| 662 | 1.4.1.4.1.5.10 | **SIT Component Integration Test Readiness Report** | 28d | 2023-09-14 A | 2023-10-23 A |  | 100% |  |
| 663 |  | PP submit Test Readiness Report to Programme for assurance | 0d | 2023-10-20 A | 2023-10-20 A | 661, 602, 658 | 100% | start no earlier than 2023-10-09 |
| 664 |  | SI assure Test Participants' Test Readiness Reports | 1d | 2023-10-23 A | 2023-10-23 A | 663SS | 100% |  |
| 665 |  | SI develop Overarching SIT Component Integration Test Readiness Report | 23d | 2023-09-14 A | 2023-10-16 A | 588FS+40d | 100% |  |
| 666 |  | Artefact review (via TMAG) and updates | 4d | 2023-10-17 A | 2023-10-20 A | 665 | 100% |  |
| 667 |  | SIT Component Integration Testing 1 Preparation Complete (incl. approval of SI SIT Component Integration Test Readiness Report) | 0d | 2023-10-27 A | 2023-10-27 A | 666FS+1d, 663, 619, 661, 658, 236, 241, 230, 250, 251, 664 | 100% |  |
| 668 | 1.4.1.4.1.6 | **CIT Interval 2 Preparation** | 103d | 2023-07-03 A | 2023-11-22 A |  | 100% |  |
| 669 | 1.4.1.4.1.6.1 | **Environments (SIT A)** | 43d | 2023-09-22 A | 2023-11-22 A |  | 100% |  |
| 670 |  | SIT Participants' SIT A environments ready to start connectivity proving CIT Interval 2 | 0d | 2023-09-22 A | 2023-09-22 A |  | 100% |  |
| 671 |  | Programme Participants Ready to Start Connectivity Proving | 0d | 2023-09-22 A | 2023-09-22 A |  | 100% | finish no earlier than 2023-09-22 |
| 672 |  | Internal Connectivity Proving Phase | 10d | 2023-09-25 A | 2023-10-06 A | 671 | 100% |  |
| 673 |  | Internal Connectivity Proving Phase Complete | 0d | 2023-10-06 A | 2023-10-06 A | 672 | 100% | start no earlier than 2023-10-06 |
| 674 |  | DIP Onboarding Activity (1. PKI Officers and Certificates, 2. Set-up Validation, 3. End Point Creation, 4. Controlled Smoke Test ) | 28d | 2023-10-16 A | 2023-11-22 A | 673FS+5d | 100% |  |
| 675 |  | DIP Onboarding Complete | 0d | 2023-11-22 A | 2023-11-22 A | 674 | 100% |  |
| 676 |  | PPs Register PKI Officers and request PKI certificates Complete - Interval 2 | 0d | 2023-11-22 A | 2023-11-22 A | 675 | 100% |  |
| 677 |  | PP Code Deployment | 0d | 2023-10-20 A | 2023-10-20 A |  | 100% | start no earlier than 2023-10-20 |
| 678 | 1.4.1.4.1.6.2 | **Test Data (SIT A) Interval 2** | 43d | 2023-09-20 A | 2023-11-17 A |  | 100% |  |
| 679 |  | Run data allocation | 7d | 2023-09-20 A | 2023-09-28 A | 655SS | 100% |  |
| 680 |  | Cleanse and populate data post cut | 2d | 2023-09-29 A | 2023-10-02 A | 679 | 100% |  |
| 681 |  | Transmit data sets to PPs | 1d | 2023-10-03 A | 2023-10-03 A | 680 | 100% |  |
| 682 |  | PP - Load test data to test environments | 33d | 2023-10-04 A | 2023-11-17 A | 681 | 100% |  |
| 683 |  | PP Check data integrity on test environment | 15d | 2023-10-23 A | 2023-11-17 A | 682FF | 100% |  |
| 684 |  | PP submit self-declaration to Programme to confirm loading & verification of test data | 0d | 2023-11-17 A | 2023-11-17 A | 683FF | 100% |  |
| 685 |  | Test Data (SIT A) Interval 2 Complete | 0d | 2023-11-17 A | 2023-11-17 A | 684 | 100% |  |
| 686 | 1.4.1.4.1.6.3 | **Other Preparation** | 87d | 2023-07-03 A | 2023-10-31 A |  | 100% |  |
| 687 |  | Onboarding of Test Participants to Test Management Tool (Azure DevOps) | 60d | 2023-07-03 A | 2023-09-22 A | 670SF | 100% |  |
| 688 |  | Test Management Tool onboarding | 27d | 2023-09-25 A | 2023-10-31 A | 687 | 100% |  |
| 689 | 1.4.1.4.1.6.4 | **SIT Component Integration Test Readiness Report** | 25d | 2023-10-02 A | 2023-11-03 A |  | 100% |  |
| 690 |  | PP submit Test Readiness Report to Programme for assurance | 0d | 2023-10-25 A | 2023-10-25 A | 602FS+18d | 100% |  |
| 691 |  | SI assure Test Participants' Test Readiness Reports | 2d | 2023-10-26 A | 2023-10-27 A | 690 | 100% |  |
| 692 |  | SI develop Overarching SIT Component Integration Test Readiness Report | 20d | 2023-10-02 A | 2023-10-27 A | 691FF | 100% |  |
| 693 |  | Artefact review (via TMAG) and updates | 5d | 2023-10-30 A | 2023-11-03 A | 692 | 100% |  |
| 694 |  | SIT Component Integration Testing 2 Preparation Complete (incl. approval of SI SIT Component Integration Test Readiness Report) | 0d | 2023-11-06 A | 2023-11-06 A | 688, 693FS+1d, 670, 299 | 100% |  |
| 695 | 1.4.1.4.1.7 | **CIT Interval 3 Preparation** | 54d | 2023-10-03 A | 2023-12-15 A |  | 100% |  |
| 696 | 1.4.1.4.1.7.1 | **PIT Test Completion Report (incl. evidence)** | 26d | 2023-10-13 A | 2023-11-17 A |  | 100% |  |
| 697 |  | Submit draft PIT Test Completion Report (incl. evidence) and submit to Programme for assurance | 11d | 2023-10-13 A | 2023-10-27 A |  | 100% | must start on 2023-10-13 |
| 698 |  | Finalise PIT Test Completion Report (incl. evidence) | 5d | 2023-10-30 A | 2023-11-03 A | 697 | 100% |  |
| 699 |  | PP PIT Completion Report (excl. Migration/Reverse Migration) submitted to Programme for assurance CIT Interval 3 | 0d | 2023-11-03 A | 2023-11-03 A | 698, 79, 95 | 100% |  |
| 700 |  | PP Final PIT Completion Reports assured by SI | 10d | 2023-11-06 A | 2023-11-17 A | 699 | 100% |  |

| ID | WBS | Task | Duration | Start | Finish | Predecessors | Complete | Constraint |
| --- | --- | --- | --- | --- | --- | --- | --- | --- |
| 701 | 1.4.1.4.1.7.2 | **Environments (SIT A)** | 51d | 2023-10-06 A | 2023-12-15 A |  | 100% |  |
| 702 |  | Programme Participants Ready to Start Connectivity Proving | 0d | 2023-10-06 A | 2023-10-06 A |  | 100% | start no earlier than 2023-10-06 |
| 703 |  | SIT Participants' SIT A environments ready to start connectivity proving CIT Interval 3 | 0d | 2023-10-06 A | 2023-10-06 A | 702 | 100% |  |
| 704 |  | Internal Connectivity Proving Phase | 10d | 2023-10-09 A | 2023-10-20 A | 702FS+1d | 100% |  |
| 705 |  | Internal Connectivity Proving Phase Complete | 0d | 2023-10-20 A | 2023-10-20 A | 704 | 100% |  |
| 706 |  | DIP Onboarding Activity (1. PKI Officers and Certificates, 2. Set-up Validation, 3. End Point Creation, 4. Controlled Smoke Test ) | 35d | 2023-10-30 A | 2023-12-15 A | 705FS+5d | 100% |  |
| 707 |  | DIP Onboarding Complete | 0d | 2023-12-15 A | 2023-12-15 A | 706 | 100% |  |
| 708 |  | PPs Register PKI Officers and Request PKI certificates Complete - Interval 3 | 0d | 2023-12-15 A | 2023-12-15 A | 707FF | 100% |  |
| 709 |  | PP Code Deployment | 0d | 2023-11-10 A | 2023-11-10 A | 705FS+15d | 100% | start no earlier than 2023-10-20 |
| 710 | 1.4.1.4.1.7.3 | **Test Data (SIT A) Interval 3** | 34d | 2023-10-03 A | 2023-11-17 A |  | 100% |  |
| 711 |  | Run data allocation | 4d | 2023-10-03 A | 2023-10-06 A | 681SS | 100% |  |
| 712 |  | Cleanse and populate data post cut | 5d | 2023-10-09 A | 2023-10-13 A | 711 | 100% |  |
| 713 |  | Transmit data sets to PPs | 2d | 2023-10-16 A | 2023-10-17 A | 712 | 100% |  |
| 714 |  | PP - Load test data to test environments | 8d | 2023-10-18 A | 2023-10-27 A | 713 | 100% |  |
| 715 |  | PP Check data integrity on test environment | 15d | 2023-10-30 A | 2023-11-17 A | 714 | 100% |  |
| 716 |  | PP submit self-declaration to Programme to confirm loading & verification of test data | 0d | 2023-11-17 A | 2023-11-17 A | 715FF | 100% |  |
| 717 |  | Test Data (SIT A) Interval 3 Complete | 0d | 2023-11-17 A | 2023-11-17 A | 716 | 100% |  |
| 718 | 1.4.1.4.1.7.4 | **Other Preparation** | 25d | 2023-10-16 A | 2023-11-17 A |  | 100% |  |
| 719 |  | Onboarding of Test Participants to Test Management Tool (Azure DevOps) | 25d | 2023-10-16 A | 2023-11-17 A |  | 100% | start no earlier than 2023-10-16 |
| 720 |  | Test Management Tool onboarding | 25d | 2023-10-16 A | 2023-11-17 A |  | 100% | start no earlier than 2023-10-16 |
| 721 | 1.4.1.4.1.7.5 | **SIT Component Integration Test Readiness Report** | 25d | 2023-10-16 A | 2023-11-17 A |  | 100% |  |
| 722 |  | PP submit Test Readiness Report to Programme for assurance | 0d | 2023-11-03 A | 2023-11-03 A | 606 | 100% |  |
| 723 |  | SI assure Test Participants' Test Readiness Reports | 5d | 2023-11-06 A | 2023-11-10 A | 722FF+5d | 100% |  |
| 724 |  | SI develop Overarching SIT Component Integration Test Readiness Report | 20d | 2023-10-16 A | 2023-11-10 A | 723FF | 100% |  |
| 725 |  | Artefact review (via TMAG) and updates | 5d | 2023-11-13 A | 2023-11-17 A | 724 | 100% |  |
| 726 |  | SIT Component Integration Testing 3 Preparation Complete (incl. approval of SI SIT Component Integration Test Readiness Report) | 0d | 2023-11-20 A | 2023-11-20 A | 725FS+1d, 699, 703, 722, 720, 717, 317 | 100% |  |
| 727 | 1.4.1.4.1.8 | **CIT Interval 4 Preparation** | 36d | 2023-10-16 A | 2023-12-04 A |  | 100% |  |
| 728 | 1.4.1.4.1.8.1 | **PIT Test Completion Report (incl. evidence)** | 21d | 2023-10-27 A | 2023-11-24 A |  | 100% |  |
| 729 |  | Submit draft PIT Test Completion Report (incl. evidence) and submit to Programme for assurance | 1d | 2023-10-27 A | 2023-10-27 A |  | 100% | must start on 2023-10-27 |
| 730 |  | Finalise PIT Test Completion Report (incl. evidence) | 15d | 2023-10-30 A | 2023-11-17 A | 729 | 100% |  |
| 731 |  | PP PIT Completion Report (excl. Migration/Reverse Migration) submitted to Programme for assurance CIT Interval 4 | 0d | 2023-11-17 A | 2023-11-17 A | 730, 79, 95 | 100% |  |
| 732 |  | PP Final PIT Completion Reports assured by SI | 5d | 2023-11-20 A | 2023-11-24 A | 731 | 100% |  |
| 733 | 1.4.1.4.1.8.2 | **Environments (SIT A)** | 25d | 2023-10-23 A | 2023-11-24 A |  | 100% |  |
| 734 |  | Programme Participants Ready to Start Connectivity Proving | 0d | 2023-10-23 A | 2023-10-23 A |  | 100% | start no earlier than 2023-10-23 |
| 735 |  | SIT Participants' SIT A environments ready to start connectivity proving CIT Interval 4 | 0d | 2023-10-23 A | 2023-10-23 A | 734 | 100% |  |
| 736 |  | Internal Connectivity Proving Phase | 10d | 2023-10-23 A | 2023-11-03 A | 735 | 100% |  |
| 737 |  | Internal Connectivity Proving Phase Complete | 0d | 2023-11-03 A | 2023-11-03 A | 736 | 100% |  |
| 738 |  | DIP Onboarding Activity (1. PKI Officers and Certificates, 2. Set-up Validation, 3. End Point Creation, 4. Controlled Smoke Test ) | 10d | 2023-11-13 A | 2023-11-24 A | 737FS+5d | 100% |  |
| 739 |  | DIP Onboarding Complete | 0d | 2023-11-24 A | 2023-11-24 A | 738 | 100% |  |
| 740 |  | PPs register PKI Officers and Request PKI Certificates Complete - Interval 4 | 0d | 2023-11-24 A | 2023-11-24 A | 739 | 100% |  |
| 741 |  | PP Code Deployment | 0d | 2023-11-17 A | 2023-11-17 A |  | 100% | start no earlier than 2023-11-17 |
| 742 | 1.4.1.4.1.8.3 | **Test Data (SIT A) Interval 4** | 30d | 2023-10-23 A | 2023-12-01 A |  | 100% |  |
| 743 |  | Run data allocation | 5d | 2023-10-23 A | 2023-10-27 A | 712FS+5d | 100% |  |
| 744 |  | Cleanse and populate data post cut | 2d | 2023-10-30 A | 2023-10-31 A | 743 | 100% |  |
| 745 |  | Transmit data sets to PPs | 5d | 2023-11-01 A | 2023-11-07 A | 744 | 100% |  |
| 746 |  | PP - Load test data to test environments | 5d | 2023-11-08 A | 2023-11-14 A | 745 | 100% |  |
| 747 |  | PP Check data integrity on test environment | 13d | 2023-11-15 A | 2023-12-01 A | 746 | 100% |  |
| 748 |  | PP submit self-declaration to Programme to confirm loading & verification of test data | 0d | 2023-12-01 A | 2023-12-01 A | 747FF | 100% |  |
| 749 |  | Test Data (SIT A) Interval 4 Complete | 0d | 2023-12-01 A | 2023-12-01 A | 748 | 100% |  |
| 750 | 1.4.1.4.1.8.4 | **Other Preparation** | 25d | 2023-10-30 A | 2023-12-01 A |  | 100% |  |
| 751 |  | Onboarding of Test Participants to Test Management Tool (Azure DevOps) | 25d | 2023-10-30 A | 2023-12-01 A |  | 100% | start no earlier than 2023-10-30 |
| 752 |  | Test Management Tool onboarding | 25d | 2023-10-30 A | 2023-12-01 A |  | 100% | start no earlier than 2023-10-30 |
| 753 | 1.4.1.4.1.8.5 | **SIT Component Integration Test Readiness Report** | 27d | 2023-10-16 A | 2023-11-21 A |  | 100% |  |
| 754 |  | PP submit Test Readiness Report to Programme for assurance | 0d | 2023-11-03 A | 2023-11-03 A | 606 | 100% |  |
| 755 |  | SI assure Test Participants' Test Readiness Reports | 5d | 2023-11-06 A | 2023-11-10 A | 754FF+5d | 100% |  |
| 756 |  | SI develop Overarching SIT Component Integration Test Readiness Report | 20d | 2023-10-16 A | 2023-11-10 A | 755FF | 100% |  |
| 757 |  | Artefact review (via SITAG) and updates | 7d | 2023-11-13 A | 2023-11-21 A | 756 | 100% |  |
| 758 |  | SIT Component Integration Testing 4 Preparation Complete (incl. approval of SI SIT Component Integration Test Readiness Report) | 0d | 2023-12-04 A | 2023-12-04 A | 757FS+2d, 731, 735, 754, 749, 334FS+1d | 100% |  |
| 759 | 1.4.1.4.1.9 | **CIT Interval 5 Preparation** | 53d | 2023-11-01 A | 2024-01-12 A |  | 100% |  |
| 760 | 1.4.1.4.1.9.1 | **PIT Test Completion Report (incl. evidence)** | 21d | 2023-11-17 A | 2023-12-15 A |  | 100% |  |
| 761 |  | Submit draft PIT Test Completion Report (incl. evidence) and submit to Programme for assurance | 1d | 2023-11-17 A | 2023-11-17 A |  | 100% | must start on 2023-11-17 |
| 762 |  | Finalise PIT Test Completion Report (incl. evidence) | 15d | 2023-11-20 A | 2023-12-08 A | 761 | 100% |  |
| 763 |  | PP PIT Completion Report (excl. Migration/Reverse Migration) submitted to Programme for assurance CIT Interval 5 | 0d | 2023-12-08 A | 2023-12-08 A | 762, 79, 95 | 100% |  |
| 764 |  | PP Final PIT Completion Reports assured by SI | 5d | 2023-12-11 A | 2023-12-15 A | 763 | 100% |  |
| 765 | 1.4.1.4.1.9.2 | **Environments (SIT A)** | 21d | 2023-11-10 A | 2023-12-08 A |  | 100% |  |
| 766 |  | Programme Participants Ready to Start Connectivity Proving | 0d | 2023-11-10 A | 2023-11-10 A |  | 100% | start no earlier than 2023-11-10 |
| 767 |  | SIT Participants' SIT A environments ready to start connectivity proving CIT Interval 5 | 0d | 2023-11-10 A | 2023-11-10 A | 766 | 100% |  |
| 768 |  | Internal Connectivity Proving Phase | 10d | 2023-11-13 A | 2023-11-24 A | 766FS+1d | 100% |  |
| 769 |  | Internal Connectivity Proving Phase Complete | 0d | 2023-11-24 A | 2023-11-24 A | 768 | 100% |  |
| 770 |  | DIP Onboarding Activity (1. PKI Officers and Certificates, 2. Set-up Validation, 3. End Point Creation, 4. Controlled Smoke Test ) | 10d | 2023-11-27 A | 2023-12-08 A | 769 | 100% |  |

| ID | WBS | Task | Duration | Start | Finish | Predecessors | Complete | Total float | Constraint |
| --- | --- | --- | --- | --- | --- | --- | --- | --- | --- |
| 771 |  | DIP Onboarding Complete | 0d | 2023-12-08 A | 2023-12-08 A | 770 | 100% |  |  |
| 772 |  | PPs register PKI Officers and Request PKI Certificates Complete - Interval 5 | 0d | 2023-12-08 A | 2023-12-08 A | 771 | 100% |  |  |
| 773 |  | PP Code Deployment | 0d | 2023-12-08 A | 2023-12-08 A | 772 | 100% |  | start no earlier than 2023-10-20 |
| 774 | 1.4.1.4.1.9.3 | **Test Data (SIT A) Interval 5** | 33d | 2023-11-01 A | 2023-12-15 A |  | 100% |  |  |
| 775 |  | Run data allocation | 5d | 2023-11-01 A | 2023-11-07 A | 745SS | 100% |  |  |
| 776 |  | Cleanse and populate data post cut | 8d | 2023-11-08 A | 2023-11-17 A | 775 | 100% |  |  |
| 777 |  | Transmit data sets to PPs | 2d | 2023-11-20 A | 2023-11-21 A | 776 | 100% |  |  |
| 778 |  | PP - Load test data to test environments | 8d | 2023-11-22 A | 2023-12-01 A | 777 | 100% |  |  |
| 779 |  | PP Check data integrity on test environment | 10d | 2023-12-04 A | 2023-12-15 A | 778 | 100% |  |  |
| 780 |  | PP submit self-declaration to Programme to confirm loading & verification of test data | 0d | 2023-12-15 A | 2023-12-15 A | 779FF | 100% |  |  |
| 781 |  | Test Data (SIT A) Interval 5 Complete | 0d | 2023-12-15 A | 2023-12-15 A | 780 | 100% |  |  |
| 782 | 1.4.1.4.1.9.4 | **Other Preparation** | 40d | 2023-11-20 A | 2024-01-12 A |  | 100% |  |  |
| 783 |  | Onboarding of Test Participants to Test Management Tool (Azure DevOps) | 40d | 2023-11-20 A | 2024-01-12 A |  | 100% |  | start no earlier than 2023-11-20 |
| 784 |  | Test Management Tool onboarding | 36d | 2023-11-20 A | 2024-01-08 A |  | 100% |  | start no earlier than 2023-11-20 |
| 785 | 1.4.1.4.1.9.5 | **SIT Component Integration Test Readiness Report** | 35d | 2023-11-20 A | 2024-01-05 A |  | 100% |  |  |
| 786 |  | PP submit Test Readiness Report to Programme for assurance | 0d | 2023-12-08 A | 2023-12-08 A | 610 | 100% |  |  |
| 787 |  | SI assure Test Participants' Test Readiness Reports | 5d | 2023-12-11 A | 2023-12-15 A | 786FF+5d | 100% |  |  |
| 788 |  | SI develop Overarching SIT Component Integration Test Readiness Report | 20d | 2023-11-20 A | 2023-12-15 A | 787FF | 100% |  |  |
| 789 |  | Artefact review (via SITAG) and updates | 15d | 2023-12-18 A | 2024-01-05 A | 788 | 100% |  |  |
| 790 |  | SIT Component Integration Testing 5 Preparation Complete (incl. approval of SI SIT Component Integration Test Readiness Report) | 0d | 2024-01-08 A | 2024-01-08 A | 789FS+1d, 763, 767, 784, 786, 781, 436, 419 | 100% |  |  |
| 791 | 1.4.1.4.1.10 | **CIT Interval 6 Preparation** | 45d | 2023-11-20 A | 2024-01-19 A |  | 100% |  |  |
| 792 | 1.4.1.4.1.10.1 | **PIT Test Completion Report (incl. evidence)** | 31d | 2023-12-01 A | 2024-01-12 A |  | 100% |  |  |
| 793 |  | Submit draft PIT Test Completion Report (incl. evidence) and submit to Programme for assurance | 1d | 2023-12-01 A | 2023-12-01 A |  | 100% |  | must start on 2023-12-01 |
| 794 |  | Finalise PIT Test Completion Report (incl. evidence) | 25d | 2023-12-04 A | 2024-01-05 A | 793 | 100% |  |  |
| 795 |  | PP PIT Completion Report (excl. Migration/Reverse Migration) submitted to Programme for assurance CIT Interval 6 | 0d | 2024-01-05 A | 2024-01-05 A | 794, 79, 95, 256, 261, 264 | 100% |  |  |
| 796 |  | PP Final PIT Completion Reports assured by SI | 5d | 2024-01-08 A | 2024-01-12 A | 795 | 100% |  |  |
| 797 | 1.4.1.4.1.10.2 | **Environments (SIT A)** | 30d | 2023-11-24 A | 2024-01-05 A |  | 100% |  |  |
| 798 |  | Programme Participants Ready to Start Connectivity Proving | 0d | 2023-11-24 A | 2023-11-24 A |  | 100% |  | start no earlier than 2023-11-24 |
| 799 |  | SIT Participants' SIT A environments ready to start connectivity proving CIT Interval 6 | 0d | 2023-11-24 A | 2023-11-24 A | 798 | 100% |  |  |
| 800 |  | Internal Connectivity Proving Phase | 10d | 2023-11-27 A | 2023-12-08 A | 799FS+1d | 100% |  |  |
| 801 |  | Internal Connectivity Proving Phase Complete | 0d | 2023-12-08 A | 2023-12-08 A | 800 | 100% |  |  |
| 802 |  | DIP Onboarding Activity (1. PKI Officers and Certificates, 2. Set-up Validation, 3. End Point Creation, 4. Controlled Smoke Test ) | 5d | 2023-12-04 A | 2023-12-08 A | 799FS+6d | 100% |  |  |
| 803 |  | DIP Onboarding Complete | 0d | 2023-12-08 A | 2023-12-08 A | 802 | 100% |  |  |
| 804 |  | PPs register PKI Officers and Request PKI Certificates Complete - Interval 6 | 0d | 2023-12-08 A | 2023-12-08 A | 803 | 100% |  | start no earlier than 2023-12-08 |
| 805 |  | PP Code Deployment | 0d | 2024-01-05 A | 2024-01-05 A |  | 100% |  | start no earlier than 2024-01-05 |
| 806 | 1.4.1.4.1.10.3 | **Test Data (SIT A) Interval 6** | 25d | 2023-11-20 A | 2023-12-22 A |  | 100% |  |  |
| 807 |  | Run data allocation | 10d | 2023-11-20 A | 2023-12-01 A | 777SS | 100% |  |  |
| 808 |  | Cleanse and populate data post cut | 1d | 2023-12-04 A | 2023-12-04 A | 807 | 100% |  |  |
| 809 |  | Transmit data sets to PPs | 1d | 2023-12-05 A | 2023-12-05 A | 808 | 100% |  |  |
| 810 |  | PP - Load test data to test environments | 8d | 2023-12-06 A | 2023-12-15 A | 809 | 100% |  |  |
| 811 |  | PP Check data integrity on test environment | 5d | 2023-12-18 A | 2023-12-22 A | 810 | 100% |  |  |
| 812 |  | PP submit self-declaration to Programme to confirm loading & verification of test data | 0d | 2023-12-22 A | 2023-12-22 A | 811FF | 100% |  |  |
| 813 |  | Test Data (SIT A) Interval 6 Complete | 0d | 2023-12-22 A | 2023-12-22 A | 812 | 100% |  |  |
| 814 | 1.4.1.4.1.10.4 | **Other Preparation** | 31d | 2023-12-04 A | 2024-01-15 A |  | 100% |  |  |
| 815 |  | Onboarding of Test Participants to Test Management Tool (Azure DevOps) | 31d | 2023-12-04 A | 2024-01-15 A |  | 100% |  | start no earlier than 2023-12-04 |
| 816 |  | Test Management Tool onboarding | 31d | 2023-12-04 A | 2024-01-15 A |  | 100% |  | start no earlier than 2023-12-04 |
| 817 | 1.4.1.4.1.10.5 | **SIT Component Integration Test Readiness Report** | 25d | 2023-11-20 A | 2023-12-22 A |  | 100% |  |  |
| 818 |  | PP submit Test Readiness Report to Programme for assurance | 0d | 2023-12-08 A | 2023-12-08 A | 610 | 100% |  |  |
| 819 |  | SI assure Test Participants' Test Readiness Reports | 5d | 2023-12-11 A | 2023-12-15 A | 818FF+5d | 100% |  |  |
| 820 |  | SI develop Overarching SIT Component Integration Test Readiness Report | 20d | 2023-11-20 A | 2023-12-15 A | 819FF | 100% |  |  |
| 821 |  | Artefact review (via TMAG) and updates | 5d | 2023-12-18 A | 2023-12-22 A | 820 | 100% |  |  |
| 822 |  | SIT Component Integration Testing 6 Preparation Complete (incl. approval of SI SIT Component Integration Test Readiness Report) | 0d | 2024-01-19 A | 2024-01-19 A | 821FS+1d, 795, 799, 816, 818, 813, 282, 453 | 100% |  |  |
| 823 | 1.4.1.4.2 | **SIT Functional Preparation** | 636d? | 2022-10-31 A | 2025-04-07 |  | 85% | 708d |  |
| 824 |  | Environment Approach and Plan - SIT Functional | 1d? | 2023-11-20 A | 2023-11-20 A |  | 100% |  | start no earlier than 2023-11-20 |
| 825 | 1.4.1.4.2.2 | **Test Approach & Plan** | 208d | 2022-10-31 A | 2023-08-16 A |  | 100% |  |  |
| 826 |  | Develop document with SITWG | 179d | 2022-10-31 A | 2023-07-06 A |  | 100% |  | finish no earlier than 2023-07-06 |
| 827 |  | Industry Consultation | 10d | 2023-07-07 A | 2023-07-20 A | 826 | 100% |  |  |
| 828 |  | Artefact review (via TMAG) and updates | 19d | 2023-07-21 A | 2023-08-16 A | 827 | 100% |  | finish no earlier than 2023-08-03 |
| 829 |  | SIT Functional Test Approach & Plan approved | 0d | 2023-08-16 A | 2023-08-16 A |  | 100% |  | finish no earlier than 2023-08-16 |
| 830 | 1.4.1.4.2.3 | **Test Data Approach & Plan** | 29d | 2023-07-07 A | 2023-08-16 A |  | 100% |  |  |
| 831 |  | Industry Consultation | 10d | 2023-07-07 A | 2023-07-20 A | 827SS | 100% |  |  |
| 832 |  | Artefact review (via TMAG) and updates | 19d | 2023-07-21 A | 2023-08-16 A | 831 | 100% |  |  |
| 833 |  | SIT Functional Testing Test Data Approach & Plan approved | 0d | 2023-08-16 A | 2023-08-16 A | 832 | 100% |  |  |
| 834 | 1.4.1.4.2.4 | **Test scenarios** | 298d | 2023-01-02 A | 2024-02-21 A |  | 100% |  |  |
| 835 |  | Development of test scenarios | 85d | 2023-01-02 A | 2023-04-28 A | 826SS+45d | 100% |  |  |
| 836 |  | Review test scenarios with SIT Working Group | 65d | 2023-08-17 A | 2023-11-15 A | 835FS+78d | 100% |  |  |
| 837 |  | SIT Functional Testing Test scenarios (themes 1-5) approved | 0d | 2023-12-08 A | 2023-12-08 A | 836FS+17d | 100% |  |  |
| 838 |  | SIT Functional Testing Test scenarios (themes 6,7,9) approved | 0d | 2024-01-17 A | 2024-01-17 A | 837FS+28d | 100% |  |  |
| 839 |  | SIT Functional Testing Test scenarios (theme 8) approved | 0d | 2024-02-21 A | 2024-02-21 A | 838FS+25d | 100% |  |  |
| 840 | 1.4.1.4.2.5 | **Test cases** | 465d? | 2023-05-01 A | 2025-02-07 |  | 84% | 749d |  |

| ID | WBS | Task | Duration | Start | Finish | Predecessors | Complete | Total float | Constraint |
| --- | --- | --- | --- | --- | --- | --- | --- | --- | --- |
| 841 | 1.4.1.4.2.5.1 | **SI Test cases** | 213d | 2023-05-01 A | 2024-02-21 A |  | 100% |  |  |
| 842 |  | Development of Test cases | 150d | 2023-05-01 A | 2023-11-24 A | 835 | 100% |  |  |
| 843 |  | Review Test cases with SIT Working Group | 78d | 2023-09-25 A | 2024-01-10 A | 842SS+105d | 100% |  |  |
| 844 |  | SIT Functional Testing Test Cases (themes 1-5) approved | 0d | 2024-01-17 A | 2024-01-17 A | 843FS+5d | 100% |  |  |
| 845 |  | SIT Functional Testing Test cases (themes 6,7,9) approved | 0d | 2024-01-17 A | 2024-01-17 A | 844 | 100% |  |  |
| 846 |  | SIT Functional Testing Test cases (theme 8) approved | 0d | 2024-02-21 A | 2024-02-21 A | 845FS+25d | 100% |  |  |
| 847 | 1.4.1.4.2.5.2 | **SIT Functional Programme RTTM** | 55d? | 2024-07-29 A | 2024-10-11 |  | 95% | 834d |  |
| 848 | 1.4.1.4.2.5.2.1 | **RTTM Development** | 40d? | 2024-07-29 A | 2024-09-20 |  | 99% | 849d |  |
| 849 |  | Development of Manual SIT Functional RTTM | 30d? | 2024-07-29 A | 2024-09-06 A |  | 100% |  | start no earlier than 2024-07-29 |
| 850 |  | Manual SIT Functional RTTM Complete | 0d? | 2024-09-06 A | 2024-09-06 A | 849 | 100% |  | start no earlier than 2024-07-29 |
| 851 |  | Development of Automated SIT Functional RTTM | 40d? | 2024-07-29 A | 2024-09-20 A |  | 100% |  | start no earlier than 2024-07-29 |
| 852 |  | Automated SIT Functional RTTM Complete | 0d? | 2024-09-20 A | 2024-09-20 | 851 | 80% | 849d | finish no earlier than 2024-09-20 |
| 853 | 1.4.1.4.2.5.2.2 | **Gap analysis** | 35d? | 2024-08-26 A | 2024-10-11 |  | 86% | 834d |  |
| 854 |  | Identify gaps in test case coverage following RTTM review. | 20d? | 2024-08-26 A | 2024-09-20 A | 851SS+20d | 100% |  |  |
| 855 |  | Address gaps in test case coverage following RTTM review. | 20d | 2024-09-09 A | 2024-10-04 | 854SS+10d | 80% | 834d |  |
| 856 |  | SRO Walkthrough | 1d? | 2024-10-09 | 2024-10-09 | 855FS+2d |  | 836d |  |
| 857 |  | SRO Approval | 1d? | 2024-10-09 | 2024-10-09 | 855FS+2d |  | 834d |  |
| 858 |  | Gap analysis complete | 0d | 2024-10-11 | 2024-10-11 | 857FS+2d |  | 834d |  |
| 859 | 1.4.1.4.2.5.3 | **Cycle 3 Test Evidence Capturing Approach** | 25d? | 2024-09-16 A | 2024-10-18 |  | 93% | 3d |  |
| 860 |  | Define guiding principles and proof of concept | 10d | 2024-09-16 A | 2024-09-27 A |  | 100% |  | start no earlier than 2024-09-16 |
| 861 |  | Draft proposed test evidence capturing approach | 3d | 2024-09-30 A | 2024-10-02 A | 860 | 100% |  |  |
| 862 |  | SRO review | 5d | 2024-10-03 A | 2024-10-09 A | 861 | 100% |  |  |
| 863 |  | Present proposed approach | 1d? | 2024-10-11 A | 2024-10-11 A | 862FS+1d | 100% |  |  |
| 864 |  | Incorporate feedback | 4d | 2024-10-14 A | 2024-10-17 | 863 | 80% | 3d |  |
| 865 |  | Publish proposed approach ahead of Cycle 3 start | 1d? | 2024-10-18 | 2024-10-18 | 864 |  | 3d |  |
| 866 | 1.4.1.4.2.5.4 | **DITL Cycle 3 Pack Development** | 8d? | 2024-10-08 A | 2024-10-17 |  | 31% | 830d |  |
| 867 |  | Programme Cycle 2 Retro | 1d? | 2024-10-08 A | 2024-10-08 A |  | 100% |  | start no earlier than 2024-10-08 |
| 868 |  | Post-retro DITL Changes | 3d | 2024-10-09 A | 2024-10-11 | 867 | 50% | 830d |  |
| 869 |  | SRO Review | 2d | 2024-10-14 | 2024-10-15 | 868 |  | 830d |  |
| 870 |  | Post-SRO Review Changes | 1d? | 2024-10-16 | 2024-10-16 | 869 |  | 830d |  |
| 871 |  | Publish Cycle 3 DITL / Cycle 3 DITL Online Sessions for SIT PPs | 1d? | 2024-10-17 | 2024-10-17 | 870 |  | 830d |  |
| 872 | 1.4.1.4.2.5.5 | **Test Script Exit Points** | 85d | 2024-10-14 A | 2025-02-07 |  | 7% | 749d |  |
| 873 |  | Identify exit points for Sprint 5 | 5d | 2024-10-14 A | 2024-10-18 | 865FS-5d | 60% | 829d |  |
| 874 |  | Identify exit points for Sprint 6 | 5d | 2024-10-21 | 2024-10-25 | 1255SS |  | 824d |  |
| 875 |  | Identify exit points for Sprint 7 | 5d | 2024-11-04 | 2024-11-08 | 1256SS |  | 814d |  |
| 876 |  | Identify exit points for Sprint 8 | 5d | 2024-11-18 | 2024-11-22 | 1257SS |  | 804d |  |
| 877 |  | Identify exit points for Sprint 9 | 5d | 2024-12-02 | 2024-12-06 | 1258SS |  | 794d |  |
| 878 |  | Identify exit points for Sprint 10 | 5d | 2024-12-23 | 2024-12-27 | 1259SS |  | 779d |  |
| 879 |  | Identify exit points for Sprint 11 | 5d | 2025-01-06 | 2025-01-10 | 1260SS |  | 769d |  |
| 880 |  | Identify exit points for Sprint 12 | 5d | 2025-01-20 | 2025-01-24 | 1261SS |  | 759d |  |
| 881 |  | Identify exit points for Sprint 13 | 5d | 2025-02-03 | 2025-02-07 | 1262SS |  | 749d |  |
| 882 | 1.4.1.4.2.5.6 | **Cycle 3 Test Case Rationalisation (Functional and Migration)** | 36d? | 2024-09-16 A | 2024-11-04 |  | 59% | 818d |  |
| 883 |  | Review Cycle 3 scope and identify candidates for rationalisation | 25d | 2024-09-16 A | 2024-10-18 |  | 60% | 829d | start no earlier than 2024-09-16 |
| 884 |  | Define proposal for rationalisation of test cases | 15d | 2024-09-30 A | 2024-10-18 A | 883 | 100% |  |  |
| 885 |  | SRO review | 5d | 2024-10-21 | 2024-10-25 | 884 |  | 818d |  |
| 886 |  | Present proposed approach | 1d? | 2024-10-28 | 2024-10-28 | 885 |  | 818d |  |
| 887 |  | Incorporate feedback | 4d | 2024-10-29 | 2024-11-01 | 886 |  | 818d |  |
| 888 |  | Publish proposed approach ahead of Cycle 3 start | 1d? | 2024-11-04 | 2024-11-04 | 887 |  | 818d |  |
| 889 | 1.4.1.4.2.6 | **Environments (SIT-Staging)** | 10d | 2023-12-04 A | 2023-12-15 A |  | 100% |  |  |
| 890 | 1.4.1.4.2.6.1 | **SIT Functional pre-requisites** | 10d | 2023-12-04 A | 2023-12-15 A |  | 100% |  |  |
| 891 | 1.4.1.4.2.6.1.1 | **DCC** | 10d | 2023-12-04 A | 2023-12-15 A |  | 100% |  |  |
| 892 | 1.4.1.4.2.6.1.1.1 | **CSS** | 10d | 2023-12-04 A | 2023-12-15 A |  | 100% |  |  |
| 893 |  | SIT participants have requested DCC CSS PKI certificates for access to UIT-B environment | 10d | 2023-12-04 A | 2023-12-15 A |  | 100% |  | start no earlier than 2023-12-04 |
| 894 |  | SIT participants have received DCC CSS PKI certificates for UIT-B environment | 0d | 2023-12-15 A | 2023-12-15 A | 893 | 100% |  |  |
| 895 | 1.4.1.4.2.6.1.1.2 | **DSP** | 10d | 2023-12-04 A | 2023-12-15 A |  | 100% |  |  |
| 896 |  | SIT participants have requested DCC DSP PKI certificates for access to UIT-B environment | 10d | 2023-12-04 A | 2023-12-15 A |  | 100% |  | start no earlier than 2023-12-04 |
| 897 |  | SIT participants have received DCC DSP PKI certificates for UIT-B environment | 0d | 2023-12-15 A | 2023-12-15 A | 896 | 100% |  |  |
| 898 | 1.4.1.4.2.7 | **Stand up SIT A Environment** | 25d | 2024-02-05 A | 2024-03-08 A |  | 100% |  |  |
| 899 | 1.4.1.4.2.7.1 | **SIT Functional Connectivity Proving** | 15d | 2024-02-12 A | 2024-03-01 A |  | 100% |  |  |
| 900 |  | SIT Functional Connectivity Proving Period | 15d | 2024-02-12 A | 2024-03-01 A |  | 100% |  | start no earlier than 2024-01-08 |
| 901 |  | SIT Functional Connectivity Proving Complete | 0d | 2024-03-01 A | 2024-03-01 A | 900 | 100% |  | start no earlier than 2024-03-01 |
| 902 | 1.4.1.4.2.7.2 | **PP Environments (SIT A)** | 25d | 2024-02-05 A | 2024-03-08 A |  | 100% |  |  |
| 903 |  | Deployment of MHHS solution code to SIT A environments | 25d | 2024-02-05 A | 2024-03-08 A |  | 100% |  | start no earlier than 2024-02-05 |
| 904 | 1.4.1.4.2.7.3 | **SI Environments (SIT A)** | 25d | 2024-02-05 A | 2024-03-08 A |  | 100% |  |  |
| 905 |  | Coordinate deployment of MHHS solution code to SIT Participants' SIT A environments | 25d | 2024-02-05 A | 2024-03-08 A | 903SS | 100% |  |  |
| 906 | 1.4.1.4.2.8 | **Test data (SIT A)** | 341d? | 2023-12-18 A | 2025-04-07 |  | 57% | 708d |  |
| 907 | 1.4.1.4.2.8.1 | **Cycle 1 Test data (SIT A)** | 55d | 2023-12-18 A | 2024-03-01 A |  | 100% |  |  |
| 908 |  | Prepare, Generate and Allocate Test Data | 28d | 2023-12-18 A | 2024-01-24 A | 642, 650 | 100% |  | start no earlier than 2023-12-11 |
| 909 |  | Transmit Data Sets to PPs | 4d | 2024-01-26 A | 2024-01-31 A | 908FS+1d | 100% |  |  |
| 910 |  | PP's Iterative load and data integrity check | 22d | 2024-02-01 A | 2024-03-01 A | 909 | 100% |  |  |

| ID | WBS | Task | Duration | Start | Finish | Predecessors | Complete | Total float | Constraint |
| --- | --- | --- | --- | --- | --- | --- | --- | --- | --- |
| 911 |  | Cycle 1 - PP's confirmation that test data is ready for SIT Functional | 0d | 2024-03-01 A | 2024-03-01 A | 910 | 100% |  |  |
| 912 | 1.4.1.4.2.8.2 | **Cycle 2 Test data (inc. Settlement Data) (SIT A)** | 57d | 2024-03-28 A | 2024-06-14 A |  | 100% |  |  |
| 913 |  | Prepare, Generate and Allocate Test Data | 31d | 2024-03-28 A | 2024-05-09 A | 911FS+18d | 100% |  |  |
| 914 |  | Transmit Data Sets to PPs | 3d | 2024-05-10 A | 2024-05-14 A | 913 | 100% |  |  |
| 915 |  | PP's Iterative load and data integrity check | 13d | 2024-05-15 A | 2024-05-31 A | 914 | 100% |  |  |
| 916 |  | Cycle 2 - PP's confirmation that test data is ready for SIT Functional | 0d | 2024-06-14 A | 2024-06-14 A | 915FS+10d | 100% |  |  |
| 917 | 1.4.1.4.2.8.3 | **Cycle 3 Test data (SIT A) (2)** | 71d? | 2024-07-15 A | 2024-10-21 |  | 80% | 828d |  |
| 918 |  | Cycle 3 data requirments analysis - check Cycle 2 data for gaps Check blocked test cases | 10d? | 2024-07-15 A | 2024-07-26 A |  | 100% |  | finish no earlier than 2024-07-26 |
| 919 |  | Provide DCC with MPANS for deletion secure file with password | 1d? | 2024-08-12 A | 2024-08-12 A |  | 100% |  |  |
| 920 |  | Receive MPANS from DCC to exclude | 1d? | 2024-08-09 A | 2024-08-09 A |  | 100% |  |  |
| 921 |  | Exclude MPANS from allocation | 1d | 2024-08-16 A | 2024-08-16 A |  | 100% |  |  |
| 922 |  | Allocate Cycle 3 MPANS | 16d? | 2024-08-06 A | 2024-08-27 A |  | 100% |  |  |
| 923 |  | Generate Cycle 3 Data | 2d? | 2024-08-27 A | 2024-08-28 A |  | 100% |  |  |
| 924 |  | Check data prior to sending to DCC | 5d? | 2024-08-22 A | 2024-08-28 A |  | 100% |  |  |
| 925 |  | Share Cycle 3 MPAN data with DCC | 1d? | 2024-08-29 A | 2024-08-29 A |  | 100% |  |  |
| 926 |  | DCC - load data and create registration Id's for Cycle 3 data | 13d? | 2024-08-27 A | 2024-09-12 A |  | 100% |  |  |
| 927 |  | Add registration ID's to Cycle 3 Data | 2d? | 2024-09-12 A | 2024-09-13 A |  | 100% |  |  |
| 928 |  | Share subset of data with St Cls for data load | 2d? | 2024-09-12 A | 2024-09-13 A |  | 100% |  |  |
| 929 |  | St Clements to run test with Subset of data - MPRS business process checks including Import/Export MPANS | 5d? | 2024-09-16 A | 2024-09-20 A |  | 100% |  |  |
| 930 |  | Send Cycle 3 data to partcipants for early sight of data | 3d? | 2024-09-25 A | 2024-09-27 A |  | 100% |  |  |
| 931 |  | St Clements MPRS data load bulk files for Cycle 3 | 15d? | 2024-09-23 A | 2024-10-11 A |  | 100% |  |  |
| 932 |  | New MPAN creation and load through DCC and St Clements | 1d? | 2024-10-11 A | 2024-10-11 |  | 95% | 834d | start no earlier than 2024-10-11 |
| 933 |  | Share files with PP's and central parties | 1d | 2024-10-11 | 2024-10-11 |  |  | 834d | start no earlier than 2024-10-11 |
| 934 |  | Avanade to load data | 6d | 2024-10-14 | 2024-10-21 |  |  | 828d | start no earlier than 2024-10-14 |
| 935 |  | Helix to load data | 6d | 2024-10-14 | 2024-10-21 |  |  | 828d | start no earlier than 2024-10-14 |
| 936 |  | PP's and central parties to load all Cycle 3 data | 6d | 2024-10-14 | 2024-10-21 |  |  | 828d | start no earlier than 2024-10-14 |
| 937 |  | All parties to finalise data load | 1d? | 2024-10-21 | 2024-10-21 |  |  | 34d | start no earlier than 2024-10-21 |
| 938 | 1.4.1.4.2.8.4 | **Regression Test data (SIT A)** | 116d | 2024-10-28 | 2025-04-07 |  |  | 34d |  |
| 939 |  | Prepare, Generate and Allocate Test Data | 94d | 2024-10-28 | 2025-03-06 | 937FS+4d |  | 34d |  |
| 940 |  | Transmit Data Sets to PPs | 2d | 2025-03-07 | 2025-03-10 | 939 |  | 34d |  |
| 941 |  | PP's Iterative load and data integrity check | 20d | 2025-03-11 | 2025-04-07 | 940 |  | 34d |  |
| 942 |  | Regression - PP's confirmation that test data is ready for SIT Functional | 0d | 2025-04-07 | 2025-04-07 | 941 |  | 34d |  |
| 943 | 1.4.1.4.2.9 | **SIT Functional Test Readiness Report** | 45d | 2024-01-01 A | 2024-03-01 A |  | 100% |  |  |
| 944 | 1.4.1.4.2.9.1 | **PP SIT Functional Test Readiness Report** | 44d | 2024-01-01 A | 2024-02-29 A |  | 100% |  |  |
| 945 |  | Develop draft Test Readiness Report and submit to Programme for assurance | 21d | 2024-01-01 A | 2024-01-29 A |  | 100% |  | start no earlier than 2024-01-01 |
| 946 |  | Placing Reliance Stage 2 Review | 34d | 2024-01-15 A | 2024-02-29 A | 945SS+10d | 100% |  |  |
| 947 |  | Finalise Test Readiness Report and submit to Programme for assurance | 9d | 2024-01-30 A | 2024-02-09 A | 945 | 100% |  |  |
| 948 | 1.4.1.4.2.9.2 | **SI SIT Functional Test Readiness Report** | 40d | 2024-01-01 A | 2024-02-23 A |  | 100% |  |  |
| 949 |  | Assure Test Participants' Test Readiness Reports | 35d | 2024-01-01 A | 2024-02-16 A | 945SS, 947FF+5d | 100% |  |  |
| 950 |  | Develop Overarching SIT Functional Test Readiness Report | 20d | 2024-01-22 A | 2024-02-16 A | 949FF | 100% |  |  |
| 951 |  | Artefact review (via TMAG) and updates | 5d | 2024-02-19 A | 2024-02-23 A | 950 | 100% |  |  |
| 952 |  | SIT Functional Testing Preparation Complete | 0d | 2024-03-01 A | 2024-03-01 A | 951FF+5d, 829, 351, 946, 837, 844, 911 | 100% |  |  |
| 953 | 1.4.1.4.3 | **SIT Migration Testing Preparation** | 505d? | 2022-10-31 A | 2024-10-04 |  | 98% | 839d |  |
| 954 | 1.4.1.4.3.1 | **Test Approach & Plan** | 75d | 2023-09-07 A | 2023-12-20 A |  | 100% |  |  |
| 955 |  | Develop document with SITWG | 32d | 2023-09-07 A | 2023-10-20 A | 2177 | 100% |  | finish no earlier than 2023-10-11 |
| 956 |  | Draft document review with Code Bodies | 8d | 2023-10-23 A | 2023-11-01 A | 955 | 100% |  |  |
| 957 |  | Industry Consultation | 10d | 2023-11-02 A | 2023-11-15 A | 956 | 100% |  |  |
| 958 |  | Artefact review (via TMAG) and updates | 25d | 2023-11-16 A | 2023-12-20 A | 957 | 100% |  |  |
| 959 |  | SIT Migration Testing Test Approach & Plan approved | 0d | 2023-12-20 A | 2023-12-20 A | 958 | 100% |  | finish no earlier than 2023-12-20 |
| 960 | 1.4.1.4.3.2 | **Test Data Approach & Plan** | 35d | 2023-11-02 A | 2023-12-20 A |  | 100% |  |  |
| 961 |  | Industry Consultation | 10d | 2023-11-02 A | 2023-11-15 A | 957SS | 100% |  |  |
| 962 |  | Artefact review (via TMAG) and updates | 25d | 2023-11-16 A | 2023-12-20 A | 961 | 100% |  |  |
| 963 |  | SIT Migration Test Data Test Approach & Plan approved | 0d | 2023-12-20 A | 2023-12-20 A | 962 | 100% |  |  |
| 964 | 1.4.1.4.3.3 | **Test scenarios & Test Cases** | 207d? | 2023-12-21 A | 2024-10-04 |  | 93% | 839d |  |
| 965 | 1.4.1.4.3.3.1 | **Theme 1** | 65d | 2023-12-21 A | 2024-03-20 A |  | 100% |  |  |
| 966 |  | Develop Test Scenarios & Test Cases | 25d | 2023-12-21 A | 2024-01-24 A | 959 | 100% |  |  |
| 967 |  | Industry Review Workshop | 1d | 2024-01-25 A | 2024-01-25 A | 966 | 100% |  |  |
| 968 |  | Industry Consultation Review | 6d | 2024-02-05 A | 2024-02-12 A | 967FS+6d | 100% |  |  |
| 969 |  | Review with SIT Working Group | 5d | 2024-02-29 A | 2024-03-06 A | 968FS+12d | 100% |  |  |
| 970 |  | SIT Migration Test scenarios & Test Cases Approved - Theme 1 | 0d | 2024-03-20 A | 2024-03-20 A | 969FS+10d | 100% |  |  |
| 971 | 1.4.1.4.3.3.2 | **Theme 2** | 85d | 2023-12-21 A | 2024-04-17 A |  | 100% |  |  |
| 972 |  | Develop Test Scenarios & Test Cases | 40d | 2023-12-21 A | 2024-02-14 A | 959 | 100% |  |  |
| 973 |  | Industry Review Workshop | 1d | 2024-02-15 A | 2024-02-15 A | 972 | 100% |  |  |
| 974 |  | Industry Consultation Review | 6d | 2024-02-26 A | 2024-03-04 A | 973FS+6d | 100% |  |  |
| 975 |  | Review with SIT Working Group | 5d | 2024-03-28 A | 2024-04-03 A | 974FS+17d | 100% |  |  |
| 976 |  | SIT Migration Test scenarios & Test Cases Approved - Theme 2 | 0d | 2024-04-17 A | 2024-04-17 A | 975FS+10d | 100% |  |  |
| 977 | 1.4.1.4.3.3.3 | **Theme 3** | 85d | 2023-12-21 A | 2024-04-17 A |  | 100% |  |  |
| 978 |  | Develop Test Scenarios & Test Cases | 55d | 2023-12-21 A | 2024-03-06 A | 959 | 100% |  |  |
| 979 |  | Industry Review Workshop | 1d | 2024-03-07 A | 2024-03-07 A | 978 | 100% |  |  |
| 980 |  | Industry Consultation Review | 6d | 2024-03-13 A | 2024-03-20 A | 979FS+3d | 100% |  |  |

| ID | WBS | Task | Duration | Start | Finish | Predecessors | Complete | Total float | Constraint |
| --- | --- | --- | --- | --- | --- | --- | --- | --- | --- |
| 981 |  | Review with SIT Working Group | 5d | 2024-03-28 A | 2024-04-03 A | 980FS+5d | 100% |  |  |
| 982 |  | SIT Migration Test scenarios & Test Cases Approved - Theme 3 | 0d | 2024-04-17 A | 2024-04-17 A | 981FS+10d | 100% |  |  |
| 983 | 1.4.1.4.3.3.4 | **RTTM Development** | 27d? | 2024-08-29 A | 2024-10-04 |  | 84% | 839d |  |
| 984 |  | Develop Manual SIT Migration RTTM | 17d | 2024-08-29 A | 2024-09-20 A |  | 100% |  | start no earlier than 2024-08-29 |
| 985 |  | Manual SIT Migration RTTM Complete | 0d | 2024-09-20 A | 2024-09-20 A | 984 | 100% |  |  |
| 986 |  | Develop Automated SIT Migration RTTM | 20d | 2024-09-09 A | 2024-10-04 |  | 70% | 839d | start no earlier than 2024-09-09 |
| 987 |  | Automated SIT Migration RTTM Complete | 0d? | 2024-10-04 | 2024-10-04 | 986 |  | 839d |  |
| 988 | 1.4.1.4.3.3.5 | **Gap analysis** | 17d? | 2024-09-12 A | 2024-10-04 |  | 60% | 839d |  |
| 989 |  | Identify gaps in test case coverage following RTTM review. | 12d | 2024-09-12 A | 2024-09-27 A | 984SS+10d | 100% |  |  |
| 990 |  | Address gaps in test case coverage following RTTM review. | 12d | 2024-09-19 A | 2024-10-04 | 989SS+5d | 20% | 839d |  |
| 991 |  | Gap analysis complete | 0d? | 2024-10-04 | 2024-10-04 | 990 |  | 839d |  |
| 992 | 1.4.1.4.3.4 | **Environments (SIT B)** | 435d | 2022-10-31 A | 2024-06-28 A |  | 100% |  |  |
| 993 | 1.4.1.4.3.4.1 | **PP Environments (SIT B)** | 41d | 2024-05-03 A | 2024-06-28 A |  | 100% |  |  |
| 994 |  | PP Environments available | 0d | 2024-05-03 A | 2024-05-03 A | 504 | 100% |  | start no earlier than 2024-05-03 |
| 995 |  | PP Onboarding / Smoke test | 35d | 2024-05-13 A | 2024-06-28 A | 994FS+6d | 100% |  |  |
| 996 |  | DTN Connectivity Proving Complete | 5d | 2024-06-10 A | 2024-06-14 A | 994FS+26d | 100% |  |  |
| 997 |  | PP Code Deployment | 0d | 2024-06-14 A | 2024-06-14 A | 996 | 100% |  |  |
| 998 | 1.4.1.4.3.4.2 | **SI Environments (SIT B)** | 425d | 2022-10-31 A | 2024-06-14 A |  | 100% |  |  |
| 999 |  | Coordinate SIT Participants' SIT B environment preparation | 420d | 2022-10-31 A | 2024-06-07 A |  | 100% |  |  |
| 1000 |  | Assure PPs' self-declaration of environment preparation complete (incl. security certificates and security compliance) | 0d | 2024-06-07 A | 2024-06-07 A | 999 | 100% |  |  |
| 1001 |  | SIT Participants' SIT B environments ready to start connectivity proving (incl. certificates and security compliance) | 0d | 2024-06-05 A | 2024-06-05 A | 994FS+24d | 100% |  |  |
| 1002 |  | Coordinate SIT Participants' SIT B environment connectivity proving | 2d | 2024-06-06 A | 2024-06-07 A | 1001 | 100% |  |  |
| 1003 |  | Coordinate deployment of MHHS solution code to SIT Participants' SIT B environments | 0d | 2024-06-14 A | 2024-06-14 A | 997 | 100% |  |  |
| 1004 | 1.4.1.4.3.5 | **SIT Migration Test Readiness Report** | 44d | 2024-04-02 A | 2024-05-31 A |  | 100% |  |  |
| 1005 | 1.4.1.4.3.5.1 | **PP SIT Migration Test Readiness Report** | 44d | 2024-04-02 A | 2024-05-31 A |  | 100% |  |  |
| 1006 |  | Develop draft Test Readiness Report and submit to Programme for assurance | 20d | 2024-04-02 A | 2024-04-29 A |  | 100% |  | start no earlier than 2024-04-02 |
| 1007 |  | Placing Reliance Stage 2 Review | 35d | 2024-04-15 A | 2024-05-31 A | 1006SS+9d | 100% |  |  |
| 1008 |  | Finalise Test Readiness Report and submit to Programme for assurance | 10d | 2024-04-30 A | 2024-05-13 A | 1006 | 100% |  |  |
| 1009 | 1.4.1.4.3.5.2 | **SI SIT Migration Test Readiness Report** | 40d | 2024-04-02 A | 2024-05-27 A |  | 100% |  |  |
| 1010 |  | Assure Test Participants' Test Readiness Reports | 35d | 2024-04-02 A | 2024-05-20 A | 1006SS, 1008FF+5d | 100% |  |  |
| 1011 |  | Develop Overarching SIT Migration Test Readiness Report | 20d | 2024-04-23 A | 2024-05-20 A | 1010FF | 100% |  |  |
| 1012 |  | Artefact review (via SITAG) and updates | 5d | 2024-05-21 A | 2024-05-27 A | 1011 | 100% |  |  |
| 1013 |  | SIT Migration Testing Preparation Complete | 0d | 2024-06-03 A | 2024-06-03 A | 1012FF+5d, 959, 368, 1007, 970, 976, 982 | 100% |  |  |
| 1014 | 1.4.1.4.4 | **SIT Non-Functional Preparation** | 337d? | 2023-11-30 A | 2025-03-14 |  | 51% | 724d |  |
| 1015 | 1.4.1.4.4.1 | **Test Approach & Plan** | 120d | 2023-11-30 A | 2024-05-15 A |  | 100% |  |  |
| 1016 |  | Develop document with SITWG | 67d | 2023-11-30 A | 2024-03-01 A |  | 100% |  | must start on 2023-11-30 |
| 1017 |  | Draft document review with Code Bodies | 10d | 2024-03-04 A | 2024-03-15 A | 1016 | 100% |  |  |
| 1018 |  | Industry Consultation | 10d | 2024-03-18 A | 2024-03-29 A | 1017 | 100% |  |  |
| 1019 |  | Industry Assurance Review | 5d | 2024-04-11 A | 2024-04-17 A | 1018FS+8d | 100% |  |  |
| 1020 |  | SIT Non-Functional Testing Test Approach & Plan approved | 0d | 2024-05-15 A | 2024-05-15 A | 1019FS+20d | 100% |  |  |
| 1021 | 1.4.1.4.4.2 | **Test Data Approach & Plan** | 41d | 2024-03-20 A | 2024-05-15 A |  | 100% |  |  |
| 1022 |  | Industry Consultation | 14d | 2024-03-20 A | 2024-04-08 A | 1018SS+2d | 100% |  |  |
| 1023 |  | Artefact review (via SITAG) and updates | 27d | 2024-04-09 A | 2024-05-15 A | 1022 | 100% |  |  |
| 1024 |  | SIT Non-Functional Testing Test Data Approach & Plan approved | 0d | 2024-05-15 A | 2024-05-15 A | 1020FF, 1023 | 100% |  |  |
| 1025 | 1.4.1.4.4.3 | **Test scenarios & Test Cases** | 98d? | 2024-03-04 A | 2024-07-17 |  | 78% |  |  |
| 1026 | 1.4.1.4.4.3.1 | **Theme 1** | 78d | 2024-03-04 A | 2024-06-19 A |  | 100% |  |  |
| 1027 |  | Develop Test Scenarios & Test Cases | 33d | 2024-03-04 A | 2024-04-17 A | 1016 | 100% |  |  |
| 1028 |  | Industry Review Workshop | 1d | 2024-04-18 A | 2024-04-18 A | 1027 | 100% |  |  |
| 1029 |  | Industry Consultation Review | 7d | 2024-05-02 A | 2024-05-10 A | 1028FS+9d | 100% |  |  |
| 1030 |  | Review with NFT Working Group | 5d | 2024-05-31 A | 2024-06-06 A | 1029FS+14d | 100% |  |  |
| 1031 |  | SIT NFT Scenarios & Test Cases Approved - Theme 1 | 0d | 2024-06-19 A | 2024-06-19 A | 1030FS+9d | 100% |  |  |
| 1032 | 1.4.1.4.4.3.2 | **Theme 2** | 98d | 2024-03-04 A | 2024-07-17 A |  | 100% |  |  |
| 1033 |  | Develop Test Scenarios & Test Cases | 53d | 2024-03-04 A | 2024-05-15 A | 1016 | 100% |  |  |
| 1034 |  | Industry Review Workshop | 1d | 2024-05-16 A | 2024-05-16 A | 1033 | 100% |  |  |
| 1035 |  | Industry Consultation Review | 7d | 2024-05-20 A | 2024-05-28 A | 1034FS+1d | 100% |  |  |
| 1036 |  | Review with NFT Working Group | 5d | 2024-06-28 A | 2024-07-04 A | 1035FS+22d | 100% |  |  |
| 1037 |  | SIT NFT Scenarios & Test Cases Approved - Theme 2 | 0d | 2024-07-17 A | 2024-07-17 A | 1036FS+9d | 100% |  |  |
| 1038 | 1.4.1.4.4.3.3 | **Theme 3** | 98d? | 2024-03-04 A | 2024-07-17 |  | 100% |  |  |
| 1039 |  | Develop Test Scenarios & Test Cases | 63d | 2024-03-04 A | 2024-05-29 A | 1016 | 100% |  |  |
| 1040 |  | Industry Review Workshop | 1d | 2024-05-30 A | 2024-05-30 A | 1039 | 100% |  |  |
| 1041 |  | Industry Consultation Review | 6d | 2024-06-10 A | 2024-06-17 A | 1040FS+6d | 100% |  |  |
| 1042 |  | Review with NFT Working Group | 5d | 2024-06-28 A | 2024-07-04 A | 1041FS+8d | 100% |  |  |
| 1043 |  | SIT NFT Scenarios & Test Cases Approved - Theme 3 | 0d | 2024-09-18 A | 2024-09-18 A | 1042FS+9d | 100% |  | start no earlier than 2024-09-18 |
| 1044 | 1.4.1.4.4.3.4 | **SIT NFT Programme RTTM** | 21d? | 2024-09-18 | 2024-10-16 |  |  | 831d |  |
| 1045 |  | Develop Manual SIT NFT RTTM | 15d | 2024-09-18 | 2024-10-08 | 1043 |  | 831d |  |
| 1046 |  | Review with SRO | 1d? | 2024-10-09 | 2024-10-09 | 1045 |  | 836d |  |
| 1047 |  | Manual SIT NFT RTTM Complete | 0d | 2024-10-08 | 2024-10-08 | 1045 |  | 831d |  |
| 1048 |  | Develop Automated SIT NFT RTTM | 5d | 2024-10-09 | 2024-10-15 | 1047 |  | 831d |  |
| 1049 |  | Review with SRO | 1d? | 2024-10-16 | 2024-10-16 | 1048 |  | 831d |  |
| 1050 |  | Automated SIT NFT RTTM Complete | 0d | 2024-10-15 | 2024-10-15 | 1048 |  | 832d |  |

| ID | WBS | Task | Duration | Start | Finish | Predecessors | Complete | Total float | Constraint |
| --- | --- | --- | --- | --- | --- | --- | --- | --- | --- |
| 1051 | 1.4.1.4.4.3.5 | **NFT Performance Tool Theme 1 Setup** | 225d? | 2024-03-04 A | 2025-01-10 |  | 68% | 769d |  |
| 1052 |  | Theme 1 injection tool initial POC | 85d? | 2024-03-04 A | 2024-06-28 A |  | 100% |  |  |
| 1053 |  | Theme 1 injection tool configuration and validation against DIP SIM (IR7.1) | 38d | 2024-07-01 A | 2024-08-21 A | 1052 | 100% |  |  |
| 1054 |  | Theme 1 injection tool configuration and validation against DIP SIM (IR8.1) | 29d | 2024-08-22 A | 2024-10-01 A | 1053 | 100% |  |  |
| 1055 |  | Theme 1 injection tool configuration and validation againast UIT DIP (IR8.1) | 11d | 2024-10-02 | 2024-10-16 | 1054 |  | 769d |  |
| 1056 |  | Theme 1 injection tool configuration and validation against SIT-B DIP (IR8.3) | 62d? | 2024-10-17 | 2025-01-10 | 1055 |  | 769d |  |
| 1057 | 1.4.1.4.4.4 | **Environments (SIT B)** | 94d? | 2024-08-27 A | 2025-01-03 |  |  | 774d |  |
| 1058 | 1.4.1.4.4.4.1 | **PP Environments (SIT B)** | 0d | 2024-08-27 A | 2024-08-27 A |  | 100% |  |  |
| 1059 |  | Deployment of MHHS solution code to SIT B environments | 0d | 2024-08-27 A | 2024-08-27 A |  | 100% |  | start no earlier than 2024-08-27 |
| 1060 | 1.4.1.4.4.4.2 | **SI Environments (SIT B)** | 0d | 2024-08-27 | 2024-08-27 |  |  | 868d |  |
| 1061 |  | Coordinate deployment of MHHS solution code to SIT Participants' SIT B environments | 0d | 2024-08-27 | 2024-08-27 | 1059SS |  | 868d |  |
| 1062 | 1.4.1.4.4.4.3 | **Helix and Avanade Environments Upscale** | 10d? | 2024-12-23 | 2025-01-03 |  |  | 60d |  |
| 1063 |  | Environment Uplift Window | 10d? | 2024-12-23 | 2025-01-03 | 1271 |  | 60d |  |
| 1064 | 1.4.1.4.4.5 | **Test Data - Non-Functional and Operational (SIT B)** | 50d? | 2025-01-06 | 2025-03-14 |  |  | 60d |  |
| 1065 | 1.4.1.4.4.5.1 | **Data Load** | 50d? | 2025-01-06 | 2025-03-14 |  |  | 60d |  |
| 1066 |  | Non-Functional Theme 1 (Helix & DIP Volume Testing) Data Load | 5d? | 2025-01-06 | 2025-01-10 | 1063 |  | 60d |  |
| 1067 |  | Non-Functional Theme 2 & 3 (Helix and DIP) Data Load | 5d | 2025-02-03 | 2025-02-07 | 1327 |  | 70d |  |
| 1068 |  | Non-Functional Themes 2 & 3 (Central Parties and PPs) Data Load | 20d? | 2025-01-06 | 2025-01-31 | 1063 |  | 100d |  |
| 1069 |  | Operational Themes 1, 2 & 3 (Batch 2) (Central Parties and PPs) Data Load | 20d? | 2025-01-06 | 2025-01-31 | 1063 |  | 65d | start no earlier than 2025-01-06 |
| 1070 |  | Operational Themes 1, 2 & 3 (Batch 2) (Helix & DIP) Data Load | 5d | 2025-02-03 | 2025-02-07 | 1327 |  | 60d |  |
| 1071 |  | Non-Functional and Operational Test Data Preparation Complete | 0d | 2025-02-07 | 2025-02-07 | 1070 |  | 749d |  |
| 1072 |  | Non-Functional Theme 2 & 3 PP Preparation | 25d? | 2025-02-10 | 2025-03-14 | 1067 |  | 70d |  |
| 1073 | 1.4.1.4.4.6 | **SIT Non-Functional Test Readiness Report** | 184d | 2024-06-25 A | 2025-03-07 |  | 19% | 70d |  |
| 1074 | 1.4.1.4.4.6.1 | **PP SIT Non-Functional Test Readiness Report** | 184d | 2024-06-25 A | 2025-03-07 |  | 18% | 70d |  |
| 1075 |  | Develop draft Test Readiness Report and submit to Programme for assurance | 20d | 2024-06-25 A | 2024-07-22 A |  | 100% |  | start no earlier than 2024-06-25 |
| 1076 |  | Placing Reliance Stage 2 Review | 180d | 2024-07-01 A | 2025-03-07 |  | 16% | 70d |  |
| 1077 |  | Finalise Test Readiness Report and submit to Programme for assurance | 104d | 2024-07-23 A | 2024-12-13 | 1075 | 7% | 7d |  |
| 1078 | 1.4.1.4.4.6.2 | **SI SIT Non-Functional Test Readiness Report** | 144d | 2024-06-25 A | 2025-01-10 |  | 22% | 95d |  |
| 1079 |  | Assure Test Participants' Test Readiness Reports | 114d | 2024-06-25 A | 2024-12-13 | 1075SS, 1077FF | 19% | 7d |  |
| 1080 |  | Develop Overarching SIT Non-Functional Test Readiness Report | 15d | 2024-12-02 A | 2024-12-20 | 1079FS-10d | 47% | 95d |  |
| 1081 |  | Artefact review (via SITAG / SRO) and updates | 5d | 2025-01-06 | 2025-01-10 | 1080FS+10d |  | 95d |  |
| 1082 |  | SIT Non-Functional Testing Preparation Complete | 0d | 2025-03-07 | 2025-03-07 | 1081FF+15d, 829, 385, 1031, 1037, 1043, 1076 |  | 70d |  |
| 1083 | 1.4.1.4.5 | **SIT Operational Preparation** | 262d? | 2024-02-01 A | 2025-01-31 |  | 38% | 754d |  |
| 1084 | 1.4.1.4.5.1 | **Test Approach & Plan** | 75d | 2024-02-01 A | 2024-05-15 A |  | 100% |  |  |
| 1085 |  | Develop document with SITWG | 25d | 2024-02-01 A | 2024-03-06 A |  | 100% |  | must start on 2024-02-01 |
| 1086 |  | Draft document review with Code Bodies | 4d | 2024-03-21 A | 2024-03-26 A | 1085FS+10d | 100% |  |  |
| 1087 |  | Industry Consultation | 10d | 2024-03-27 A | 2024-04-09 A | 1086 | 100% |  |  |
| 1088 |  | Artefact review (via SITAG) and updates | 26d | 2024-04-10 A | 2024-05-15 A | 1087 | 100% |  |  |
| 1089 |  | SIT Operational Testing Test Approach & Plan approved | 0d | 2024-05-15 A | 2024-05-15 A | 1088 | 100% |  |  |
| 1090 | 1.4.1.4.5.2 | **Test Data Approach & Plan** | 36d | 2024-03-27 A | 2024-05-15 A |  | 100% |  |  |
| 1091 |  | Industry Consultation | 10d | 2024-03-27 A | 2024-04-09 A | 1087SS | 100% |  |  |
| 1092 |  | Artefact review (via SITAG) and updates | 26d | 2024-04-10 A | 2024-05-15 A | 1091 | 100% |  |  |
| 1093 |  | SIT Operational Testing Test Data Approach & Plan approved | 0d | 2024-05-15 A | 2024-05-15 A | 1092 | 100% |  |  |
| 1094 | 1.4.1.4.5.3 | **Test scenarios & Test Cases** | 213d? | 2024-04-10 A | 2025-01-31 |  | 31% | 754d |  |
| 1095 | 1.4.1.4.5.3.1 | **Theme 1** | 108d | 2024-04-10 A | 2024-09-06 A |  | 100% |  |  |
| 1096 |  | Develop Test Scenarios & Test Cases | 53d | 2024-04-10 A | 2024-06-21 A | 1087 | 100% |  |  |
| 1097 |  | Industry Review Workshop | 1d | 2024-06-24 A | 2024-06-24 A | 1096 | 100% |  |  |
| 1098 |  | Industry Consultation Review | 6d | 2024-07-02 A | 2024-07-09 A | 1097FS+17d | 100% |  |  |
| 1099 |  | Review with SIT Working Group | 5d | 2024-08-19 A | 2024-08-23 A | 1098FS+16d | 100% |  |  |
| 1100 |  | SIT Operational Scenarios & Test Cases Approved - Theme 1 | 0d | 2024-09-06 A | 2024-09-06 A | 1099FS+10d | 100% |  | start no earlier than 2024-09-06 |
| 1101 | 1.4.1.4.5.3.2 | **Theme 2** | 107d | 2024-04-10 A | 2024-09-06 A |  | 100% |  |  |
| 1102 |  | Develop Test Scenarios & Test Cases | 53d | 2024-04-10 A | 2024-06-21 A | 1087 | 100% |  | finish no earlier than 2024-06-21 |
| 1103 |  | Industry Review Workshop | 1d | 2024-06-24 A | 2024-06-24 A | 1102 | 100% |  |  |
| 1104 |  | Industry Consultation Review | 6d | 2024-07-02 A | 2024-07-09 A | 1103FS+7d | 100% |  |  |
| 1105 |  | Review with SIT Working Group | 5d | 2024-08-19 A | 2024-08-23 A | 1104FS+11d | 100% |  |  |
| 1106 |  | SIT Operational Scenarios & Test Cases Approved - Theme 2 | 0d | 2024-09-06 A | 2024-09-06 A | 1105FS+10d | 100% |  |  |
| 1107 | 1.4.1.4.5.3.3 | **Elexon / Helix Service Management Test Prep** | 145d? | 2024-07-15 | 2025-01-31 |  |  | 115d |  |
| 1108 |  | Elexon Service Now Build and Implementation | 145d? | 2024-07-15 | 2025-01-31 |  |  | 115d | start no earlier than 2024-07-15 |
| 1109 |  | Helix Engagement and Comms | 105d? | 2024-09-09 | 2025-01-31 |  |  | 115d | start no earlier than 2024-09-09 |
| 1110 |  | Helix Service Management Documentation (Service Design Pack and Service User Op Model) | 105d? | 2024-09-09 | 2025-01-31 |  |  | 115d | start no earlier than 2024-09-09 |
| 1111 |  | Helix Knowledge Articles | 105d? | 2024-09-09 | 2025-01-31 |  |  | 115d | start no earlier than 2024-09-09 |
| 1112 | 1.4.1.4.5.3.4 | **Theme 3 (Batch 2)** | 60d? | 2024-09-19 A | 2024-12-11 |  | 26% | 791d |  |
| 1113 |  | Conclude BCDR Scope with SRO, Code Bodies and DIP Manager | 22d | 2024-09-19 A | 2024-10-18 |  | 50% | 829d | start no earlier than 2024-09-19 |
| 1114 |  | Develop BDCR Test Scenarios & Test Cases (Batch 2) | 10d | 2024-10-14 A | 2024-10-25 A | 1113 | 100% |  |  |
| 1115 |  | Develop DIP Test Scenarios and Test Cases (Batch 2) | 27d | 2024-09-19 | 2024-10-25 |  |  | 1d | start no earlier than 2024-09-19 |
| 1116 |  | SRO Review | 5d | 2024-10-28 | 2024-11-01 | 1115 |  | 1d | start no earlier than 2024-10-28 |
| 1117 |  | Industry Review Workshop (Batch 2) | 10d | 2024-11-04 A | 2024-11-15 | 1116 | 10% | 94d |  |
| 1118 |  | Review Feedback and Update | 5d | 2024-11-18 | 2024-11-22 | 1117 |  | 94d |  |
| 1119 |  | Review with SIT WG (Batch 2) | 6d | 2024-11-28 | 2024-12-05 | 1118FS+3d |  | 94d |  |
| 1120 |  | SITAG Approval (Batch 2) | 1d? | 2024-12-11 | 2024-12-11 | 1119FS+3d |  | 94d |  |

| ID | WBS | Task | Duration | Start | Finish | Predecessors | Complete | Total float | Constraint |
| --- | --- | --- | --- | --- | --- | --- | --- | --- | --- |
| 1121 | 1.4.1.4.5.3.5 | **Theme 3 (Batch 1)** | 176d? | 2024-04-10 A | 2024-12-11 |  | 75% | 94d |  |
| 1122 |  | Develop Test Scenarios & Test Cases (Batch 1) | 78d | 2024-04-10 A | 2024-07-26 A | 1087 | 100% |  |  |
| 1123 |  | Conclude Industry Consultation (Batch 1) | 11d | 2024-09-05 A | 2024-09-19 A |  | 100% |  | start no earlier than 2024-09-05 |
| 1124 |  | Review Feedback and Update | 5d | 2024-09-20 A | 2024-09-26 | 1123 | 90% | 7.5d |  |
| 1125 |  | Draft Test Cases from Feedback and LLSD | 15d? | 2024-09-30 A | 2024-10-18 | 1124FS+1d, 1134 | 50% | 94d |  |
| 1126 |  | SRO Review | 5d? | 2024-10-21 | 2024-10-25 | 1125 |  | 94d |  |
| 1127 |  | Industry Consultation | 10d? | 2024-10-28 | 2024-11-08 | 1126 |  | 94d |  |
| 1128 |  | Review Feedback and Update | 5d | 2024-11-11 | 2024-11-15 | 1127 |  | 94d |  |
| 1129 |  | Review with SITWG (Batch 1) | 5d? | 2024-11-28 | 2024-12-04 | 1128FS+8d |  | 94d |  |
| 1130 |  | SITAG for approval (Batch 1) | 1d | 2024-12-11 | 2024-12-11 | 1129FS+4d |  | 94d |  |
| 1131 |  | SIT Operational Scenarios & Test Cases Approved - Theme 3 (Batch 1 + 2) | 0d | 2024-12-11 | 2024-12-11 | 1134, 1120, 1130 |  | 94d |  |
| 1132 | 1.4.1.4.5.3.6 | **Helix SDD and LLSD Development and Approval** | 1d | 2024-09-27 | 2024-09-30 |  |  | 8.5d |  |
| 1133 |  | Development | 0d | 2024-09-27 | 2024-09-27 |  |  | 845d | start no earlier than 2024-09-27 |
| 1134 |  | Approval | 0d | 2024-09-30 | 2024-09-30 |  |  | 7.5d | start no earlier than 2024-09-30 |
| 1135 | 1.4.1.4.5.4 | **SIT Operational Programme RTTM** | 27d? | 2024-12-12 | 2025-01-17 |  |  | 764d |  |
| 1136 |  | Develop Manual SIT Operational RTTM | 22d? | 2024-12-12 | 2025-01-10 | 1131 |  | 764d |  |
| 1137 |  | Manual SIT Operational RTTM Complete | 0d | 2025-01-10 | 2025-01-10 | 1136 |  | 769d |  |
| 1138 |  | Develop Automated SIT Operational RTTM | 5d | 2025-01-13 | 2025-01-17 | 1136 |  | 764d |  |
| 1139 |  | Automated SIT Operational RTTM Complete | 0d | 2025-01-17 | 2025-01-17 | 1138 |  | 764d |  |
| 1140 | 1.4.1.4.5.5 | **Environments (SIT B)** | 0d | 2024-10-07 | 2024-10-07 |  |  | 38d |  |
| 1141 | 1.4.1.4.5.5.1 | **PP Environments (SIT B)** | 0d | 2024-10-07 | 2024-10-07 |  |  | 38d |  |
| 1142 |  | Deployment of MHHS solution code to SIT B environments | 0d | 2024-10-07 | 2024-10-07 | 141 |  | 38d | start no earlier than 2024-08-27 |
| 1143 | 1.4.1.4.5.5.2 | **SI Environments (SIT B)** | 0d | 2024-10-07 | 2024-10-07 |  |  | 38d |  |
| 1144 |  | Coordinate deployment of MHHS solution code to SIT Participants' SIT B environments | 0d | 2024-10-07 | 2024-10-07 | 1142SS |  | 38d |  |
| 1145 | 1.4.1.4.6 | **SIT Operational Test Readiness Report** | 33d | 2024-08-05 | 2024-09-18 |  |  |  |  |
| 1146 | 1.4.1.4.6.1 | **PP SIT Operational Test Readiness Report** | 0d | 2024-08-05 | 2024-08-05 |  |  |  |  |
| 1147 |  | Test Readiness Report submitted to Programme for assurance | 0d | 2024-08-05 | 2024-08-05 |  |  | 769d | start no earlier than 2024-08-05 |
| 1148 | 1.4.1.4.6.2 | **SI SIT Operational Test Readiness Report** | 120d | 2024-08-05 | 2025-01-17 |  |  | 152d |  |
| 1149 |  | Assure Test Participants' Test Readiness Reports | 115d | 2024-08-05 | 2025-01-10 | 1147 |  | 769d |  |
| 1150 |  | Develop Overarching SIT Operational Test Readiness Report | 30d | 2024-12-02 | 2025-01-10 |  |  | 67d | start no earlier than 2024-12-02 |
| 1151 |  | Artefact review (via SITAG) and updates | 5d | 2025-01-13 | 2025-01-17 | 1150 |  | 67d |  |
| 1152 |  | SIT Operational Testing Preparation Complete | 0d | 2025-01-17 | 2025-01-17 | 402, 1100, 1106, 1131, 1151 |  | 67d | finish no earlier than 2024-10-04 |
| 1153 | 1.4.1.4.7 | **Regression Test Preperation** | 175d? | 2024-09-16 A | 2025-05-16 |  | 3% | 679d |  |
| 1154 | 1.4.1.4.7.1 | **Regression Test Approach** | 48d | 2024-09-16 A | 2024-11-20 |  | 7% | 119d |  |
| 1155 |  | Develop approach doc | 22d | 2024-09-16 A | 2024-10-15 |  | 10% | 119d | start no earlier than 2024-09-16 |
| 1156 |  | SRO review of approach doc | 3d | 2024-10-16 | 2024-10-18 | 1155 |  | 119d |  |
| 1157 |  | SITWG feedback on approach doc | 2d | 2024-10-28 | 2024-10-29 | 1156FS+5d |  | 119d |  |
| 1158 |  | Incorporate SRO + SITWG feedback into approach doc | 2d | 2024-10-30 | 2024-10-31 | 1157 |  | 119d |  |
| 1159 |  | SITWG Recommendation | 1d | 2024-11-07 | 2024-11-07 | 1158FS+4d |  | 119d |  |
| 1160 |  | SITAG (inc SRO) Approval | 0d | 2024-11-20 | 2024-11-20 | 1159FS+9d |  | 119d |  |
| 1161 |  | SIT Regression Testing Approach and Plan Approval | 0d | 2024-11-20 | 2024-11-20 | 1160 |  | 119d |  |
| 1162 | 1.4.1.4.7.2 | **Regression Test Suite** | 38d? | 2024-11-21 | 2025-01-13 |  |  | 119d |  |
| 1163 |  | Build Regression Test Suite | 12d | 2024-11-21 | 2024-12-06 | 1161 |  | 119d |  |
| 1164 |  | SRO Review of regression suite doc | 10d | 2024-12-09 | 2024-12-20 | 1163 |  | 119d |  |
| 1165 |  | SITWG Feedback on regression suite doc | 5d | 2024-12-30 | 2025-01-03 | 1164FS+5d |  | 119d |  |
| 1166 |  | Incorporate SRO + SITWG feedback into regression suite doc | 1d? | 2025-01-06 | 2025-01-06 | 1165 |  | 119d |  |
| 1167 |  | SRO Approval | 0d | 2025-01-06 | 2025-01-06 | 1166 |  | 119d |  |
| 1168 |  | SIT Regression Suite Approval at SITAG | 0d | 2025-01-13 | 2025-01-13 | 1167FS+5d |  | 768d |  |
| 1169 | 1.4.1.4.7.3 | **Regression Test Data Load Window (SIT Functional and Migration) - SIT A** | 1d? | 2025-03-14 | 2025-03-17 |  |  |  |  |
| 1170 |  | Regression Test Data Load Start | 0d? | 2025-04-28 | 2025-04-28 | 1309, 1267FS+1d, 1313FS+1d |  | 5d |  |
| 1171 |  | Regression Test Data Load Window | 15d? | 2025-04-28 | 2025-05-16 | 1170FS-1d |  | 5d |  |
| 1172 | 1.4.1.4.8 | **Single Instance ADO** | 32d? | 2024-08-21 A | 2024-10-03 |  | 86% | 840d |  |
| 1173 | 1.4.1.4.8.1 | **Single ADO Project for all Cohorts - Implementation and Test Phase** | 30d? | 2024-08-21 A | 2024-10-01 |  | 89% | 842d |  |
| 1174 |  | Create test plans and suites in master project | 2d? | 2024-08-21 A | 2024-08-22 A |  | 100% |  | finish no earlier than 2024-08-22 |
| 1175 |  | Create area paths / iterations | 2d? | 2024-08-21 A | 2024-08-22 A |  | 100% |  | finish no earlier than 2024-08-22 |
| 1176 |  | Create IAM roles | 2d? | 2024-08-21 A | 2024-08-22 A |  | 100% |  | finish no earlier than 2024-08-22 |
| 1177 |  | Add users to roles | 1d? | 2024-08-23 A | 2024-08-23 A |  | 100% |  | start no earlier than 2024-08-23 |
| 1178 | 1.4.1.4.8.1.5 | **Testing permissions** | 2d? | 2024-08-27 A | 2024-08-28 A |  | 100% |  |  |
| 1179 |  | Adding tests | 2d? | 2024-08-27 A | 2024-08-28 A |  | 100% |  | finish no earlier than 2024-08-28 |
| 1180 |  | Deleting tests | 2d? | 2024-08-27 A | 2024-08-28 A |  | 100% |  | finish no earlier than 2024-08-28 |
| 1181 |  | Adding tests to incorrect Cohort | 2d? | 2024-08-27 A | 2024-08-28 A |  | 100% |  | finish no earlier than 2024-08-28 |
| 1182 |  | Add / delete defects | 2d? | 2024-08-27 A | 2024-08-28 A |  | 100% |  | finish no earlier than 2024-08-28 |
| 1183 |  | Migrate defects from cohort project to master - Option 2 | 3d | 2024-09-23 | 2024-09-25 |  |  | 846d | start no earlier than 2024-09-23 |
| 1184 |  | Testing Permissions - Evidence attachment security | 10d? | 2024-09-18 A | 2024-10-01 A |  | 100% |  | finish no earlier than 2024-10-01 |
| 1185 | 1.4.1.4.8.2 | **ADO Dashboard Updates** | 20d? | 2024-09-03 A | 2024-09-30 A |  | 100% |  |  |
| 1186 |  | Update reporting dashboards in ADO | 3d | 2024-09-03 A | 2024-09-05 A |  | 100% |  | start no earlier than 2024-09-03 |
| 1187 |  | Review dashboards with SI LDP leads | 16d | 2024-09-06 A | 2024-09-27 A |  | 100% |  | start no earlier than 2024-09-06 |
| 1188 |  | Review dashboards with SRO | 16d | 2024-09-09 A | 2024-09-30 A |  | 100% |  | start no earlier than 2024-09-09 |
| 1189 |  | Update dashboards following review | 2d | 2024-09-12 A | 2024-09-13 A |  | 100% |  | start no earlier than 2024-09-12 |
| 1190 |  | Document changes to dashboard creation process | 4d | 2024-09-16 A | 2024-09-19 A |  | 100% |  | start no earlier than 2024-09-16 |

| ID | WBS | Task | Duration | Start | Finish | Predecessors | Complete | Total float | Constraint |
| --- | --- | --- | --- | --- | --- | --- | --- | --- | --- |
| 1191 |  | Update SIT Dashboards for Sprints 4.1 & 4.2 across all Cohorts | 1d? | 2024-09-03 A | 2024-09-03 A |  | 100% |  | start no earlier than 2024-09-03 |
| 1192 | 1.4.1.4.8.3 | **Reporting Changes - PowerBI & QIP** | 23d? | 2024-08-23 A | 2024-09-24 |  | 70% | 847d |  |
| 1193 |  | Design, Create and ETL ADO Entities into PowerBI Data Model | 1d? | 2024-08-23 A | 2024-08-23 A |  | 100% |  | start no earlier than 2024-08-23 |
| 1194 |  | Determine Relationships between ADO Entities & Attributes | 1d? | 2024-08-27 A | 2024-08-27 A |  | 100% |  | start no earlier than 2024-08-27 |
| 1195 |  | Create Relevant Dax Measures | 1d? | 2024-08-28 A | 2024-08-28 A |  | 100% |  | start no earlier than 2024-08-28 |
| 1196 |  | Design & Build Visualisations (Graphs) | 1d? | 2024-08-29 A | 2024-08-29 A |  | 100% |  | start no earlier than 2024-08-29 |
| 1197 |  | Implement Filters | 1d? | 2024-09-23 A | 2024-09-23 A |  | 100% |  | start no earlier than 2024-09-23 |
| 1198 |  | Check Data Quality & Integrity | 1d? | 2024-09-24 A | 2024-09-24 A |  | 100% |  | start no earlier than 2024-09-24 |
| 1199 |  | Performance Optimisation | 1d? | 2024-09-24 A | 2024-09-24 A |  | 100% |  | start no earlier than 2024-09-24 |
| 1200 |  | Publish (QIP) | 1d? | 2024-09-04 | 2024-09-04 |  |  | 861d | start no earlier than 2024-09-04 |
| 1201 |  | Review & UAT | 1d? | 2024-09-05 | 2024-09-05 |  |  | 860d | start no earlier than 2024-09-05 |
| 1202 |  | QIP Training Material & User Guides | 1d? | 2024-09-10 | 2024-09-10 |  |  | 857d | start no earlier than 2024-09-10 |
| 1203 | 1.4.1.4.8.4 | **Reporting Changes - Daily Excel Extract & PDF** | 2d | 2024-09-05 | 2024-09-06 |  |  | 859d |  |
| 1204 |  | Excel Daily Report changes (Refer to above) | 2d | 2024-09-05 | 2024-09-06 |  |  | 859d | start no earlier than 2024-09-05 |
| 1205 |  | PDF Daily Report changes (Refer to Above) | 2d | 2024-09-05 | 2024-09-06 |  |  | 859d | start no earlier than 2024-09-05 |
| 1206 | 1.4.1.4.8.5 | **Documentation Updates** | 23d? | 2024-09-02 A | 2024-10-02 |  | 80% | 841d |  |
| 1207 |  | Changes to onboarding process (security) | 10d | 2024-09-02 | 2024-09-13 |  |  | 854d | start no earlier than 2024-09-02 |
| 1208 |  | Update the documents on loading tests into ADO? | 10d | 2024-09-02 A | 2024-09-13 A |  | 100% |  | start no earlier than 2024-09-02 |
| 1209 |  | Update ADO Training material | 10d | 2024-09-02 A | 2024-09-13 A |  | 100% |  | start no earlier than 2024-09-02 |
| 1210 |  | Update ADO User Guide | 10d | 2024-09-02 A | 2024-09-13 A |  | 100% |  | start no earlier than 2024-09-02 |
| 1211 |  | Update ADO Configuration document | 10d | 2024-09-02 A | 2024-09-13 A |  | 100% |  | start no earlier than 2024-09-02 |
| 1212 |  | Update ADO Training Material and User Guide following SRO review | 1d? | 2024-10-02 A | 2024-10-02 A |  | 100% |  | start no earlier than 2024-10-02 |
| 1213 | 1.4.1.4.8.6 | **ADO Changes - Review Stage** | 19d? | 2024-09-09 A | 2024-10-03 A |  | 100% |  |  |
| 1214 |  | Review implementation with SI LDP leads | 1d? | 2024-09-27 A | 2024-09-27 A |  | 100% |  | start no earlier than 2024-09-27 |
| 1215 |  | Review implementation with SRO | 1d? | 2024-09-30 A | 2024-09-30 A |  | 100% |  | start no earlier than 2024-09-30 |
| 1216 |  | LDP Review - ADO User Guide, Training Materials | 5d | 2024-09-09 A | 2024-09-13 A |  | 100% |  | start no earlier than 2024-09-09 |
| 1217 |  | SRO Review - ADO User Guide, Training Materials | 1d? | 2024-09-30 A | 2024-09-30 A |  | 100% |  | start no earlier than 2024-09-30 |
| 1218 |  | LDP Review - Config doc | 1d? | 2024-09-30 A | 2024-09-30 A |  | 100% |  | start no earlier than 2024-09-30 |
| 1219 |  | SRO Review - Config doc | 1d? | 2024-09-30 A | 2024-09-30 A |  | 100% |  | start no earlier than 2024-09-30 |
| 1220 |  | SRO Sign-off of all changes | 1d? | 2024-10-03 A | 2024-10-03 A |  | 100% |  | start no earlier than 2024-10-03 |
| 1221 | 1.4.1.4.8.7 | **Azure DevOps Changes - Final Implementation** | 1d? | 2024-10-03 A | 2024-10-03 A |  | 100% |  |  |
| 1222 |  | Final task rollout | 1d? | 2024-10-03 A | 2024-10-03 A |  | 100% |  | start no earlier than 2024-10-03 |
| 1223 |  | ADO Training Drop-in Session ahead of Cycle 3 | 1d? | 2024-10-03 A | 2024-10-03 A |  | 100% |  | start no earlier than 2024-10-03 |
| 1224 | 1.4.2 | **SIT Execution** | 804d? | 2022-10-31 A | 2025-11-27 |  | 15% | 540d |  |
| 1225 |  | System Integration Testing Start (M9) | 0d | 2023-10-30 A | 2023-10-30 A | 667FS+5d, 581 | 100% |  | must start on 2023-10-30 |
| 1226 | 1.4.2.2 | **SIT Component Integration Testing** | 96d | 2023-10-30 A | 2024-03-11 A |  | 100% |  |  |
| 1227 |  | SIT Component Integration Testing Start | 0d | 2023-10-30 A | 2023-10-30 A | 1225 | 100% |  |  |
| 1228 |  | Component Integration Testing Interval 1 Start | 0d | 2023-10-30 A | 2023-10-30 A | 667SS+1d, 588, 592, 596, 114 | 100% |  |  |
| 1229 |  | Component Integration Testing Interval 2 Start | 0d | 2023-11-13 A | 2023-11-13 A | 694SS+5d, 588, 596, 592, 114 | 100% |  |  |
| 1230 |  | Component Integration Testing Interval 3 Start | 0d | 2023-11-27 A | 2023-11-27 A | 726SS+5d, 588, 592, 596, 114 | 100% |  |  |
| 1231 |  | Component Integration Testing Interval 4 Start | 0d | 2023-12-11 A | 2023-12-11 A | 758SS+5d, 588, 592, 596, 114 | 100% |  |  |
| 1232 |  | Component Integration Testing Interval 5 Start | 0d | 2024-01-15 A | 2024-01-15 A | 790SS+5d, 588, 592, 596, 114 | 100% |  |  |
| 1233 |  | Component Integration Testing Interval 6 Start | 0d | 2024-01-29 A | 2024-01-29 A | 588, 592, 596, 822, 114, 634 | 100% |  | must start on 2024-01-29 |
| 1234 |  | SIT Component Integration Testing Execution | 85d | 2023-10-30 A | 2024-02-23 A | 1228SS | 100% |  | must start on 2023-10-30 |
| 1235 |  | SIT Component Integration Testing End (incl. confirmation that PPs have submitted their Test Completion Reports to Programme for assurance) | 0d | 2024-02-23 A | 2024-02-23 A | 1234FF | 100% |  |  |
| 1236 |  | Assurance of PPs Test Completion Reports | 30d | 2024-01-22 A | 2024-03-01 A | 1235FF+5d | 100% |  |  |
| 1237 | 1.4.2.2.11 | **SIT CI Test Completion Report** | 18d | 2024-02-07 A | 2024-03-01 A |  | 100% |  |  |
| 1238 |  | Develop document | 13d | 2024-02-07 A | 2024-02-23 A | 1235FF | 100% |  |  |
| 1239 |  | Review & agree document | 5d | 2024-02-26 A | 2024-03-01 A | 1238, 1236FF | 100% |  |  |
| 1240 |  | SIT Component Integration Testing Test Completion Report Approved | 0d | 2024-03-11 A | 2024-03-11 A | 1239FS+6d | 100% |  |  |
| 1241 | 1.4.2.3 | **SIT - Minimum Viable Cohort (MVC)** | 735d? | 2022-10-31 A | 2025-08-22 |  | 8% | 609d |  |
| 1242 | 1.4.2.3.1 | **SIT Functional Testing (MVC)** | 730d? | 2022-10-31 A | 2025-08-15 |  | 20% | 614d |  |
| 1243 |  | SIT Functional Testing Start | 0d | 2024-03-11 A | 2024-03-11 A | 1240, 952FS+5d, 829, 837, 838, 839, 846 | 100% |  |  |
| 1244 | 1.4.2.3.1.2 | **SIT Functional Testing Execution (Minimum Viable Cohort)** | 730d? | 2022-10-31 A | 2025-08-15 |  | 20% | 614d |  |
| 1245 | 1.4.2.3.1.2.1 | **Cycle 1 (Full Cycle)** | 70d | 2024-03-11 A | 2024-06-14 A |  | 100% |  |  |
| 1246 |  | Test Execution | 55d | 2024-03-11 A | 2024-05-24 A | 1243SS-1d, 911 | 100% |  |  |
| 1247 |  | Defect resolution, assurance, review, data & environments maintenance | 15d | 2024-05-27 A | 2024-06-14 A | 1246 | 100% |  |  |
| 1248 | 1.4.2.3.1.2.2 | **Cycle 2 (Defect retests and targeted regression testing)** | 80d | 2024-06-17 A | 2024-10-04 |  | 41% | 839d |  |
| 1249 |  | Test Execution | 70d | 2024-06-17 A | 2024-09-20 | 1247, 916 | 47% | 190d |  |
| 1250 |  | Defect resolution, assurance, review, data & environments maintenance | 10d | 2024-09-23 | 2024-10-04 | 1249 |  | 839d |  |
| 1251 | 1.4.2.3.1.2.3 | **SIT Functional Testing back-up progress risk-assessment** | 0d | 2022-10-31 | 2022-10-31 |  |  | 1344d |  |
| 1252 |  | Back-up risk-assessment of SIT Functional progress to assess whether Qualification Execution can start early | 15d | 2024-10-07 | 2024-10-25 | 1250 |  | 819d |  |
| 1253 |  | Back-up SITAG decision on early Qualification Testing Execution start | 0d | 2024-11-01 | 2024-11-01 | 1252FS+5d |  | 819d |  |
| 1254 | 1.4.2.3.1.2.4 | **Cycle 3 (Defect retests and targeted regression testing)** | 105d? | 2024-10-21 | 2025-03-14 |  |  |  |  |
| 1255 |  | Sprint 5 | 10d? | 2024-10-21 | 2024-11-01 | 140SS-1d |  | 5d |  |
| 1256 |  | Sprint 6 | 10d? | 2024-11-04 | 2024-11-15 | 1255 |  | 5d |  |
| 1257 |  | Sprint 7 | 10d? | 2024-11-18 | 2024-11-29 | 1256 |  | 5d |  |
| 1258 |  | Sprint 8 | 15d? | 2024-12-02 | 2024-12-20 | 1257 |  | 5d |  |
| 1259 |  | Christmas downtime | 10d? | 2024-12-23 | 2025-01-03 | 1258 |  | 5d |  |
| 1260 |  | Sprint 9 | 10d? | 2025-01-06 | 2025-01-17 | 1259 |  | 5d |  |

| ID | WBS | Task | Duration | Start | Finish | Predecessors | Total float | Constraint |
| --- | --- | --- | --- | --- | --- | --- | --- | --- |
| 1261 |  | Sprint 10 | 10d? | 2025-01-20 | 2025-01-31 | 1260 | 5d |  |
| 1262 |  | Sprint 11 | 10d? | 2025-02-03 | 2025-02-14 | 1261 | 5d |  |
| 1263 |  | Sprint 12 | 10d? | 2025-02-17 | 2025-02-28 | 1262 | 5d |  |
| 1264 |  | Sprint 13 (RTTM Gap Analysis + CR056) | 10d? | 2025-03-03 | 2025-03-14 | 1263 | 5d |  |
| 1265 |  | Sprint 14 (RTTM Gap Analysis + CR056) | 10d? | 2025-03-17 | 2025-03-28 | 1264 | 5d |  |
| 1266 |  | Sprint 15 (Contingency 1) | 10d? | 2025-03-31 | 2025-04-11 | 1265 | 5d |  |
| 1267 |  | Sprint 16 (Contingency 2) | 10d? | 2025-04-14 | 2025-04-25 | 1266 | 5d |  |
| 1268 |  | Defect resolution, assurance, review, data & environments maintenance | 10d | 2024-10-21 | 2024-11-01 |  | 819d |  |
| 1269 | 1.4.2.3.1.2.5 | **SIT Functional Settlement Testing** | 230d? | 2024-06-17 | 2025-05-02 |  |  |  |
| 1270 |  | Settlement Testing Cycle 1 | 70d | 2024-06-17 | 2024-09-20 |  | 849d | start no earlier than 2024-06-17 |
| 1271 |  | Settlement Testing Cycle 2 | 55d? | 2024-10-07 | 2024-12-20 | 1144 | 38d |  |
| 1272 |  | Settlement Testing Cycle 3 (CoS Settlement Testing) | 20d? | 2025-05-19 | 2025-06-13 | 942, 1171 | 5d |  |
| 1273 | 1.4.2.3.1.2.6 | **SIT Functional MVC Regression Testing (code freeze)** | 40d? | 2025-06-16 | 2025-08-08 |  | 5d |  |
| 1274 |  | Regression Sprint 1 | 10d? | 2025-06-16 | 2025-06-27 | 1272, 1167 | 5d |  |
| 1275 |  | Regression Sprint 2 | 10d | 2025-06-30 | 2025-07-11 | 1274 | 5d |  |
| 1276 |  | Regression Sprint 3 | 15d | 2025-07-14 | 2025-08-01 | 1275 | 5d |  |
| 1277 |  | SIT Functional Testing End (Minimum Viable Cohort) (incl. confirmation that PPs have submitted their Test Completion Reports to Programme for assurance) | 0d | 2025-08-01 | 2025-08-01 | 1276 | 5d | start no earlier than 2025-03-14 |
| 1278 |  | Assurance of PPs Test Completion Reports | 30d | 2025-06-30 | 2025-08-08 | 1277FF+5d | 5d |  |
| 1279 | 1.4.2.3.1.2.7 | **SIT Functional Test Completion Report (Minimum Viable Cohort)** | 25d | 2025-07-14 | 2025-08-15 |  | 5d |  |
| 1280 |  | Develop document | 15d | 2025-07-14 | 2025-08-01 | 1277FF | 5d |  |
| 1281 |  | Review & agree document | 5d | 2025-08-04 | 2025-08-08 | 1280, 1278FF | 5d |  |
| 1282 |  | SIT Functional Testing Test Completion Report (Minimum Viable Cohort) Approved | 0d | 2025-08-15 | 2025-08-15 | 1281FF+5d | 5d |  |
| 1283 | 1.4.2.3.2 | **Helix E2E Settlement Testing** | 65d | 2025-01-06 | 2025-04-04 |  | 38d |  |
| 1284 |  | Helix E2E Settlement Testing Execution | 65d | 2025-01-06 | 2025-04-04 | 1271FS+10d | 38d |  |
| 1285 |  | Helix E2E Settlement Testing Execution Complete | 0d | 2025-04-04 | 2025-04-04 | 1284 | 38d |  |
| 1286 |  | MHHSP Helix E2E Testing Assurance | 65d | 2025-01-06 | 2025-04-04 | 1271FS+10d | 38d |  |
| 1287 |  | MHHSP Helix E2E Testing Assurance Complete | 0d | 2025-04-04 | 2025-04-04 | 1286 | 38d |  |
| 1288 | 1.4.2.3.3 | **SIT Migration Testing (MVC)** | 380d? | 2024-03-11 | 2025-08-22 |  | 0d |  |
| 1289 |  | SIT Migration Testing Start | 0d? | 2024-03-11 | 2024-03-11 |  | 989d | start no earlier than 2024-03-11 |
| 1290 | 1.4.2.3.3.2 | **SIT Migration Testing Execution (Minimum Viable Cohort)** | 380d? | 2024-03-11 | 2025-08-22 |  | 0d |  |
| 1291 | 1.4.2.3.3.2.1 | **Cycle 1 (Full Cycle)** | 70d? | 2024-03-11 | 2024-06-14 |  |  |  |
| 1292 |  | Test Execution | 55d? | 2024-03-11 | 2024-05-24 |  | 934d | start no earlier than 2024-03-11 |
| 1293 |  | Defect resolution, assurance, review, data& environments maintenance | 15d? | 2024-05-27 | 2024-06-14 |  | 819d | finish no earlier than 2024-06-14 |
| 1294 | 1.4.2.3.3.2.2 | **Cycle 2 (Defect retests and targeted regression testing)** | 80d? | 2024-03-11 | 2024-06-28 |  |  |  |
| 1295 |  | Test Execution | 70d? | 2024-06-17 | 2024-09-20 | 1293 | 819d | start no earlier than 2024-06-17 |
| 1296 |  | Defect resolution, assurance, review, data & environments maintenance | 10d? | 2024-09-23 | 2024-10-04 | 1295 | 819d | finish no earlier than 2024-10-04 |
| 1297 | 1.4.2.3.3.2.3 | **SIT Functional Testing back-up progress risk-assessment** | 70d? | 2024-06-17 | 2024-09-20 |  |  |  |
| 1298 |  | Back-up risk-assessment of SIT Migration progress to assess whether Qualification Execution can start early | 15d? | 2024-10-07 | 2024-10-25 | 1296 | 819d | finish no earlier than 2024-10-04 |
| 1299 |  | Back-up SITAG decision on early Qualification Testing Execution start | 0d? | 2024-11-01 | 2024-11-01 | 1298FS+5d | 819d |  |
| 1300 | 1.4.2.3.3.2.4 | **Cycle 3 (Defect retests and targeted regression testing)** | 135d? | 2024-10-21 | 2025-04-25 |  | 5d |  |
| 1301 |  | Sprint 5 | 10d | 2024-10-21 | 2024-11-01 | 140FS-1d | 5d | start no earlier than 2024-10-21 |
| 1302 |  | Sprint 6 | 10d | 2024-11-04 | 2024-11-15 | 1301 | 5d | start no earlier than 2024-11-04 |
| 1303 |  | Sprint 7 | 10d | 2024-11-18 | 2024-11-29 | 1302 | 5d |  |
| 1304 |  | Sprint 8 | 15d | 2024-12-02 | 2024-12-20 | 1303 | 5d | finish no earlier than 2024-11-15 |
| 1305 |  | Christmas downtime | 10d | 2024-12-23 | 2025-01-03 | 1304 | 5d | finish no earlier than 2024-11-29 |
| 1306 |  | Sprint 9 | 10d | 2025-01-06 | 2025-01-17 | 1305 | 5d | finish no earlier than 2024-12-20 |
| 1307 |  | Sprint 10 | 10d | 2025-01-20 | 2025-01-31 | 1306 | 5d | finish no earlier than 2025-01-03 |
| 1308 |  | Sprint 11 | 10d | 2025-02-03 | 2025-02-14 | 1307 | 5d | finish no earlier than 2025-01-17 |
| 1309 |  | Sprint 12 | 10d | 2025-02-17 | 2025-02-28 | 1308 | 5d | finish no earlier than 2025-01-31 |
| 1310 |  | Sprint 13 | 10d | 2025-03-03 | 2025-03-14 | 1309 | 5d |  |
| 1311 |  | Sprint 14 (RTTM Gap Analysis + CR056) | 10d? | 2025-03-17 | 2025-03-28 | 1310 | 5d |  |
| 1312 |  | Sprint 15 (Contingency 1) | 10d? | 2025-03-31 | 2025-04-11 | 1311 | 5d |  |
| 1313 |  | Sprint 16 (Contingency 2) | 10d? | 2025-04-14 | 2025-04-25 | 1312 | 5d |  |
| 1314 | 1.4.2.3.3.2.5 | **SIT Migration MVC Regression Testing (code freeze)** | 35d? | 2025-06-16 | 2025-08-01 |  | 609d |  |
| 1315 |  | Regression Sprint 1 | 10d? | 2025-06-16 | 2025-06-27 | 1272 | 609d |  |
| 1316 |  | Regression Sprint 2 | 10d? | 2025-06-30 | 2025-07-11 | 1315 | 609d |  |
| 1317 |  | Regression Sprint 3 | 15d? | 2025-07-14 | 2025-08-01 | 1316 | 609d |  |
| 1318 |  | SIT Migration Testing End (Minimum Viable Cohort) (incl. confirmation that PPs have submitted their Test Completion Reports to Programme for assurance) | 0d | 2025-08-01 | 2025-08-01 | 1317 | 609d | start no earlier than 2025-06-20 |
| 1319 | 1.4.2.3.3.2.6 | **SIT Migration Test Completion Report (Minimum Viable Cohort)** | 25d | 2025-07-14 | 2025-08-15 | 1013, 959, 963, 970, 976, 982 | 609d |  |
| 1320 |  | Develop document | 15d | 2025-07-14 | 2025-08-01 | 1318FF | 609d |  |
| 1321 |  | Review & agree document | 5d | 2025-08-04 | 2025-08-08 | 1320 | 609d |  |
| 1322 |  | SIT Migration Testing Test Completion Report (Minimum Viable Cohort) Approved | 0d | 2025-08-15 | 2025-08-15 | 1321FS+5d | 609d |  |
| 1323 |  | SIT Migration Testing End (Minimum Viable Cohort) (incl. confirmation that PPs have submitted their Test Completion Reports to Programme for assurance) | 0d | 2025-08-15 | 2025-08-15 | 1320FF, 1322 | 609d | start no earlier than 2025-03-14 |
| 1324 |  | Assurance of PPs Test Completion Reports | 30d | 2025-07-14 | 2025-08-22 | 1323FF+5d | 609d |  |
| 1325 | 1.4.2.3.4 | **SIT Non-Functional Testing (all SIT PPs)** | 104d? | 2025-01-13 | 2025-06-05 |  | 60d |  |
| 1326 |  | Theme 1 (Helix and DIP Volume Testing) Start | 0d? | 2025-01-13 | 2025-01-13 | 1066 | 60d | start no earlier than 2025-01-13 |
| 1327 |  | Theme 1 (Helix and DIP Volume Testing) Execution | 15d? | 2025-01-13 | 2025-01-31 | 1326 | 60d | start no earlier than 2025-01-13 |
| 1328 |  | Theme 2 SIT Non-Functional Testing Start | 0d | 2025-03-14 | 2025-03-14 | 1082FS+5d, 1249FS+5d, 1020, 1024, 1031, 1037, 1043, 1068, 1072 | 70d |  |
| 1329 |  | Theme 2 SIT Non-Functional Testing Execution | 40d | 2025-03-17 | 2025-05-09 | 1328SS | 70d |  |
| 1330 |  | Theme 3 SIT Non-Functional Testing Start | 1d? | 2025-03-17 | 2025-03-17 | 1068, 1072 | 70d |  |

| ID | WBS | Task | Duration | Start | Finish | Predecessors | Complete | Total float | Constraint |
| --- | --- | --- | --- | --- | --- | --- | --- | --- | --- |
| 1331 |  | Theme 3 SIT Non-Functional Testing Execution | 40d? | 2025-03-17 | 2025-05-09 | 1330SS |  | 70d |  |
| 1332 |  | SIT Non-Functional Testing End (all SIT PPs) (incl. confirmation that PPs have submitted their Test Completion Reports to Programme for assurance) | 0d | 2025-05-23 | 2025-05-23 | 1329FF, 1331FF |  | 61d | start no earlier than 2025-05-23 |
| 1333 |  | Assurance of PPs Test Completion Reports | 20d | 2025-05-02 | 2025-05-29 | 1332FF+5d |  | 61d |  |
| 1334 | 1.4.2.3.4.9 | **SIT Non-Functional Testing Test Completion Report (all SIT PPs)** | 20d | 2025-05-02 | 2025-05-29 |  |  | 61d |  |
| 1335 |  | Develop document | 15d | 2025-05-02 | 2025-05-23 | 1332FF |  | 61d |  |
| 1336 |  | Review & agree document | 5d | 2025-05-23 | 2025-05-29 | 1335, 1333FF |  | 61d |  |
| 1337 |  | SIT Non-Functional Testing Test Completion Report (all SIT PPs) Approved | 0d | 2025-06-05 | 2025-06-05 | 1336FF+5d |  | 61d |  |
| 1338 | 1.4.2.3.5 | **SIT Operational Testing (all SIT PPs)** | 90d? | 2025-02-03 | 2025-06-06 |  |  | 60d |  |
| 1339 | 1.4.2.3.5.1 | **Non-SIT B Testing** | 25d? | 2025-02-03 | 2025-03-07 |  |  | 115d |  |
| 1340 |  | SIT Operational Testing Start (Theme 3 - Batch 1 (Service Management)) | 0d? | 2025-02-03 | 2025-02-03 | 1131, 1108, 1109, 1110, 1111, 1130 |  | 115d | start no earlier than 2025-02-03 |
| 1341 |  | SIT Operational Testing Execution Window (Theme 3 - Batch 1 (Service Management)) | 25d? | 2025-02-03 | 2025-03-07 | 1340 |  | 115d | start no earlier than 2025-01-06 |
| 1342 | 1.4.2.3.5.2 | **SIT B Testing** | 70d? | 2025-02-07 | 2025-05-16 |  |  | 60d |  |
| 1343 |  | SIT Operational Testing Start (SIT B) | 0d | 2025-02-07 | 2025-02-07 | 1152FS+8d, 1089, 1093, 1100, 1106, 1131, 1069, 1070 |  | 60d |  |
| 1344 |  | SIT Operational Testing Execution Theme 3 Batch 2 | 25d? | 2025-02-10 | 2025-03-14 | 1343, 1120 |  | 60d |  |
| 1345 |  | SIT Operational Testing Execution Theme 1 | 25d? | 2025-03-17 | 2025-04-18 | 1344 |  | 60d |  |
| 1346 |  | SIT Operational Testing Execution Theme 2 | 20d? | 2025-04-21 | 2025-05-16 | 1345 |  | 60d |  |
| 1347 |  | SIT Operational Testing End (all SIT PPs) (incl. confirmation that PPs have submitted their Test Completion Reports to Programme for assurance) | 0d | 2025-05-23 | 2025-05-23 | 1346FS+5d, 1341 |  | 60d |  |
| 1348 |  | Assurance of PPs Test Completion Reports | 30d | 2025-04-21 | 2025-05-30 | 1347FF+5d |  | 60d |  |
| 1349 | 1.4.2.3.5.5 | **SIT Operational Testing Test Completion Report (all SIT PPs)** | 20d | 2025-05-05 | 2025-05-30 |  |  | 60d |  |
| 1350 |  | Develop document | 15d | 2025-05-05 | 2025-05-23 | 1347FF |  | 60d |  |
| 1351 |  | Review & agree document | 5d | 2025-05-26 | 2025-05-30 | 1350, 1348FF |  | 60d |  |
| 1352 |  | SIT Operational Testing Test Completion Report (all SIT PPs) Approved | 0d | 2025-06-06 | 2025-06-06 | 1351FF+5d |  | 60d |  |
| 1353 | 1.4.2.3.6 | **SIT MVC Test Exit Report** | 20d | 2025-07-14 | 2025-08-08 |  |  | 619d |  |
| 1354 |  | Develop document | 15d | 2025-07-14 | 2025-08-01 | 1280FF |  | 619d |  |
| 1355 |  | Review & agree document | 5d | 2025-08-04 | 2025-08-08 | 1354 |  | 619d |  |
| 1356 |  | SIT Minimum Viable Cohort Complete (SIT Minimum Viable Cohort Test Exit Report Approved) | 0d | 2025-08-22 | 2025-08-22 | 1240, 1282FS+5d, 1337, 1352 |  | 5d |  |
| 1357 | 1.4.2.4 | **SIT (non-MVC)** | 119d? | 2025-06-16 A | 2025-11-27 |  | 10% | 25d |  |
| 1358 | 1.4.2.4.1 | **SIT Functional Testing (non-MVC)** | 110d? | 2025-06-16 | 2025-11-14 |  |  | 25d |  |
| 1359 | 1.4.2.4.1.1 | **SIT Functional Testing Execution (non-MVC)** | 95d? | 2025-06-16 | 2025-10-24 |  |  | 25d |  |
| 1360 |  | Test Execution (Cycle 3 Completion and Regression Testing) | 95d? | 2025-06-16 | 2025-10-24 | 1272 |  | 25d |  |
| 1361 |  | SIT Functional Testing End (non-MVC) (incl. confirmation that PPs have submitted their Test Completion Reports to Programme for assurance) | 0d | 2025-10-24 | 2025-10-24 | 1360FF |  | 25d |  |
| 1362 |  | Assurance of PPs Test Completion Reports | 5d | 2025-11-03 | 2025-11-07 | 1361FS+5d |  | 25d |  |
| 1363 | 1.4.2.4.1.3 | **SIT Functional Testing Test Completion Report (non-MVC)** | 25d | 2025-10-06 | 2025-11-07 |  |  | 25d |  |
| 1364 |  | Develop document | 15d | 2025-10-06 | 2025-10-24 | 1361FF |  | 30d |  |
| 1365 |  | Review & agree document | 5d | 2025-11-03 | 2025-11-07 | 1364, 1362FF |  | 25d |  |
| 1366 |  | SIT Functional Testing Test Completion Report (non-MVC) Approved | 0d | 2025-11-14 | 2025-11-14 | 1365FF+5d |  | 25d |  |
| 1367 | 1.4.2.4.2 | **SIT Migration Testing (non-MVC)** | 110d | 2025-06-16 A | 2025-11-14 |  | 23% | 25d |  |
| 1368 |  | Test Execution (Cycle 3 Completion and Regression Testing) | 95d | 2025-06-16 A | 2025-10-24 | 1272 | 28% | 25d |  |
| 1369 |  | SIT Migration Testing End (non-MVC) (incl. confirmation that PPs have submitted their Test Completion Reports to Programme for assurance) | 0d | 2025-10-24 | 2025-10-24 | 1368FF |  | 25d |  |
| 1370 |  | Assurance of PPs Test Completion Reports | 5d | 2025-11-03 | 2025-11-07 | 1369FS+5d |  | 25d |  |
| 1371 | 1.4.2.4.2.4 | **SIT Migration Testing Test Completion Report (non-MVC)** | 25d | 2025-10-06 | 2025-11-07 |  |  | 25d |  |
| 1372 |  | Develop document | 15d | 2025-10-06 | 2025-10-24 | 1369FF |  | 30d |  |
| 1373 |  | Review & agree document | 5d | 2025-11-03 | 2025-11-07 | 1372, 1370FF |  | 25d |  |
| 1374 |  | SIT Migration Testing Test Completion Report (non-MVC Approved) | 0d | 2025-11-14 | 2025-11-14 | 1373FF+5d |  | 25d |  |
| 1375 | 1.4.2.4.3 | **SIT non-MVC Test Exit Report** | 20d | 2025-10-27 | 2025-11-21 |  |  | 25d |  |
| 1376 |  | Develop document | 15d | 2025-10-27 | 2025-11-14 | 1366FF, 1374FF |  | 25d |  |
| 1377 |  | Review & agree document | 5d | 2025-11-17 | 2025-11-21 | 1376 |  | 25d |  |
| 1378 |  | SIT non-MVC Complete | 0d | 2025-11-27 | 2025-11-27 | 1377FS+4d, 1366, 1374 |  | 25d |  |
| 1379 | 1.4.3 | **UIT Environment Preparation** | 700d? | 2022-10-31 A | 2025-07-04 |  | 46% | 644d |  |
| 1380 | 1.4.3.1 | **Test Artefact Development** | 556d? | 2023-03-01 A | 2025-04-16 |  | 51% | 701d |  |
| 1381 | 1.4.3.1.1 | **E2E Sandbox Guidance** | 539d? | 2023-03-01 A | 2025-03-24 |  | 71% | 718d |  |
| 1382 |  | Develop document | 83d | 2023-03-01 A | 2023-06-23 A |  | 100% |  | start no earlier than 2023-03-01 |
| 1383 |  | Artefact review (via SITAG) and updates | 25d | 2023-06-26 A | 2023-07-28 A | 1382 | 100% |  |  |
| 1384 |  | E2E Sandbox Guidance approved | 0d | 2024-07-18 A | 2024-07-18 A | 1383FF+5d | 100% |  | start no earlier than 2024-07-18 |
| 1385 |  | Update E2E Sandbox guidance to reflect CR55 | 29d | 2025-01-13 | 2025-02-20 |  |  | 718d | start no earlier than 2025-01-13 |
| 1386 |  | Internal SI review | 5d | 2025-02-21 | 2025-02-27 | 1385 |  | 718d |  |
| 1387 |  | SRO / Code Bodies review | 5d | 2025-02-28 | 2025-03-06 | 1386 |  | 718d |  |
| 1388 |  | Submit version to QWG | 3d | 2025-03-07 | 2025-03-11 | 1387 |  | 718d |  |
| 1389 |  | Artefact Approval (via QWG) | 0d | 2025-03-11 | 2025-03-11 | 1388 |  | 718d |  |
| 1390 |  | Final Document updates post QWG review | 1d? | 2025-03-13 | 2025-03-13 | 1389FS+1d |  | 718d |  |
| 1391 |  | Submit final version to QAG | 1d? | 2025-03-17 | 2025-03-17 | 1390FS+1d |  | 718d |  |
| 1392 |  | E2E Sandbox guidance update approved | 1d? | 2025-03-24 | 2025-03-24 | 1391FS+4d |  | 718d |  |
| 1393 | 1.4.3.1.2 | **E2E Sandbox Test Data Approach & Plan** | 68d | 2025-01-13 | 2025-04-16 |  |  | 701d |  |
| 1394 |  | Develop document | 27d | 2025-01-13 | 2025-02-18 | 1382SS+199d |  | 701d | start no earlier than 2025-01-13 |
| 1395 |  | Internal SI review and updates | 5d | 2025-02-19 | 2025-02-25 | 1394 |  | 701d |  |
| 1396 |  | SRO / Code Bodies review | 5d | 2025-02-26 | 2025-03-04 | 1395 |  | 701d |  |
| 1397 |  | Submit proposed version to QWG | 0d | 2025-03-04 | 2025-03-04 | 1396 |  | 701d |  |
| 1398 |  | Discuss document at QWG | 0d | 2025-03-11 | 2025-03-11 | 1397FS+5d |  | 701d |  |
| 1399 |  | Final updates prior to consultation | 4d | 2025-03-12 | 2025-03-17 | 1398 |  | 701d |  |
| 1400 |  | Industry Consultation for E2E Sandbox Test Data Approach and Plan document | 10d | 2025-03-18 | 2025-03-31 | 1399 |  | 701d |  |

| ID | WBS | Task | Duration | Start | Finish | Predecessors | Complete | Total float | Constraint |
| --- | --- | --- | --- | --- | --- | --- | --- | --- | --- |
| 1401 |  | Document updates post Industry Consultation | 3d | 2025-04-01 | 2025-04-03 | 1400 |  | 701d | finish no earlier than 2024-04-22 |
| 1402 |  | Submit Proposed Version to QWG | 3d | 2025-04-04 | 2025-04-08 | 1401 |  | 701d |  |
| 1403 |  | Artefact Approval (via QWG) | 0d | 2025-04-08 | 2025-04-08 | 1402 |  | 701d |  |
| 1404 |  | Final Document updates post QWG review | 0d | 2025-04-09 | 2025-04-09 | 1403FS+1d |  | 701d | start no earlier than 2024-05-01 |
| 1405 |  | Submit final version to QAG | 0d | 2025-04-10 | 2025-04-10 | 1404FS+1d |  | 701d | start no earlier than 2024-05-02 |
| 1406 |  | E2E Sandbox Test Data Approach and Plan | 0d | 2025-04-16 | 2025-04-16 | 1405FS+4d |  | 701d | start no earlier than 2024-05-09 |
| 1407 | 1.4.3.2 | **UIT Stub Specification and Delivery** | 230d | 2023-12-04 A | 2024-10-18 |  | 89% | 829d |  |
| 1408 | 1.4.3.2.1 | **Qualification Test Stubs** | 230d | 2023-12-04 A | 2024-10-18 |  | 89% | 829d |  |
| 1409 |  | Specify | 44d | 2023-12-04 A | 2024-02-01 A | 508FS+13d | 100% |  |  |
| 1410 |  | Build & Test | 141d | 2024-02-02 A | 2024-08-16 | 1409 | 90% | 33.75d |  |
| 1411 |  | Prepare for release | 45d | 2024-08-19 A | 2024-10-18 | 1410 | 75% | 829d |  |
| 1412 |  | Non-SIT LDSO Test Harness Released | 0d | 2024-10-18 | 2024-10-18 | 1411 |  | 829d |  |
| 1413 | 1.4.3.3 | **Environments (UIT)** | 700d | 2022-10-31 A | 2025-07-04 |  | 44% | 644d |  |
| 1414 | 1.4.3.3.1 | **Central Party (Avenade) Environments (UIT)** | 488d | 2022-11-16 A | 2024-09-27 |  | 97% | 844d |  |
| 1415 |  | Central Party (Avendae) environment preparation (incl. security certificates and security compliance) | 447d | 2022-11-16 A | 2024-08-01 A | 504 | 100% |  |  |
| 1416 |  | Submit self-declaration of environment preparation complete (incl. security certificates and security compliance) to Programme for assurance | 447d | 2022-11-16 A | 2024-08-01 A | 1415SS | 100% |  |  |
| 1417 |  | Central Party (Avenade) UIT environment connectivity proving | 25d | 2024-08-26 | 2024-09-27 | 1429 |  | 843d |  |
| 1418 |  | Deployment of MHHS solution code to UIT environments | 2d | 2024-07-29 | 2024-07-30 |  |  | 886d | start no earlier than 2024-07-29 |
| 1419 |  | Central Party (Avenade) UIT environment Regression Testing | 1d | 2024-07-31 | 2024-07-31 | 1418 |  | 886d |  |
| 1420 | 1.4.3.3.2 | **E2E Sandbox Participants (UIT)** | 680d | 2022-10-31 | 2025-06-06 |  |  | 0d |  |
| 1421 |  | E2E Sandbox Participants environment preparation (incl. security certificates and security compliance) | 660d | 2022-10-31 | 2025-05-09 |  |  | 0d | must finish on 2025-05-09 |
| 1422 |  | Submit self-declaration of environment preparation complete (incl. security certificates and security compliance) to Programme for assurance | 660d | 2022-10-31 | 2025-05-09 |  |  | 664d |  |
| 1423 |  | E2E Sandbox Participants UIT environment connectivity proving | 20d | 2025-05-12 | 2025-06-06 | 1422 |  | 664d |  |
| 1424 |  | Deployment of MHHS solution code to UIT environments | 10d | 2025-05-26 | 2025-06-06 | 1423FF |  | 664d |  |
| 1425 |  | Coordinate E2E Sandbox Participants' UIT environment preparation (for E2E Sandbox Testing Start) | 463d | 2022-10-31 | 2024-08-07 | 1421SS |  | 881d |  |
| 1426 | 1.4.3.3.3 | **SI Environments (UIT)** | 688d | 2022-11-16 A | 2025-07-04 |  | 69% | 644d |  |
| 1427 |  | Coordinate Central Parties' UIT environment preparation | 447d | 2022-11-16 A | 2024-08-01 A | 1415SS | 100% |  |  |
| 1428 |  | Assure Central Parties' self-declaration of environment preparation complete (incl. security certificates and security compliance) | 463d | 2022-11-16 A | 2024-08-23 | 1416SS | 97% | 869d |  |
| 1429 |  | Central Parties' UIT environments ready to start connectivity proving (incl. certificates and security compliance) | 0d | 2024-08-23 A | 2024-08-23 A | 1412 | 100% |  |  |
| 1430 |  | Coordinate Central Parties' UIT environment connectivity proving | 26d | 2024-08-26 | 2024-09-30 | 1417SS |  | 843d |  |
| 1431 |  | Coordinate deployment of MHHS solution code to Central Parties' UIT environments | 2d | 2024-07-29 A | 2024-07-30 A | 1418SS | 100% |  |  |
| 1432 |  | Coordinate Central Parties' UIT environment Regression Testing | 1d | 2024-07-31 | 2024-07-31 | 1431 |  | 886d |  |
| 1433 | 1.4.3.3.3.7 | **Environments (Non-SIT LDSO)** | 43d | 2024-08-01 | 2024-09-30 |  |  | 843d |  |
| 1434 |  | Coordinate Qualification Participants' environment preparation | 17d | 2024-08-01 | 2024-08-23 |  |  | 869d | start no earlier than 2024-08-01 |
| 1435 |  | Coordinate deployment of MHHS solution code to Qualification Participants' UIT environments | 17d | 2024-08-01 | 2024-08-23 |  |  | 843d | start no earlier than 2024-08-01 |
| 1436 |  | Qualification Testing Tranche 1 Participants' UIT environments ready to start connectivity proving (incl. certificates and security compliance) | 0d | 2024-08-26 | 2024-08-26 | 1435FS+1d |  | 843d |  |
| 1437 | 1.4.3.3.3.7.4 | **Coordinate Qualification Participants' connectivity proving (Non-SIT LDSO)** | 25d | 2024-08-27 | 2024-09-30 |  |  | 843d |  |
| 1438 |  | Assurance of Qualification Participants' connectivity proving | 25d | 2024-08-27 | 2024-09-30 | 1436 |  | 843d |  |
| 1439 | 1.4.3.3.3.8 | **Environments (S&A) Wave 1** | 41d | 2024-08-01 | 2024-09-26 |  |  |  |  |
| 1440 |  | Coordinate Qualification Participants' environment preparation | 20d | 2024-09-02 | 2024-09-27 |  |  | 844d | start no earlier than 2024-09-02 |
| 1441 |  | Coordinate deployment of MHHS solution code to Qualification Participants' UIT environments | 10d | 2024-10-21 | 2024-11-01 |  |  | 774d | start no earlier than 2024-10-21 |
| 1442 |  | Qualification Testing Wave 1 Participants' UIT environments ready to start connectivity proving (incl. certificates and security compliance) | 19d | 2024-11-05 | 2024-11-29 | 1441FS+1d |  | 774d |  |
| 1443 | 1.4.3.3.3.8.4 | **Coordinate Qualification Participants' connectivity proving (S&A)** | 25d | 2024-12-02 | 2025-01-03 |  |  | 774d |  |
| 1444 |  | Assurance of Qualification Participants' connectivity proving | 25d | 2024-12-02 | 2025-01-03 | 1442 |  | 774d |  |
| 1445 | 1.4.3.3.3.9 | **Environments (S&A) Wave 2** | 139d | 2024-08-27 | 2025-03-07 |  |  | 0d |  |
| 1446 |  | Coordinate Qualification Participants' environment preparation | 20d | 2024-11-18 | 2024-12-13 |  |  | 789d | start no earlier than 2024-11-18 |
| 1447 |  | Coordinate deployment of MHHS solution code to Qualification Participants' UIT environments | 20d | 2024-12-16 | 2025-01-10 |  |  | 729d | start no earlier than 2024-12-16 |
| 1448 |  | Qualification Testing Wave 2 Participants' UIT environments ready to start connectivity proving (incl. certificates and security compliance) | 15d | 2025-01-13 | 2025-01-31 | 1447 |  | 729d |  |
| 1449 | 1.4.3.3.3.9.4 | **Coordinate Qualification Participants' connectivity proving (S&A)** | 25d | 2024-08-27 | 2024-09-30 |  |  |  |  |
| 1450 |  | Assurance of Qualification Participants' connectivity proving | 25d | 2025-02-03 | 2025-03-07 | 1448 |  | 729d |  |
| 1451 | 1.4.3.3.3.10 | **Environments (S&A) Wave 3** | 80d | 2025-03-17 | 2025-07-04 |  |  | 644d |  |
| 1452 |  | Coordinate Qualification Participants' environment preparation | 30d | 2025-03-17 | 2025-04-25 |  |  | 694d | start no earlier than 2025-03-17 |
| 1453 |  | Coordinate deployment of MHHS solution code to Qualification Participants' UIT environments | 10d | 2025-04-28 | 2025-05-09 |  |  | 644d | start no earlier than 2025-04-28 |
| 1454 |  | Qualification Testing Wave 3 Participants' UIT environments ready to start connectivity proving (incl. certificates and security compliance) | 14d | 2025-05-13 | 2025-05-30 | 1453FS+1d |  | 644d |  |
| 1455 | 1.4.3.3.3.10.4 | **Coordinate Qualification Participants' connectivity proving (S&A)** | 25d | 2025-06-02 | 2025-07-04 |  |  | 644d |  |
| 1456 |  | Assurance of Qualification Participants' connectivity proving | 25d | 2025-06-02 | 2025-07-04 | 1454 |  | 644d |  |
| 1457 | 1.4.3.3.3.11 | **Environments (S&A) Wave 4** | 80d | 2025-03-17 | 2025-07-04 |  |  | 55d |  |
| 1458 |  | Coordinate Qualification Participants' environment preparation | 30d | 2025-03-17 | 2025-04-25 |  |  | 694d | finish no earlier than 2025-04-25 |
| 1459 |  | Coordinate deployment of MHHS solution code to Qualification Participants' UIT environments | 10d | 2025-04-28 | 2025-05-09 |  |  | 644d | finish no earlier than 2025-05-09 |
| 1460 |  | Qualification Testing Wave 4 Participants' UIT environments ready to start connectivity proving (incl. certificates and security compliance) | 14d | 2025-05-13 | 2025-05-30 | 1459FS+1d |  | 644d | finish no earlier than 2025-05-30 |
| 1461 | 1.4.3.3.3.11.4 | **Coordinate Qualification Participants' connectivity proving (S&A)** | 25d | 2025-06-02 | 2025-07-04 |  |  |  |  |
| 1462 |  | Assurance of Qualification Participants' connectivity proving | 25d | 2025-06-02 | 2025-07-04 | 1460 |  | 644d | start no earlier than 2025-06-02 |
| 1463 | 1.4.3.4 | **Test Data** | 30d | 2024-08-26 | 2024-10-04 |  |  | 819d |  |
| 1464 | 1.4.3.4.1 | **Central Parties (for E2E Sandbox & Qualification)** | 30d | 2024-08-26 | 2024-10-04 |  |  | 819d |  |
| 1465 |  | Central Parties' UIT environment test data loading & verification (& data cleansing, if required) | 30d | 2024-08-26 | 2024-10-04 |  |  | 819d | start no earlier than 2024-08-26 |
| 1466 |  | Submit self-declaration to Programme to confirm loading & verification of test data | 30d | 2024-08-26 | 2024-10-04 | 1465SS |  | 819d |  |
| 1467 | 1.4.3.4.2 | **E2E Sandbox Participants** | 30d | 2024-08-26 | 2024-10-04 |  |  | 839d |  |
| 1468 |  | UIT environment test data loading and verification (and data cleansing, if required) (for E2E Sandbox Testing Start) | 30d | 2024-08-26 | 2024-10-04 | 1465FF |  | 839d |  |
| 1469 | 1.4.3.4.3 | **SI Test Data** | 30d | 2024-08-26 | 2024-10-04 |  |  | 839d |  |
| 1470 |  | Coordinate Central Parties' UIT environment test data loading and verification (and data cleansing, if required) | 30d | 2024-08-26 | 2024-10-04 | 1465SS |  | 839d |  |

| ID | WBS | Task | Duration | Start | Finish | Predecessors | Complete | Total float | Constraint |
| --- | --- | --- | --- | --- | --- | --- | --- | --- | --- |
| 1471 |  | Assure evidence of Central Parties' UIT environment test data load and verification | 30d | 2024-08-26 | 2024-10-04 | 1466SS |  | 839d |  |
| 1472 |  | Coordinate E2E Sandbox Participants' UIT environment test data loading and verification (and data cleansing, if required) (for E2E Sandbox Testing Start) | 30d | 2024-08-26 | 2024-10-04 | 1468SS |  | 839d |  |
| 1473 | 1.4.3.5 | **Other Preparation** | 496d | 2022-10-31 A | 2024-09-23 |  | 59% | 848d |  |
| 1474 | 1.4.3.5.1 | **SI Other Preparation** | 66d | 2022-10-31 | 2023-01-30 |  |  | 1278d |  |
| 1475 |  | Onboarding of UIT E2E Sandbox Participants to Test Management Tool for E2E Sandbox Testing Start (onboarding of participants will be ongoing hereafter) | 66d | 2022-10-31 | 2023-01-30 |  |  | 1278d |  |
| 1476 | 1.4.3.5.2 | **Other Preparation (for Central Parties & E2E Sandbox Participants)** | 484d | 2022-11-16 A | 2024-09-23 |  | 67% | 848d |  |
| 1477 |  | Test Management Tool onboarding for E2E Sandbox Testing Start (onboarding will be ongoing hereafter) | 66d | 2024-05-02 | 2024-08-01 | 1475SS |  | 885d | start no earlier than 2024-05-02 |
| 1478 |  | Other Preparation (incl. test execution planning) | 484d | 2022-11-16 A | 2024-09-23 | 1415SS, 1421SS | 76% | 848d |  |
| 1479 | 1.4.3.6 | **UIT E2E Sandbox Test Readiness Report** | 114d | 2024-08-26 | 2025-01-31 |  |  | 750d |  |
| 1480 | 1.4.3.6.1 | **Central Parties E2E Sandbox Test Readiness Report** | 30d | 2024-08-26 | 2024-10-04 |  |  | 819d |  |
| 1481 |  | Develop draft Test Readiness Report and submit to Programme for assurance | 20d | 2024-08-26 | 2024-09-20 | 1466FF-10d |  | 819d |  |
| 1482 |  | Finalise Test Readiness Report and submit to Programme for assurance | 10d | 2024-09-23 | 2024-10-04 | 1466FF |  | 819d |  |
| 1483 | 1.4.3.6.2 | **SI E2E Sandbox Test Readiness Report** | 40d | 2024-08-26 | 2024-10-18 |  |  | 819d |  |
| 1484 |  | Assure Central Parties' E2E Sandbox Test Readiness Reports | 35d | 2024-08-26 | 2024-10-11 | 1481SS, 1482FF+5d |  | 819d |  |
| 1485 |  | Develop Overarching E2E Sandbox Test Readiness Report | 20d | 2024-09-16 | 2024-10-11 | 1484FF |  | 819d |  |
| 1486 |  | Artefact review (via SITAG) and updates | 5d | 2024-10-14 | 2024-10-18 | 1485 |  | 819d |  |
| 1487 |  | UIT E2E Sandbox Preparation Complete | 0d | 2025-01-31 | 2025-01-31 | 1486FS+5d |  | 750d | start no earlier than 2025-01-31 |
| 1488 | 1.4.4 | **SIT PPs Early Sandbox Testing Execution** | 316d | 2025-02-07 | 2026-04-24 |  |  | 434d |  |
| 1489 |  | SIT PPs E2E Sandbox Testing Start | 0d | 2025-02-10 | 2025-02-10 | 1487FS+5d |  | 749d | start no earlier than 2025-02-10 |
| 1490 |  | SIT PPs E2E Sandbox Testing Execution | 316d | 2025-02-07 | 2026-04-24 | 1489SS-1d |  | 434d | start no earlier than 2024-11-04 |
| 1491 | 1.4.5 | **System Integration Testing - Tier 1 Milestones** | 214d? | 2025-02-28 | 2025-12-24 |  |  | 154d |  |
| 1492 |  | M10 Checkpoint | 1d? | 2025-02-28 | 2025-02-28 | 1493FS-149d |  | 734d |  |
| 1493 |  | Central systems ready for migrating MPANs (M10) | 0d | 2025-09-24 | 2025-09-24 | 1356FS+20d, 2539, 2296FS+2d, 2293, 2308, 2295, 2275, 2279 |  | 5d | start no earlier than 2025-08-13 |
| 1494 |  | Central systems ready for migrating MPANs (M10*) - Late Exit | 0d | 2025-12-24 | 2025-12-24 | 1493FS+65d |  | 521d |  |
| 1495 | 1.4.6 | **External Programme Dependency Management** | 174d | 2022-10-31 A | 2023-06-30 A |  | 100% |  |  |
| 1496 | 1.4.6.1 | **BSC CP1558** | 173d | 2022-10-31 A | 2023-06-29 A |  | 100% |  |  |
| 1497 |  | Monitor progress to implementation date | 173d | 2022-10-31 A | 2023-06-28 A |  | 100% |  |  |
| 1498 |  | BSC CP1558 Implementation Date | 0d | 2023-06-29 A | 2023-06-29 A | 1497 | 100% |  | must start on 2023-06-29 |
| 1499 | 1.4.6.2 | **REC CP R0032** | 174d | 2022-10-31 A | 2023-06-30 A |  | 100% |  |  |
| 1500 |  | Monitor progress to implementation date | 174d | 2022-10-31 A | 2023-06-29 A |  | 100% |  |  |
| 1501 |  | REC CP R0032 Implementation Date | 0d | 2023-06-30 A | 2023-06-30 A | 1500 | 100% |  | must start on 2023-06-30 |
| 1502 | 1.4.6.3 | **REC CP R0044** | 173d | 2022-10-31 A | 2023-06-29 A |  | 100% |  |  |
| 1503 |  | Monitor progress to implementation date | 173d | 2022-10-31 A | 2023-06-28 A |  | 100% |  |  |
| 1504 |  | REC CP R0044 Implementation Date | 0d | 2023-06-29 A | 2023-06-29 A | 1503 | 100% |  | must start on 2023-06-29 |
| 1505 | 1.5 | **NON SIT LDSO QUALIFICATION** | 469d? | 2023-11-07 A | 2025-08-22 |  | 67% | 609d |  |
| 1506 | 1.5.1 | **Approach Planning** | 208d | 2023-11-07 A | 2024-08-22 A |  | 100% |  |  |
| 1507 |  | Develop Draft Testing Approach & Plan | 61d | 2023-11-07 A | 2024-01-30 A |  | 100% |  | start no earlier than 2023-11-07 |
| 1508 |  | Draft Testing Approach & Plan Issued to LDSO for Review | 1d | 2024-01-31 A | 2024-01-31 A | 1507 | 100% |  |  |
| 1509 |  | LDSO Review Complete | 10d | 2024-02-01 A | 2024-02-14 A | 1508 | 100% |  |  |
| 1510 |  | Update Following LDSO Review | 14d | 2024-02-15 A | 2024-03-05 A | 1509 | 100% |  |  |
| 1511 |  | QWG Review of Approach & Plan | 1d | 2024-03-12 A | 2024-03-12 A | 1510FS+4d | 100% |  |  |
| 1512 |  | QAG Approval for Approach & Plan | 0d | 2024-03-21 A | 2024-03-21 A | 1511FS+7d | 100% |  |  |
| 1513 |  | Confirmation of Participants for Non-SIT LDSO Qualification Testing | 0d | 2024-03-21 A | 2024-03-21 A | 1512 | 100% |  |  |
| 1514 |  | Update to Annex 1 for internal review (NF, Not Operational) | 15d | 2024-03-18 A | 2024-04-05 A | 1017 | 100% |  |  |
| 1515 |  | Non-Functional, Operational & Migration Approaches Socialised with Code Bodies & LDSO & Feedback Actioned | 86d | 2024-04-08 A | 2024-08-05 A | 1514 | 100% |  |  |
| 1516 |  | QWG Review Operational, Non-Functional & Migration Annexes of Approach & Plan | 1d | 2024-08-13 A | 2024-08-13 A | 1515FS+5d | 100% |  |  |
| 1517 |  | Update Following QWG Review | 6d | 2024-08-14 A | 2024-08-21 A | 1516 | 100% |  |  |
| 1518 |  | QAG Approval for Operational, Non-Functional & Migration Annexes of Approach & Plan | 0d | 2024-08-22 A | 2024-08-22 A | 1517FS+1d, 1513, 1020 | 100% |  |  |
| 1519 | 1.5.2 | **Functional Test Cases & Scenarios** | 58d | 2024-01-30 A | 2024-04-18 A |  | 100% |  |  |
| 1520 | 1.5.2.1 | **Functional Test Cases & Scenarios Batch 1** | 8d | 2024-01-30 A | 2024-02-08 A |  | 100% |  |  |
| 1521 |  | Walkthrough Test Cases & Scenarios Batch 1 with Code Bodies | 1d | 2024-01-30 A | 2024-01-30 A | 1507SS+60d | 100% |  |  |
| 1522 |  | Walkthrough Test Cases & Scenarios Batch 1 with LDSO | 1d | 2024-02-01 A | 2024-02-01 A | 1521 | 100% |  |  |
| 1523 |  | Action Feedback on Test Cases & Scenarios Batch 1 | 5d | 2024-02-02 A | 2024-02-08 A | 1522 | 100% |  |  |
| 1524 | 1.5.2.2 | **Functional Test Cases & Scenarios Batch 2** | 14d | 2024-02-20 A | 2024-03-08 A |  | 100% |  |  |
| 1525 |  | Walkthrough Test Cases & Scenarios Batch 2 with Code Bodies | 1d | 2024-02-20 A | 2024-02-20 A | 1507SS+75d | 100% |  |  |
| 1526 |  | Walkthrough Test Cases & Scenarios Batch 2 with LDSO | 1d | 2024-03-01 A | 2024-03-01 A | 1525FS+7d | 100% |  |  |
| 1527 |  | Action Feedback on Test Cases & Scenarios Batch 2 | 5d | 2024-03-04 A | 2024-03-08 A | 1526 | 100% |  |  |
| 1528 | 1.5.2.3 | **Functional Test Cases & Scenarios Batch 3** | 13d | 2024-03-20 A | 2024-04-05 A |  | 100% |  |  |
| 1529 |  | Walkthrough Test Cases & Scenarios Batch 3 with Code Bodies | 1d | 2024-03-20 A | 2024-03-20 A | 1507SS+96d | 100% |  |  |
| 1530 |  | Walkthrough Test Cases & Scenarios Batch 3 with LDSO | 1d | 2024-03-28 A | 2024-03-28 A | 1529FS+5d | 100% |  |  |
| 1531 |  | Action Feedback on Test Cases & Scenarios Batch 3 | 6d | 2024-03-29 A | 2024-04-05 A | 1530 | 100% |  |  |
| 1532 |  | Test Cases & Scenarios Batch 1-3 Discussion at QWG | 1d | 2024-04-09 A | 2024-04-09 A | 1523, 1527, 1531FS+1d | 100% |  |  |
| 1533 |  | Action QWG Feedback on Test Cases & Scenarios Batch 1-3 | 2d | 2024-04-10 A | 2024-04-11 A | 1532 | 100% |  |  |
| 1534 |  | Batch 1-3 Non-SIT LDSO QT Functional Test Scenarios and Test Cases approved | 0d | 2024-04-18 A | 2024-04-18 A | 1533FS+5d | 100% |  |  |
| 1535 | 1.5.3 | **Test Execution Schedule** | 161d | 2024-04-19 A | 2024-11-29 |  | 99% | 799d |  |
| 1536 |  | Draft Test Delivery Schedule for Functional and Operational Testing | 20d | 2024-04-19 A | 2024-05-16 A | 1534 | 100% |  |  |
| 1537 |  | Socialise Test Delivery Schedule with Code Bodies & LDSO for Review & Action Feedback | 37d | 2024-05-17 A | 2024-07-08 A | 1536 | 100% |  |  |
| 1538 |  | Agree Test Execution Timetable Format at QWG, Including Anonymisation Requirements | 1d | 2024-07-09 A | 2024-07-09 A | 1537 | 100% |  |  |
| 1539 |  | Action QWG Feedback | 3d | 2024-07-10 A | 2024-07-12 A | 1538 | 100% |  |  |
| 1540 |  | Agree Test Execution Timetable Format at QAG, Including Anonymisation Requirements | 0d | 2024-07-18 A | 2024-07-18 A | 1539FS+4d | 100% |  |  |

| ID | WBS | Task | Duration | Start | Finish | Predecessors | Complete | Total float | Constraint |
| --- | --- | --- | --- | --- | --- | --- | --- | --- | --- |
| 1541 |  | Qualification Testing for Non-SIT LDSOs (Functional, Migration, NFT, Operational) Test Execution Schedule Complete | 0d | 2024-11-29 | 2024-11-29 | 1518 |  | 799d | finish no earlier than 2024-11-29 |
| 1542 | 1.5.4 | **Functional, Non-Functional, Operational & Migration Test Scenarios & Cases** | 110d | 2024-03-22 A | 2024-08-22 A |  | 100% |  |  |
| 1543 |  | Test Scenarios & Cases - Functional - Drafted, Reviewed | 14d | 2024-04-01 A | 2024-04-18 A | 1512 | 100% |  |  |
| 1544 |  | Test Scenarios & Cases- Functional - Approved at QAG | 0d | 2024-04-18 A | 2024-04-18 A | 1543 | 100% |  |  |
| 1545 |  | Test Scenarios & Cases - Non-Functional - Drafted, Reviewed | 110d | 2024-03-22 A | 2024-08-22 A | 1512, 1037FF | 100% |  |  |
| 1546 |  | Test Scenarios & Cases - Non-Functional - Approved at QAG | 0d | 2024-08-22 A | 2024-08-22 A | 1545 | 100% |  |  |
| 1547 |  | Test Scenarios & Cases - Migration - Drafted, Reviewed | 45d | 2024-03-22 A | 2024-05-23 A | 1512 | 100% |  |  |
| 1548 |  | Test Scenarios & Cases - Migration - Approved at QAG | 0d | 2024-05-23 A | 2024-05-23 A | 1547 | 100% |  |  |
| 1549 |  | Test Scenarios & Cases - Operational - Drafted, Reviewed | 59d | 2024-06-03 A | 2024-08-22 A | 1512FS+51d | 100% |  |  |
| 1550 |  | Test Scenarios & Cases - Operational - Approved at QAG | 0d | 2024-08-22 A | 2024-08-22 A | 1549, 1037FF | 100% |  |  |
| 1551 | 1.5.5 | **Test Data** | 345d | 2024-01-22 A | 2025-05-16 |  | 44% | 679d |  |
| 1552 |  | Test Data Plan Drafted & Reviewed | 89d | 2024-01-22 A | 2024-05-23 A | 1507 | 100% |  |  |
| 1553 |  | Non-SIT LDSO QT Test Data Plan Approved by QAG | 0d | 2024-05-23 A | 2024-05-23 A | 1552 | 100% |  |  |
| 1554 |  | Develop Test Data Matrices | 10d | 2024-05-24 A | 2024-06-06 A | 1553 | 100% |  |  |
| 1555 |  | Test Data Cut | 17d | 2024-05-24 A | 2024-06-17 A | 1553 | 100% |  |  |
| 1556 |  | Test Data Cut Complete | 0d | 2024-06-17 A | 2024-06-17 A | 1555, 1554 | 100% |  |  |
| 1557 |  | Test Data Reviewed by the Programme | 39d | 2024-06-18 A | 2024-08-09 A | 1556 | 100% |  |  |
| 1558 |  | Test Data Loaded | 85d | 2024-08-12 | 2024-12-06 | 1557 |  | 679d |  |
| 1559 |  | Test Data Signed Off | 0d | 2024-12-06 | 2024-12-06 | 1558 |  | 679d |  |
| 1560 |  | Test Execution Data Support | 115d | 2024-12-09 | 2025-05-16 | 1559 |  | 679d |  |
| 1561 | 1.5.6 | **Tooling** | 148d | 2024-01-31 A | 2024-08-23 A |  | 100% |  |  |
| 1562 |  | Design Approach & Set-Up ADO Tool for Test & Defect Management Tool | 53d | 2024-01-31 A | 2024-04-12 A | 1507 | 100% |  |  |
| 1563 |  | Develop Training Requirements & Materials Inc. Day in the Life | 87d | 2024-04-15 A | 2024-08-13 A | 1562 | 100% |  |  |
| 1564 |  | ADO Launch complete | 1d | 2024-08-23 A | 2024-08-23 A | 1563, 1544, 1548, 1550 | 100% |  |  |
| 1565 | 1.5.7 | **Pre-Integration Testing** | 218d | 2024-01-31 A | 2024-11-29 |  | 90% | 799d |  |
| 1566 |  | PIT Guidance & Templates & Approach & Plans Developed | 106d | 2024-02-05 A | 2024-07-01 A | 1507FS+3d | 100% |  |  |
| 1567 |  | PIT Test Approach & Plan Deadline for Submission for Non-SIT LDSO​ QT | 0d | 2024-07-01 A | 2024-07-01 A | 1566 | 100% |  |  |
| 1568 |  | Develop and agree PIT Test Scenarios | 20d | 2024-07-02 A | 2024-07-29 A | 1567 | 100% |  |  |
| 1569 |  | PIT Execution | 45d | 2024-09-30 A | 2024-11-29 | 1568 | 16% |  | start no earlier than 2024-09-30 |
| 1570 |  | Non-SIT LDSO Participants have submitted PIT Test Completion Report & evidence for QT Entry​ | 0d | 2024-11-29 | 2024-11-29 | 1569 |  | 799d |  |
| 1571 | 1.5.7.6 | **Placing Reliance - Code Body & LDSO Functional and Migration** | 147d | 2024-01-31 A | 2024-08-22 A |  | 100% |  |  |
| 1572 |  | Placing Reliance Submitted & Reviewed | 21d | 2024-01-31 A | 2024-02-28 A | 1507 | 100% |  |  |
| 1573 |  | Define & Agree QT Testing for Each LDSO | 22d | 2024-02-29 A | 2024-03-29 A | 1572 | 100% |  |  |
| 1574 |  | Develop Test Scope & Reliance Submissions | 20d | 2024-04-01 A | 2024-04-26 A | 1573 | 100% |  |  |
| 1575 |  | Review and Consultation | 84d | 2024-04-29 A | 2024-08-22 A | 1574, 1518FF | 100% |  |  |
| 1576 | 1.5.7.7 | **Placing Reliance - Code Body & LDSO Non Functional and Operational** | 49d | 2024-06-17 A | 2024-08-22 A |  | 100% |  |  |
| 1577 |  | Placing Reliance Submitted & Reviewed | 32d | 2024-06-17 A | 2024-07-30 A | 1516FF-10d | 100% |  |  |
| 1578 |  | Review and Consultation | 17d | 2024-07-31 A | 2024-08-22 A | 1577 | 100% |  |  |
| 1579 |  | PP Test Scope Presented at QAG | 0d | 2024-08-22 A | 2024-08-22 A | 1578, 1575 | 100% |  |  |
| 1580 | 1.5.8 | **LDSO Test Readiness Reporting** | 71d | 2024-04-19 A | 2024-07-26 A |  | 100% |  |  |
| 1581 |  | Interim Test Readiness Report & Plan Developed & Reviewed | 71d | 2024-04-19 A | 2024-07-26 A | 1534 | 100% |  |  |
| 1582 |  | Test Plan Submission to MHHS Programme For Review | 0d | 2024-07-26 A | 2024-07-26 A | 1581 | 100% |  |  |
| 1583 | 1.5.9 | **Test Environment** | 163d | 2024-04-17 A | 2024-11-29 |  | 37% | 67d |  |
| 1584 |  | Define Test Harness Requirements and Sign-Off with SRO | 13d | 2024-04-17 A | 2024-05-03 A | 509 | 100% |  |  |
| 1585 |  | Central System (DIP Env & Helix Test Harness) Test Environment DBT | 163d | 2024-04-17 A | 2024-11-29 | 509 | 47% | 67d | finish no earlier than 2024-11-29 |
| 1586 |  | Coordinate LDSO Environment Preparation | 101d | 2024-07-12 A | 2024-11-29 | 1585FF | 14% | 67d |  |
| 1587 |  | DIP available for Onboarding | 1d | 2024-08-01 A | 2024-08-01 A |  | 100% |  | start no earlier than 2024-08-01 |
| 1588 |  | Qualification Testing for Non-SIT LDSOs Participants' environments) Ready to start DIP onboarding (incl. certificates and security compliance) | 0d | 2024-08-05 A | 2024-08-05 A | 1587FS+2d | 100% |  |  |
| 1589 |  | LDSO Test Environments Connection Confirmed to UIT Environment | 0d | 2024-11-29 | 2024-11-29 | 1588FS+32d, 1586 |  | 67d |  |
| 1590 | 1.5.10 | **Test Readiness** | 124d | 2024-07-02 A | 2024-12-20 |  | 31% | 784d |  |
| 1591 |  | Preparation for Interim Test Readiness Report | 19d | 2024-07-02 A | 2024-07-26 A | 1567 | 100% |  |  |
| 1592 |  | Interim Test Readiness Report Submission to MHHS Programme for Review | 0d | 2024-07-26 A | 2024-07-26 A | 1591 | 100% |  |  |
| 1593 |  | LDSO Update Readiness Report & Final Assurance by Programme | 99d | 2024-07-29 A | 2024-12-12 | 1592 | 20% | 42d |  |
| 1594 |  | Final Test Readiness Report Submitted to MHHS Programme | 1d | 2024-12-13 | 2024-12-13 | 1593 |  | 784d |  |
| 1595 |  | Final Programme Assurance of LDSO Test Readiness | 6d | 2024-12-13 | 2024-12-20 | 1593 |  | 42d |  |
| 1596 |  | Qualification Testing for Non-SIT LDSOs (Functional, Migration, NFT, Operational) Programme Test Readiness confirmed | 0d | 2024-12-20 | 2024-12-20 | 1594FS+5d, 1570, 1544, 1546, 1548, 1584 |  | 784d |  |
| 1597 |  | Qualification Testing for Non-SIT LDSOs (Functional, Migration, NFT, Operational) Test Readiness Confirmed (Final Test Readiness Review for LDSO) | 0d | 2024-12-20 | 2024-12-20 | 1593, 1595 |  | 42d |  |
| 1598 | 1.5.11 | **Test Window** | 94d? | 2025-01-06 | 2025-05-16 |  |  | 42d |  |
| 1599 | 1.5.11.1 | **All Non-SIT LDSOs Qualification Testing** | 94d? | 2025-01-06 | 2025-05-16 | 1597, 1589 |  | 42d |  |
| 1600 |  | Non-SIT LDSO QT Test Execution Starts | 0d | 2025-01-06 | 2025-01-06 | 1597FS+11d |  | 42d | start no earlier than 2024-11-01 |
| 1601 |  | Non-SIT LDSO QT - Migration Testing | 20d? | 2025-01-06 | 2025-01-31 | 1600FS-1d |  | 42d |  |
| 1602 |  | Non-SIT LDSO QT - Functional Testing | 40d? | 2025-02-03 | 2025-03-28 | 1601 |  | 42d |  |
| 1603 |  | Non-SIT LDSO QT - Operational Testing | 15d? | 2025-03-31 | 2025-04-18 | 1602 |  | 52d |  |
| 1604 |  | Non-SIT LDSO QT - Non-Functional Testing | 15d? | 2025-04-21 | 2025-05-09 | 1603 |  | 52d |  |
| 1605 |  | Non-SIT LDSO QT - Regression Testing | 30d? | 2025-03-31 | 2025-05-09 | 1602 |  | 42d |  |
| 1606 |  | Qualification Testing for Non-SIT LDSOs (Functional, Migration, NFT, Operational) 1 End | 0d | 2025-05-16 | 2025-05-16 | 1605 |  | 38d | start no earlier than 2025-05-16 |
| 1607 | 1.5.12 | **Test Result Assurance** | 29d | 2025-04-21 | 2025-05-29 |  |  | 38d |  |
| 1608 |  | LDSOs Develop & Submit Test Report (QT Test Completion Report) | 19d | 2025-04-21 | 2025-05-16 | 1606FF |  | 38d |  |
| 1609 |  | Test Reports Reviewed By MHHS & Code Bodies & Finalised | 10d | 2025-05-16 | 2025-05-29 | 1608 |  | 38d |  |
| 1610 |  | Non-SIT LDSOs submission deadline for their QT Test Completion Report to MHHS Programme | 0d | 2025-05-29 | 2025-05-29 | 1609, 1599 |  | 38d |  |

| ID | WBS | Task | Duration | Start | Finish | Predecessors | Complete | Total float | Constraint |
| --- | --- | --- | --- | --- | --- | --- | --- | --- | --- |
| 1611 | 1.5.13 | **Non-SIT LDSO Qualification Closure** | 61d | 2025-05-30 | 2025-08-22 |  |  | 22d |  |
| 1612 |  | Non-SIT LDSO Qualification Learned Captured | 15d | 2025-05-30 | 2025-06-19 | 1610 |  | 38d |  |
| 1613 |  | Non-SIT LDSO Qualification Closure Down | 5d | 2025-06-20 | 2025-06-26 | 1612 |  | 38d |  |
| 1614 |  | BSC PAB & REC Manager approval of Qualification for Non-SIT LDSOs (Start of Migration for Qualification Participants) | 0d | 2025-08-22 | 2025-08-22 | 1703, 1704, 1613FS+25d |  | 22d |  |
| 1615 | 1.6 | **S & A QUALIFICATION** | 843d | 2023-11-07 A | 2027-01-28 |  | 32% | 235d |  |
| 1616 | 1.6.1 | **MHHS Qualification - Qualification Deliverables** | 463d | 2023-11-07 A | 2025-08-14 |  | 60% | 615d |  |
| 1617 | 1.6.1.1 | **BSC & REC Assessment Criteria** | 463d | 2023-11-07 A | 2025-08-14 |  | 23% | 615d |  |
| 1618 |  | Draft BSC Assessment Criteria (Functional) | 21d | 2023-11-07 A | 2023-12-05 A |  | 100% |  | finish no earlier than 2023-12-05 |
| 1619 |  | BSC PAB Review | 1d | 2023-12-14 A | 2023-12-14 A |  | 100% |  | start no earlier than 2023-12-14 |
| 1620 |  | Update BSC Assessment Criteria (Functional, Non-Functional, Migration) | 30d | 2024-02-07 A | 2024-03-19 A |  | 100% |  | finish no earlier than 2024-03-19 |
| 1621 |  | REC & BSC PAB Approval | 3d | 2024-03-26 A | 2024-03-28 A |  | 100% |  | start no earlier than 2024-03-28 |
| 1622 |  | Update BSC Assessment Criteria (Functional, Non-Functional, Migration, Operational) | 20d | 2024-07-24 A | 2024-08-20 A |  | 100% |  |  |
| 1623 |  | Assessment Criteria (Functional, Non-Functional, Migration, Operational) Approved by REC PAB and BSC PAB | 250d | 2024-08-29 | 2025-08-14 | 1622FS+7d |  | 615d | start no earlier than 2023-09-15 |
| 1624 | 1.6.1.2 | **Qualification Approach and Plan** | 194d | 2023-12-04 A | 2024-08-29 A |  | 100% |  |  |
| 1625 | 1.6.1.2.1 | **Qualification Approach and Plan v2** | 84d | 2023-12-04 A | 2024-03-28 A |  | 100% |  |  |
| 1626 |  | Draft Qualification Approach and Plan v2 | 30d | 2023-12-04 A | 2024-01-12 A |  | 100% |  | finish no earlier than 2024-01-12 |
| 1627 |  | Internal Review (Code Bodies and MHHSP) for Qualification Approach and Plan V2 | 10d | 2024-01-15 A | 2024-01-26 A | 1626 | 100% |  | finish no earlier than 2024-01-26 |
| 1628 |  | Industry consultation for Qualification Approach and Plan v2 | 11d | 2024-01-31 A | 2024-02-14 A | 1627 | 100% |  | start no earlier than 2024-01-31 |
| 1629 |  | Update Qualification Approach and Plan v2 post industry consultation | 10d | 2024-02-15 A | 2024-02-28 A | 1628 | 100% |  |  |
| 1630 |  | QWG Endorsement of Qualification Approach and Plan v2 | 1d | 2024-03-12 A | 2024-03-12 A |  | 100% |  | start no earlier than 2024-03-12 |
| 1631 |  | QAG Approval of Qualification Approach and Plan v2 | 1d | 2024-03-21 A | 2024-03-21 A |  | 100% |  | start no earlier than 2024-03-21 |
| 1632 |  | BSC and REC PAB Approval of Qualification Approach and Plan v2 | 3d | 2024-03-26 A | 2024-03-28 A |  | 100% |  | finish no earlier than 2024-03-28 |
| 1633 |  | Functional Testing elements of Qualification Approach & Plan v2 approvement by REC PAB and BSC PAB | 0d | 2024-03-28 A | 2024-03-28 A | 1632 | 100% |  |  |
| 1634 |  | Migration Testing elements of Qualification Approach & Plan v2 appoved by REC PAB and BSC PAB | 0d | 2024-03-28 A | 2024-03-28 A | 1632 | 100% |  |  |
| 1635 | 1.6.1.2.2 | **Qualification Approach and Plan v3** | 84d | 2024-05-06 A | 2024-08-29 A |  | 100% |  |  |
| 1636 |  | Draft Qualification Approach and Plan v3 | 35d | 2024-05-06 A | 2024-06-21 A | 1020 | 100% |  | finish no earlier than 2024-05-17 |
| 1637 |  | Internal Review (Code Bodies and MHHSP) of Qualification Approach and Plan v3 | 10d | 2024-06-24 A | 2024-07-05 A | 1636 | 100% |  |  |
| 1638 |  | Industry consultation for Qualification Approach and Plan v3 | 10d | 2024-07-08 A | 2024-07-19 A | 1637 | 100% |  |  |
| 1639 |  | Update Qualification Approach and Plan v3 Post-Consultation | 10d | 2024-07-22 A | 2024-08-02 A | 1638 | 100% |  |  |
| 1640 |  | QWG Endorsement of Qualification Approach and Plan v3 | 1d | 2024-08-13 A | 2024-08-13 A | 1639FS+6d | 100% |  |  |
| 1641 |  | QAG Approval of Qualification Approach and Plan v3 | 0d | 2024-08-22 A | 2024-08-22 A | 1640FS+7d | 100% |  |  |
| 1642 |  | BSC and REC PAB Approval of Qualification Approach and Plan v3 | 3d | 2024-08-27 A | 2024-08-29 A | 1641FS+2d | 100% |  |  |
| 1643 |  | Non-Functional Testing elements of Qualification Approach and Plan v3 approved by REC PAB and BSC PAB | 0d | 2024-08-29 A | 2024-08-29 A | 1642 | 100% |  |  |
| 1644 | 1.6.1.3 | **Qualification Assessment Document** | 316d | 2023-12-22 A | 2025-03-07 |  | 81% | 633d |  |
| 1645 | 1.6.1.3.1 | **Qualification Assessment Document v1** | 70d | 2023-12-22 A | 2024-03-28 A |  | 100% |  |  |
| 1646 |  | Draft Qualification Assessment Document v1 | 30d | 2023-12-22 A | 2024-02-01 A |  | 100% |  | finish no earlier than 2024-02-01 |
| 1647 |  | Internal Review (Code Bodies and MHHSP) of Qualification Assessment Document v1 | 10d | 2024-02-01 A | 2024-02-14 A |  | 100% |  | finish no earlier than 2024-02-14 |
| 1648 |  | Industry consultation for Qualification Assessment Document v1 | 11d | 2024-02-16 A | 2024-03-01 A |  | 100% |  | start no earlier than 2024-02-16 |
| 1649 |  | Update Post-Consultation for Qualification Assessment Document v1 | 10d | 2024-03-04 A | 2024-03-15 A | 1648 | 100% |  |  |
| 1650 |  | BSC and REC PAB Approval of Qualification Assessment Document v1 | 3d | 2024-03-26 A | 2024-03-28 A |  | 100% |  | start no earlier than 2024-03-26 |
| 1651 |  | Qualification Assessment Document v1 approved by REC PAB and BSC PAB | 0d | 2024-03-28 A | 2024-03-28 A | 1650 | 100% |  |  |
| 1652 | 1.6.1.3.2 | **Qualification Assessment Document v3** | 110d | 2024-03-29 A | 2024-08-29 A |  | 100% |  |  |
| 1653 |  | Draft Qualification Assessment Document V1.1 | 26d | 2024-03-29 A | 2024-05-03 A | 1651 | 100% |  |  |
| 1654 |  | Industry Consultation for Qualification Assessment Document V1.1 | 12d | 2024-05-06 A | 2024-05-21 A | 1653 | 100% |  |  |
| 1655 |  | Draft Qualification Assessment Document v3 | 6d | 2024-06-14 A | 2024-06-21 A | 1103, 1654 | 100% |  |  |
| 1656 |  | Internal Review (Code Bodies and MHHSP) of Qualification Assessment Document v3 | 10d | 2024-06-24 A | 2024-07-05 A | 1655 | 100% |  |  |
| 1657 |  | Industry consultation for Qualification Assessment Document v3 | 10d | 2024-07-08 A | 2024-07-19 A | 1656 | 100% |  |  |
| 1658 |  | Update Post-Consultation for Qualification Assessment Document v3 | 10d | 2024-07-22 A | 2024-08-02 A | 1657 | 100% |  |  |
| 1659 |  | QWG Endorsement of Qualification Assessment Document v3 | 1d | 2024-08-13 A | 2024-08-13 A | 1658FS+6d | 100% |  |  |
| 1660 |  | QAG Endorsement of Qualification Assessment Document v3 | 1d | 2024-08-22 A | 2024-08-22 A | 1659FS+6d | 100% |  |  |
| 1661 |  | BSC and REC PAB Approval of Qualification Assessment Document v3 | 3d | 2024-08-27 A | 2024-08-29 A | 1660FS+2d | 100% |  |  |
| 1662 |  | Qualification Assessment Document v3 approved by REC PAB and BSC PAB | 0d | 2024-08-29 A | 2024-08-29 A | 1661 | 100% |  |  |
| 1663 | 1.6.1.3.3 | **Qualification Assessment Document Portal** | 285d | 2024-02-05 A | 2025-03-07 |  | 65% | 633d |  |
| 1664 |  | Design Completion | 30d | 2024-02-05 A | 2024-03-15 A |  | 100% |  | finish no earlier than 2024-03-15 |
| 1665 |  | Qualification Assessment Document Portal Build | 30d | 2024-03-18 A | 2024-04-26 A | 1664 | 100% |  |  |
| 1666 |  | Qualification Assessment Document Internal Testing | 20d | 2024-04-29 A | 2024-05-24 A | 1665 | 100% |  |  |
| 1667 |  | Qualification Assessment Document Portal Training and Onboarding Material Creation | 20d | 2024-05-27 A | 2024-06-21 A | 1666 | 100% |  |  |
| 1668 |  | Qualification Assessment Document Portal Webinar (Date TBC) | 1d | 2024-06-18 A | 2024-06-18 A |  | 100% |  | start no earlier than 2024-06-18 |
| 1669 |  | SIT Participant QAD Application Creation in Portal | 10d | 2024-08-12 | 2024-08-23 | 1667FS+35d |  | 773d |  |
| 1670 |  | Non-SIT LDSO Participant QAD Application Creation in Portal | 10d | 2024-08-12 | 2024-08-23 | 1667FS+35d |  | 773d |  |
| 1671 |  | QT Wave 1 Participant QAD Application Creation in Portal | 10d | 2024-09-23 | 2024-10-04 | 1667FS+65d |  | 36d |  |
| 1672 |  | QT Wave 2 Participant QAD Application Creation in Portal | 10d | 2024-10-28 | 2024-11-08 | 1667FS+90d |  | 6d |  |
| 1673 |  | QT Wave 3 Participant QAD Application Creation in Portal | 10d | 2024-12-30 | 2025-01-10 | 1667FS+135d |  | 0d |  |
| 1674 |  | QT Wave 4 Participant QAD Application Creation in Portal | 10d | 2025-02-24 | 2025-03-07 | 1667FS+175d |  | 4d |  |
| 1675 |  | Update to Qualification Assessment Document Portal post QAD V3 | 10d | 2024-08-30 A | 2024-09-12 A | 1662 | 100% |  |  |
| 1676 |  | Update to Qualification Assessment Document Portal post QAD V3 Complete | 0d | 2024-09-12 A | 2024-09-12 A | 1675 | 100% |  |  |
| 1677 | 1.6.2 | **MHHS Qualification - SIT Participants** | 251d | 2025-01-06 | 2025-12-22 |  |  | 60d |  |
| 1678 |  | Initial QAD Submission Window opens | 0d | 2025-01-06 | 2025-01-06 | 1669FS+96d |  | 773d | start no earlier than 2025-01-06 |
| 1679 |  | SIT Participants submit Initial QAD | 30d | 2025-01-06 | 2025-02-14 |  |  | 60d | start no earlier than 2025-01-06 |
| 1680 |  | Code Bodies review Initial QAD | 36d | 2025-02-14 | 2025-04-04 | 1679FS-1d |  | 60d |  |

| ID | WBS | Task | Duration | Start | Finish | Predecessors | Complete | Total float | Constraint |
| --- | --- | --- | --- | --- | --- | --- | --- | --- | --- |
| 1681 |  | Completion of Code Bodies review of Initial QAD | 0d | 2025-04-04 | 2025-04-04 | 1680 |  | 60d |  |
| 1682 | 1.6.2.5 | **MHHS Qualification - SIT MVC Participants** | 114d | 2025-04-07 | 2025-09-11 |  |  | 5d |  |
| 1683 |  | Final QAD Submission Window (MVC) opens | 0d | 2025-04-07 | 2025-04-07 | 1680, 1676, 1681FS+1d |  | 60d |  |
| 1684 |  | SIT MVC Participants submit Final QAD | 25d | 2025-04-07 | 2025-05-09 | 1683FS-1d |  | 60d |  |
| 1685 |  | Completion of Code Bodies review of Final QAD (MVC) | 20d | 2025-05-12 | 2025-06-06 | 1684, 1347FF |  | 60d |  |
| 1686 |  | QAD Sign Off Deadline (MVC) | 0d | 2025-08-22 | 2025-08-22 | 1356, 1685 |  | 5d | start no earlier than 2025-07-11 |
| 1687 |  | REC Code Manager / BSC PAB Approval of Qualification (MVC) | 0d | 2025-09-11 | 2025-09-11 | 1686FS+14d |  | 5d |  |
| 1688 | 1.6.2.6 | **MHHS Qualification - SIT Non-MVC Participants** | 156d | 2025-05-19 | 2025-12-22 |  |  | 25d |  |
| 1689 |  | Final QAD Submission Window (Non-MVC) opens | 0d | 2025-05-19 | 2025-05-19 | 1681FS+31d |  | 134d |  |
| 1690 |  | SIT Non-MVC Participants submit Final QAD | 90d | 2025-05-19 | 2025-09-19 | 1689SS-1d |  | 45d |  |
| 1691 |  | Completion of Code Bodies review of Final QAD (Non-MVC) | 25d | 2025-09-22 | 2025-10-24 | 1690 |  | 45d |  |
| 1692 |  | QAD Sign Off Deadline (Non-MVC) | 1d | 2025-11-28 | 2025-11-28 | 1691FS+4d, 1378 |  | 25d |  |
| 1693 |  | REC Code Manager / BSC PAB Approval of Qualification (Non-MVC) | 0d | 2025-12-22 | 2025-12-22 | 1692FS+16d |  | 25d |  |
| 1694 | 1.6.3 | **MHHS Qualification - Non-SIT LDSO** | 179d | 2025-01-06 | 2025-09-11 |  |  | 71d |  |
| 1695 |  | Initial QAD Submission window opens | 0d | 2025-01-06 | 2025-01-06 | 1670FS+96d |  | 773d |  |
| 1696 |  | Non-SIT LDSO Participants submit initial QAD | 30d | 2025-01-06 | 2025-02-14 |  |  | 71d | start no earlier than 2025-01-06 |
| 1697 |  | Non-SIT LDSO QT Participants have submitted their initial QAD | 0d | 2025-02-14 | 2025-02-14 | 1696 |  | 71d |  |
| 1698 |  | Code Bodies review of Non-SIT LDSO participants Initial QAD | 35d | 2025-02-17 | 2025-04-04 | 1697 |  | 71d |  |
| 1699 |  | Completion of Code Bodies review of Initial QAD | 0d | 2025-04-04 | 2025-04-04 | 1698 |  | 71d |  |
| 1700 |  | Final QAD Submission window opens | 0d | 2025-04-07 | 2025-04-07 | 1699FS+1d |  | 71d |  |
| 1701 |  | Non-SIT LDSO Participants submit Final QAD | 25d | 2025-04-21 | 2025-05-23 | 1608SS, 1700SS |  | 62d |  |
| 1702 |  | Non-SIT LDSO QT Participants have submitted their final QAD | 0d | 2025-05-23 | 2025-05-23 | 1701 |  | 62d |  |
| 1703 |  | Completion of Code Bodies review of the Final QAD | 20d | 2025-05-26 | 2025-06-20 | 1702 |  | 62d |  |
| 1704 |  | QAD Sign Off Deadline (Non-SIT LDSOs) | 0d | 2025-08-22 | 2025-08-22 | 1703FS+5d, 1356 |  | 22d |  |
| 1705 |  | BSC PAB & REC Manager approval of Qualification for Non-SIT LDSOs (Start of Migration for Qualification Participants) | 0d | 2025-09-11 | 2025-09-11 | 1606, 1704FS+14d |  | 595d |  |
| 1706 | 1.6.4 | **MHHS Qualification - Qualification Waves** | 814d | 2023-12-18 A | 2027-01-28 |  | 29% | 235d |  |
| 1707 | 1.6.4.1 | **Qualification Wave Prep** | 530d | 2023-12-18 A | 2025-12-26 |  | 55% | 519d |  |
| 1708 | 1.6.4.1.1 | **Non-SIT Supplier and Agent Test Approach and Plan** | 119d | 2023-12-18 A | 2024-05-30 A |  | 100% |  |  |
| 1709 |  | Draft Non-SIT S&A Test Approach and Plan | 50d | 2023-12-18 A | 2024-02-23 A |  | 100% |  | finish no earlier than 2024-02-23 |
| 1710 |  | Internal Review of Non-SIT S&A Test Approach and Plan (Code Bodies and MHHSP) | 10d | 2024-02-26 A | 2024-03-08 A | 1709 | 100% |  |  |
| 1711 |  | Issue Non-SIT S&A Test Approach and Plan for Consultation | 15d | 2024-03-18 A | 2024-04-05 A | 1710 | 100% |  | start no earlier than 2024-03-18 |
| 1712 |  | Update Non-SIT S&A Test Approach and Plan Post-Consultation | 10d | 2024-04-08 A | 2024-04-19 A | 1711 | 100% |  |  |
| 1713 |  | QWG Endorsement of Non-SIT S&A Test Approach and Plan | 1d | 2024-05-14 A | 2024-05-14 A |  | 100% |  | finish no earlier than 2024-05-14 |
| 1714 |  | QAG Approval of Non-SIT S&A Test Approach and Plan | 0d | 2024-05-23 A | 2024-05-23 A | 1713FS+7d | 100% |  |  |
| 1715 |  | BSC & REC PAB Approval of Non-SIT S&A Test Approach and Plan | 0d | 2024-05-30 A | 2024-05-30 A | 1714FS+5d | 100% |  |  |
| 1716 | 1.6.4.1.2 | **QT Test Data Approach and Plan** | 64d | 2024-04-19 A | 2024-07-18 A |  | 100% |  |  |
| 1717 |  | QT Test Data Approach agreed as part of the Non-SIT Supplier and Agent Test Approach and Plan | 0d | 2024-04-19 A | 2024-04-19 A | 1712 | 100% |  |  |
| 1718 |  | Draft Test Data Approach and Plan for QT | 10d | 2024-05-06 A | 2024-05-17 A | 1717 | 100% |  |  |
| 1719 |  | Internal Review (Code Bodies and MHHSP) of QT Test Data Approach and Plan | 15d | 2024-05-20 A | 2024-06-07 A | 1718 | 100% |  |  |
| 1720 |  | Issue QT Test Data Approach and Plan for Industry Consultation | 10d | 2024-06-10 A | 2024-06-21 A | 1719 | 100% |  |  |
| 1721 |  | Update QT Test Approach and Plan Post Industry Consultation | 5d | 2024-06-24 A | 2024-06-28 A | 1720 | 100% |  |  |
| 1722 |  | QWG Endorsement of Test Data Approach and Plan | 1d | 2024-07-09 A | 2024-07-09 A | 1721FS+6d | 100% |  |  |
| 1723 |  | QAG Approval of QT Test Data Approach and Plan | 0d | 2024-07-18 A | 2024-07-18 A | 1722FS+7d | 100% |  |  |
| 1724 | 1.6.4.1.3 | **QT Functional Test Scenarios and Test Cases** | 59d | 2024-03-04 A | 2024-05-23 A |  | 100% |  |  |
| 1725 |  | Draft Test Scenarios and Test Case list - Batch 1 | 10d | 2024-03-04 A | 2024-03-15 A |  | 100% |  | finish no earlier than 2024-03-15 |
| 1726 |  | Issue Batch 1 for Consultation | 15d | 2024-03-18 A | 2024-04-05 A | 1725 | 100% |  | start no earlier than 2024-03-18 |
| 1727 |  | Gap analysis against QT Requirements | 8d | 2024-03-18 A | 2024-03-27 A | 1725 | 100% |  |  |
| 1728 |  | Update Test Scenarios and Test Case list - Batch 2 | 6d | 2024-03-28 A | 2024-04-04 A | 1727 | 100% |  |  |
| 1729 |  | Issue Batch 2 for consultation | 10d | 2024-04-05 A | 2024-04-18 A | 1728 | 100% |  |  |
| 1730 |  | Update Batch 2 post consultation | 10d | 2024-04-19 A | 2024-05-02 A | 1729 | 100% |  |  |
| 1731 |  | QWG Endorsement of Batch 1 and 2 | 1d | 2024-05-14 A | 2024-05-14 A |  | 100% |  | finish no earlier than 2024-05-14 |
| 1732 |  | QAG Approval of QT Functional Test Scenarios and Test Cases Batches 1 and 2 | 0d | 2024-05-23 A | 2024-05-23 A | 1731FS+7d | 100% |  |  |
| 1733 | 1.6.4.1.4 | **QT Migration Test Scenarios and Test Cases** | 54d | 2024-05-06 A | 2024-07-18 A |  | 100% |  |  |
| 1734 |  | Draft Test Scenarios and Test Case list - Batch 1 | 20d | 2024-05-06 A | 2024-05-31 A | 982FS+12d | 100% |  |  |
| 1735 |  | Issue Batch 1 for Consultation | 10d | 2024-06-03 A | 2024-06-14 A | 1734 | 100% |  |  |
| 1736 |  | Update Batch 1 Post Consultation | 10d | 2024-06-17 A | 2024-06-28 A | 1735 | 100% |  |  |
| 1737 |  | QWG Endorsement of Batch 1 | 0d | 2024-07-09 A | 2024-07-09 A | 1736FS+7d | 100% |  |  |
| 1738 |  | QAG Approval of QT Migration Test Scenarios and Test Cases Batches 1 | 0d | 2024-07-18 A | 2024-07-18 A | 1737FS+7d | 100% |  |  |
| 1739 | 1.6.4.1.5 | **QT Non-Functional Test Scenarios and Test Cases** | 61d | 2024-09-20 | 2024-12-13 |  |  | 775d |  |
| 1740 |  | Draft Test Scenarios and Test Case list - Batch 2 | 27d | 2024-09-20 | 2024-10-28 | 1043FS+2d, 1037FS+2d |  | 775d |  |
| 1741 |  | Issue Batch 2 for Consultation | 10d | 2024-10-29 | 2024-11-11 | 1740 |  | 775d |  |
| 1742 |  | Update Batch 2 Post Consultation | 10d | 2024-11-12 | 2024-11-25 | 1741 |  | 775d |  |
| 1743 |  | QWG Endorsement of Batch 2 | 0d | 2024-12-04 | 2024-12-04 | 1742FS+7d, 1643 |  | 775d |  |
| 1744 |  | QAG Approval of QT Non-Functional Test Scenarios and Test Cases Batch 2 | 0d | 2024-12-13 | 2024-12-13 | 1743FS+7d |  | 775d |  |
| 1745 | 1.6.4.1.6 | **QT Operational Test Scenarios and Test Cases** | 82d | 2024-09-10 | 2025-01-01 |  |  | 762d |  |
| 1746 |  | Draft QT Operational Test Cases - Batch 1 | 47d | 2024-09-11 | 2024-11-14 | 1100FS+2d, 1723 |  | 762d |  |
| 1747 |  | Issue Batch 1 for Consultation | 10d | 2024-11-15 | 2024-11-28 | 1746 |  | 762d |  |
| 1748 |  | Update Batch 1 Post Consultation | 10d | 2024-11-29 | 2024-12-12 | 1747 |  | 762d |  |
| 1749 |  | QWG Endorsement of Batch 1 | 0d | 2024-12-23 | 2024-12-23 | 1748FS+7d |  | 762d |  |
| 1750 |  | QAG Approval of QT Operational Test Scenarios and Test Cases Batch 1 | 0d | 2025-01-01 | 2025-01-01 | 1749FS+7d |  | 762d |  |

| ID | WBS | Task | Duration | Start | Finish | Predecessors | Complete | Total float | Constraint |
| --- | --- | --- | --- | --- | --- | --- | --- | --- | --- |
| 1751 |  | Draft QT Operational Test Cases - Batch 2 | 10d | 2024-09-10 | 2024-09-23 | 1106FS+2d |  | 800d |  |
| 1752 |  | Issue Batch 2 for Consultation | 10d | 2024-09-24 | 2024-10-07 | 1751 |  | 800d |  |
| 1753 |  | Update Batch 2 Post Consultation | 10d | 2024-10-08 | 2024-10-21 | 1752 |  | 800d |  |
| 1754 |  | QWG Endorsement of Batch 2 | 0d | 2024-10-30 | 2024-10-30 | 1753FS+7d |  | 800d |  |
| 1755 |  | QAG Approval of QT Operational Test Scenarios and Test Cases Batch 2 | 0d | 2024-11-08 | 2024-11-08 | 1754FS+7d |  | 800d |  |
| 1756 | 1.6.4.1.7 | **Qualification Testing Framework (Test Stubs and Supporting UI)** | 500d | 2024-01-29 A | 2025-12-26 |  | 50% | 519d |  |
| 1757 |  | Proof of Concept for QTF Completion | 45d | 2024-01-29 A | 2024-03-29 A |  | 100% |  | start no earlier than 2024-01-22 |
| 1758 |  | Discovery and Mobilisation | 25d | 2024-04-01 A | 2024-05-03 A | 1757 | 100% |  |  |
| 1759 | 1.6.4.1.7.3 | **Agile DBT of Qualification Testing Framework** | 83d | 2024-04-24 A | 2024-08-16 A |  | 100% |  |  |
| 1760 | 1.6.4.1.7.3.1 | **User Interface (UI)** | 48d | 2024-04-24 A | 2024-06-28 A |  | 100% |  |  |
| 1761 |  | UI Wireframe | 48d | 2024-04-24 A | 2024-06-28 A | 1712FS+2d | 100% |  |  |
| 1762 |  | UI Standards | 35d | 2024-05-13 A | 2024-06-28 A | 1761SS+13d | 100% |  |  |
| 1763 |  | Elexon Branding Sylesheet | 1d | 2024-05-17 A | 2024-05-20 A | 1758FS+10d | 100% |  |  |
| 1764 |  | Elexon Branding QTF Logo | 1d | 2024-05-31 A | 2024-06-03 A | 1758FS+20d | 100% |  |  |
| 1765 | 1.6.4.1.7.3.2 | **Design, Build, Test** | 70d | 2024-05-13 A | 2024-08-16 A |  | 100% |  |  |
| 1766 |  | Core UI Screens | 60d | 2024-05-13 A | 2024-08-02 A | 1762SS | 100% |  |  |
| 1767 |  | Tooling (Trigger Files / Template Generators) | 70d | 2024-05-13 A | 2024-08-16 A | 1761SS+13d | 100% |  |  |
| 1768 |  | Database Schema | 50d | 2024-05-13 A | 2024-07-19 A | 1761SS+13d | 100% |  |  |
| 1769 |  | Core API's | 60d | 2024-05-13 A | 2024-08-02 A | 1761SS+13d | 100% |  |  |
| 1770 |  | DIP (SIT-A) Onboarding for Development inc. Test Stubs | 1d | 2024-07-12 A | 2024-07-12 A | 1758FS+49d | 100% |  |  |
| 1771 |  | DTN Onboarding for Development inc. Test Stubs | 1d | 2024-07-15 A | 2024-07-15 A | 1770 | 100% |  |  |
| 1772 |  | QTF Test Cases DBT Refinement, Execution and Results Validation, Defect Management, Error Handling | 131d | 2024-07-03 | 2025-01-01 | 1738FF, 1744FF, 1750FF, 1755FF |  | 762d |  |
| 1773 | 1.6.4.1.7.5 | **Environments** | 202d | 2024-04-15 A | 2025-01-21 |  | 54% | 762d |  |
| 1774 | 1.6.4.1.7.5.1 | **Azure Devops** | 120d | 2024-04-15 A | 2024-09-27 |  | 42% | 216d |  |
| 1775 | 1.6.4.1.7.5.1.1 | **QFT ADO Development Instance** | 15d | 2024-04-15 A | 2024-05-03 A |  | 100% |  |  |
| 1776 |  | Elexon Instance Setup for QTF Build | 5d | 2024-04-15 A | 2024-04-19 A | 1758SS+10d | 100% |  |  |
| 1777 |  | Configuration and User Access | 10d | 2024-04-22 A | 2024-05-03 A | 1776 | 100% |  |  |
| 1778 | 1.6.4.1.7.5.1.2 | **MHHSP ADO Instance** | 49d | 2024-07-23 A | 2024-09-27 |  | 24% | 216d |  |
| 1779 |  | MHHSP Instance Setup for QTF Production | 29d | 2024-07-23 A | 2024-08-30 | 1785SS+41d | 41% | 216d |  |
| 1780 |  | Configuration and User Access | 20d | 2024-09-02 | 2024-09-27 | 1779, 1836 |  | 216d |  |
| 1781 | 1.6.4.1.7.5.2 | **Temporary Development Environment** | 35d | 2024-04-15 A | 2024-05-31 A |  | 100% |  |  |
| 1782 |  | Design | 15d | 2024-04-15 A | 2024-05-03 A | 1758SS+10d | 100% |  |  |
| 1783 |  | Build and Deployment | 20d | 2024-05-06 A | 2024-05-31 A | 1777, 1782 | 100% |  |  |
| 1784 | 1.6.4.1.7.5.3 | **Dev, Test & Prod Environment Requirements + Design** | 105d | 2024-05-27 A | 2024-10-18 |  | 58% | 829d |  |
| 1785 |  | Design (including Security Review) | 70d | 2024-05-27 A | 2024-08-30 | 1758FS+15d | 76% | 864d |  |
| 1786 |  | Hub Deployment | 20d | 2024-06-10 A | 2024-07-05 A | 1785SS+10d | 100% |  |  |
| 1787 |  | Development Envn. Deployment | 40d | 2024-07-08 A | 2024-08-30 | 1786 | 58% | 815d |  |
| 1788 |  | Test Envn. Deployment | 10d | 2024-09-02 | 2024-09-13 | 1787 |  | 815d |  |
| 1789 |  | Production Envn. Deployment | 25d | 2024-09-16 | 2024-10-18 | 1788 |  | 815d |  |
| 1790 | 1.6.4.1.7.5.4 | **QTF Deployment into Production** | 14d | 2025-01-02 | 2025-01-21 |  |  | 762d |  |
| 1791 |  | App Deployment | 1d | 2025-01-02 | 2025-01-02 | 1772, 1789 |  | 762d |  |
| 1792 |  | Smoke Test | 2d | 2025-01-02 | 2025-01-03 | 1791SS |  | 762d |  |
| 1793 |  | PEN Test | 2d | 2025-01-06 | 2025-01-07 | 1792 |  | 762d |  |
| 1794 |  | Regression Test | 10d | 2025-01-08 | 2025-01-21 | 1793 |  | 762d |  |
| 1795 | 1.6.4.1.7.5.5 | **DIP Onboarding (UIT)** | 37d | 2024-08-05 A | 2024-09-24 |  | 46% | 847d |  |
| 1796 |  | DIP available for Onboarding | 1d | 2024-08-05 A | 2024-08-05 A | 1782 | 100% |  | start no earlier than 2024-08-05 |
| 1797 |  | Qualification Testing for Non-SIT S&A Participants' environments) Ready to start DIP onboarding (incl. certificates and security compliance) | 15d | 2024-08-06 A | 2024-08-26 A | 1796 | 100% |  |  |
| 1798 |  | Non-SIT S&A QTF Environments Connection Confirmed to UIT Environment | 1d | 2024-08-27 A | 2024-08-27 A | 1797 | 100% |  |  |
| 1799 |  | DIP UIT Test Stubs | 20d | 2024-08-28 | 2024-09-24 | 1798 |  | 847d |  |
| 1800 | 1.6.4.1.7.5.6 | **DTN Onboarding** | 95d | 2024-05-20 A | 2024-09-27 |  | 47% | 844d |  |
| 1801 |  | DTN Request Raised for Onboarding | 25d | 2024-05-20 A | 2024-06-21 A | 1782FS+10d | 100% |  |  |
| 1802 |  | Setup, configuration of New Host and Test Flags | 5d | 2024-06-24 A | 2024-06-28 A | 1801 | 100% |  |  |
| 1803 |  | New VPN Connection | 30d | 2024-08-05 A | 2024-09-13 | 1802FS+25d | 10% | 844d |  |
| 1804 |  | DTN Test Stubs | 10d | 2024-09-16 | 2024-09-27 | 1803 |  | 844d |  |
| 1805 | 1.6.4.1.7.6 | **Test Data (MPANs, DIP Messages, Settlement, Consumption, Reference)** | 405d | 2024-06-10 A | 2025-12-26 |  | 15% | 519d |  |
| 1806 |  | Sample MPAN Data + Attributes from Suppliers | 15d | 2024-06-10 A | 2024-06-28 A | 1719 | 100% |  |  |
| 1807 |  | Test Data Templates and generator tools ready | 30d | 2024-06-24 A | 2024-08-02 A | 1767SS+20d, 1806FF+25d | 100% |  |  |
| 1808 | 1.6.4.1.7.6.3 | **Industry Standing Data (ISD)** | 33d | 2024-07-26 A | 2024-09-10 |  | 6% | 857d |  |
| 1809 |  | Dependant on Receiving ISD Agreed Source Data from Helix | 1d | 2024-07-26 A | 2024-07-26 A |  | 100% |  | start no earlier than 2024-07-26 |
| 1810 |  | First View of Migrated ISD Data | 1d | 2024-08-19 | 2024-08-19 | 1809 |  | 857d | start no earlier than 2024-08-19 |
| 1811 |  | Final Cycle 3 Migrated ISD Data | 1d | 2024-08-20 | 2024-08-20 | 1810 |  | 857d |  |
| 1812 |  | Create ISD Template inc. DIP ID | 5d | 2024-08-21 | 2024-08-27 | 1811 |  | 857d |  |
| 1813 |  | Publish Qualification ISD | 10d | 2024-08-28 | 2024-09-10 | 1812 |  | 857d |  |
| 1814 | 1.6.4.1.7.6.4 | **Wave 1 Test Data** | 46d | 2025-05-12 | 2025-07-14 |  |  | 35d |  |
| 1815 |  | Test Data Request + Templates Completed | 16d | 2025-05-12 | 2025-06-02 | 1858 |  | 35d |  |
| 1816 |  | Test Data Generated | 10d | 2025-06-03 | 2025-06-16 | 1815 |  | 35d |  |
| 1817 |  | Test Data Loaded into QP Systems | 20d | 2025-06-17 | 2025-07-14 | 1816 |  | 35d |  |
| 1818 |  | Test Data Loaded into QTF + ADO | 19d | 2025-06-17 | 2025-07-11 | 1816 |  | 36d |  |
| 1819 | 1.6.4.1.7.6.5 | **Wave 2 Test Data** | 42d | 2025-07-07 | 2025-09-02 |  |  | 39d |  |
| 1820 |  | Test Data Request + Templates Completed | 16d | 2025-07-07 | 2025-07-28 | 1888 |  | 39d |  |

| ID | WBS | Task | Duration | Start | Finish | Predecessors | Complete | Total float | Constraint |
| --- | --- | --- | --- | --- | --- | --- | --- | --- | --- |
| 1821 |  | Test Data Generated | 10d | 2025-07-29 | 2025-08-11 | 1820 |  | 39d |  |
| 1822 |  | Test Data Loaded into QP Systems | 16d | 2025-08-12 | 2025-09-02 | 1821 |  | 39d |  |
| 1823 |  | Test Data Loaded into QTF + ADO | 16d | 2025-08-12 | 2025-09-02 | 1821 |  | 39d |  |
| 1824 | 1.6.4.1.7.6.6 | **Wave 3 Test Data** | 45d | 2025-09-08 | 2025-11-07 |  |  | 29d |  |
| 1825 |  | Test Data Request + Templates Completed | 15d | 2025-09-08 | 2025-09-26 | 1918 |  | 29d |  |
| 1826 |  | Test Data Generated | 10d | 2025-09-29 | 2025-10-10 | 1825 |  | 29d |  |
| 1827 |  | Test Data Loaded into QP Systems | 20d | 2025-10-13 | 2025-11-07 | 1826 |  | 29d |  |
| 1828 |  | Test Data Loaded into QTF + ADO | 20d | 2025-10-13 | 2025-11-07 | 1826 |  | 29d |  |
| 1829 | 1.6.4.1.7.6.7 | **Wave 4 Test Data** | 45d | 2025-10-27 | 2025-12-26 |  |  | 49d |  |
| 1830 |  | Test Data Request + Templates Completed | 15d | 2025-10-27 | 2025-11-14 | 1948 |  | 49d |  |
| 1831 |  | Test Data Generated | 10d | 2025-11-17 | 2025-11-28 | 1830 |  | 49d |  |
| 1832 |  | Test Data Loaded into QP Systems | 20d | 2025-12-01 | 2025-12-26 | 1831 |  | 49d |  |
| 1833 |  | Test Data Loaded into QTF + ADO | 20d | 2025-12-01 | 2025-12-26 | 1831 |  | 49d |  |
| 1834 | 1.6.4.1.7.7 | **Governance** | 130d | 2024-07-01 A | 2024-12-27 |  | 29% | 779d |  |
| 1835 |  | Onboarding Strategy and Develop Training Requirements & Materials Inc. Day in the Life | 65d | 2024-07-01 A | 2024-09-27 | 1761 | 43% | 844d |  |
| 1836 |  | Design Approach & Set-Up ADO Tool for Test & Defect Management Tool | 45d | 2024-07-01 A | 2024-08-30 | 1835SS | 62% | 216d |  |
| 1837 |  | Knowledge Transfer, Training, Demonstrations, Documentation, Governance | 85d | 2024-09-02 | 2024-12-27 | 1835SS+45d |  | 176d |  |
| 1838 |  | Qualification Testing Wave Readiness Confirmed | 0d | 2024-12-27 | 2024-12-27 | 1837 |  | 176d |  |
| 1839 | 1.6.4.1.8 | **Wave Allocation** | 129d | 2024-01-02 A | 2024-06-28 A |  | 100% |  |  |
| 1840 |  | Draft Pre-Qualification Submission (PQS) document | 20d | 2024-01-02 A | 2024-01-29 A |  | 100% |  | finish no earlier than 2024-01-26 |
| 1841 |  | Publish PQS document | 1d | 2024-01-31 A | 2024-01-31 A |  | 100% |  | start no earlier than 2024-01-31 |
| 1842 |  | PQS Submission window | 60d | 2024-02-05 A | 2024-04-26 A |  | 100% |  | start no earlier than 2024-02-05 |
| 1843 |  | Pre-Qualification Submission and PIT Test Plan Deadline for Submission​ | 0d | 2024-04-26 A | 2024-04-26 A | 1842 | 100% |  |  |
| 1844 |  | PQS Review by Code Bodies | 25d | 2024-04-29 A | 2024-05-31 A | 1842, 1843 | 100% |  |  |
| 1845 |  | Draft Wave Allocations | 15d | 2024-06-03 A | 2024-06-21 A | 1844 | 100% |  |  |
| 1846 |  | Confirmation of participant Qualification Wave allocation | 0d | 2024-06-28 A | 2024-06-28 A | 1845FS+5d | 100% |  |  |
| 1847 | 1.6.4.2 | **Qualification Wave 1** | 275d | 2025-03-24 | 2026-04-10 |  |  | 5d |  |
| 1848 | 1.6.4.2.1 | **Qualification Wave 1 QAD Prep** | 80d | 2025-03-24 | 2025-07-11 |  |  | 36d |  |
| 1849 |  | Initial QAD Submission window opens | 0d | 2025-03-24 | 2025-03-24 | 1846, 1671FS+121d |  | 36d |  |
| 1850 |  | Qualification Wave 1 Participants Submit Initial QAD | 50d | 2025-03-24 | 2025-05-30 | 1849FS-1d |  | 36d |  |
| 1851 |  | Qualification Wave 1 Participants have submitted their initial QAD | 0d | 2025-06-02 | 2025-06-02 | 1850FS+1d |  | 36d |  |
| 1852 |  | Code Bodies review of Wave 1 Participants Initial QAD | 30d | 2025-06-02 | 2025-07-11 | 1850FS-1d, 1851FS-1d |  | 36d |  |
| 1853 |  | Completion of Code Bodies review of Initial QAD | 0d | 2025-07-11 | 2025-07-11 | 1852 |  | 36d |  |
| 1854 | 1.6.4.2.2 | **Qualification Wave 1 Test Prep** | 60d | 2025-04-14 | 2025-07-04 |  |  | 41d |  |
| 1855 |  | Confirmation from Qualification Wave 1 Participants that DIP onboarding has commenced | 0d | 2025-04-14 | 2025-04-14 |  |  | 61d | start no earlier than 2025-04-14 |
| 1856 |  | Qualification Wave 1 Participants DIP Onboarding Window | 35d | 2025-04-14 | 2025-05-30 | 1855 |  | 61d |  |
| 1857 |  | Confirmation from Qualification Wave 1 Participants that DIP onboarding has completed | 0d | 2025-05-30 | 2025-05-30 | 1856 |  | 61d |  |
| 1858 |  | Qualification Wave 1 Participants' to provide status of PIT completion and submit QT Test Plan | 0d | 2025-05-12 | 2025-05-12 |  |  | 35d | start no earlier than 2025-05-12 |
| 1859 |  | Review of Participants' PIT Status and QT Test Plan | 15d | 2025-05-12 | 2025-05-30 | 1858 |  | 61d |  |
| 1860 |  | Qualification Test Plans for Wave 1 Participants approved | 0d | 2025-05-30 | 2025-05-30 | 1859 |  | 61d |  |
| 1861 |  | Qualification Wave 1 Participants have submitted PIT Test Completion Report and evidence for QT Entry | 0d | 2025-06-02 | 2025-06-02 |  |  | 36d | start no earlier than 2025-06-02 |
| 1862 |  | Review of Participants PIT Test Completion Report | 25d | 2025-06-02 | 2025-07-04 | 1861 |  | 36d |  |
| 1863 |  | Onboarding to QTF & ADO | 25d | 2025-06-02 | 2025-07-04 | 1862SS, 1780 |  | 41d |  |
| 1864 | 1.6.4.2.3 | **Qualification Wave 1 QT Execution** | 130d | 2025-07-07 | 2026-01-02 |  |  | 10d |  |
| 1865 |  | Review Entry Criteria Evidence for each Wave 1 Participant | 5d | 2025-07-07 | 2025-07-11 | 1853FF, 1857, 1860, 1862 |  | 36d |  |
| 1866 |  | Qualification Wave 1 Participant Test Readiness Confirmed | 0d | 2025-07-14 | 2025-07-14 | 1852, 1853, 1865FF, 1817, 1818 |  | 35d |  |
| 1867 |  | Qualification Wave 1 QT Execution Start | 0d | 2025-08-25 | 2025-08-25 | 1866, 1838, 1863, 1282FS+6d |  | 5d | start no earlier than 2025-07-14 |
| 1868 |  | Qualification Wave 1 QT Execution Window | 95d | 2025-08-25 | 2026-01-02 | 1867FS-1d |  | 10d |  |
| 1869 |  | Qualification Wave 1 QT Projected Execution End | 0d | 2026-01-02 | 2026-01-02 | 1868 |  | 10d |  |
| 1870 | 1.6.4.2.4 | **Qualification Wave 1 Exit** | 165d | 2025-08-25 | 2026-04-10 |  |  | 5d |  |
| 1871 |  | Final QAD Submission window opens | 0d | 2025-08-25 | 2025-08-25 | 1867 |  | 5d |  |
| 1872 |  | Qualification Wave 1 Participants submit their Final QAD | 100d | 2025-08-25 | 2026-01-09 | 1871FS-1d |  | 5d |  |
| 1873 |  | Qualification Wave 1 Participants have submitted their final QAD | 0d | 2026-01-09 | 2026-01-09 | 1872, 1869 |  | 5d |  |
| 1874 |  | Completion of Code Bodies review of Final QAD | 35d | 2026-01-12 | 2026-02-27 | 1872, 1873 |  | 5d |  |
| 1875 |  | QAD Sign Off deadline | 1d | 2026-03-13 | 2026-03-13 | 1874FS+9d |  | 5d |  |
| 1876 |  | Qualification Wave 1 Participants Qualification approved by BSC PAB and REC Manager | 0d | 2026-04-10 | 2026-04-10 | 1875FS+20d |  | 5d |  |
| 1877 | 1.6.4.3 | **Qualification Wave 2** | 253d | 2025-06-09 | 2026-05-27 |  |  | 6d |  |
| 1878 | 1.6.4.3.1 | **Qualification Wave 2 QAD Prep** | 95d | 2025-06-09 | 2025-10-17 |  |  | 6d |  |
| 1879 |  | Initial QAD Submission window opens | 0d | 2025-06-09 | 2025-06-09 | 1672FS+151d |  | 6d |  |
| 1880 |  | Qualification Wave 2 Participants Submit Initial QAD | 70d | 2025-06-09 | 2025-09-12 | 1879FS-1d |  | 6d |  |
| 1881 |  | Qualification Wave 2 Participants have submitted their initial QAD | 0d | 2025-09-12 | 2025-09-12 | 1880 |  | 6d |  |
| 1882 |  | Code Bodies review of Wave 2 Participants' Initial QAD | 25d | 2025-09-15 | 2025-10-17 | 1881 |  | 6d |  |
| 1883 |  | Completion of Code Bodies review of Initial QAD | 0d | 2025-10-17 | 2025-10-17 | 1882 |  | 6d |  |
| 1884 | 1.6.4.3.2 | **Qualification Wave 2 Test Prep** | 60d | 2025-06-09 | 2025-08-29 |  |  | 42d |  |
| 1885 |  | Confirmation from Qualification Wave 2 Participants that DIP Onboarding has commenced | 0d | 2025-06-09 | 2025-06-09 |  |  | 61d | start no earlier than 2025-06-09 |
| 1886 |  | Qualification Wave 2 Participants DIP Onboarding Window | 35d | 2025-06-09 | 2025-07-25 | 1885 |  | 61d |  |
| 1887 |  | Confirmation from Qualificiation Wave 2 Participants that DIP onboarding has completed | 0d | 2025-07-25 | 2025-07-25 | 1886 |  | 61d |  |
| 1888 |  | Qualification Wave 2 Participants' to provide status of PIT completion and submit QT Test Plan | 0d | 2025-07-07 | 2025-07-07 |  |  | 39d | start no earlier than 2025-07-07 |
| 1889 |  | Review of Participants' PIT Status and QT Test Plan | 15d | 2025-07-07 | 2025-07-25 | 1888 |  | 61d | start no earlier than 2025-07-07 |
| 1890 |  | Qualification Test Plans for Wave 2 Participants approved | 0d | 2025-07-25 | 2025-07-25 | 1889 |  | 61d | start no earlier than 2025-07-25 |

| ID | WBS | Task | Duration | Start | Finish | Predecessors | Total float | Constraint |
| --- | --- | --- | --- | --- | --- | --- | --- | --- |
| 1891 |  | Qualification Wave 2 Participants have submitted PIT Test Completion Report and evidence for QT entry | 0d | 2025-07-28 | 2025-07-28 |  | 36d | start no earlier than 2025-07-28 |
| 1892 |  | Review of Participants' PIT Test Completion Report | 25d | 2025-07-28 | 2025-08-29 | 1891 | 36d |  |
| 1893 |  | Onboarding to QTF & ADO | 25d | 2025-07-28 | 2025-08-29 | 1892SS | 42d |  |
| 1894 | 1.6.4.3.3 | **Qualification Wave 2 QT Execution** | 100d | 2025-10-13 | 2026-02-27 |  | 6d |  |
| 1895 |  | Review Entry Criteria Evidence for each Wave 2 Participant | 5d | 2025-10-13 | 2025-10-17 | 1883FF, 1887, 1890, 1892 | 6d |  |
| 1896 |  | Qualification Wave 2 Participant Test Readiness Confirmed | 0d | 2025-10-17 | 2025-10-17 | 1895, 1883, 1822, 1823 | 6d |  |
| 1897 |  | Qualification Wave 2 Execution Start | 0d | 2025-10-20 | 2025-10-20 | 1896FS+1d, 1893 | 6d |  |
| 1898 |  | Qualification Wave 2 QT Execution Window | 95d | 2025-10-20 | 2026-02-27 | 1897SS-1d | 11d |  |
| 1899 |  | Qualfication Wave 2 QT Execution End | 0d | 2026-02-27 | 2026-02-27 | 1898 | 11d |  |
| 1900 | 1.6.4.3.4 | **Qualification Wave 2 Exit** | 158d | 2025-10-20 | 2026-05-27 |  | 6d |  |
| 1901 |  | Final QAD Submission window opens | 0d | 2025-10-20 | 2025-10-20 | 1897 | 6d |  |
| 1902 |  | Qualification Wave 2 Participants submit their Final QAD | 100d | 2025-10-20 | 2026-03-06 | 1901FS-1d | 6d |  |
| 1903 |  | Qualification Wave 2 Participants have submitted their final QAD | 0d | 2026-03-06 | 2026-03-06 | 1902, 1899 | 6d |  |
| 1904 |  | Completion of Code Bodies review of Final QAD | 26d | 2026-03-09 | 2026-04-13 | 1903 | 6d |  |
| 1905 |  | QAD Sign Off deadline | 1d | 2026-04-20 | 2026-04-20 | 1904FS+4d | 6d |  |
| 1906 |  | Qualification Wave 2 Participants Qualification approved by BSC PAB and REC Manager | 0d | 2026-05-27 | 2026-05-27 | 1905FS+27d | 6d |  |
| 1907 | 1.6.4.4 | **Qualification Wave 3** | 254d | 2025-08-04 | 2026-07-23 |  | 5d |  |
| 1908 | 1.6.4.4.1 | **Qualification Wave 3 QAD Prep** | 95d | 2025-08-11 | 2025-12-19 |  | 0d |  |
| 1909 |  | Initial QAD Submission window opens | 0d | 2025-08-11 | 2025-08-11 | 1673FS+151d | 0d |  |
| 1910 |  | Qualification Wave 3 Participants Submit Initial QAD | 65d | 2025-08-11 | 2025-11-07 | 1909FS-1d | 0d |  |
| 1911 |  | Qualification Wave 3 Participants have submitted their initial QAD | 0d | 2025-11-07 | 2025-11-07 | 1910 | 0d |  |
| 1912 |  | Code Bodies review of Wave 3 Participants' Initial QAD | 30d | 2025-11-10 | 2025-12-19 | 1911 | 0d |  |
| 1913 |  | Completion of Code Bodies review of Initial QAD | 0d | 2025-12-19 | 2025-12-19 | 1912 | 0d |  |
| 1914 | 1.6.4.4.2 | **Qualification Wave 3 Test Prep** | 65d | 2025-08-04 | 2025-10-31 |  | 54d |  |
| 1915 |  | Confirmation from Qualification Wave 3 Participants that DIP Onboarding has commenced | 0d | 2025-08-04 | 2025-08-04 |  | 60d | start no earlier than 2025-08-04 |
| 1916 |  | Qualification Wave 3 Participants DIP Onboarding window | 35d | 2025-08-04 | 2025-09-19 | 1915 | 60d | start no earlier than 2025-08-04 |
| 1917 |  | Confirmation from Qualification Wave 3 Participants that DIP onboarding has completed | 0d | 2025-09-22 | 2025-09-22 | 1916 | 60d | start no earlier than 2025-09-22 |
| 1918 |  | Qualification Wave 3 Participants' to provide status of PIT completion and submit QT Test Plan | 0d | 2025-09-08 | 2025-09-08 |  | 29d | start no earlier than 2025-09-08 |
| 1919 |  | Review of Participants' PIT Status and QT Test Plan | 15d | 2025-09-08 | 2025-09-26 | 1918 | 584d | start no earlier than 2025-09-08 |
| 1920 |  | Qualification Test Plans for Wave 3 Participants approved | 0d | 2025-09-26 | 2025-09-26 | 1919 | 584d | start no earlier than 2025-09-26 |
| 1921 |  | Qualification Wave 3 Participants have submitted PIT Test Completion Report and evidence for QT Entry | 0d | 2025-09-29 | 2025-09-29 |  | 30d | start no earlier than 2025-09-29 |
| 1922 |  | Review of Participants' PIT Test Completion Report | 25d | 2025-09-29 | 2025-10-31 | 1921 | 30d | start no earlier than 2025-09-29 |
| 1923 |  | Onboarding to QTF & ADO | 25d | 2025-09-29 | 2025-10-31 | 1922SS | 30d | finish no earlier than 2025-10-31 |
| 1924 | 1.6.4.4.3 | **Qualification Wave 3 QT Execution** | 102d | 2025-11-03 | 2026-03-24 |  |  |  |
| 1925 |  | Review Entry Criteria Evidence for each Wave 3 Participant | 5d | 2025-12-15 | 2025-12-19 | 1917, 1913FF, 1923 | 0d | start no earlier than 2025-11-03 |
| 1926 |  | Qualification Wave 3 Participant Test Readiness confirmed | 0d | 2025-12-19 | 2025-12-19 | 1917, 1925FS-1d, 1827, 1828 | 0d |  |
| 1927 |  | Qualification Wave 3 Execution Start | 0d | 2026-01-05 | 2026-01-05 | 1926FS+12d, 1923FS+1d | 0d | start no earlier than 2025-11-03 |
| 1928 |  | Qualification Wave 3 QT Execution Window | 95d | 2026-01-05 | 2026-05-15 | 1925, 1927FS-1d | 5d |  |
| 1929 |  | Qualification Wave 3 Projected Execution End | 0d | 2026-05-15 | 2026-05-15 | 1928 | 5d |  |
| 1930 | 1.6.4.4.4 | **Qualification Wave 3 Exit** | 144d | 2026-01-05 | 2026-07-23 |  | 0d |  |
| 1931 |  | Final QAD Submission window opens | 0d | 2026-01-05 | 2026-01-05 | 1927 | 0d |  |
| 1932 |  | Qualification Wave 3 Participants submit their Final QAD | 100d | 2026-01-05 | 2026-05-22 | 1931FS-1d | 0d |  |
| 1933 |  | Qualification Wave 3 Participants have submitted their Final QAD | 0d | 2026-05-22 | 2026-05-22 | 1932, 1929 | 0d |  |
| 1934 |  | Completion of Code Bodies review of Final QAD | 20d | 2026-05-25 | 2026-06-19 | 1933 | 0d |  |
| 1935 |  | QAD Sign Off deadline | 1d | 2026-06-26 | 2026-06-26 | 1934FS+4d | 0d |  |
| 1936 |  | Qualification Wave 3 Participants Qualification approved by BSC PAB and REC Manager | 0d | 2026-07-23 | 2026-07-23 | 1935FS+19d | 0d |  |
| 1937 | 1.6.4.5 | **Qualification Wave 4** | 354d | 2025-09-22 | 2027-01-28 |  | 24d |  |
| 1938 | 1.6.4.5.1 | **Qualification Wave 4 QAD Prep** | 95d | 2025-10-20 | 2026-02-27 |  | 4d |  |
| 1939 |  | Initial QAD Submission window opens | 0d | 2025-10-20 | 2025-10-20 | 1674FS+161d | 4d |  |
| 1940 |  | Qualification Wave 4 Participants Submit Initial QAD | 65d | 2025-10-20 | 2026-01-16 | 1939FS-1d | 4d |  |
| 1941 |  | Qualification Wave 4 Participants have submitted their Initial QAD | 0d | 2026-01-16 | 2026-01-16 | 1940 | 4d |  |
| 1942 |  | Code Bodies review of Wave 4 Participants' Initial QAD | 30d | 2026-01-19 | 2026-02-27 | 1941 | 4d |  |
| 1943 |  | Completion of Code Bodies review of Initial QAD | 0d | 2026-02-27 | 2026-02-27 | 1942 | 4d |  |
| 1944 | 1.6.4.5.2 | **Qualification Wave 4 Test Prep** | 65d | 2025-09-22 | 2025-12-19 |  | 60d |  |
| 1945 |  | Confirmation from Qualification 4 Participants that DIP Onboarding has commenced | 0d | 2025-09-22 | 2025-09-22 |  | 79d | start no earlier than 2025-09-22 |
| 1946 |  | Qualification Wave 4 Participants DIP Onboarding Window | 35d | 2025-09-22 | 2025-11-07 | 1945 | 79d |  |
| 1947 |  | Confirmation from Qualification Wave 4 Participants that DIP onboarding has completed | 0d | 2025-11-07 | 2025-11-07 | 1946 | 79d |  |
| 1948 |  | Qualification Wave 4 Participants' to provide status of PIT completion and submit QT Test Plan | 0d | 2025-10-27 | 2025-10-27 |  | 49d | start no earlier than 2025-10-27 |
| 1949 |  | Review of Participants' PIT Status and QT Test Plan | 15d | 2025-10-27 | 2025-11-14 | 1948 | 60d |  |
| 1950 |  | Qualification Test Plans for Qualification Wave 4 Participants approved | 0d | 2025-11-14 | 2025-11-14 | 1949 | 60d |  |
| 1951 |  | Qualification Wave 4 Participants have submitted PIT Test Completion Report and evidence for QT entry | 0d | 2025-11-14 | 2025-11-14 | 1950 | 60d |  |
| 1952 |  | Review of Participants' PIT Test Completion Report | 25d | 2025-11-17 | 2025-12-19 | 1951 | 60d |  |
| 1953 |  | Onboarding to QTF & ADO | 20d | 2025-11-24 | 2025-12-19 | 1952SS | 55d | start no earlier than 2025-11-24 |
| 1954 | 1.6.4.5.3 | **Qualification Wave 4 QT Execution** | 100d | 2026-02-23 | 2026-07-10 |  | 4d |  |
| 1955 |  | Review Entry Criteria Evidence for each Wave 4 Participant | 5d | 2026-02-23 | 2026-02-27 | 1943FF, 1947 | 4d | start no earlier than 2026-01-05 |
| 1956 |  | Qualification Wave 4 Participant Test Readiness Confirmed | 0d | 2026-02-27 | 2026-02-27 | 1947, 1955, 1832, 1833 | 4d |  |
| 1957 |  | Qualification Wave 4 QT Execution Start | 0d | 2026-03-02 | 2026-03-02 | 1956FS+1d, 1953 | 4d | start no earlier than 2026-01-07 |
| 1958 |  | Qualification Wave 4 QT Execution Window | 95d | 2026-03-02 | 2026-07-10 | 1957FS-1d, 1955 | 9d |  |
| 1959 |  | Qualification Wave 4 Projected Execution End | 0d | 2026-07-10 | 2026-07-10 | 1958 | 9d |  |
| 1960 | 1.6.4.5.4 | **Qualification Wave 4 Exit** | 145d | 2026-03-02 | 2026-09-18 |  | 4d |  |

| ID | WBS | Task | Duration | Start | Finish | Predecessors | Complete | Total float | Constraint |
| --- | --- | --- | --- | --- | --- | --- | --- | --- | --- |
| 1961 |  | Final QAD Submission window opens | 0d | 2026-03-02 | 2026-03-02 | 1957 |  | 4d |  |
| 1962 |  | Qualification Wave 4 Participants submit their Final QAD | 100d | 2026-03-02 | 2026-07-17 | 1961FS-1d |  | 4d |  |
| 1963 |  | Qualification Wave 4 Participants have submitted their Final QAD | 0d | 2026-07-17 | 2026-07-17 | 1962, 1959 |  | 4d |  |
| 1964 |  | Completion of Code Bodies review of Final QAD | 20d | 2026-07-20 | 2026-08-14 | 1963 |  | 4d |  |
| 1965 |  | QAD Sign Off deadline | 1d | 2026-08-21 | 2026-08-21 | 1964FS+4d |  | 4d |  |
| 1966 |  | Qualification Wave 4 Participants Qualification approved by BSC PAB and REC Manager | 0d | 2026-09-18 | 2026-09-18 | 1965FS+20d |  | 4d |  |
| 1967 | 1.6.4.5.5 | **Qualification Tier 1 Milestone** | 66d | 2026-10-28 | 2027-01-28 |  |  | 235d |  |
| 1968 |  | All suppliers must be able to access MPANs under the new TOM (M14) | 0d | 2026-10-28 | 2026-10-28 | 1966FS+28d |  | 235d | start no earlier than 2026-03-12 |
| 1969 |  | All suppliers must be able to access MPANs under the new TOM (M14*) - Late Exit | 0d | 2027-01-28 | 2027-01-28 | 1968FS+66d |  | 235d |  |
| 1970 | 1.7 | **REGULATORY** | 823d | 2022-10-31 A | 2025-12-24 |  | 93% | 521d |  |
| 1971 | 1.7.1 | **Baseline MHHS Code Changes** | 475d | 2022-10-31 A | 2024-08-23 A |  | 100% |  |  |
| 1972 | 1.7.1.1 | **Preparation and planning** | 35d | 2022-10-31 A | 2022-12-16 A |  | 100% |  |  |
| 1973 |  | Impact assessment of Programme design on codes to determine required changes | 20d | 2022-10-31 A | 2022-11-25 A | 47 | 100% |  |  |
| 1974 |  | Become 'code draft ready' | 35d | 2022-10-31 A | 2022-12-16 A |  | 100% |  |  |
| 1975 |  | Soft start drafting where possible | 35d | 2022-10-31 A | 2022-12-16 A |  | 100% |  |  |
| 1976 | 1.7.1.2 | **Code drafting** | 443d | 2022-12-12 A | 2024-08-21 A |  | 100% |  |  |
| 1977 | 1.7.1.2.1 | **Data Services (BSC driven)** | 118d | 2022-12-12 A | 2023-05-24 A |  | 100% |  |  |
| 1978 |  | Pre Code Drafting activities | 5d | 2022-12-12 A | 2022-12-16 A |  | 100% |  | start no earlier than 2022-12-12 |
| 1979 |  | Code and subsidiary document drafting takes place offline | 19d | 2023-01-03 A | 2023-01-27 A | 1978FS+11d | 100% |  |  |
| 1980 |  | Internal review and cross-checking of drafting across code drafters | 11d | 2023-01-30 A | 2023-02-13 A | 1979 | 100% |  |  |
| 1981 |  | External industry review via consultation | 20d | 2023-02-14 A | 2023-03-13 A | 1980 | 100% |  |  |
| 1982 |  | Triage and action comments | 19d | 2023-03-10 A | 2023-04-05 A | 1981FS-2d | 100% |  |  |
| 1983 |  | CDWG review | 30d | 2023-04-06 A | 2023-05-17 A | 1982 | 100% |  |  |
| 1984 |  | CCAG review | 5d | 2023-05-18 A | 2023-05-24 A | 1983 | 100% |  |  |
| 1985 |  | Code drafting for Data Services topic area approved | 0d | 2023-05-24 A | 2023-05-24 A | 1984 | 100% |  |  |
| 1986 | 1.7.1.2.2 | **Metering (REC driven)** | 118d | 2022-12-12 A | 2023-05-24 A |  | 100% |  |  |
| 1987 |  | Pre Code Drafting activities | 5d | 2022-12-12 A | 2022-12-16 A | 1978SS | 100% |  |  |
| 1988 |  | Code and subsidiary document drafting takes place offline | 19d | 2023-01-03 A | 2023-01-27 A | 1987FS+11d | 100% |  |  |
| 1989 |  | Internal review and cross-checking of drafting across code drafters | 11d | 2023-01-30 A | 2023-02-13 A | 1988 | 100% |  |  |
| 1990 |  | External industry review via consultation | 20d | 2023-02-14 A | 2023-03-13 A | 1989 | 100% |  |  |
| 1991 |  | Triage and action comments | 19d | 2023-03-10 A | 2023-04-05 A | 1990FS-2d | 100% |  |  |
| 1992 |  | CDWG review | 30d | 2023-04-06 A | 2023-05-17 A | 1991 | 100% |  |  |
| 1993 |  | CCAG review | 5d | 2023-05-18 A | 2023-05-24 A | 1992 | 100% |  |  |
| 1994 |  | Code drafting for Metering topic area approved | 0d | 2023-05-24 A | 2023-05-24 A | 1993 | 100% |  |  |
| 1995 | 1.7.1.2.3 | **BSC Central Services (BSC driven)** | 156d | 2023-02-22 A | 2023-09-27 A |  | 100% |  |  |
| 1996 |  | Pre Code Drafting activities | 5d | 2023-02-22 A | 2023-02-28 A | 1997SS-5d | 100% |  |  |
| 1997 |  | Code Drafting (offline) | 80d | 2023-03-01 A | 2023-06-20 A | 1981SS | 100% |  | must start on 2023-03-01 |
| 1998 |  | Internal review and cross-checking of drafting across code drafters | 70d | 2023-03-15 A | 2023-06-20 A | 1997SS+10d | 100% |  |  |
| 1999 |  | External industry review via consultation | 15d | 2023-06-21 A | 2023-07-11 A | 1998 | 100% |  |  |
| 2000 |  | Triage and action comments | 19d | 2023-07-10 A | 2023-08-03 A | 1999FS-2d | 100% |  |  |
| 2001 |  | CDWG review | 28d | 2023-08-04 A | 2023-09-12 A | 2000 | 100% |  |  |
| 2002 |  | CCAG review | 11d | 2023-09-13 A | 2023-09-27 A | 2001 | 100% |  |  |
| 2003 |  | Code drafting for BSC Central Services topic area approved | 0d | 2023-09-27 A | 2023-09-27 A | 2002 | 100% |  |  |
| 2004 | 1.7.1.2.4 | **Registration (BSC & REC driven)** | 131d | 2023-02-22 A | 2023-08-23 A |  | 100% |  |  |
| 2005 |  | Pre Code Drafting activities | 5d | 2023-02-22 A | 2023-02-28 A | 2006SS-5d | 100% |  |  |
| 2006 |  | Code Drafting (offline) | 65d | 2023-03-01 A | 2023-05-30 A | 1980, 1989 | 100% |  | must start on 2023-03-01 |
| 2007 |  | Internal review and cross-checking of drafting across code drafters | 55d | 2023-03-15 A | 2023-05-30 A | 2006SS+10d | 100% |  |  |
| 2008 |  | External industry review via consultation | 15d | 2023-05-31 A | 2023-06-20 A | 2007 | 100% |  |  |
| 2009 |  | Triage and action comments | 19d | 2023-06-19 A | 2023-07-13 A | 2008FS-2d | 100% |  |  |
| 2010 |  | CDWG review | 18d | 2023-07-14 A | 2023-08-08 A | 2009 | 100% |  |  |
| 2011 |  | CCAG review | 11d | 2023-08-09 A | 2023-08-23 A | 2010 | 100% |  |  |
| 2012 |  | Code drafting for Registration topic area approved | 0d | 2023-08-23 A | 2023-08-23 A | 2011 | 100% |  |  |
| 2013 | 1.7.1.2.5 | **Governance and Qualification (BSC & REC driven)** | 130d | 2023-05-25 A | 2023-11-22 A |  | 100% |  |  |
| 2014 |  | Pre Code Drafting activities | 5d | 2023-05-25 A | 2023-05-31 A | 2015SS-5d | 100% |  |  |
| 2015 |  | Code Drafting (offline) | 55d | 2023-06-01 A | 2023-08-16 A | 2008SS+1d | 100% |  |  |
| 2016 |  | Internal review and cross-checking of drafting across code drafters | 45d | 2023-06-15 A | 2023-08-16 A | 2015SS+10d | 100% |  |  |
| 2017 |  | External industry review via consultation | 15d | 2023-08-18 A | 2023-09-07 A | 2016FS+1d | 100% |  |  |
| 2018 |  | Triage and action comments | 19d | 2023-09-06 A | 2023-10-02 A | 2017FS-2d | 100% |  |  |
| 2019 |  | CDWG review | 31d | 2023-10-03 A | 2023-11-14 A | 2018 | 100% |  |  |
| 2020 |  | CCAG review | 6d | 2023-11-15 A | 2023-11-22 A | 2019 | 100% |  |  |
| 2021 |  | Code drafting for Governance and Qualification topic areas approved | 0d | 2023-11-22 A | 2023-11-22 A | 2020 | 100% |  |  |
| 2022 | 1.7.1.2.6 | **Interfaces / Data Specification (REC driven)** | 174d | 2023-05-25 A | 2024-01-23 A |  | 100% |  |  |
| 2023 |  | Pre Code Drafting activities | 5d | 2023-05-25 A | 2023-05-31 A | 2024SS-5d | 100% |  |  |
| 2024 |  | Code Drafting (offline) | 94d | 2023-06-01 A | 2023-10-10 A | 2008SS+1d | 100% |  |  |
| 2025 |  | Internal review and cross-checking of drafting across code drafters | 84d | 2023-06-15 A | 2023-10-10 A | 2024SS+10d | 100% |  |  |
| 2026 |  | External industry review via consultation | 15d | 2023-10-11 A | 2023-10-31 A | 2025 | 100% |  |  |
| 2027 |  | Triage and action comments | 20d | 2023-10-30 A | 2023-11-24 A | 2026FS-2d | 100% |  |  |
| 2028 |  | CDWG review | 37d | 2023-11-27 A | 2024-01-16 A | 2027 | 100% |  |  |
| 2029 |  | CCAG review | 5d | 2024-01-17 A | 2024-01-23 A | 2028 | 100% |  |  |
| 2030 |  | Code drafting for Interfaces / Data Specification topic areas approved | 0d | 2024-01-23 A | 2024-01-23 A | 2029 | 100% |  |  |

| ID | WBS | Task | Duration | Start | Finish | Predecessors | Complete | Total float | Constraint |
| --- | --- | --- | --- | --- | --- | --- | --- | --- | --- |
| 2031 | 1.7.1.2.7 | **Migration (BSC & REC driven)** | 130d | 2023-05-25 A | 2023-11-22 A |  | 100% |  |  |
| 2032 |  | Pre Code Drafting activities | 5d | 2023-05-25 A | 2023-05-31 A | 2033SS-5d | 100% |  |  |
| 2033 |  | Code Drafting (offline) | 55d | 2023-06-01 A | 2023-08-16 A | 2008SS+1d | 100% |  |  |
| 2034 |  | Internal review and cross-checking of drafting across code drafters | 45d | 2023-06-15 A | 2023-08-16 A | 2033SS+10d | 100% |  |  |
| 2035 |  | External industry review via consultation | 15d | 2023-08-18 A | 2023-09-07 A | 2034FS+1d | 100% |  |  |
| 2036 |  | Triage and action comments | 19d | 2023-09-06 A | 2023-10-02 A | 2035FS-2d | 100% |  |  |
| 2037 |  | CDWG review | 31d | 2023-10-03 A | 2023-11-14 A | 2036 | 100% |  |  |
| 2038 |  | CCAG review | 6d | 2023-11-15 A | 2023-11-22 A | 2037 | 100% |  |  |
| 2039 |  | Code drafting for Migration topic area approved | 0d | 2023-11-22 A | 2023-11-22 A | 2038 | 100% |  |  |
| 2040 | 1.7.1.2.8 | **Consequential Code Change** | 109d | 2023-10-11 A | 2024-03-11 A |  | 100% |  |  |
| 2041 |  | External industry review via consultation - drop 1 (DCUSA) | 15d | 2023-10-11 A | 2023-10-31 A | 2047SS | 100% |  |  |
| 2042 |  | External industry review via consultation - drop 2 (Elexon) | 16d | 2024-02-19 A | 2024-03-11 A | 2057SS | 100% |  | start no earlier than 2024-02-19 |
| 2043 | 1.7.1.2.9 | **Transition Text (all codes)** | 118d | 2023-08-11 A | 2024-01-23 A |  | 100% |  |  |
| 2044 |  | Pre Code Drafting activities | 8d | 2023-08-11 A | 2023-08-22 A | 2045SS-5d | 100% |  |  |
| 2045 |  | Code Drafting (offline) | 38d | 2023-08-18 A | 2023-10-10 A | 2035SS | 100% |  |  |
| 2046 |  | Internal review and cross-checking of drafting across code drafters | 28d | 2023-09-01 A | 2023-10-10 A | 2045SS+10d | 100% |  |  |
| 2047 |  | External industry review via consultation | 15d | 2023-10-11 A | 2023-10-31 A | 2046 | 100% |  |  |
| 2048 |  | Triage and action comments | 20d | 2023-10-30 A | 2023-11-24 A | 2047FS-2d | 100% |  |  |
| 2049 |  | CDWG review | 37d | 2023-11-27 A | 2024-01-16 A | 2048 | 100% |  |  |
| 2050 |  | CCAG review | 5d | 2024-01-17 A | 2024-01-23 A | 2049 | 100% |  |  |
| 2051 |  | Code drafting for Transition Text topic area approved | 0d | 2024-01-23 A | 2024-01-23 A | 2050 | 100% |  |  |
| 2052 | 1.7.1.2.10 | **Final Code Drafting (mop-up) (all codes)** | 199d | 2023-08-18 A | 2024-05-22 A |  | 100% |  |  |
| 2053 |  | Forward look and confirm remaining plan | 15d | 2023-08-18 A | 2023-09-07 A | 2045SS | 100% |  |  |
| 2054 |  | Identify remaining or additional areas of code (e.g. consequential change requirements) to be completed | 15d | 2023-08-18 A | 2023-09-07 A | 2053SS | 100% |  |  |
| 2055 |  | Code Drafting (offline) Interim Consultation (1) | 60d | 2023-09-08 A | 2023-11-30 A | 2054 | 100% |  |  |
| 2056 |  | Internal review and cross-checking of drafting across code drafters Interim Consultation (1) | 50d | 2023-09-22 A | 2023-11-30 A | 2055SS+10d | 100% |  |  |
| 2057 |  | External industry review via consultation Interim Consultation (1) | 23d | 2023-12-01 A | 2024-01-02 A | 2056 | 100% |  |  |
| 2058 |  | Code Drafting (offline) Final Consultation (2) | 55d | 2023-12-01 A | 2024-02-15 A | 2056 | 100% |  |  |
| 2059 |  | Internal review and cross-checking of drafting across code drafters Final Consultation (2) | 45d | 2023-12-15 A | 2024-02-15 A | 2058SS+10d | 100% |  |  |
| 2060 |  | External industry review via consultation Final Consultation (2) | 16d | 2024-02-19 A | 2024-03-11 A | 2059FS+1d | 100% |  |  |
| 2061 |  | Triage and action comments | 18d | 2024-03-11 A | 2024-04-03 A | 2060FS-1d | 100% |  |  |
| 2062 |  | CDWG review | 29d | 2024-04-04 A | 2024-05-14 A | 2061 | 100% |  |  |
| 2063 |  | CCAG review | 6d | 2024-05-15 A | 2024-05-22 A | 2062 | 100% |  |  |
| 2064 |  | Final code drafting (mop-up) approved | 0d | 2024-05-22 A | 2024-05-22 A | 2063 | 100% |  |  |
| 2065 | 1.7.1.2.11 | **Final code review, consistency check and approval** | 100d | 2024-04-04 A | 2024-08-21 A |  | 100% |  |  |
| 2066 |  | Gap analysis of final code against design artefacts (reverse process to code drafting) | 38d | 2024-04-04 A | 2024-05-27 A | 2062SS | 100% |  |  |
| 2067 |  | Outputs of gap analysis actioned offline | 11d | 2024-05-28 A | 2024-06-11 A | 2066 | 100% |  |  |
| 2068 |  | Final documentation collated for final consultation | 8d | 2024-06-12 A | 2024-06-21 A | 2067 | 100% |  |  |
| 2069 |  | External industry review via consultation | 15d | 2024-06-24 A | 2024-07-12 A | 2068 | 100% |  |  |
| 2070 |  | Triage and action comments | 10d | 2024-07-15 A | 2024-07-26 A | 2069 | 100% |  |  |
| 2071 |  | Final CDWG review | 8d | 2024-08-02 A | 2024-08-13 A | 2070FS+4d | 100% |  |  |
| 2072 |  | Final CCAG review | 6d | 2024-08-14 A | 2024-08-21 A | 2071 | 100% |  |  |
| 2073 |  | CCAG recommend final code to PSG for baselining | 0d | 2024-08-21 A | 2024-08-21 A | 2072 | 100% |  |  |
| 2074 |  | Code changes baselined (M6) | 0d | 2024-08-23 A | 2024-08-23 A | 2072FS+2d, 2064, 2051, 2039, 2030, 2021, 2012, 2003, 1994, 1985 | 100% |  |  |
| 2075 | 1.7.2 | **Ofgem preparation and enactment of SCR powers** | 225d | 2024-02-05 A | 2024-12-13 |  | 71% | 789d |  |
| 2076 | 1.7.2.1 | **Preparation and enactment of SCR Powers** | 223d | 2024-02-05 A | 2024-12-11 |  | 72% | 726d |  |
| 2077 |  | Ofgem to keep Ofgem legal informed of process followed and nature of Code drafting to ensure that prepared for SCR go/no go decision | 101d | 2024-02-05 A | 2024-06-24 A | 2078SF | 100% |  |  |
| 2078 |  | OFGEM Legal to review Code Artefacts deliver policy intent and process followed and confirm that SCR powers are appropriate to use rather than SMAP - SCR go/no go | 14d | 2024-06-24 A | 2024-07-11 A | 2069SS | 100% |  |  |
| 2079 |  | Code Bodies to draft MOD proposal forms | 20d | 2024-07-12 A | 2024-08-08 A | 2078 | 100% |  |  |
| 2080 |  | Ofgem discuss and agree code mod timetable with code bodies (and MHHSP in relation to the dates for expected decisions) | 20d | 2024-07-12 A | 2024-08-08 A | 2078 | 100% |  |  |
| 2081 |  | Ofgem to publish each Direction to each code body specifying the timetable for each modification | 1d | 2024-08-28 A | 2024-08-28 A | 2080FS+13d | 100% |  |  |
| 2082 |  | Formally submit (by separate email) Modification Proposal Forms and legal texts to each code body | 1d | 2024-08-28 A | 2024-08-28 A | 2080FS+13d | 100% |  |  |
| 2083 |  | Each Code Body publishes and issues Modification Proposal Forms | 3d | 2024-08-29 A | 2024-09-02 A | 2082, 2081 | 100% |  |  |
| 2084 |  | Each Code Body sends Modification Proposal Forms to Panel to approve Mod to go to consultation | 10d | 2024-09-03 A | 2024-09-16 | 2083 | 33% | 726d |  |
| 2085 |  | Modification Proposal approved by Panel for Consultation | 1d | 2024-09-17 | 2024-09-17 | 2084 |  | 726d |  |
| 2086 |  | Draft Modification Report issued for consultation | 1d | 2024-09-18 | 2024-09-18 | 2085 |  | 726d |  |
| 2087 |  | Consultation Close-out for representations | 15d | 2024-09-19 | 2024-10-09 | 2086 |  | 726d |  |
| 2088 |  | Each Code Body reviews consultation response and drafts Modification Report | 10d | 2024-10-10 | 2024-10-23 | 2087 |  | 726d |  |
| 2089 |  | Final Modification Report sent to Panel for decision with recommendation to approve | 1d | 2024-10-24 | 2024-10-24 | 2088 |  | 726d |  |
| 2090 |  | Modification Panel decision | 1d | 2024-11-07 | 2024-11-07 | 2089FS+9d |  | 726d |  |
| 2091 |  | Code Bodies Submit Final Modification/Change Reports | 1d | 2024-11-08 | 2024-11-08 | 2090 |  | 726d |  |
| 2092 |  | Ofgem Reviews Final Modification/Change Reports | 10d | 2024-11-11 | 2024-11-22 | 2091 |  | 726d |  |
| 2093 |  | Ofgem Drafts Decision/Direction Letters | 17d | 2024-11-18 | 2024-12-10 | 2092SS+5d |  | 726d |  |
| 2094 |  | Ofgem Internally Signs Off the Decision/Direction Letters and Sends Them to the Code Bodies | 1d | 2024-12-11 | 2024-12-11 | 2093 |  | 726d |  |
| 2095 |  | Ofgem decisions on M6 baselined code modification proposals (M7) | 0d | 2024-12-11 | 2024-12-11 | 2074, 2094 |  | 726d |  |
| 2096 |  | Ofgem Publishes the Decisions/Directions | 2d | 2024-12-12 | 2024-12-13 | 2095 |  | 789d |  |
| 2097 | 1.7.3 | **Deliver MHHS Code Changes** | 292d | 2024-11-12 | 2025-12-24 |  |  | 521d |  |
| 2098 | 1.7.3.1 | **Releases** | 292d | 2024-11-12 | 2025-12-24 |  |  | 521d |  |
| 2099 |  | Impacted codes make resourcing provisions and prepare to implement new Code via internal code body change processes | 78d | 2024-11-12 | 2025-02-27 |  |  | 735d | start no earlier than 2024-11-12 |
| 2100 | 1.7.3.1.2 | **Main Code Release** | 71d | 2025-09-17 | 2025-12-24 |  |  | 521d |  |

| ID | WBS | Task | Duration | Start | Finish | Predecessors | Complete | Total float | Constraint |
| --- | --- | --- | --- | --- | --- | --- | --- | --- | --- |
| 2101 |  | Release preparation (e.g. preparing release documentation) | 6d | 2025-09-17 | 2025-09-24 | 2102SF |  | 586d |  |
| 2102 |  | Implement new code on day of code release | 0d | 2025-09-24 | 2025-09-24 | 2103SF |  | 586d |  |
| 2103 |  | Code changes delivered (M8) | 0d | 2025-09-24 | 2025-09-24 | 2095, 2074, 1493SS |  | 521d |  |
| 2104 |  | Code changes delivered (M8*) late exit | 0d | 2025-12-24 | 2025-12-24 | 2103FS+65d |  | 521d |  |
| 2105 | 1.7.4 | **External Programme Dependency Management** | 38d | 2023-12-01 A | 2024-01-24 A |  | 100% |  |  |
| 2106 | 1.7.4.1 | **DCP397** | 38d | 2023-12-01 A | 2024-01-24 A |  | 100% |  |  |
| 2107 |  | Ensure DCP397 drafting included in mop-up code drafting activity (link to mop-up) | 20d | 2023-12-01 A | 2023-12-28 A | 2058SS, 2055SS | 100% |  |  |
| 2108 |  | Implementation of DCP397 | 0d | 2024-01-24 A | 2024-01-24 A |  | 100% |  | start no earlier than 2024-01-24 |
| 2109 | 1.8 | **MIGRATION** | 1246d | 2022-10-31 A | 2027-08-09 |  | 35% | 98d |  |
| 2110 |  | Migration Period Plan Review 1 Completed | 0d | 2025-01-31 | 2025-01-31 |  |  | 754d | finish no earlier than 2025-01-31 |
| 2111 | 1.8.2 | **Regulatory Governance** | 198d | 2024-04-01 A | 2025-01-01 |  | 47% | 776d |  |
| 2112 |  | Incentive Mods Created | 110d | 2024-04-01 A | 2024-08-30 |  | 85% | 776d | start no earlier than 2024-04-01 |
| 2113 |  | Incentives Implemented | 88d | 2024-09-02 | 2025-01-01 | 2112 |  | 776d | start no earlier than 2024-07-02 |
| 2114 | 1.8.3 | **Migration Framework Agreed and Implemented** | 256d | 2024-02-01 A | 2025-01-23 |  | 62% | 121d |  |
| 2115 | 1.8.3.1 | **Consultation 1 - Schedule** | 70d | 2024-02-01 A | 2024-05-08 A |  | 100% |  |  |
| 2116 |  | Prepare Artefacts for Consultation | 33d | 2024-02-01 A | 2024-03-18 A |  | 100% |  |  |
| 2117 |  | Industry Consultation | 16d | 2024-03-18 A | 2024-04-08 A |  | 100% |  |  |
| 2118 |  | Triage and Action Comments | 10d | 2024-04-08 A | 2024-04-19 A |  | 100% |  |  |
| 2119 |  | Industry Assurance Review | 6d | 2024-04-19 A | 2024-04-26 A |  | 100% |  |  |
| 2120 |  | MWG Recommendation | 1d | 2024-04-26 A | 2024-04-26 A |  | 100% |  |  |
| 2121 |  | MCAG Interim Approval Artefacts | 1d | 2024-05-08 A | 2024-05-08 A |  | 100% |  |  |
| 2122 | 1.8.3.2 | **Consultation 2 - Control** | 79d | 2024-04-08 A | 2024-07-25 A |  | 100% |  |  |
| 2123 |  | Prepare Artefacts for Consultation | 49d | 2024-04-08 A | 2024-06-13 A |  | 100% |  |  |
| 2124 |  | Industry Consultation | 11d | 2024-06-14 A | 2024-06-28 A | 2123 | 100% |  |  |
| 2125 |  | Triage and Action Comments | 9d | 2024-07-01 A | 2024-07-11 A | 2124 | 100% |  |  |
| 2126 |  | Industry Assurance Review | 5d | 2024-07-12 A | 2024-07-18 A | 2125 | 100% |  |  |
| 2127 |  | MWG Recommendation | 0d | 2024-07-18 A | 2024-07-18 A | 2126 | 100% |  |  |
| 2128 |  | Consultation 2 - Control - MCAG Approval of Interim Artefacts | 0d | 2024-07-25 A | 2024-07-25 A | 2127FS+5d | 100% |  |  |
| 2129 | 1.8.3.3 | **Consultation 3 - Parameters** | 143d | 2024-07-09 A | 2025-01-23 |  | 18% | 121d |  |
| 2130 |  | Prepare Artefacts (9) for Consultation | 95d | 2024-07-09 A | 2024-11-18 | 2137SS+6d | 23% | 121d |  |
| 2131 |  | Industry Consultation | 10d | 2024-11-19 | 2024-12-02 | 2130 |  | 121d |  |
| 2132 |  | Triage and Action Comments | 10d | 2024-12-03 | 2024-12-16 | 2131 |  | 121d |  |
| 2133 |  | Industry Assurance Review | 7d | 2024-12-17 | 2024-12-25 | 2132 |  | 121d |  |
| 2134 |  | MWG Recommendation | 0d | 2025-01-06 | 2025-01-06 | 2133FS+8d |  | 121d |  |
| 2135 |  | MCAG Approval of Migration Framework Artefacts (Baselined) | 0d | 2025-01-23 | 2025-01-23 | 2138, 2134FS+13d |  | 121d |  |
| 2136 | 1.8.4 | **Migration Schedule Agreed and Maintained** | 415d | 2024-07-01 A | 2026-01-30 |  | 14% | 494d |  |
| 2137 |  | Indicative Envelopes Issued | 23d | 2024-07-01 A | 2024-07-31 A | 2121FS+37d | 100% |  |  |
| 2138 |  | Supplier Submissions | 45d | 2024-08-01 A | 2024-10-02 | 2137, 2128 | 11% | 202d |  |
| 2139 |  | Team Assess Responses | 10d | 2024-10-03 | 2024-10-16 | 2138 |  | 552d |  |
| 2140 |  | Discuss and Agree Approach with Participants where necessary | 4d | 2024-10-17 | 2024-10-22 | 2139 |  | 552d |  |
| 2141 |  | V1.0 of Migration Schedule Baseline Approved at MCAG | 0d | 2025-01-10 | 2025-01-10 | 2150, 2140 |  | 494d |  |
| 2142 |  | Sprint Planning (Cycle 1) | 40d | 2025-06-16 | 2025-08-08 | 2141FS+110d |  | 494d |  |
| 2143 |  | Sprint Planning (Cycle 2) | 40d | 2025-09-15 | 2025-11-07 | 2142FS+25d |  | 494d |  |
| 2144 |  | Sprint Planning (Cycle 3) | 40d | 2025-12-08 | 2026-01-30 | 2143FS+20d, 2158 |  | 494d |  |
| 2145 | 1.8.5 | **Migration Control Centre Tooling** | 242d | 2024-05-09 A | 2025-04-11 |  | 30% | 112d |  |
| 2146 |  | Data Source Definition | 120d | 2024-05-09 A | 2024-10-23 | 2121 | 46% | 112d |  |
| 2147 |  | Scheduling and Data Requirements | 120d | 2024-05-09 A | 2024-10-23 | 2121 | 46% | 112d |  |
| 2148 |  | Tool Phase 1 | 11d | 2024-10-24 | 2024-11-07 | 2147, 2146 |  | 112d |  |
| 2149 |  | Data Requirements | 21d | 2024-11-08 | 2024-12-06 | 2121, 2148 |  | 112d |  |
| 2150 |  | Tool Phase 2 | 25d | 2024-12-09 | 2025-01-10 | 2149 |  | 112d |  |
| 2151 |  | Data Source Provision | 7d | 2025-01-13 | 2025-01-21 | 2150 |  | 112d |  |
| 2152 |  | Tool - Internal and External Testing | 58d | 2025-01-22 | 2025-04-11 | 2151 |  | 112d |  |
| 2153 | 1.8.6 | **Migration Control Centre Mobilised and Ready** | 185d | 2024-07-30 A | 2025-04-14 |  | 1% | 112d |  |
| 2154 |  | Migration Control Centre TOM Definition | 65d | 2024-07-30 A | 2024-10-28 | 2128FS+2d | 3% | 126d |  |
| 2155 |  | Access to Data | 25d | 2024-11-04 | 2024-12-06 | 2154FS+4d |  | 126d |  |
| 2156 |  | Migration Control Centre Delegation of Authority | 12d | 2024-12-24 | 2025-01-08 | 2155FS+11d |  | 126d |  |
| 2157 |  | Recruit and Train | 65d | 2024-12-24 | 2025-03-24 | 2156SS |  | 126d |  |
| 2158 |  | Dress Rehearsal | 1d | 2025-04-14 | 2025-04-14 | 2152, 2157, 2162, 2163 |  | 112d |  |
| 2159 | 1.8.7 | **PP's Prepared for Migration** | 196d | 2024-07-01 A | 2025-03-31 |  | 23% | 121d |  |
| 2160 |  | Prep for Envelope Webinar | 26d | 2024-07-01 A | 2024-08-05 A | 2137SS | 100% |  |  |
| 2161 |  | Envelope/Submission Webinar | 1d | 2024-08-05 A | 2024-08-05 A | 2160FF | 100% |  |  |
| 2162 |  | Guides Creation | 45d | 2025-01-28 | 2025-03-31 | 2135FS+2d |  | 121d |  |
| 2163 |  | Support Channels | 45d | 2025-01-28 | 2025-03-31 | 2135FS+2d |  | 121d |  |
| 2164 | 1.8.8 | **Migration Artefact Development and Publication** | 743d | 2022-10-31 A | 2025-09-03 |  | 80% | 601d |  |
| 2165 | 1.8.8.1 | **Migration Approach** | 28d | 2022-10-31 A | 2022-12-07 A |  | 100% |  |  |
| 2166 |  | Option analysis (via MWG and PPIR) and recommendation | 23d | 2022-10-31 A | 2022-11-30 A |  | 100% |  |  |
| 2167 |  | Migration Approach approved | 0d | 2022-12-07 A | 2022-12-07 A | 2166FS+5d | 100% |  |  |
| 2168 | 1.8.8.2 | **Migration Design** | 100d | 2022-11-14 A | 2023-03-31 A |  | 100% |  |  |
| 2169 |  | Review and update existing design artefacts and socialise with participants ahead of MDSG | 10d | 2022-11-14 A | 2022-11-25 A |  | 100% |  |  |
| 2170 |  | Develop design artefacts and supporting technical documents in line with MDSG | 53d | 2022-11-30 A | 2023-02-10 A | 2169FS+2d | 100% |  |  |

| ID | WBS | Task | Duration | Start | Finish | Predecessors | Complete | Total float | Constraint |
| --- | --- | --- | --- | --- | --- | --- | --- | --- | --- |
| 2171 |  | Migration design artefacts issued for consultation | 0d | 2023-02-13 A | 2023-02-13 A | 2170FS+1d | 100% |  |  |
| 2172 |  | Industry consultation | 5d | 2023-02-14 A | 2023-02-20 A | 2171SS | 100% |  |  |
| 2173 |  | Review consultation feedback, address comments and update artefacts | 5d | 2023-02-21 A | 2023-02-27 A | 2172 | 100% |  |  |
| 2174 |  | Internal artefact review and comms preparation | 3d | 2023-02-28 A | 2023-03-02 A | 2173 | 100% |  |  |
| 2175 |  | Updated Migration Design artefacts issued to PPs for assurance review | 0d | 2023-03-03 A | 2023-03-03 A | 2174FS+1d | 100% |  |  |
| 2176 |  | Final Migration Design artefacts walkthrough with PPs | 0d | 2023-03-22 A | 2023-03-22 A | 2175FS+13d | 100% |  |  |
| 2177 |  | Migration Design approved | 0d | 2023-03-31 A | 2023-03-31 A | 2176FS+7d | 100% |  |  |
| 2178 | 1.8.8.3 | **Transition Design** | 186d | 2023-03-01 A | 2023-11-15 A |  | 100% |  |  |
| 2179 | 1.8.8.3.1 | **Tranche 1** | 56d | 2023-03-01 A | 2023-05-17 A |  | 100% |  |  |
| 2180 |  | Develop design artefacts and supporting technical details with participants | 50d | 2023-03-01 A | 2023-05-09 A |  | 100% |  |  |
| 2181 |  | Issue Material for DAG approval | 1d | 2023-05-10 A | 2023-05-10 A | 2180 | 100% |  |  |
| 2182 |  | Tranche 1 Transition Design approved | 0d | 2023-05-17 A | 2023-05-17 A | 2181FS+5d | 100% |  |  |
| 2183 | 1.8.8.3.2 | **Tranche 2** | 130d | 2023-05-18 A | 2023-11-15 A |  | 100% |  |  |
| 2184 |  | Develop Initial design artefacts and supporting technical details | 76d | 2023-05-18 A | 2023-08-31 A | 2182 | 100% |  |  |
| 2185 |  | Communicate Initial Design Artefacts with Industry (MTDSG) | 1d | 2023-09-01 A | 2023-09-01 A | 2184 | 100% |  |  |
| 2186 |  | Host MTDSG | 1d | 2023-09-11 A | 2023-09-11 A | 2185FS+5d | 100% |  |  |
| 2187 |  | Process MTDSG Feedback and Amend Design Artefacts | 4d | 2023-09-12 A | 2023-09-15 A | 2186 | 100% |  |  |
| 2188 |  | Communicate Amended Design Artefacts with Industry | 1d | 2023-09-15 A | 2023-09-15 A | 2187FF | 100% |  |  |
| 2189 |  | Host MTDSG | 1d | 2023-09-26 A | 2023-09-26 A | 2188FS+6d | 100% |  |  |
| 2190 |  | Make Final Amendments to Design Artefact | 5d | 2023-09-27 A | 2023-10-03 A | 2189 | 100% |  |  |
| 2191 |  | Request DAG Consultation | 1d | 2023-10-04 A | 2023-10-04 A | 2190 | 100% |  |  |
| 2192 |  | Consultation Period | 11d | 2023-10-04 A | 2023-10-18 A | 2191SS | 100% |  |  |
| 2193 |  | Action Consultation Comments | 5d | 2023-10-19 A | 2023-10-25 A | 2192 | 100% |  |  |
| 2194 |  | Post Consultation Industry Assurance | 5d | 2023-10-26 A | 2023-11-01 A | 2193 | 100% |  |  |
| 2195 |  | Request DAG Approval | 1d | 2023-11-01 A | 2023-11-01 A | 2194FF | 100% |  |  |
| 2196 |  | DAG Transition Design Approved | 1d | 2023-11-08 A | 2023-11-08 A | 2195FS+4d | 100% |  |  |
| 2197 |  | Update Transition Design Admin | 5d | 2023-11-09 A | 2023-11-15 A | 2196 | 100% |  |  |
| 2198 |  | Tranche 2 Transition Design Baselined | 0d | 2023-11-15 A | 2023-11-15 A | 2197 | 100% |  |  |
| 2199 | 1.8.8.4 | **Data Assessment Report** | 61d | 2022-12-06 A | 2023-02-28 A |  | 100% |  |  |
| 2200 |  | Develop document with MWG | 49d | 2022-12-06 A | 2023-02-10 A |  | 100% |  |  |
| 2201 |  | Artefact review (via TMAG) and updates | 25d | 2023-01-18 A | 2023-02-21 A | 2200FS-18d | 100% |  |  |
| 2202 |  | Data Assessment Report approved | 0d | 2023-02-28 A | 2023-02-28 A | 2201FS+5d | 100% |  |  |
| 2203 | 1.8.8.5 | **Migration, Cutover & Data Strategy (incl. Migration Entry Criteria)** | 102d | 2022-12-08 A | 2023-04-28 A |  | 100% |  |  |
| 2204 |  | Develop document with MWG | 67d | 2022-12-08 A | 2023-03-10 A | 2167 | 100% |  |  |
| 2205 |  | Artefact review (via TMAG) and updates | 28d | 2023-03-15 A | 2023-04-21 A | 2204FS+2d | 100% |  |  |
| 2206 |  | Migration, Cutover & Data Strategy approved | 0d | 2023-04-28 A | 2023-04-28 A | 2205FF+5d | 100% |  |  |
| 2207 | 1.8.8.6 | **Data Cleanse Plan** | 655d | 2023-03-02 A | 2025-09-03 |  | 65% | 601d |  |
| 2208 |  | Develop document with MWG | 50d | 2023-03-02 A | 2023-05-10 A |  | 100% |  |  |
| 2209 |  | Artefact review (via TMAG) and updates | 20d | 2023-05-11 A | 2023-06-07 A | 2208 | 100% |  |  |
| 2210 |  | Data Cleanse Plan approved | 0d | 2023-07-19 A | 2023-07-19 A | 2209FS+30d | 100% |  |  |
| 2211 |  | Monitor Programme Participant adherence to Data Cleanse Plan | 467d | 2023-06-15 A | 2025-03-28 | 2210 | 64% | 714d |  |
| 2212 | 1.8.8.6.5 | **MTDs** | 120d | 2024-08-16 A | 2025-01-31 |  | 45% | 754d |  |
| 2213 | 1.8.8.6.5.1 | **ESME ID** | 90d | 2024-08-16 A | 2024-12-20 |  |  | 784d |  |
| 2214 |  | DCC to extract ESME ID and share with LDSO | 0d | 2024-08-16 A | 2024-08-16 A | 2210FS+282d | 100% |  |  |
| 2215 |  | LDSO ‘full refresh’ between their Registration Service and the EES (ESME ID) | 16d | 2024-10-21 | 2024-11-11 | 2214FS+45d |  | 784d |  |
| 2216 |  | Suppliers complete investigation of exceptions and resolution of exceptions | 1d | 2024-12-20 | 2024-12-20 | 2215FS+28d |  | 784d |  |
| 2217 |  | ESME ID Complete | 0d | 2024-12-20 | 2024-12-20 | 2216 |  | 784d |  |
| 2218 | 1.8.8.6.5.2 | **Meter Location and Number of Displayed Register Digits** | 101d | 2024-09-13 A | 2025-01-31 |  | 78% | 754d |  |
| 2219 |  | MEM to extract data and share with LDSO | 6d | 2024-09-13 A | 2024-09-20 A | 2210FS+301d | 100% |  |  |
| 2220 |  | LDSO ‘full refresh’ between their Registration Service and the EES (Meter Location and Number of Displayed Register Digits) | 16d | 2024-10-28 A | 2024-11-18 | 2219FS+25d | 75% | 754d |  |
| 2221 |  | Suppliers complete investigation of exceptions and resolution of exceptions | 1d | 2025-01-31 | 2025-01-31 | 2220FS+53d |  | 754d |  |
| 2222 |  | Meter Location and Number of Displayed Register Digits Complete | 0d | 2025-01-31 | 2025-01-31 | 2221 |  | 754d |  |
| 2223 | 1.8.8.6.6 | **Registration Data** | 259d | 2024-09-06 A | 2025-09-03 |  | 5% | 601d |  |
| 2224 | 1.8.8.6.6.1 | **Connection Type** | 47d | 2024-09-06 A | 2024-11-11 |  | 6% | 813d |  |
| 2225 |  | Automated Population of Connection Type for Measurement Classes ‘B’, ‘D’, ‘F’ & ‘G’ | 0d | 2024-10-04 A | 2024-10-04 A | 2210FS+317d | 100% |  | start no earlier than 2024-09-13 |
| 2226 |  | BAU Population of Connection Type for Site Specific LLFCs within Measurement Classes ‘C’ & ‘E’ | 0d | 2024-10-04 A | 2024-10-04 A | 2210FS+317d | 100% |  |  |
| 2227 |  | Automated Population of Connection Type for Smart Meters within Measurement Class ‘A’ | 0d | 2024-10-04 A | 2024-10-04 A | 2210FS+317d | 100% |  |  |
| 2228 |  | Population of Connection Type for Traditional and Advanced Meters within Measurement Class ‘A’ | 1d | 2024-09-06 A | 2024-09-06 A | 2210FS+296d | 100% |  |  |
| 2229 |  | Automated Population of Null Connection Type | 0d | 2024-10-04 A | 2024-10-04 A | 2210FS+317d | 100% |  |  |
| 2230 |  | Full MPAN refresh to ESS | 16d | 2024-10-21 | 2024-11-11 | 2210FS+327d |  | 813d |  |
| 2231 |  | Connection Type Complete | 0d | 2024-11-11 | 2024-11-11 | 2225, 2226, 2227, 2228, 2229, 2230 |  | 813d |  |
| 2232 | 1.8.8.6.6.2 | **Domestic Premises Indicator** | 19d | 2025-08-08 | 2025-09-03 |  |  | 601d |  |
| 2233 |  | The DCC to extract Domestic Premises Indicator from the CSS and provide a file to each LDSO and EES. | 2d | 2025-08-08 | 2025-08-11 |  |  | 601d | start no earlier than 2025-08-08 |
| 2234 |  | Each LDSO notifies the DCC of any exceptions | 1d | 2025-08-12 | 2025-08-12 | 2233 |  | 601d |  |
| 2235 |  | Each LDSO and DCC completes investigation and resolution of exceptions | 1d | 2025-09-03 | 2025-09-03 | 2233FS+15d, 2234FS+15d |  | 601d |  |
| 2236 |  | Domestic Premises Indicator Complete | 0d | 2025-09-03 | 2025-09-03 | 2235 |  | 601d |  |
| 2237 | 1.8.8.6.7 | **Export / Import MPANs** | 151d | 2024-03-22 A | 2024-10-18 |  | 99% | 829d |  |
| 2238 | 1.8.8.6.7.1 | **Linking of Export / Import MPANS** | 151d | 2024-03-22 A | 2024-10-18 |  | 99% | 829d |  |
| 2239 |  | LDSO utilises BAU processing (DB05s) to populate each import/export association | 1d | 2024-03-22 A | 2024-03-22 A | 2210FS+176d | 100% |  |  |
| 2240 |  | Each LDSO notifies the Registered Supplier of any exceptions | 1d | 2024-04-19 A | 2024-04-19 A | 2239FS+19d | 100% |  |  |

| ID | WBS | Task | Duration | Start | Finish | Predecessors | Complete | Total float | Constraint |
| --- | --- | --- | --- | --- | --- | --- | --- | --- | --- |
| 2241 |  | Each Supplier completes investigation and resolution of exceptions | 1d | 2024-08-23 A | 2024-08-23 A | 2240FS+89d | 100% |  |  |
| 2242 |  | Each LDSO has linked al relevant import/export MPANS | 0d | 2024-10-18 | 2024-10-18 | 2241FS+40d |  | 829d |  |
| 2243 |  | Linking of Export / Import MPANS Complete | 0d | 2024-10-18 | 2024-10-18 | 2242 |  | 829d |  |
| 2244 |  | Pre-migration data cleanse complete | 0d | 2025-08-13 | 2025-08-13 |  |  | 617d | start no earlier than 2025-08-13 |
| 2245 | 1.8.9 | **Migration Period Planning** | 367d | 2023-07-03 A | 2024-11-26 |  | 83% | 678d |  |
| 2246 | 1.8.9.1 | **Migration Implementation Plan (incl. Migration Exit Criteria)** | 367d | 2023-07-03 A | 2024-11-26 |  | 83% | 678d |  |
| 2247 | 1.8.9.1.1 | **Migration Threshold Volumes** | 101d | 2023-07-03 A | 2023-11-20 A |  | 100% |  |  |
| 2248 |  | Threshold volumes reviewed by MWG | 54d | 2023-07-03 A | 2023-09-14 A |  | 100% |  |  |
| 2249 |  | Artefact review (via TMAG) and updates | 47d | 2023-09-15 A | 2023-11-20 A | 2248 | 100% |  |  |
| 2250 |  | Threshold volumes approved at TMAG | 0d | 2023-11-20 A | 2023-11-20 A | 2249 | 100% |  |  |
| 2251 | 1.8.9.1.2 | **Define acceptance criteria for M15** | 78d | 2023-09-04 A | 2023-12-20 A |  | 100% |  |  |
| 2252 |  | Review acceptance criteria and reporting requirements with MWG | 49d | 2023-09-04 A | 2023-11-09 A |  | 100% |  | start no earlier than 2023-09-04 |
| 2253 |  | Artefact review (via TMAG) and updates | 29d | 2023-11-10 A | 2023-12-20 A | 2252 | 100% |  | start no earlier than 2023-10-30 |
| 2254 |  | Acceptance criteria for M15 agreed at TMAG | 0d | 2023-12-20 A | 2023-12-20 A | 2253 | 100% |  | finish no earlier than 2023-11-30 |
| 2255 | 1.8.9.1.3 | **M10/M11 cut-over plan** | 119d | 2023-12-21 A | 2024-06-04 A |  | 100% |  |  |
| 2256 |  | Draft Document | 84d | 2023-12-21 A | 2024-04-16 A | 2254 | 100% |  |  |
| 2257 |  | Share Document with SRO | 1d | 2024-04-17 A | 2024-04-17 A | 2256 | 100% |  |  |
| 2258 |  | Industry Consultation | 11d | 2024-04-23 A | 2024-05-07 A | 2257FS+3d | 100% |  |  |
| 2259 |  | Assurance Meeting | 1d | 2024-05-21 A | 2024-05-21 A | 2258FS+9d | 100% |  |  |
| 2260 |  | MCAG Approval of M10/M11 Cut-over Plan | 0d | 2024-06-04 A | 2024-06-04 A | 2259FS+10d | 100% |  |  |
| 2261 | 1.8.9.1.4 | **M16 Methodology** | 85d | 2024-07-31 A | 2024-11-26 |  | 10% | 678d |  |
| 2262 |  | Draft Document | 50d | 2024-07-31 A | 2024-10-08 |  | 12% | 678d |  |
| 2263 |  | Share Document with SRO | 1d | 2024-10-09 | 2024-10-09 | 2262 |  | 678d |  |
| 2264 |  | Industry Consultation | 11d | 2024-10-15 | 2024-10-29 | 2263FS+3d |  | 678d |  |
| 2265 |  | Assurance Meeting | 1d | 2024-11-12 | 2024-11-12 | 2264FS+9d |  | 678d |  |
| 2266 |  | M16 methodology approved | 0d | 2024-11-26 | 2024-11-26 | 2265FS+10d |  | 678d |  |
| 2267 | 1.8.10 | **Preparation for Cutover to Live** | 344d | 2024-06-28 A | 2025-10-22 |  |  | 566d |  |
| 2268 | 1.8.10.1 | **Central Systems Prepare for Cutover to Live** | 326d | 2024-06-28 A | 2025-09-26 |  |  | 584d |  |
| 2269 |  | DCC (Functionality available June 2024) | 0d | 2024-06-28 A | 2024-06-28 A |  | 100% |  | start no earlier than 2024-06-28 |
| 2270 | 1.8.10.1.2 | **Development of Comms Approach and Declaration Guidance** | 79d | 2025-03-03 | 2025-06-19 |  |  | 74d |  |
| 2271 |  | Draft Cutover Comms Approach | 59d | 2025-03-03 | 2025-05-22 |  |  | 74d | start no earlier than 2025-03-03 |
| 2272 |  | Draft Cutover Comms Approach shared | 0d | 2025-05-22 | 2025-05-22 | 2271 |  | 74d |  |
| 2273 |  | Development of Implementation Group | 59d | 2025-03-03 | 2025-05-22 |  |  | 74d | start no earlier than 2025-03-03 |
| 2274 |  | Implementation Group Established | 0d | 2025-05-22 | 2025-05-22 | 2273 |  | 74d |  |
| 2275 |  | Finalised Cutover Comms Approach shared | 0d | 2025-06-19 | 2025-06-19 | 2272FS+20d, 2274FS+20d |  | 74d |  |
| 2276 | 1.8.10.1.3 | **Development of Cutover Plan requirements with Participants** | 113d | 2025-03-03 | 2025-08-06 |  |  | 40d |  |
| 2277 |  | Development of SIT Participant Cutover Plans | 59d | 2025-03-03 | 2025-05-22 |  |  | 40d | start no earlier than 2025-03-03 |
| 2278 |  | SIT Participant Cutover Plans Ready | 0d | 2025-05-22 | 2025-05-22 | 2277 |  | 40d |  |
| 2279 |  | Programme SIT Participant Cutover Plan Assurance | 44d | 2025-06-06 | 2025-08-06 | 2278FS+10d |  | 40d |  |
| 2280 | 1.8.10.1.4 | **M10/M11 Cutover Activities** | 119d | 2025-04-14 | 2025-09-26 |  |  | 112d |  |
| 2281 |  | Production DIP Portal (DIP Deployment) | 0d | 2025-09-05 | 2025-09-05 | 1356FS+10d |  | 13d |  |
| 2282 |  | Production Certificates (DIP Deployment) | 0d | 2025-09-05 | 2025-09-05 | 1356FS+10d |  | 13d |  |
| 2283 |  | Completion of the pre-M10 MHHS Data Cleanse | 0d | 2025-09-24 | 2025-09-24 | 1493 |  | 586d |  |
| 2284 |  | Market-wide Participant MHHS Supporting Functionality Ready - Confirmation from Code Bodies | 0d | 2025-09-15 | 2025-09-15 | 1493FS-8d |  | 594d |  |
| 2285 |  | Market-wide Participant MHHS Supporting Functionality Ready | 0d | 2025-09-22 | 2025-09-22 | 1493FS-3d |  | 589d |  |
| 2286 |  | Elexon Central Services Deployment | 0d | 2025-09-19 | 2025-09-19 | 2308 |  | 5d |  |
| 2287 |  | Service Management Go-Live | 0d | 2025-09-19 | 2025-09-19 | 2308 |  | 5d |  |
| 2288 |  | Data Transfer Service (DTS) New Functionality Deployment | 0d | 2025-09-19 | 2025-09-19 | 2308 |  | 5d |  |
| 2289 |  | Electricity Enquiry Service (EES) Deployment | 0d | 2025-09-19 | 2025-09-19 | 2308 |  | 5d |  |
| 2290 |  | MPRS, UMSO Role, LDSO Role Operational | 0d | 2025-09-19 | 2025-09-19 | 2308 |  | 5d |  |
| 2291 |  | Population of Domestic Premises Indicator | 0d | 2025-09-19 | 2025-09-19 | 2308 |  | 5d |  |
| 2292 |  | Population of Market Segment | 0d | 2025-09-19 | 2025-09-19 | 2308 |  | 5d |  |
| 2293 |  | Early Life Support Implemented | 0d | 2025-09-19 | 2025-09-19 | 2308 |  | 8d |  |
| 2294 |  | MCC Tested and Ready to Operate | 0d | 2025-04-14 | 2025-04-14 | 2158 |  | 112d |  |
| 2295 |  | MCC Operational | 0d | 2025-04-14 | 2025-04-14 | 2294 |  | 122d |  |
| 2296 |  | Central Systems live and Codes designated at 00:00 | 0d | 2025-09-22 | 2025-09-22 | 2286FS+1d, 2287FS+1d, 2288FS+1d, 2289FS+1d, 2290FS+1d, 2291FS+1d, 2292FS+1d, 2269FS+1d |  | 5d |  |
| 2297 |  | SIT Participant Qualification - The final date by which participant qualification status can be confirmed for participants to be ready for the start of Migration at M11. | 0d | 2025-09-26 | 2025-09-26 | 1356FS+25d |  | 16d |  |
| 2298 | 1.8.10.2 | **Cutover Governance M10** | 41d | 2025-07-30 | 2025-09-24 |  |  | 39d |  |
| 2299 |  | Confirmation that Pre-migration Data Cleanse Activities have successfully taken place | 0d | 2025-07-30 | 2025-07-30 |  |  | 41d | start no earlier than 2025-07-30 |
| 2300 |  | Confirmation of Helix E2E Settlement Testing Complete | 0d | 2025-08-01 | 2025-08-01 | 1285FS+85d |  | 38d |  |
| 2301 |  | Confirmation of assurance of Helix E2E Settlement Testing | 0d | 2025-08-01 | 2025-08-01 | 1287FS+85d |  | 38d |  |
| 2302 |  | Confirmation of Qualification Status for SIT MVC | 0d | 2025-09-12 | 2025-09-12 | 1356FS+15d |  | 6d |  |
| 2303 |  | Confirmation of Qualification Status for Non-SIT LDSOs | 0d | 2025-09-15 | 2025-09-15 | 2308FS-5d |  | 594d |  |
| 2304 |  | Confirmation of Qualification Status of at least one Supplier and their contracted Agents | 0d | 2025-09-12 | 2025-09-12 | 2302 |  | 6d |  |
| 2305 |  | Declaration from all Central Services and LDSOs that they are in a position to move forwards | 0d | 2025-09-15 | 2025-09-15 | 2308FS-5d, 1285, 1287 |  | 594d |  |
| 2306 |  | Market-wide Participant MHHS Migration Supporting Functionality is Live | 0d | 2025-09-15 | 2025-09-15 | 2284 |  | 594d |  |
| 2307 |  | TORWG (Recommendation from TORWG that the Programme should enter M10) | 0d | 2025-09-16 | 2025-09-16 | 2299, 2302FS+2d, 2304FS+2d, 2281, 2282, 2390, 2300, 2301 |  | 6d |  |
| 2308 |  | MCAG (Confirm that the Programme can Enter M10) | 0d | 2025-09-19 | 2025-09-19 | 2307FS+2d, 2396 |  | 5d |  |
| 2309 |  | Self-Declaration from all Central Services and LDSOs that Cutover activities have been successfully carried out | 0d | 2025-09-22 | 2025-09-22 | 2308FS+1d |  | 5d |  |
| 2310 |  | Confirmation that DIP and ECS have been deployed, Service management is active, ISD has been populated | 0d | 2025-09-22 | 2025-09-22 | 2308FS+1d |  | 5d |  |

| ID | WBS | Task | Duration | Start | Finish | Predecessors | Complete | Total float | Constraint |
| --- | --- | --- | --- | --- | --- | --- | --- | --- | --- |
| 2311 |  | Self-Declarations against all M10 Data Cleanse Activities | 0d | 2025-09-22 | 2025-09-22 | 2308FS+1d |  | 5d |  |
| 2312 |  | IF-047 has been sent | 0d | 2025-09-22 | 2025-09-22 | 2308FS+1d |  | 5d |  |
| 2313 |  | Recommendation from TORWG that PSG should approve M10 | 0d | 2025-09-23 | 2025-09-23 | 2309FS+1d, 2310FS+1d, 2311FS+1d, 2312FS+1d, 2394 |  | 5d |  |
| 2314 |  | PSG (OFGEM and PSG to Approve That Conditions of M10 and M13 Have Been Met) | 0d | 2025-09-24 | 2025-09-24 | 2313FS+1d |  | 5d |  |
| 2315 | 1.8.10.3 | **Cutover Governance M11** | 19d | 2025-09-26 | 2025-10-22 |  |  | 5d |  |
| 2316 |  | Confirmation of Qualified Parties from Code Bodies | 11d | 2025-09-26 | 2025-10-10 | 2314FS+1d |  | 5d |  |
| 2317 |  | Self-Declaration that MHHS Functionality will be deployed to Production by Qualified parties | 0d | 2025-10-10 | 2025-10-10 | 2314FS+12d |  | 5d |  |
| 2318 |  | Production Service Activation Activities have taken place | 0d | 2025-10-10 | 2025-10-10 | 2314FS+12d |  | 5d |  |
| 2319 |  | TORWG (Confirmation of Qualified Parties from TORWG) | 0d | 2025-10-13 | 2025-10-13 | 2316FS+1d, 2317FS+1d, 2318FS+1d, 2297, 2391, 2395 |  | 5d |  |
| 2320 |  | MCAG (Provide recommendation to PSG on M11 decision) | 0d | 2025-10-17 | 2025-10-17 | 2319FS+4d |  | 5d |  |
| 2321 |  | PSG (OFGEM and PSG Decision to Confirm M11 and M12) | 0d | 2025-10-22 | 2025-10-22 | 2320FS+3d |  | 5d |  |
| 2322 | 1.8.11 | **UMS / Advanced Migration** | 402d | 2025-10-23 | 2027-05-07 |  |  | 0d |  |
| 2323 |  | SIT MVC UMS / Advanced Migration | 391d | 2025-10-23 | 2027-04-22 | 2396, 2352 |  | 11d |  |
| 2324 |  | SIT Non-MVC UMS / Advanced Migration | 326d | 2026-01-02 | 2027-04-02 | 2417 |  | 25d |  |
| 2325 |  | Wave 1 UMS / Advanced Migration | 251d | 2026-05-15 | 2027-04-30 | 2433 |  | 5d |  |
| 2326 |  | Wave 2 UMS / Advanced Migration | 217d | 2026-07-01 | 2027-04-29 | 2457 |  | 6d |  |
| 2327 |  | Wave 3 UMS / Advanced Migration | 182d | 2026-08-27 | 2027-05-07 | 2481 |  | 0d |  |
| 2328 |  | Wave 4 UMS / Advanced Migration | 136d | 2026-10-23 | 2027-04-30 | 2505 |  | 5d |  |
| 2329 | 1.8.12 | **Smart / Non-Smart Migration** | 402d | 2025-10-23 | 2027-05-07 |  |  | 0d |  |
| 2330 |  | SIT MVC Smart / Non-Smart Migration | 391d | 2025-10-23 | 2027-04-22 | 2396, 2352 |  | 11d |  |
| 2331 |  | SIT Non-MVC Smart / Non-Smart Migration | 326d | 2026-01-02 | 2027-04-02 | 2417 |  | 25d |  |
| 2332 |  | Wave 1 Smart / Non-Smart Migration | 251d | 2026-05-15 | 2027-04-30 | 2433 |  | 5d | start no earlier than 2025-10-03 |
| 2333 |  | Wave 2 Smart / Non-Smart Migration | 217d | 2026-07-01 | 2027-04-29 | 2457 |  | 6d |  |
| 2334 |  | Wave 3 Smart / Non-Smart Migration | 182d | 2026-08-27 | 2027-05-07 | 2481 |  | 0d |  |
| 2335 |  | Wave 4 Smart / Non-Smart Migration | 136d | 2026-10-23 | 2027-04-30 | 2505 |  | 4d |  |
| 2336 | 1.8.13 | **External Programme Dependency Management** | 740d | 2022-10-31 A | 2025-08-29 |  | 66% | 604d |  |
| 2337 | 1.8.13.1 | **BSC Mod P432 & REC CP R0015** | 392d | 2022-10-31 A | 2024-04-30 A |  | 100% |  |  |
| 2338 |  | MHHSP engagement with BSCCo until Ofgem decision | 316d | 2022-10-31 A | 2024-01-15 A |  | 100% |  |  |
| 2339 |  | Monitor progress and await implementation date | 76d | 2024-01-16 A | 2024-04-30 A | 2338 | 100% |  |  |
| 2340 | 1.8.13.2 | **BSC Mod P434** | 713d | 2022-10-31 A | 2025-07-23 |  | 57% | 631d |  |
| 2341 |  | MHHSP engagement with BSCCo until Ofgem decision | 61d | 2022-10-31 A | 2023-01-23 A |  | 100% |  |  |
| 2342 |  | Monitor progress and await implementation date | 652d | 2023-01-24 A | 2025-07-23 | 2341 | 52% | 631d |  |
| 2343 | 1.8.13.3 | **Elexon System Capacity Upgrade** | 697d | 2022-10-31 A | 2025-07-01 |  | 58% | 647d |  |
| 2344 |  | Monitor progress to implementation | 697d | 2022-10-31 A | 2025-07-01 |  | 58% | 647d |  |
| 2345 |  | Implementation date | 0d | 2025-07-01 | 2025-07-01 | 2344 |  | 647d |  |
| 2346 | 1.8.13.4 | **DCC System Capacity Upgrade** | 25d | 2025-07-28 | 2025-08-29 |  |  | 604d |  |
| 2347 |  | Assurance of DCC capacity upgrade to ensure suitability to support migration | 20d | 2025-07-28 | 2025-08-22 | 1493FF-23d |  | 604d |  |
| 2348 |  | DCC Capacity Upgrade Operational | 0d | 2025-08-29 | 2025-08-29 | 2347FS+5d |  | 604d |  |
| 2349 | 1.8.14 | **Migration - Tier 1 Milestones** | 488d | 2025-09-24 | 2027-08-09 |  |  | 25d |  |
| 2350 |  | Load Shaping Service switched on (M13) | 0d | 2025-09-24 | 2025-09-24 | 1493 |  | 25d |  |
| 2351 |  | Load Shaping Service switched on (M13*) - Late Exit | 0d | 2025-12-24 | 2025-12-24 | 2350FS+65d |  | 521d |  |
| 2352 |  | Start of 18-month migration for UMS / Advanced (M11) | 0d | 2025-10-22 | 2025-10-22 | 2350, 2320, 2321, 2396, 1493FS+20d |  | 5d |  |
| 2353 |  | Start of 18-month migration for UMS / Advanced (M11*) - Late Exit | 0d | 2026-01-21 | 2026-01-21 | 2352FS+65d |  | 501d |  |
| 2354 |  | Start of 18-month migration for Smart / Non-smart (M12) | 0d | 2025-10-22 | 2025-10-22 | 2350, 1493FS+20d |  | 501d |  |
| 2355 |  | Start of 18-month migration for Smart / Non-smart (M12*) - Late Exit | 0d | 2026-01-21 | 2026-01-21 | 2354FS+65d |  | 501d |  |
| 2356 |  | Full transition complete (M15) | 0d | 2027-05-07 | 2027-05-07 | 2323, 2324, 2325, 2326, 2327, 2328, 2330, 2331, 2332, 2333, 2334, 2335FS+1d |  | 0d |  |
| 2357 |  | Full transition complete (M15*) - Late Exit | 0d | 2027-08-09 | 2027-08-09 | 2356FS+66d |  | 98d |  |
| 2358 | 1.9 | **BUSINESS & OPERATIONAL READINESS** | 1344d? | 2022-10-31 A | 2027-12-23 |  | 6% | 0d |  |
| 2359 | 1.9.1 | **Service Management** | 983d | 2023-09-19 A | 2027-06-24 |  | 26% | 130d |  |
| 2360 | 1.9.1.1 | **Service Management Strategy** | 116d | 2023-09-19 A | 2024-02-27 A |  | 100% |  |  |
| 2361 |  | Develop document with relevant participants (incl. review of the design baseline to ensure service management arrangements are in place across the solution architecture) | 84d | 2023-09-19 A | 2024-01-12 A |  | 100% |  | start no earlier than 2023-09-19 |
| 2362 |  | Artefact review (via relevant Advisory Group) and updates | 31d | 2024-01-15 A | 2024-02-26 A | 2361 | 100% |  |  |
| 2363 |  | Service Management Strategy approved | 0d | 2024-02-27 A | 2024-02-27 A | 2362FS+1d | 100% |  |  |
| 2364 | 1.9.1.2 | **Early Life Support Model** | 110d | 2024-02-28 A | 2024-07-30 |  | 82% | 842d |  |
| 2365 |  | Draft Document | 74d | 2024-02-28 A | 2024-06-10 | 2363 | 96% | 842d |  |
| 2366 |  | Share document with SRO | 1d | 2024-06-11 | 2024-06-11 | 2365 |  | 842d |  |
| 2367 |  | Industry Consultation | 11d | 2024-06-18 | 2024-07-02 | 2366FS+4d |  | 842d |  |
| 2368 |  | Assurance Meeting | 1d | 2024-07-16 | 2024-07-16 | 2367FS+9d |  | 842d |  |
| 2369 |  | MCAG Approval of Early Life Support Model | 0d | 2024-07-30 | 2024-07-30 | 2368FS+10d |  | 842d |  |
| 2370 | 1.9.1.3 | **Service Management Arrangements Implementation** | 456d | 2025-09-25 | 2027-06-24 |  |  | 130d |  |
| 2371 |  | Hypercare post M10 | 80d | 2025-09-25 | 2026-01-14 | 1493 |  | 506d |  |
| 2372 |  | Monitor Elexon implementation of Service Management arrangements | 436d | 2025-10-23 | 2027-06-24 | 2323SS, 2330SS |  | 130d |  |
| 2373 | 1.9.2 | **Service Activation** | 1039d? | 2022-10-31 | 2026-10-22 |  |  | 305d |  |
| 2374 | 1.9.2.1 | **SIT MVC** | 166d? | 2025-02-03 | 2025-09-22 |  |  | 163d |  |
| 2375 | 1.9.2.1.1 | **SIT MVC Service Activation Preparation Tasks** | 20d | 2025-02-03 | 2025-02-28 |  |  | 164d |  |
| 2376 |  | Identify operational resources | 5d | 2025-02-03 | 2025-02-07 |  |  | 749d | finish no earlier than 2025-02-07 |
| 2377 |  | Define and approve operational support model | 5d | 2025-02-10 | 2025-02-14 |  |  | 744d | finish no earlier than 2025-02-14 |
| 2378 |  | Confirm SA Training completed | 10d | 2025-02-10 | 2025-02-21 |  |  | 739d | finish no earlier than 2025-02-21 |
| 2379 |  | Participant Engagement / Communications | 15d | 2025-02-10 | 2025-02-28 |  |  | 734d | finish no earlier than 2025-02-28 |
| 2380 |  | Internal Communications | 15d | 2025-02-10 | 2025-02-28 |  |  | 734d | finish no earlier than 2025-02-28 |

| ID | WBS | Task | Duration | Start | Finish | Predecessors | Total float | Constraint |
| --- | --- | --- | --- | --- | --- | --- | --- | --- |
| 2381 |  | Validate User Access | 5d | 2025-02-17 | 2025-02-21 |  | 739d | finish no earlier than 2025-02-21 |
| 2382 |  | Target Systems and Environments Ready | 3d | 2025-02-20 | 2025-02-24 |  | 738d | finish no earlier than 2025-02-24 |
| 2383 |  | Provide opeartional resources with LWIs | 5d | 2025-02-17 | 2025-02-21 |  | 739d | finish no earlier than 2025-02-21 |
| 2384 |  | Business Readiness Governance Approval | 3d | 2025-02-17 | 2025-02-19 |  | 741d | finish no earlier than 2025-02-19 |
| 2385 |  | SIT MVC Service Activation Preparation Tasks Complete | 0d | 2025-02-28 | 2025-02-28 |  | 144d | finish no earlier than 2025-02-28 |
| 2386 |  | MHHSP Confirms SIT MVC PPs MHHS Enabled | 1d | 2025-04-15 | 2025-04-15 | 2294 | 112d |  |
| 2387 | 1.9.2.1.3 | **SIT MVC Service Activation Implementation** | 7d? | 2025-09-12 | 2025-09-22 |  | 5d |  |
| 2388 |  | Add EDF to DIP | 1d | 2025-09-12 | 2025-09-12 | 1687SS, 2386, 2385 | 5d |  |
| 2389 |  | DIP Promoted to Production | 1d? | 2025-09-15 | 2025-09-15 | 2388 | 5d |  |
| 2390 |  | SIT LDSOs Create Certificates and Test Connectivity | 1d? | 2025-09-16 | 2025-09-16 | 2389 | 6d |  |
| 2391 |  | SIT MVC S&As Create Certificates and Test Connectivity | 1d? | 2025-09-16 | 2025-09-16 | 2389 | 24d |  |
| 2392 |  | Create M16 in Customer Solution | 2d | 2025-09-16 | 2025-09-17 | 2389 | 5d | finish no earlier than 2025-03-07 |
| 2393 |  | Publish ISD | 2d | 2025-09-18 | 2025-09-19 | 2392 | 5d | finish no earlier than 2025-03-07 |
| 2394 |  | SIT LDSOs to update systems with ISD | 1d? | 2025-09-22 | 2025-09-22 | 2393 | 6d |  |
| 2395 |  | SIT MVC S&As to update systems with ISD | 1d? | 2025-09-22 | 2025-09-22 | 2393 | 20d |  |
| 2396 |  | SIT MVC Service Activation Implementation Complete | 0d | 2025-09-19 | 2025-09-19 | 2393 | 5d | finish no earlier than 2025-03-07 |
| 2397 | 1.9.2.1.4 | **SIT MVC Service Activation Implementation MDD** | 14d | 2025-03-06 | 2025-03-25 |  | 717d |  |
| 2398 |  | MDD Manual Load | 7d | 2025-03-06 | 2025-03-14 |  | 724d | finish no earlier than 2025-03-14 |
| 2399 |  | MDD Update | 8d | 2025-03-14 | 2025-03-25 |  | 717d | finish no earlier than 2025-03-25 |
| 2400 |  | SIT MVC Service Activation Implementation MDD Complete | 0d | 2025-03-25 | 2025-03-25 |  | 717d | finish no earlier than 2025-03-25 |
| 2401 | 1.9.2.1.5 | **SIT MVC Service Activation Hypercare** | 18d | 2025-03-03 | 2025-03-26 |  | 716d |  |
| 2402 |  | Service & Process Monitoring | 18d | 2025-03-03 | 2025-03-26 |  | 716d | finish no earlier than 2025-03-26 |
| 2403 |  | Daily Reporting | 18d | 2025-03-03 | 2025-03-26 |  | 716d | finish no earlier than 2025-03-26 |
| 2404 |  | Issue Management | 18d | 2025-03-03 | 2025-03-26 |  | 716d | finish no earlier than 2025-03-26 |
| 2405 |  | SA Hypercare Close Down Activities | 18d | 2025-03-03 | 2025-03-26 |  | 716d | finish no earlier than 2025-03-26 |
| 2406 |  | Handover to MHHSP | 3d | 2025-03-21 | 2025-03-25 |  | 717d | finish no earlier than 2025-03-25 |
| 2407 |  | SIT MVC Service Activation Hypercare Complete | 0d | 2025-03-25 | 2025-03-25 |  | 717d | finish no earlier than 2025-03-25 |
| 2408 | 1.9.2.2 | **SIT Non-MVC** | 829d | 2022-10-31 | 2026-01-01 |  | 515d |  |
| 2409 | 1.9.2.2.1 | **SIT Non-MVC Service Activation Preparation Tasks** | 1d | 2022-10-31 | 2022-10-31 |  | 845d |  |
| 2410 |  | Helix Preparatory Activities Complete | 0d | 2022-10-31 | 2022-10-31 |  | 1344d |  |
| 2411 |  | MHHSP Confirms SIT Non-MVC PPs MHHS Enabled | 1d | 2022-10-31 | 2022-10-31 |  | 845d |  |
| 2412 | 1.9.2.2.2 | **SIT Non-MVC Service Activation Implementation** | 8d | 2025-12-23 | 2026-01-01 |  | 25d |  |
| 2413 |  | Add EDF to DIP | 2d | 2025-12-23 | 2025-12-24 | 1693SS, 2411 | 25d | finish no earlier than 2025-06-04 |
| 2414 |  | DIP Promoted to Production | 2d | 2025-12-25 | 2025-12-26 | 2413 | 25d | finish no earlier than 2025-06-05 |
| 2415 |  | Create M16 in Customer Solution | 2d | 2025-12-29 | 2025-12-30 | 2414 | 25d | finish no earlier than 2025-06-06 |
| 2416 |  | Publish ISD | 2d | 2025-12-31 | 2026-01-01 | 2415 | 25d | finish no earlier than 2025-06-06 |
| 2417 |  | SIT Non-MVC Service Activation Implementation Complete | 0d | 2026-01-01 | 2026-01-01 | 2416 | 25d | finish no earlier than 2025-06-06 |
| 2418 | 1.9.2.2.3 | **SIT Non-MVC Service Activation Implementation MDD** | 14d | 2025-06-05 | 2025-06-24 |  | 652d |  |
| 2419 |  | MDD Manual Load | 7d | 2025-06-05 | 2025-06-13 |  | 659d | finish no earlier than 2025-06-13 |
| 2420 |  | MDD Update | 8d | 2025-06-13 | 2025-06-24 |  | 652d | finish no earlier than 2025-06-24 |
| 2421 |  | SIT Non-MVC Service Activation Implementation MDD Complete | 0d | 2025-06-24 | 2025-06-24 |  | 652d | finish no earlier than 2025-06-24 |
| 2422 | 1.9.2.2.4 | **Non-SIT MVC Service Activation Hypercare** | 19d | 2025-06-02 | 2025-06-26 |  | 650d |  |
| 2423 |  | Service& Process Monitoring | 18d | 2025-06-02 | 2025-06-25 |  | 651d | finish no earlier than 2025-06-25 |
| 2424 |  | Daily Reporting | 18d | 2025-06-02 | 2025-06-25 |  | 651d | finish no earlier than 2025-06-25 |
| 2425 |  | Issue Management | 18d | 2025-06-02 | 2025-06-25 |  | 651d | finish no earlier than 2025-06-25 |
| 2426 |  | SA Hypercare Close Down Activities | 18d | 2025-06-02 | 2025-06-25 |  | 651d | finish no earlier than 2025-06-25 |
| 2427 |  | Handover to MHHSP | 4d | 2025-06-23 | 2025-06-26 |  | 650d | finish no earlier than 2025-06-26 |
| 2428 |  | Non-SIT MVC Service Activation Hypercare Complete (M) | 0d | 2025-06-25 | 2025-06-25 |  | 651d | finish no earlier than 2025-06-25 |
| 2429 | 1.9.2.3 | **Wave 1** | 924d | 2022-10-31 | 2026-05-14 |  | 420d |  |
| 2430 | 1.9.2.3.1 | **SIT Non-MVC Service Activation Preparation Tasks** | 924d | 2022-10-31 | 2026-05-14 |  | 420d |  |
| 2431 |  | Helix Preparatory Activities Complete | 0d | 2022-10-31 | 2022-10-31 |  | 1344d |  |
| 2432 |  | MHHSP Confirms Wave 1 PPs MHHS Enabled | 1d | 2022-10-31 | 2022-10-31 |  | 904d |  |
| 2433 |  | Wave 1 Service Activation | 24d | 2026-04-13 | 2026-05-14 | 1876, 2432 | 5d |  |
| 2434 | 1.9.2.3.2 | **Wave 1 - Service Activation Implementation** | 5d | 2025-09-01 | 2025-09-05 |  | 599d |  |
| 2435 |  | MHHSP Enabled Confirmation | 2d | 2025-09-01 | 2025-09-02 |  | 602d | finish no earlier than 2025-09-02 |
| 2436 |  | PAB Approval | 2d | 2025-09-01 | 2025-09-02 |  | 602d | finish no earlier than 2025-09-02 |
| 2437 |  | Add EDF to DIP | 2d | 2025-09-02 | 2025-09-03 |  | 601d | finish no earlier than 2025-09-03 |
| 2438 |  | DIP Promoted to Production | 2d | 2025-09-03 | 2025-09-04 |  | 600d | finish no earlier than 2025-09-04 |
| 2439 |  | Create M16 in Customer Solution | 2d | 2025-09-04 | 2025-09-05 |  | 599d | finish no earlier than 2025-09-05 |
| 2440 |  | Publish ISD | 2d | 2025-09-04 | 2025-09-05 |  | 599d | finish no earlier than 2025-09-05 |
| 2441 |  | Wave 1 - Service Activation Implementation Complete (M) | 0d | 2025-09-05 | 2025-09-05 |  | 599d | finish no earlier than 2025-09-05 |
| 2442 | 1.9.2.3.3 | **Wave 1 - Service Activation Implementation MDD** | 10d | 2025-09-04 | 2025-09-17 |  | 591d |  |
| 2443 |  | MDD Manual Load | 5d | 2025-09-04 | 2025-09-10 |  | 596d | finish no earlier than 2025-09-10 |
| 2444 |  | MDD Update | 6d | 2025-09-10 | 2025-09-17 |  | 591d | finish no earlier than 2025-09-17 |
| 2445 |  | Wave 1 - Service Activation Implementation MDD Complete (M) | 0d | 2025-09-17 | 2025-09-17 |  | 591d | finish no earlier than 2025-09-17 |
| 2446 | 1.9.2.3.4 | **Wave 1 - Service Activation Hypercare** | 754d | 2022-10-31 | 2025-09-18 |  | 590d |  |
| 2447 |  | Service& Process Monitoring | 14d | 2025-09-01 | 2025-09-18 |  | 590d | finish no earlier than 2025-09-18 |
| 2448 |  | Daily Reporting | 14d | 2025-09-01 | 2025-09-18 |  | 590d | finish no earlier than 2025-09-18 |
| 2449 |  | Issue Management | 14d | 2025-09-01 | 2025-09-18 |  | 590d | finish no earlier than 2025-09-18 |
| 2450 |  | SA Hypercare Close Down Activities | 14d | 2025-09-01 | 2025-09-18 |  | 590d | finish no earlier than 2025-09-18 |

| ID | WBS | Task | Duration | Start | Finish | Predecessors | Total float | Constraint |
| --- | --- | --- | --- | --- | --- | --- | --- | --- |
| 2451 |  | Handover to MHHSP | 4d | 2025-09-15 | 2025-09-18 |  | 590d | finish no earlier than 2025-09-18 |
| 2452 |  | Non-SIT LDSO Service Activation Hypercare Complete (M) | 0d | 2022-10-31 | 2022-10-31 |  | 1344d |  |
| 2453 | 1.9.2.4 | **Wave 2** | 957d | 2022-10-31 | 2026-06-30 |  | 387d |  |
| 2454 | 1.9.2.4.1 | **SIT Non-MVC Service Activation Preparation Tasks** | 957d | 2022-10-31 | 2026-06-30 |  | 387d |  |
| 2455 |  | Helix Preparatory Activities Complete | 0d | 2022-10-31 | 2022-10-31 |  | 1344d |  |
| 2456 |  | MHHSP Confirms Wave 2 PPs MHHS Enabled | 1d | 2022-10-31 | 2022-10-31 |  | 938d |  |
| 2457 |  | Wave 2 Service Activation | 24d | 2026-05-28 | 2026-06-30 | 1906, 2456 | 6d |  |
| 2458 | 1.9.2.4.2 | **Wave 2 - Service Activation Implementation** | 5d | 2025-11-03 | 2025-11-07 |  | 554d |  |
| 2459 |  | MHHSP Enabled Confirmation | 2d | 2025-11-03 | 2025-11-04 |  | 557d | finish no earlier than 2025-11-04 |
| 2460 |  | PAB Approval | 2d | 2025-11-03 | 2025-11-04 |  | 557d | finish no earlier than 2025-11-04 |
| 2461 |  | Add EDF to DIP | 2d | 2025-11-04 | 2025-11-05 |  | 556d | finish no earlier than 2025-11-05 |
| 2462 |  | DIP Promoted to Production | 2d | 2025-11-05 | 2025-11-06 |  | 555d | finish no earlier than 2025-11-06 |
| 2463 |  | Create M16 in Customer Solution | 2d | 2025-11-06 | 2025-11-07 |  | 554d | finish no earlier than 2025-11-07 |
| 2464 |  | Publish ISD | 2d | 2025-11-06 | 2025-11-07 |  | 554d | finish no earlier than 2025-11-07 |
| 2465 |  | Wave 2 - Service Activation Implementation Complete (M) | 0d | 2025-11-07 | 2025-11-07 |  | 554d | finish no earlier than 2025-11-07 |
| 2466 | 1.9.2.4.3 | **Wave 2 - Service Activation Implementation MDD** | 10d | 2025-11-06 | 2025-11-19 |  | 546d |  |
| 2467 |  | MDD Manual Load | 5d | 2025-11-06 | 2025-11-12 |  | 551d | finish no earlier than 2025-11-12 |
| 2468 |  | MDD Update | 6d | 2025-11-12 | 2025-11-19 |  | 546d | finish no earlier than 2025-11-19 |
| 2469 |  | Wave 2 - Service Activation Implementation MDD Complete (M) | 0d | 2025-11-19 | 2025-11-19 |  | 546d | finish no earlier than 2025-11-19 |
| 2470 | 1.9.2.4.4 | **Wave 2 - Service Activation Hypercare** | 14d | 2025-11-03 | 2025-11-20 |  | 545d |  |
| 2471 |  | Service& Process Monitoring | 14d | 2025-11-03 | 2025-11-20 |  | 545d | finish no earlier than 2025-11-20 |
| 2472 |  | Daily Reporting | 14d | 2025-11-03 | 2025-11-20 |  | 545d | finish no earlier than 2025-11-20 |
| 2473 |  | Issue Management | 14d | 2025-11-03 | 2025-11-20 |  | 545d | finish no earlier than 2025-11-20 |
| 2474 |  | SA Hypercare Close Down Activities | 14d | 2025-11-03 | 2025-11-20 |  | 545d | finish no earlier than 2025-11-20 |
| 2475 |  | Handover to MHHSP | 4d | 2025-11-17 | 2025-11-20 |  | 545d | finish no earlier than 2025-11-20 |
| 2476 |  | Wave 2 - Service Activation Hypercare Complete (M) | 0d | 2025-11-19 | 2025-11-19 |  | 546d | finish no earlier than 2025-11-19 |
| 2477 | 1.9.2.5 | **Wave 3** | 998d | 2022-10-31 | 2026-08-26 |  | 346d |  |
| 2478 | 1.9.2.5.1 | **SIT Non-MVC Service Activation Preparation Tasks** | 998d | 2022-10-31 | 2026-08-26 |  | 346d |  |
| 2479 |  | Helix Preparatory Activities Complete | 0d | 2022-10-31 | 2022-10-31 |  | 1344d |  |
| 2480 |  | MHHSP Confirms Wave 3 PPs MHHS Enabled | 1d | 2022-10-31 | 2022-10-31 |  | 973d |  |
| 2481 |  | Wave 3 Service Activation | 24d | 2026-07-24 | 2026-08-26 | 1936, 2480 | 0d |  |
| 2482 | 1.9.2.5.2 | **Wave 3 - Service Activation Implementation** | 7d | 2025-12-22 | 2025-12-30 |  | 517d |  |
| 2483 |  | MHHSP Enabled Confirmation | 2d | 2025-12-22 | 2025-12-23 |  | 522d | finish no earlier than 2025-12-23 |
| 2484 |  | PAB Approval | 2d | 2025-12-22 | 2025-12-23 |  | 522d | finish no earlier than 2025-12-23 |
| 2485 |  | Add EDF to DIP | 2d | 2025-12-23 | 2025-12-24 |  | 521d | finish no earlier than 2025-12-24 |
| 2486 |  | DIP Promoted to Production | 2d | 2025-12-29 | 2025-12-30 |  | 517d | finish no earlier than 2025-12-30 |
| 2487 |  | Create M16 in Customer Solution | 2d | 2025-12-29 | 2025-12-30 |  | 517d | finish no earlier than 2025-12-30 |
| 2488 |  | Publish ISD | 2d | 2025-12-29 | 2025-12-30 |  | 517d | finish no earlier than 2025-12-30 |
| 2489 |  | Wave 3 - Service Activation Implementation Complete (M) | 0d | 2025-12-30 | 2025-12-30 |  | 517d | finish no earlier than 2025-12-30 |
| 2490 | 1.9.2.5.3 | **Wave 3 - Service Activation Implementation MDD** | 839d | 2022-10-31 | 2026-01-15 |  | 505d |  |
| 2491 |  | MDD Manual Load | 7d | 2025-12-29 | 2026-01-06 |  | 512d | finish no earlier than 2026-01-06 |
| 2492 |  | MDD Update | 269d | 2025-01-06 | 2026-01-15 |  | 505d | finish no earlier than 2026-01-15 |
| 2493 |  | Wave 3 - Service Activation Implementation MDD Complete (M) | 0d | 2022-10-31 | 2022-10-31 |  | 1344d |  |
| 2494 | 1.9.2.5.4 | **Wave 3 - Service Activation Hypercare** | 840d | 2022-10-31 | 2026-01-16 |  | 504d |  |
| 2495 |  | Service& Process Monitoring | 20d | 2025-12-22 | 2026-01-16 |  | 504d | finish no earlier than 2026-01-16 |
| 2496 |  | Daily Reporting | 20d | 2025-12-22 | 2026-01-16 |  | 504d | finish no earlier than 2026-01-16 |
| 2497 |  | Issue Management | 20d | 2025-12-22 | 2026-01-16 |  | 504d | finish no earlier than 2026-01-16 |
| 2498 |  | SA Hypercare Close Down Activities | 20d | 2025-12-22 | 2026-01-16 |  | 504d | finish no earlier than 2026-01-16 |
| 2499 |  | Handover to MHHSP | 4d | 2026-01-12 | 2026-01-15 |  | 505d | finish no earlier than 2026-01-15 |
| 2500 |  | Wave 3 Service Activation Hypercare Complete (M) | 0d | 2022-10-31 | 2022-10-31 |  | 1344d |  |
| 2501 | 1.9.2.6 | **Wave 4** | 1039d | 2022-10-31 | 2026-10-22 |  | 305d |  |
| 2502 | 1.9.2.6.1 | **SIT Non-MVC Service Activation Preparation Tasks** | 1039d | 2022-10-31 | 2026-10-22 |  | 305d |  |
| 2503 |  | Helix Preparatory Activities Complete | 0d | 2022-10-31 | 2022-10-31 |  | 1344d |  |
| 2504 |  | MHHSP Confirms Wave 4 PPs MHHS Enabled | 1d | 2022-10-31 | 2022-10-31 |  | 1018d |  |
| 2505 |  | Wave 4 Service Activation | 24d | 2026-09-21 | 2026-10-22 | 1966, 2504 | 4d |  |
| 2506 | 1.9.2.6.2 | **Wave 4 - Service Activation Implementation** | 265d | 2025-03-03 | 2026-03-06 |  | 469d |  |
| 2507 |  | MHHSP Enabled Confirmation | 2d | 2026-03-02 | 2026-03-03 |  | 472d | finish no earlier than 2026-03-03 |
| 2508 |  | PAB Approval | 1d | 2025-03-03 | 2025-03-03 |  | 733d | finish no earlier than 2025-03-03 |
| 2509 |  | Add EDF to DIP | 2d | 2026-03-03 | 2026-03-04 |  | 471d | finish no earlier than 2026-03-04 |
| 2510 |  | DIP Promoted to Production | 2d | 2026-03-04 | 2026-03-05 |  | 470d | finish no earlier than 2026-03-05 |
| 2511 |  | Create M16 in Customer Solution | 2d | 2026-03-05 | 2026-03-06 |  | 469d | finish no earlier than 2026-03-06 |
| 2512 |  | Publish ISD | 2d | 2026-03-05 | 2026-03-06 |  | 469d | finish no earlier than 2026-03-06 |
| 2513 |  | Wave 4 - Service Activation Implementation Complete (M) | 0d | 2026-03-06 | 2026-03-06 |  | 469d | finish no earlier than 2026-03-06 |
| 2514 | 1.9.2.6.3 | **Wave 4 - Service Activation Implementation MDD** | 15d | 2026-03-06 | 2026-03-26 |  | 455d |  |
| 2515 |  | MDD Manual Load | 7d | 2026-03-06 | 2026-03-16 |  | 463d | finish no earlier than 2026-03-16 |
| 2516 |  | MDD Update | 9d | 2026-03-16 | 2026-03-26 |  | 455d | finish no earlier than 2026-03-26 |
| 2517 |  | Wave 4 - Service Activation Implementation MDD Complete | 0d | 2026-03-25 | 2026-03-25 |  | 456d | finish no earlier than 2026-03-25 |
| 2518 | 1.9.2.6.4 | **Wave 4 - Service Activation Hypercare** | 19d | 2026-03-02 | 2026-03-26 |  | 455d |  |
| 2519 |  | Service& Process Monitoring | 19d | 2026-03-02 | 2026-03-26 |  | 455d | finish no earlier than 2026-03-26 |
| 2520 |  | Daily Reporting | 19d | 2026-03-02 | 2026-03-26 |  | 455d | finish no earlier than 2026-03-26 |

| ID | WBS | Task | Duration | Start | Finish | Predecessors | Total float | Constraint |
| --- | --- | --- | --- | --- | --- | --- | --- | --- |
| 2521 |  | Issue Management | 19d | 2026-03-02 | 2026-03-26 |  | 455d | finish no earlier than 2026-03-26 |
| 2522 |  | SA Hypercare Close Down Activities | 19d | 2026-03-02 | 2026-03-26 |  | 455d | finish no earlier than 2026-03-26 |
| 2523 |  | Handover to MHHSP | 4d | 2026-03-02 | 2026-03-05 |  | 470d | finish no earlier than 2026-03-05 |
| 2524 |  | Wave 4 - Service Activation Hypercare Complete (M) | 0d | 2026-03-25 | 2026-03-25 |  | 456d | finish no earlier than 2026-03-25 |
| 2525 | 1.9.2.7 | **Non-SIT LDSO** | 741d | 2022-10-31 | 2025-09-01 |  | 603d |  |
| 2526 | 1.9.2.7.1 | **Non-SIT LDSO Service Activation Data Loading** | 176d | 2024-06-07 | 2025-02-07 |  | 749d |  |
| 2527 |  | Define pre Non-SIT LDSO upfront activities | 7d | 2024-06-07 | 2024-06-17 |  | 918d | finish no earlier than 2024-06-17 |
| 2528 | 1.9.2.7.1.2 | **Execute Non-SIT LDSO Activities** | 5d | 2025-02-03 | 2025-02-07 |  | 749d |  |
| 2529 |  | Create Entity Forms in Customer Solution | 3d | 2025-02-03 | 2025-02-05 |  | 751d | finish no earlier than 2025-02-05 |
| 2530 |  | DIP - Promote to Production Environment | 3d | 2025-02-03 | 2025-02-05 |  | 751d | finish no earlier than 2025-02-05 |
| 2531 |  | DIP - Enable Technology capabilities for participants | 3d | 2025-02-03 | 2025-02-05 |  | 751d | finish no earlier than 2025-02-05 |
| 2532 |  | DIP - Add EFD to DIP | 3d | 2025-02-03 | 2025-02-05 |  | 751d | finish no earlier than 2025-02-05 |
| 2533 |  | ISD - Replicate Entity Forms from CS | 2d | 2025-02-06 | 2025-02-07 |  | 749d | finish no earlier than 2025-02-07 |
| 2534 |  | MDD - Load MHHS roles | 3d | 2025-02-03 | 2025-02-05 |  | 751d | finish no earlier than 2025-02-05 |
| 2535 |  | Non-SIT LDSO Service Activation Data Loading Completed (M) | 0d | 2025-02-07 | 2025-02-07 |  | 749d | finish no earlier than 2025-02-07 |
| 2536 | 1.9.2.7.2 | **SIT Non-MVC Service Activation Preparation Tasks** | 741d | 2022-10-31 | 2025-09-01 |  | 603d |  |
| 2537 |  | Helix Preparatory Activities Complete | 0d | 2022-10-31 | 2022-10-31 |  | 1344d |  |
| 2538 |  | MHHSP Confirms Non-SIT LDSO PPs MHHS Enabled | 1d | 2022-10-31 | 2022-10-31 |  | 756d |  |
| 2539 |  | Non-SIT LDSO Service Activation | 6d | 2025-08-25 | 2025-09-01 | 1614, 2538 | 22d |  |
| 2540 | 1.9.2.7.3 | **Non-SIT LDSO Service Activation Implementation** | 4d | 2025-02-24 | 2025-02-27 |  | 735d |  |
| 2541 |  | MHHSP Enabled Confirmation | 2d | 2025-02-24 | 2025-02-25 |  | 737d | finish no earlier than 2025-02-25 |
| 2542 |  | PAB Approval | 2d | 2025-02-24 | 2025-02-25 |  | 737d | finish no earlier than 2025-02-25 |
| 2543 |  | Add EDF to DIP | 2d | 2025-02-25 | 2025-02-26 |  | 736d | finish no earlier than 2025-02-26 |
| 2544 |  | DIP Promoted to Production | 2d | 2025-02-26 | 2025-02-27 |  | 735d | finish no earlier than 2025-02-27 |
| 2545 |  | Create M16 in Customer Solution | 2d | 2025-02-26 | 2025-02-27 |  | 735d | finish no earlier than 2025-02-27 |
| 2546 |  | Publish ISD | 2d | 2025-02-26 | 2025-02-27 |  | 735d | finish no earlier than 2025-02-27 |
| 2547 |  | Non-SIT LDSO Service Activation Implementation Completed (M) | 0d | 2025-02-27 | 2025-02-27 |  | 735d | finish no earlier than 2025-02-27 |
| 2548 | 1.9.2.7.4 | **Non-SIT LDSO Service Activation Implementation MDD** | 14d | 2025-02-27 | 2025-03-18 |  | 722d |  |
| 2549 |  | MDD Manual Load | 7d | 2025-02-27 | 2025-03-07 |  | 729d | finish no earlier than 2025-03-07 |
| 2550 |  | MDD Update | 8d | 2025-03-07 | 2025-03-18 |  | 722d | finish no earlier than 2025-03-18 |
| 2551 |  | Non-SIT LDSO Service Activation Implementation MDD Complete (M) | 0d | 2025-03-18 | 2025-03-18 |  | 722d | finish no earlier than 2025-03-18 |
| 2552 | 1.9.2.7.5 | **Non-SIT LDSO Service Activation Hypercare** | 18d | 2025-02-24 | 2025-03-19 |  | 721d |  |
| 2553 | 1.9.2.7.5.1 | **Non-SIT LDSO Service Activation Hypercare Support** | 18d | 2025-02-24 | 2025-03-19 |  | 721d |  |
| 2554 |  | Service& Process Monitoring | 18d | 2025-02-24 | 2025-03-19 |  | 721d | finish no earlier than 2025-03-19 |
| 2555 |  | Daily Reporting | 18d | 2025-02-24 | 2025-03-19 |  | 721d | finish no earlier than 2025-03-19 |
| 2556 |  | Issue Management | 18d | 2025-02-24 | 2025-03-19 |  | 721d | finish no earlier than 2025-03-19 |
| 2557 |  | SA Hypercare Close Down Activities | 18d | 2025-02-24 | 2025-03-19 |  | 721d | finish no earlier than 2025-03-19 |
| 2558 |  | Handover to MHHSP | 3d | 2025-03-14 | 2025-03-18 |  | 722d | finish no earlier than 2025-03-18 |
| 2559 |  | Non-SIT LDSO Service Activation Hypercare Complete (M) | 0d | 2025-03-18 | 2025-03-18 |  | 722d | finish no earlier than 2025-03-18 |
| 2560 | 1.9.3 | **Implement Early Life Support Plan** | 45d | 2025-01-06 | 2025-03-07 |  | 729d |  |
| 2561 |  | Implement Early Life Support Plan | 45d | 2025-01-06 | 2025-03-07 | 2369 | 729d | start no earlier than 2025-01-06 |
| 2562 | 1.9.4 | **Business Continuity and Disaster Recovery Plan** | 40d | 2025-07-31 | 2025-09-24 |  | 586d |  |
| 2563 |  | Central Parties BCDRs in Place | 20d | 2025-07-31 | 2025-08-27 | 2103FS-40d | 586d |  |
| 2564 |  | Risk Based Assurance of Cental Party BCDRs | 20d | 2025-08-28 | 2025-09-24 | 2563 | 586d |  |
| 2565 | 1.9.5 | **Training and Support Materials** | 39d | 2025-08-21 | 2025-10-14 |  | 572d |  |
| 2566 |  | Develop document | 20d | 2025-08-21 | 2025-09-17 | 2354FS-45d | 572d |  |
| 2567 |  | Document review and update | 19d | 2025-09-18 | 2025-10-14 | 2566 | 572d |  |
| 2568 |  | Training and Support Materials approved | 0d | 2025-10-14 | 2025-10-14 | 2567 | 572d |  |
| 2569 | 1.9.6 | **PP Business Change** | 129d | 2025-02-03 | 2025-07-31 |  | 625d |  |
| 2570 |  | Plan stakeholder management | 129d | 2025-02-03 | 2025-07-31 |  | 625d | start no earlier than 2025-02-03 |
| 2571 |  | Manage stakeholders | 129d | 2025-02-03 | 2025-07-31 |  | 625d | start no earlier than 2025-02-03 |
| 2572 |  | Develop & implement changes to KPIs, organisation & people management | 129d | 2025-02-03 | 2025-07-31 |  | 625d | start no earlier than 2025-02-03 |
| 2573 |  | Develop & test changes to business processes | 129d | 2025-02-03 | 2025-07-31 |  | 625d | start no earlier than 2025-02-03 |
| 2574 |  | Develop and deliver training | 129d | 2025-02-03 | 2025-07-31 |  | 625d | start no earlier than 2025-02-03 |
| 2575 |  | Programme support for PP Business Change activities | 129d | 2025-02-03 | 2025-07-31 |  | 625d | start no earlier than 2025-02-03 |
| 2576 | 1.9.7 | **Transition to New Settlement Timetable (M16)** | 566d | 2025-10-22 | 2027-12-23 |  | 0d |  |
| 2577 |  | Elexon to produce Settlement Calendar for Settlement Year 2025/2026 | 0d | 2025-10-22 | 2025-10-22 | 2352 | 5d |  |
| 2578 |  | Elexon monitor settlement data of migrated MPANs | 436d | 2025-10-23 | 2027-06-24 | 2577 | 6d |  |
| 2579 |  | M16 Checkpoint 1 | 0d | 2026-06-25 | 2026-06-25 | 2577FS+176d | 5d |  |
| 2580 |  | Confirm if M16 date retained as 07/12/2026 | 0d | 2026-07-23 | 2026-07-23 | 2579FS+20d | 5d |  |
| 2581 |  | Readiness assessment of participants' readiness to transition to new Settlement Timetable | 0d | 2026-08-20 | 2026-08-20 | 2580FS+20d | 5d |  |
| 2582 |  | Elexon to produce Settlement Calendar for Settlement Year 2026 up until day before M16 cutover | 0d | 2026-10-19 | 2026-10-19 | 2581FS+42d | 5d |  |
| 2583 |  | M16 Checkpoint 2 | 0d | 2027-04-02 | 2027-04-02 | 2582FS+119d | 5d |  |
| 2584 |  | Readiness assessment of participants' readiness to transition to new Settlement Timetable | 0d | 2027-04-19 | 2027-04-19 | 2583FS+11d | 5d |  |
| 2585 |  | Confirm M16 Date | 0d | 2027-04-30 | 2027-04-30 | 2584FS+9d | 5d |  |
| 2586 |  | Raise fast track change to ISD (November publish) | 0d | 2027-04-30 | 2027-04-30 | 2585 | 45d |  |
| 2587 | 1.9.7.11 | **M16 Approval Window** | 129d | 2027-06-25 | 2027-12-23 |  | 0d |  |
| 2588 |  | Panel approval that M16 criteria met | 0d | 2027-06-25 | 2027-06-25 | 2585FS+40d | 5d |  |
| 2589 |  | Cut over to new settlement timetable (M16) | 0d | 2027-07-02 | 2027-07-02 | 2588, 2356FS+40d, 2578, 2586, 2266 | 0d |  |
| 2590 |  | Maximum 6-month window for approval of M16 | 124d | 2027-07-05 | 2027-12-23 | 2589 | 0d |  |

| ID | WBS | Task | Duration | Start | Finish | Predecessors | Complete | Total float | Constraint |
| --- | --- | --- | --- | --- | --- | --- | --- | --- | --- |
| 2591 |  | Cut over to new settlement timetable (M16*) - Late Exit | 0d | 2027-12-23 | 2027-12-23 | 2590 |  | 0d |  |
| 2592 | 1.10 | **EARLY LIVE RUNNING** | 45d | 2027-05-10 | 2027-07-09 |  |  | 119d |  |
| 2593 | 1.10.1 | **Early Live Running Stabilisation Period** | 45d | 2027-05-10 | 2027-07-09 |  |  | 119d |  |
| 2594 |  | Manage Early Live Running stabilisation period | 45d | 2027-05-10 | 2027-07-09 | 2356 |  | 119d |  |
| 2595 |  | Monitor Early Live Running stabilisation period | 45d | 2027-05-10 | 2027-07-09 | 2594SS |  | 119d |  |
| 2596 | 1.11 | **PROGRAMME CLOSURE** | 80d | 2027-03-08 | 2027-06-25 |  |  | 129d |  |
| 2597 | 1.11.1 | **Handover Pack** | 80d | 2027-03-08 | 2027-06-25 |  |  | 129d |  |
| 2598 | 1.11.1.1 | **Draft Handover Pack (for M15)** | 40d | 2027-03-08 | 2027-04-30 |  |  | 169d |  |
| 2599 |  | Develop document | 20d | 2027-03-08 | 2027-04-02 | 2356FS-45d |  | 169d |  |
| 2600 |  | Document review and update | 20d | 2027-04-05 | 2027-04-30 | 2599 |  | 169d |  |
| 2601 |  | Draft Handover Pack approved | 0d | 2027-04-30 | 2027-04-30 | 2600 |  | 169d |  |
| 2602 | 1.11.1.2 | **Master Handover Pack (for M16)** | 40d | 2027-05-03 | 2027-06-25 |  |  | 129d |  |
| 2603 |  | Update document | 20d | 2027-05-03 | 2027-05-28 | 2589FS-45d |  | 129d |  |
| 2604 |  | Document review and update | 20d | 2027-05-31 | 2027-06-25 | 2603 |  | 129d |  |
| 2605 |  | Master Handover Pack approved | 0d | 2027-06-25 | 2027-06-25 | 2604 |  | 129d |  |
| 2606 | 1.11.2 | **Programme Lessons Learned** | 40d | 2027-03-08 | 2027-04-30 |  |  | 169d |  |
| 2607 |  | Develop document | 20d | 2027-03-08 | 2027-04-02 | 2356FS-45d |  | 169d |  |
| 2608 |  | Document review and update | 20d | 2027-04-05 | 2027-04-30 | 2607 |  | 169d |  |
| 2609 |  | Programme Lessons Learned document approved | 0d | 2027-04-30 | 2027-04-30 | 2608 |  | 169d |  |
| 2610 | 1.11.3 | **Programme Closure Report** | 40d | 2027-03-08 | 2027-04-30 |  |  | 169d |  |
| 2611 |  | Develop document | 20d | 2027-03-08 | 2027-04-02 | 2356FS-45d |  | 169d |  |
| 2612 |  | Document review and update | 20d | 2027-04-05 | 2027-04-30 | 2611 |  | 169d |  |
| 2613 |  | Programme Closure Report approved | 0d | 2027-04-30 | 2027-04-30 | 2612 |  | 169d |  |
| 2614 | 1.11.4 | **Benefit Realisation Report** | 45d | 2027-03-08 | 2027-05-07 |  |  | 164d |  |
| 2615 |  | Develop document | 20d | 2027-03-08 | 2027-04-02 | 2356FS-45d |  | 164d |  |
| 2616 |  | Document review and update | 20d | 2027-04-05 | 2027-04-30 | 2615 |  | 164d |  |
| 2617 |  | Benefit Realisation Report approved | 0d | 2027-05-07 | 2027-05-07 | 2616FS+5d |  | 164d |  |
| 2618 | 1.11.5 | **Operating Model Gap Review with recommendations** | 45d | 2027-03-08 | 2027-05-07 |  |  | 164d |  |
| 2619 |  | Develop document | 20d | 2027-03-08 | 2027-04-02 | 2356FS-45d |  | 164d |  |
| 2620 |  | Document review and update | 20d | 2027-04-05 | 2027-04-30 | 2619 |  | 164d |  |
| 2621 |  | Operating Model Gap Review with recommendations approved | 0d | 2027-05-07 | 2027-05-07 | 2620FS+5d |  | 164d |  |
| 2622 | 1.11.6 | **Post-Implementation Review** | 45d | 2027-03-08 | 2027-05-07 |  |  | 164d |  |
| 2623 |  | Develop document | 20d | 2027-03-08 | 2027-04-02 | 2356FS-45d |  | 164d |  |
| 2624 |  | Document review and update | 20d | 2027-04-05 | 2027-04-30 | 2623 |  | 164d |  |
| 2625 |  | Post-Implementation Review approved | 0d | 2027-05-07 | 2027-05-07 | 2624FS+5d |  | 164d |  |
| 2626 | 1.11.7 | **Reinforcement Guide** | 45d | 2027-03-08 | 2027-05-07 |  |  | 164d |  |
| 2627 |  | Develop document | 20d | 2027-03-08 | 2027-04-02 | 2356FS-45d |  | 164d |  |
| 2628 |  | Document review and update | 20d | 2027-04-05 | 2027-04-30 | 2627 |  | 164d |  |
| 2629 |  | Reinforcement Guide approved | 0d | 2027-05-07 | 2027-05-07 | 2628FS+5d |  | 164d |  |
| 2630 | 1.11.8 | **Material and Licenses Transfer** | 60d | 2027-04-05 | 2027-06-25 |  |  | 129d |  |
| 2631 |  | Transfer of Programme material to Elexon and perpetual licenses as appropriate | 60d | 2027-04-05 | 2027-06-25 | 2589FF-5d |  | 129d |  |
| 2632 | 1.12 | **READINESS ASSESSMENTS** | 988d | 2023-09-05 A | 2027-06-17 |  | 23% | 135d |  |
| 2633 | 1.12.1 | **Readiness Assessment 3 - Design and Build Progress Check and CP2 Check** | 60d | 2023-09-05 A | 2023-11-27 A |  | 100% |  |  |
| 2634 |  | Launch Readiness Assessment survey | 0d | 2023-09-05 A | 2023-09-05 A | 1225FS-40d | 100% |  |  |
| 2635 |  | PPs submit survey responses | 15d | 2023-09-05 A | 2023-09-25 A | 2634 | 100% |  |  |
| 2636 |  | Analyse survey responses | 15d | 2023-09-26 A | 2023-10-16 A | 2635 | 100% |  |  |
| 2637 |  | Conduct deep-dive interviews (sample of PPs) | 15d | 2023-09-26 A | 2023-10-16 A | 2635 | 100% |  |  |
| 2638 |  | Produce Readiness Assessment Reports (Overall Report & Individual Participant Reports) | 25d | 2023-10-17 A | 2023-11-20 A | 2636, 2637 | 100% |  |  |
| 2639 |  | Readiness Assessment 3 - Design & Build Checkpoint 1 - Completed (incl. Readiness Assessment Report approval) | 0d | 2023-11-27 A | 2023-11-27 A | 2638FS+5d | 100% |  |  |
| 2640 | 1.12.2 | **Readiness Assessment 5 / 6 - Start of Qualification and Participant Readiness for M10 and M11 and CP3/CP4 check** | 47d | 2025-04-21 | 2025-06-24 |  |  | 652d |  |
| 2641 |  | Launch Readiness Assessment survey | 0d | 2025-04-21 | 2025-04-21 |  |  | 652d | start no earlier than 2025-04-21 |
| 2642 |  | PPs submit survey responses | 15d | 2025-04-21 | 2025-05-09 | 2641 |  | 652d |  |
| 2643 |  | Analyse survey responses | 15d | 2025-05-12 | 2025-05-30 | 2642 |  | 652d |  |
| 2644 |  | Conduct deep-dive interviews (sample of PPs) | 15d | 2025-05-12 | 2025-05-30 | 2642 |  | 652d |  |
| 2645 |  | Produce Readiness Assessment Reports (Overall Report & Individual Participant Reports) | 15d | 2025-06-02 | 2025-06-20 | 2643, 2644 |  | 652d |  |
| 2646 |  | Readiness Assessment 5 / 6 - Start of Qualification and Participant Readiness for M10 and M11 and CP3/CP4 check (incl. Readiness Assessment Report approval) Completed | 0d | 2025-06-24 | 2025-06-24 | 2645FS+2d |  | 652d |  |
| 2647 | 1.12.3 | **Readiness Assessment 7 - Migration Checkpoint** | 49d | 2026-01-12 | 2026-03-19 |  |  | 460d |  |
| 2648 |  | Launch Readiness Assessment survey | 0d | 2026-01-12 | 2026-01-12 |  |  | 460d | start no earlier than 2026-01-12 |
| 2649 |  | PPs submit survey responses | 15d | 2026-01-12 | 2026-01-30 | 2648 |  | 460d |  |
| 2650 |  | Analyse survey responses | 15d | 2026-02-02 | 2026-02-20 | 2649 |  | 460d |  |
| 2651 |  | Conduct deep-dive interviews (sample of PPs) | 15d | 2026-02-02 | 2026-02-20 | 2649 |  | 460d |  |
| 2652 |  | Produce Readiness Assessment Reports (Overall Report & Individual Participant Reports) | 15d | 2026-02-23 | 2026-03-13 | 2650, 2651 |  | 460d |  |
| 2653 |  | Readiness Assessment 7 - Migration Checkpoint - Completed (incl. Readiness Assessment Report approval) | 0d | 2026-03-19 | 2026-03-19 | 2652FS+4d |  | 460d |  |
| 2654 | 1.12.4 | **Readiness Assessment 8 - Ready to Accept New MPANs** | 49d | 2026-08-06 | 2026-10-13 |  |  | 312d |  |
| 2655 |  | Launch Readiness Assessment survey | 0d | 2026-08-06 | 2026-08-06 | 1968FS-60d |  | 312d |  |
| 2656 |  | PPs submit survey responses | 15d | 2026-08-06 | 2026-08-26 | 2655 |  | 312d |  |
| 2657 |  | Analyse survey responses | 15d | 2026-08-27 | 2026-09-16 | 2656 |  | 312d |  |
| 2658 |  | Conduct deep-dive interviews (sample of PPs) | 15d | 2026-08-27 | 2026-09-16 | 2656 |  | 312d |  |
| 2659 |  | Produce Readiness Assessment Reports (Overall Report & Individual Participant Reports) | 15d | 2026-09-17 | 2026-10-07 | 2657, 2658 |  | 312d |  |
| 2660 |  | Readiness Assessment 8 - Ready to Accept New MPANs - Completed (incl. Readiness Assessment Report approval) | 0d | 2026-10-13 | 2026-10-13 | 2659FS+4d |  | 312d |  |

| ID | WBS | Task | Duration | Start | Finish | Predecessors | Complete | Total float | Constraint |
| --- | --- | --- | --- | --- | --- | --- | --- | --- | --- |
| 2661 | 1.12.5 | **Readiness Assessment 9 - Ready for New Settlement Timetable and CP5 Check** | 49d | 2027-04-12 | 2027-06-17 |  |  | 135d |  |
| 2662 |  | Launch Readiness Assessment survey | 0d | 2027-04-12 | 2027-04-12 | 2589FS-60d |  | 135d |  |
| 2663 |  | PPs submit survey responses | 15d | 2027-04-12 | 2027-04-30 | 2662 |  | 135d |  |
| 2664 |  | Analyse survey responses | 15d | 2027-05-03 | 2027-05-21 | 2663 |  | 135d |  |
| 2665 |  | Conduct deep-dive interviews (sample of PPs) | 15d | 2027-05-03 | 2027-05-21 | 2663 |  | 135d |  |
| 2666 |  | Produce Readiness Assessment Reports (Overall Report & Individual Participant Reports) | 15d | 2027-05-24 | 2027-06-11 | 2664, 2665 |  | 135d |  |
| 2667 |  | Readiness Assessment 9 - Readiness for New Settlement Timetable - Completed (incl. Readiness Assessment Report approval) | 0d | 2027-06-17 | 2027-06-17 | 2666FS+4d |  | 135d |  |
| 2668 | 1.12.6 | **Readiness Assessments - Tier 1 Milestones** | 517d | 2025-06-24 | 2027-06-17 |  |  | 135d |  |
| 2669 |  | Readiness Assessment 6 - Start of Migration - Completed (incl. Readiness Assessment Report approval) | 0d | 2025-06-24 | 2025-06-24 | 2646 |  | 652d | finish no earlier than 2025-04-04 |
| 2670 |  | Readiness Assessment 7 - Migration Checkpoint - Completed (incl. Readiness Assessment Report approval) | 0d | 2026-03-19 | 2026-03-19 | 2653 |  | 460d |  |
| 2671 |  | Readiness Assessment 8 - Ready to Accept New MPANs - Completed (incl. Readiness Assessment Report approval) | 0d | 2026-10-13 | 2026-10-13 | 2660 |  | 312d |  |
| 2672 |  | Readiness Assessment 9 - Readiness for New Settlement Timetable - Completed (incl. Readiness Assessment Report approval) | 0d | 2027-06-17 | 2027-06-17 | 2667 |  | 135d |  |
| 2673 | 1.13 | **CONTROL POINTS** | 1204d | 2022-11-10 A | 2027-06-23 |  | 51% | 132d |  |
| 2674 | 1.13.1 | **Control Point 1 - Start of System Design, Build & Test** | 20d | 2022-11-10 A | 2022-12-07 A |  | 100% |  |  |
| 2675 |  | Control Point 1 Preparation (incl. Control Point Report development and review) | 15d | 2022-11-10 A | 2022-11-30 A | 2676SS-20d | 100% |  |  |
| 2676 |  | Control Point 1 - Start of System Design, Build & Test (incl. Control Point Report approval) | 0d | 2022-12-07 A | 2022-12-07 A |  | 100% |  | must finish on 2022-12-07 |
| 2677 | 1.13.2 | **Control Point 2 - Start of Integration & Test** | 20d | 2023-10-02 A | 2023-10-30 A |  | 100% |  |  |
| 2678 |  | Control Point 2 Preparation (incl. Control Point Report development and review) | 15d | 2023-10-02 A | 2023-10-20 A | 2679SS-20d | 100% |  |  |
| 2679 |  | Control Point 2 - Start of Integration & Test (incl. Control Point Report approval) | 0d | 2023-10-30 A | 2023-10-30 A | 1225 | 100% |  |  |
| 2680 | 1.13.3 | **Control Point 3/4 - Readiness for Migration** | 20d | 2025-08-21 | 2025-09-18 |  |  | 591d |  |
| 2681 |  | Control Point 3/4 Preparation (incl. Control Point Report development and review) | 14d | 2025-08-21 | 2025-09-09 | 2682SS-20d |  | 597d |  |
| 2682 |  | Control Point 3/4 - Readiness for Migration (incl. Control Point Report approval) | 0d | 2025-09-18 | 2025-09-18 | 1493FS-5d |  | 591d |  |
| 2683 | 1.13.4 | **Control Point 5 - Cut Over to New Settlement Timetable** | 20d | 2027-05-26 | 2027-06-23 |  |  | 132d |  |
| 2684 |  | Control Point 5 Preparation (incl. Control Point Report development and review) | 15d | 2027-05-26 | 2027-06-15 | 2685SS-20d |  | 137d |  |
| 2685 |  | Control Point 5 - Cut Over to New Settlement Timetable (incl. Control Point Report approval) | 0d | 2027-06-23 | 2027-06-23 | 2589FS-8d |  | 132d |  |
| 2686 | 1.13.5 | **Control Points - Tier 1 Milestones** | 1184d | 2022-12-07 A | 2027-06-23 |  |  | 132d |  |
| 2687 |  | Control Point 1 - Start of System Design, Build & Test (incl. Control Point Report approval) | 0d | 2022-12-07 A | 2022-12-07 A | 2676SS | 100% |  |  |
| 2688 |  | Control Point 2 - Start of Integration & Test (incl. Control Point Report approval) | 0d | 2023-10-30 A | 2023-10-30 A | 2679SS | 100% |  |  |
| 2689 |  | Control Point 3/4 - Readiness for Migration (incl. Control Point Report approval) | 0d | 2025-09-18 | 2025-09-18 | 2682SS |  | 591d |  |
| 2690 |  | Control Point 5 - Cut Over to New Settlement Timetable (incl. Control Point Report approval) | 0d | 2027-06-23 | 2027-06-23 | 2685SS |  | 132d |  |
| 2691 | 1.14 | **MILESTONE RANGE CHECKPOINTS** | 1160d? | 2022-10-31 | 2027-04-12 |  |  | 184d |  |
| 2692 | 1.14.1 | **M10, M11, M12 and M13 milestone checkpoint** | 0d | 2025-07-31 | 2025-07-31 |  |  | 626d |  |
| 2693 |  | M10, M11, M12, and M13 milestone checkpoint - date approval | 0d | 2025-07-31 | 2025-07-31 | 2352FS-3mo, 2354FS-3mo, 2350FS-3mo, 1493FS-3mo |  | 626d |  |
| 2694 | 1.14.2 | **M14 milestone checkpoint** | 0d | 2026-08-06 | 2026-08-06 |  |  | 361d |  |
| 2695 |  | M14 milestone checkpoint - date approval | 0d | 2026-08-06 | 2026-08-06 | 1968FS-3mo |  | 361d |  |
| 2696 | 1.14.3 | **M15 milestone checkpoint** | 0d | 2027-02-15 | 2027-02-15 |  |  | 224d |  |
| 2697 |  | M15 milestone checkpoint - date approval | 0d | 2027-02-15 | 2027-02-15 | 2356FS-3mo |  | 224d |  |
| 2698 | 1.14.4 | **M16 milestone checkpoint** | 1160d? | 2022-10-31 | 2027-04-12 |  |  | 184d |  |
| 2699 |  | M16 milestone checkpoint - date approval | 0d | 2027-04-12 | 2027-04-12 | 2589FS-3mo |  | 184d |  |

## Version 2 (data date 2024-10-21, saved 2024-12-20, file MHHS-DEL1139 - MHHS Plan v6.15.mpp)

Last finish 2027-12-23 → 2148-12-31 (+44203d). Complete tasks 1107 → 1371.

Added:

| ID | Task | Duration | Start | Finish | Predecessors | Constraint |
| --- | --- | --- | --- | --- | --- | --- |
| 146 | **Interim Release 8.5** | 71d | 2024-10-16 A | 2025-01-22 |  |  |
| 147 | Update baselined artefacts | 8d | 2024-10-16 A | 2024-10-25 A |  | start no earlier than 2024-10-16 |
| 148 | Interim Release 8.5 Published | 0d | 2024-11-06 A | 2024-11-06 A | 147FS+8d |  |
| 149 | Interim Release 8.5 Deployed to SIT by Participants | 3d | 2025-01-20 | 2025-01-22 | 148FS+52d |  |
| 150 | **Interim Release 8.6** | 45d? | 2024-11-21 A | 2025-01-22 |  |  |
| 151 | Update baselined artefacts | 2d? | 2024-11-21 A | 2024-11-22 A |  | start no earlier than 2024-11-21 |
| 152 | Interim Release 8.6 Published | 1d? | 2024-11-25 A | 2024-11-25 A | 151 |  |
| 153 | Interim Release 8.6 Deployed to SIT by Participants | 3d | 2025-01-20 | 2025-01-22 | 152FS+39d |  |
| 154 | **Interim Release 8.7 Placeholder** | 6d | 2025-01-20 | 2025-01-27 |  |  |
| 155 | Update baselined artefacts | 2d | 2025-01-20 | 2025-01-21 |  | start no earlier than 2025-01-20 |
| 156 | Interim Release 8.7 Published | 1d | 2025-01-22 | 2025-01-22 | 155 |  |
| 157 | Interim Release 8.7 Deployed to SIT by Participants | 3d | 2025-01-23 | 2025-01-27 | 156 |  |
| 398 | SIT Non-Functional PIT Completion Report Theme 2 & 3 MHHS Review Completed | 0d | 2025-02-21 | 2025-02-21 | 384, 389, 392, 396FS+60d |  |
| 870 | Test Script updates identified | 1d? | 2024-10-14 A | 2024-10-14 A | 869 |  |
| 871 | Test Scripts updates | 1d | 2024-10-15 A | 2024-10-15 A | 870 |  |
| 872 | RTTM Updated Additional Static RTTM WBS items | 10d | 2024-10-14 A | 2024-10-25 A | 870FS-1d |  |
| 873 | Removal of de-scoped TCs from the RTTMs | 5d | 2024-10-21 A | 2024-10-25 A | 872FS-5d |  |
| 874 | Update and stabilisation of all TC ADO IDs | 14d | 2024-10-21 A | 2024-11-07 A | 872FS-5d |  |
| 875 | Addition and integration of Role tags to reqs in the Role RTTMs | 5d | 2024-10-21 A | 2024-10-25 A | 872FS-5d |  |
| 876 | Update of the RTTM All sheet (porting of the individual RTTMs) | 7d | 2024-10-24 A | 2024-11-01 A | 872FS-2d |  |
| 877 | Define Additional ADO Tags | 1d | 2024-10-23 A | 2024-10-23 A | 872FS-3d |  |
| 878 | Functional RTTM ready for import into ADO | 0d | 2024-11-01 A | 2024-11-01 A | 876 |  |
| 879 | Further Interative Deepdive on the requirements to testcase mapping | 9d | 2024-10-21 A | 2024-10-31 A | 876FS-10d |  |
| 880 | Internal review | 5d | 2024-10-21 A | 2024-10-25 A | 879FS-9d |  |
| 881 | Issue Static RTTM to Code Bodies | 1d? | 2024-10-29 A | 2024-10-29 A | 880FS+1d |  |
| 882 | Code Body Acceptance of RTTM | 5d | 2024-10-30 A | 2024-11-05 A | 881 |  |
| 906 | Exit point identified and evidence capture flags updated | 0d | 2025-02-07 A | 2025-02-07 A | 905 |  |
| 1005 | Test Script updates identified | 1d? | 2024-10-14 A | 2024-10-14 A | 1004 |  |
| 1006 | Test Scripts updates | 16d? | 2024-10-14 A | 2024-11-04 A | 1005FS-1d |  |
| 1007 | RTTM Updated | 1d? | 2024-10-29 A | 2024-10-29 A | 1006FS-5d |  |
| 1008 | Removal of de-scoped TCs from the RTTMs | 2d | 2024-10-31 A | 2024-11-01 A | 1006FS-3d |  |
| 1009 | Update and stabilisation of all TC ADO IDs | 2d | 2024-10-31 A | 2024-11-01 A | 1006FS-3d |  |
| 1010 | Addition and integration of Role tags to reqs in the Role RTTMs | 3d | 2024-10-30 A | 2024-11-01 A | 1006FS-4d |  |
| 1011 | Update of the RTTM All sheet (porting of the individual RTTMs) | 2d | 2024-10-31 A | 2024-11-01 A | 1006FS-3d |  |
| 1012 | ADO IDs corrected | 1d? | 2024-11-04 A | 2024-11-04 A | 1011 | start no earlier than 2024-10-16 |
| 1013 | Migration RTTM ready for import into ADO | 0d | 2024-11-04 A | 2024-11-04 A | 1012 |  |
| 1014 | Issue Static RTTM to Code Bodies | 1d? | 2024-11-05 A | 2024-11-05 A | 1013 |  |
| 1015 | Implement Code Bodies feedback on RTTM | 6d | 2024-11-06 A | 2024-11-13 A | 1014 |  |
| 1016 | Code Body Acceptance of RTTM | 0d | 2024-11-13 A | 2024-11-13 A | 1014, 1015 |  |
| 1017 | **ADO Clean-up** | 17d? | 2024-10-24 | 2024-11-15 A |  |  |
| 1018 | Theme alignment | 1d? | 2024-10-28 A | 2024-10-28 A |  | start no earlier than 2024-10-28 |
| 1019 | Understand Additional suffix Fields in ADO as defined by Kevin | 1d? | 2024-10-25 A | 2024-10-25 A |  | finish no earlier than 2024-10-25 |
| 1020 | Correct Missing Test Case References | 1d? | 2024-10-28 A | 2024-10-28 A |  | start no earlier than 2024-10-28 |
| 1021 | Load Functional RTTMs into ADO | 1d? | 2024-10-28 A | 2024-10-28 A |  | start no earlier than 2024-10-28 |
| 1022 | Load Migration RTTMs into ADO | 1d? | 2024-11-06 A | 2024-11-06 A |  | start no earlier than 2024-11-06 |
| 1023 | Confirm Missing fields in ADO are resolved | 1d? | 2024-11-07 A | 2024-11-07 A |  | finish no earlier than 2024-11-07 |
| 1024 | Reload Functional RTTM into ADO | 1d? | 2024-11-07 A | 2024-11-07 A |  | start no earlier than 2024-11-07 |
| 1025 | **ADO Design Documentation** | 10d? | 2024-11-04 | 2024-11-15 A |  |  |
| 1026 | Produce ADO high Level Design and Data Model | 1d? | 2024-11-15 A | 2024-11-15 A |  | finish no earlier than 2024-11-15 |
| 1027 | Produce Report derivation document | 1d? | 2024-11-15 A | 2024-11-15 A |  | finish no earlier than 2024-11-15 |
| 1028 | **Test Case Rationalisation (Fuctional + Migration)** | 62d | 2024-11-07 A | 2025-01-31 |  |  |
| 1029 | Internal preliminary rationalisation workshop 1 | 1d | 2024-11-07 A | 2024-11-07 A | 1014FS+1d |  |
| 1030 | Baseline RTTMs | 0d | 2024-11-13 A | 2024-11-13 | 1016, 882 |  |
| 1031 | Baseline test cases | 0d | 2024-11-13 A | 2024-11-13 A | 1016 |  |
| 1032 | Produce requirements / test case analysis | 1d | 2024-11-14 A | 2024-11-14 A | 1031 |  |
| 1033 | Internal finalisation rationalisation workshop 2 | 13d | 2024-11-15 A | 2024-12-03 | 1032 |  |
| 1034 | SRO walkthrough | 1d | 2024-12-04 | 2024-12-04 | 1033 |  |
| 1035 | Code Bodies walkthrough | 1d | 2024-12-04 | 2024-12-04 | 1033 |  |
| 1036 | Send invites to PPs for walkthrough | 1d | 2024-12-04 A | 2024-12-04 A | 1035FS-1d |  |
| 1037 | PP walkthrough | 1d | 2024-12-17 | 2024-12-17 | 1036FS+8d |  |
| 1038 | Update test cases | 20d | 2024-12-18 | 2025-01-14 | 1037 |  |
| 1039 | Update RTTM | 20d | 2024-12-18 | 2025-01-14 | 1037 |  |
| 1040 | Update master test case spreadsheet | 20d | 2024-12-18 | 2025-01-14 | 1037 |  |
| 1041 | SITWG Paper Day | 0d | 2025-01-14 | 2025-01-14 | 1040 |  |
| 1042 | SITWG recommendation | 0d | 2025-01-21 | 2025-01-21 | 1041FS+5d |  |
| 1043 | Issue to SITAG / SITAG paper day | 0d | 2025-01-22 | 2025-01-22 | 1038, 1042FS+1d |  |
| 1044 | Prepare ADO update | 6d | 2025-01-15 | 2025-01-22 | 1040 |  |
| 1045 | Sign off by SITAG | 0d | 2025-01-29 | 2025-01-29 | 1043FS+5d |  |
| 1046 | Update ADO | 2d | 2025-01-30 | 2025-01-31 | 1045 |  |
| 1047 | Update all ADO reporting | 2d | 2025-01-30 | 2025-01-31 | 1045 |  |
| 1048 | Test Case Rationalisation complete | 0d | 2025-01-31 | 2025-01-31 | 1046, 1047 |  |
| 1103 | LDP peer review | 10d | 2024-10-30 A | 2024-11-12 A | 1102 |  |
| 1105 | DIP Manager / Code Bodies / Full SRO to review | 5d | 2024-11-13 A | 2024-11-19 | 1103 |  |
| 1110 | **Production of NFT RTTM** | 19d? | 2024-03-04 | 2024-03-28 |  |  |
| 1111 | Test Script updates identified | 1d? | 2024-03-04 | 2024-03-04 |  |  |
| 1112 | Test Scripts updates | 1d | 2024-03-05 | 2024-03-05 | 1111 |  |
| 1113 | RTTM Updated Additional Static RTTM WBS items | 10d | 2024-03-04 | 2024-03-15 | 1111FS-1d |  |
| 1114 | Removal of de-scoped TCs from the RTTMs | 5d | 2024-03-11 | 2024-03-15 | 1113FS-5d |  |
| 1115 | Update and stabilisation of all TC ADO IDs | 14d | 2024-03-11 | 2024-03-28 | 1113FS-5d |  |
| 1116 | Addition and integration of Role tags to reqs in the Role RTTMs | 5d | 2024-03-11 | 2024-03-15 | 1113FS-5d |  |
| 1117 | Update of the RTTM All sheet (porting of the individual RTTMs) | 7d | 2024-03-14 | 2024-03-22 | 1113FS-2d |  |
| 1118 | Define Additional ADO Tags | 1d | 2024-03-13 | 2024-03-13 | 1113FS-3d |  |
| 1119 | Non-Functional RTTM ready for import into ADO | 0d | 2024-03-22 | 2024-03-22 | 1117 |  |
| 1120 | Further Interative Deepdive on the requirements to testcase mapping | 9d | 2024-03-11 | 2024-03-21 | 1117FS-10d |  |
| 1121 | Internal review | 5d | 2024-03-11 | 2024-03-15 | 1120FS-9d |  |
| 1122 | Issue Static RTTM to Code Bodies | 1d? | 2024-03-19 | 2024-03-19 | 1121FS+1d |  |
| 1123 | Code Body Acceptance of RTTM | 0d | 2024-03-19 | 2024-03-19 | 1122 |  |
| 1124 | **NFT (Theme 1, 2 and 3) DITL** | 18d | 2025-02-03 | 2025-02-26 |  |  |
| 1125 | DITL Development | 10d | 2025-02-03 | 2025-02-14 |  | start no earlier than 2025-02-03 |
| 1126 | SRO Review | 5d | 2025-02-17 | 2025-02-21 | 1125 |  |
| 1127 | Post-SRO Review Changes | 3d | 2025-02-24 | 2025-02-26 | 1126 |  |
| 1128 | Programme walkthrough with Theme 1 PPs on DITL | 0d | 2025-02-26 | 2025-02-26 | 1127 |  |
| 1155 | NFTWG paper day | 0d | 2025-01-16 | 2025-01-16 | 1154 |  |
| 1156 | NFTWG review the Non-Functional Theme 1 Overarching Test Readiness Report | 0d | 2025-01-23 | 2025-01-23 | 1155FS+5d |  |
| 1157 | Update Non-Functional Theme 1 Overarching Test Readiness Report following SRO / NFTWG feedback | 19d | 2025-01-17 | 2025-02-12 | 1154 |  |
| 1158 | SITAG paper day | 0d | 2025-02-12 | 2025-02-12 | 1157 |  |
| 1159 | SITAG endorse Non-Functional Theme 1 Overarching Test Readiness Report | 0d | 2025-02-19 | 2025-02-19 | 1158FS+5d |  |
| 1160 | eSITAG approve Non-Functional Theme 1 Overarching Test Readiness Report | 0d | 2025-02-28 | 2025-02-28 | 1144, 1159 |  |
| 1161 | **SIT Non-Functional Overarching Test Readiness Report Theme 2 & 3** | 55d | 2025-01-13 | 2025-03-28 |  |  |
| 1162 | Develop Overarching SIT Non-Functional Overarching Test Readiness Report Theme 2 & 3 | 17d | 2025-01-13 | 2025-02-04 |  | start no earlier than 2025-01-13 |
| 1163 | SRO review | 5d | 2025-02-05 | 2025-02-11 | 1162 |  |
| 1164 | NFTWG paper day | 0d | 2025-02-11 | 2025-02-11 | 1163 |  |
| 1165 | NFTWG review the Non-Functional Overarching Test Readiness Report Theme 2 & 3 | 0d | 2025-02-18 | 2025-02-18 | 1164FS+5d |  |
| 1166 | Update Non-Functional Overarching Test Readiness Report Theme 2 & 3 following SRO / NFTWG feedback | 16d | 2025-02-19 | 2025-03-12 | 1165 |  |
| 1167 | SITAG paper day | 0d | 2025-03-12 | 2025-03-12 | 1166 |  |
| 1168 | SITAG endorse Non-Functional Overarching Test Readiness Report Theme 2 & 3 | 0d | 2025-03-19 | 2025-03-19 | 1167FS+5d |  |
| 1169 | eSITAG approve Non-Functional Overarching Test Readiness Report Theme 2 & 3 | 0d | 2025-03-28 | 2025-03-28 | 1145, 1146 |  |
| 1170 | **SIT Non-Functional Execution Model** | 38d | 2024-12-23 | 2025-02-12 |  |  |
| 1171 | **Theme 1** | 18d | 2025-01-20 | 2025-02-12 |  |  |
| 1172 | Develop execution model Theme 1 | 3d | 2025-01-20 | 2025-01-22 |  | start no earlier than 2025-01-20 |
| 1173 | SRO provide feedback | 5d | 2025-01-23 | 2025-01-29 | 1172 |  |
| 1174 | Address SRO feedback on execution model | 2d | 2025-01-30 | 2025-01-31 | 1173 |  |
| 1175 | Finalise execution model | 3d | 2025-02-03 | 2025-02-05 | 1174 |  |
| 1176 | SITWG paper day | 0d | 2025-02-05 | 2025-02-05 | 1175 |  |
| 1177 | SITWG update on execution model | 0d | 2025-02-12 | 2025-02-12 | 1176FS+5d |  |
| 1178 | **Theme 2 & 3** | 18d | 2025-01-20 | 2025-02-12 |  |  |
| 1179 | Develop execution model Theme 2& 3 | 3d | 2025-01-20 | 2025-01-22 |  | start no earlier than 2025-01-20 |
| 1180 | SRO provide feedback | 5d | 2025-01-23 | 2025-01-29 | 1179 |  |
| 1181 | Address SRO feedback on execution model | 2d | 2025-01-30 | 2025-01-31 | 1180 |  |
| 1182 | Finalise execution model | 3d | 2025-02-03 | 2025-02-05 | 1181 |  |
| 1183 | SITWG paper day | 0d | 2025-02-05 | 2025-02-05 | 1182 |  |
| 1184 | SITWG update on execution model | 0d | 2025-02-12 | 2025-02-12 | 1183FS+5d |  |
| 1185 | **SIT Non-Functional Progress reporting** | 25d | 2024-12-23 | 2025-01-24 |  |  |
| 1186 | Determine reporting methodology | 2d | 2025-01-23 | 2025-01-24 | 1179, 1172 |  |
| 1188 | SIT Non-Functional Testing Preparation Complete Theme 1 | 0d | 2025-02-28 | 2025-02-28 | 1144 | start no earlier than 2025-02-28 |
| 1189 | SIT Non-Functional Testing Preparation Complete Theme 2 & 3 | 0d | 2025-03-28 | 2025-03-28 | 1145, 1146, 398FS+5d |  |
| 1214 | **SIT Operations Manual** | 589d? | 2022-10-31 A | 2025-01-31 |  |  |
| 1215 | **Version 1 SIT Operations Manual** | 35d | 2024-10-07 A | 2024-11-22 A |  |  |
| 1216 | Creation of SIT Operations Manual Template | 8d | 2024-10-07 A | 2024-10-16 A |  | start no earlier than 2024-10-07 |
| 1217 | November TORWG Paper Day | 0d | 2024-11-07 A | 2024-11-07 A | 1216FS+16d |  |
| 1218 | November TORWG (Timeline and Next Steps for SIT Operations Manual) | 0d | 2024-11-14 A | 2024-11-14 A | 1217FS+5d |  |
| 1219 | SIT Operations Manual Version 1 Shared with MHHSP | 0d | 2024-11-11 A | 2024-11-11 A | 1216FS+18d |  |
| 1220 | MHHSP provide feedback on SIT Operations Manual Version 1 | 9d | 2024-11-12 A | 2024-11-22 A | 1219 |  |
| 1221 | SIT Operations Manual Version 1 Shared with Programme Participants | 0d | 2024-11-13 A | 2024-11-13 A | 1216FS+20d |  |
| 1222 | PPs provide feedback on SIT Operations Manual Version 1 | 7d | 2024-11-14 A | 2024-11-22 A | 1221 |  |
| 1223 | Programme Participants and MHHSP Feedback and Actions Received (SIT Ops Manual Version 1) | 0d | 2024-11-22 A | 2024-11-22 A | 1222, 1220 |  |
| 1224 | **Version 2 SIT Operations Manual** | 27d | 2024-11-12 A | 2024-12-18 A |  |  |
| 1225 | Version 2 SIT Operations Manual (Composition) | 12d | 2024-11-12 A | 2024-11-27 A | 1217FS+2d |  |
| 1226 | Version 2 SIT Operations Manual Completed | 0d | 2024-11-27 A | 2024-11-27 A | 1225 |  |
| 1227 | Version 2 SIT Operations Manual Shared with MHHSP & PPs for TORWG (Consultation Starts) | 0d | 2024-11-27 A | 2024-11-27 A | 1226 |  |
| 1228 | Version 2 SIT Ops Manual - PP Consultation (Iterative Feedback Process) | 10d | 2024-11-28 A | 2024-12-11 A | 1227 |  |
| 1229 | Version 2 SIT Ops Manual - PP Consultation Completed | 0d | 2024-12-11 A | 2024-12-11 A | 1228 |  |
| 1230 | December TORWG Paper Day | 0d | 2024-12-04 A | 2024-12-04 A | 1225FS+5d |  |
| 1231 | December TORWG (Initial Feedback, Common Themes and Comments) | 0d | 2024-12-11 A | 2024-12-11 A | 1230FS+5d |  |
| 1232 | December Extraordinary TORWG Paper Day | 0d | 2024-12-11 A | 2024-12-11 A | 1229 |  |
| 1233 | Publication of key themes from consultation to eTORWG | 2d | 2024-12-12 A | 2024-12-13 A | 1232 |  |
| 1234 | December Extraordinary TORWG (Summary of Version 2 Feedback and Response Approach Shared with PPs) | 0d | 2024-12-18 A | 2024-12-18 A | 1233FS+3d |  |
| 1235 | **Version 3 (Final) SIT Operations Manual** | 44d | 2024-11-28 A | 2025-01-28 |  |  |
| 1236 | Update SIT Operations Manual (Final) Version 3 (with Comments Received From Version 2) [Pre-Christmas Furlough] | 17d | 2024-11-28 A | 2024-12-20 | 1226, 181FF |  |
| 1237 | Update SIT Operations Manual (Final) Version 3 (with Comments Received From Version 2) [Post-Christmas Furlough] | 5d | 2025-01-02 | 2025-01-08 | 1236FS+8d |  |
| 1238 | SIT Operations Manual (Final) Version 3 Completed | 0d | 2025-01-08 | 2025-01-08 | 1237 |  |
| 1239 | January TORWG Paper Day | 0d | 2025-01-08 | 2025-01-08 | 1238 |  |
| 1240 | January TORWG (SIT Operations Manual Agreement) [Assurance Meeting] | 0d | 2025-01-15 | 2025-01-15 | 1239FS+5d |  |
| 1241 | January MCAG Paper Day (Final SIT Operations Manual Submitted) | 0d | 2025-01-21 | 2025-01-21 | 1240FS+4d |  |
| 1242 | January MCAG (Final SIT Operations Manual Endorsement) [Advisory Group Sign-off] | 0d | 2025-01-28 | 2025-01-28 | 1241FS+5d |  |
| 1244 | **Incident Management Build** | 75d? | 2024-08-05 A | 2024-11-15 A |  |  |
| 1245 | Build | 40d | 2024-08-05 A | 2024-09-27 A |  | finish no earlier than 2024-09-27 |
| 1246 | Test | 15d | 2024-09-30 A | 2024-10-18 A | 1245 | finish no earlier than 2024-10-18 |
| 1247 | Deploy | 20d | 2024-10-21 A | 2024-11-15 A | 1246 | finish no earlier than 2024-11-15 |
| 1248 | Incident Management Build & Configuration Complete | 0d | 2024-11-15 A | 2024-11-15 A | 1247 |  |
| 1249 | **Major Incident Management Build & Configuration** | 0d? | 2024-11-15 | 2024-11-15 |  |  |
| 1250 | Build | 40d | 2024-10-02 A | 2024-11-26 A |  | finish no earlier than 2024-11-26 |
| 1251 | Test | 15d | 2024-11-27 A | 2024-12-17 A | 1250 | finish no earlier than 2024-12-17 |
| 1252 | Deploy | 20d | 2024-12-18 A | 2025-01-14 A | 1251 | finish no earlier than 2025-01-14 |
| 1253 | Major Incident Management Build & Configuration Complete | 0d | 2025-01-14 A | 2025-01-14 A | 1252 |  |
| 1254 | **Knowledge Management Build & Configuration** | 75d? | 2024-10-02 A | 2025-01-14 A |  |  |
| 1255 | Build | 40d | 2024-10-02 A | 2024-11-26 A |  | finish no earlier than 2024-11-26 |
| 1256 | Test | 15d | 2024-11-27 A | 2024-12-17 A | 1255 | finish no earlier than 2024-12-17 |
| 1257 | Deploy | 20d | 2024-12-18 A | 2025-01-14 A | 1256 | finish no earlier than 2025-01-14 |
| 1258 | Knowledge Management Build & Configuration Complete | 0d | 2025-01-14 A | 2025-01-14 A | 1257 |  |
| 1259 | **Problem Management Build & Configuration** | 1d? | 2024-08-01 | 2024-08-01 |  |  |
| 1260 | Build | 40d | 2024-10-02 A | 2024-11-26 A |  | finish no earlier than 2024-11-26 |
| 1261 | Test | 15d | 2024-11-27 A | 2024-12-17 A | 1260 | finish no earlier than 2024-12-17 |
| 1262 | Deploy | 20d | 2024-12-18 | 2025-01-14 | 1261 | finish no earlier than 2025-01-14 |
| 1263 | Problem Management Build & Configuration Complete | 0d | 2025-01-14 | 2025-01-14 | 1262 | start no earlier than 2025-01-14 |
| 1264 | **Change Management Build & Configuration** | 75d? | 2024-10-02 A | 2025-01-14 |  |  |
| 1265 | Build | 40d | 2024-10-02 A | 2024-11-26 A |  | finish no earlier than 2024-11-26 |
| 1266 | Test | 15d | 2024-11-27 A | 2024-12-17 A | 1265 | finish no earlier than 2024-12-17 |
| 1267 | Deploy | 20d | 2024-12-18 | 2025-01-14 | 1266 | finish no earlier than 2025-01-14 |
| 1268 | Change Management Build & Configuration Complete | 0d | 2025-01-14 | 2025-01-14 | 1267 | start no earlier than 2025-01-14 |
| 1269 | **Service Catalogue Management Build & Configuration** | 75d? | 2024-10-02 A | 2025-01-14 |  |  |
| 1270 | Build | 40d | 2024-10-02 A | 2024-11-26 A |  | finish no earlier than 2024-11-26 |
| 1271 | Test | 15d | 2024-11-27 A | 2024-12-17 A | 1270 | finish no earlier than 2024-12-17 |
| 1272 | Deploy | 20d | 2024-12-18 | 2025-01-14 | 1271 | finish no earlier than 2025-01-14 |
| 1273 | Service Catalogue Management Build & Configuration Complete | 0d | 2025-01-14 | 2025-01-14 | 1272 | start no earlier than 2025-01-14 |
| 1276 | Document Drafting | 95d | 2024-08-01 A | 2024-12-11 |  | finish no earlier than 2024-12-11 |
| 1277 | Internal Elexon Review | 3d | 2024-12-12 | 2024-12-16 | 1276 | finish no earlier than 2024-12-16 |
| 1278 | Elexon Service Panel Review | 5d | 2024-12-16 | 2024-12-20 |  | finish no earlier than 2024-12-20 |
| 1279 | Elexon Service Panel Sign off | 0d | 2024-12-20 | 2024-12-20 | 1278 | start no earlier than 2024-12-20 |
| 1280 | **Incident Management Support** | 1d? | 2022-10-31 | 2022-10-31 |  |  |
| 1281 | Identify Relevant Stakeholders to Support Incident Management Process | 10d | 2024-12-02 | 2024-12-13 |  | start no earlier than 2024-12-02 |
| 1282 | Schedule Time to Upskill Stakeholders | 5d | 2024-12-16 | 2024-12-20 | 1281 |  |
| 1283 | Helix Stakeholders Attendance at MHHS Defect Triage Meetings [Meeting Dates to be Confirmed] | 10d | 2025-01-06 | 2025-01-17 | 1282FS+10d |  |
| 1284 | SIT Service Readiness (Elexon & Helix) Completed | 0d | 2025-01-17 | 2025-01-17 | 1283 |  |
| 1285 | **SIT Service Readiness (External Parties)** | 71d | 2024-09-30 A | 2025-01-06 |  |  |
| 1286 | Helix Engagement & Comms | 71d | 2024-09-30 A | 2025-01-06 |  | start no earlier than 2024-09-30 |
| 1287 | Engagement Execution | 66d | 2024-10-07 A | 2025-01-06 |  | start no earlier than 2024-10-07 |
| 1288 | Information Gathering | 32d | 2024-10-31 | 2024-12-13 |  | start no earlier than 2024-10-31 |
| 1289 | SIT Participants Preparation | 32d | 2024-11-22 | 2025-01-06 |  | start no earlier than 2024-11-22 |
| 1290 | SIT Service Readiness (External Parties) Completed | 0d | 2025-01-06 | 2025-01-06 | 1286, 1287, 1288, 1289 |  |
| 1291 | **ServiceNow Support Portal Onboarding (Helix Suppliers & SIT Participants)** | 78d? | 2024-10-02 A | 2025-01-17 |  |  |
| 1292 | **ServiceNow Portal Preparation and Planning** | 40d? | 2024-10-02 A | 2024-11-26 A |  |  |
| 1293 | Define Supplier Requirements | 30d? | 2024-10-02 A | 2024-11-12 A |  | start no earlier than 2024-10-02 |
| 1294 | Determine Supplier ServiceNow modules | 10d? | 2024-11-13 A | 2024-11-26 A | 1293 | finish no earlier than 2024-11-26 |
| 1295 | Review compliance requirements, including data privacy and access limitations. | 10d? | 2024-11-13 A | 2024-11-26 A | 1293 | finish no earlier than 2024-11-26 |
| 1296 | Conduct a security assessment to ensure the supplier complies with organisational policies. | 10d? | 2024-11-13 A | 2024-11-26 A | 1293 | finish no earlier than 2024-11-26 |
| 1297 | **ServiceNow Portal System Configuration** | 30d? | 2024-11-27 | 2025-01-07 |  |  |
| 1298 | Create Supplier User Accounts | 14d | 2024-11-27 | 2024-12-16 | 1296, 1289SS | finish no earlier than 2024-12-10 |
| 1299 | Assign appropriate access based on the supplier’s needs and security requirements (e.g., read-only access, submit requests, etc.). | 10d? | 2024-12-17 | 2024-12-30 | 1298 | finish no earlier than 2024-12-24 |
| 1300 | Configure Access Controls | 10d? | 2024-12-31 | 2025-01-13 | 1299 | finish no earlier than 2025-01-07 |
| 1301 | **ServiceNow Portal Training and Documentation** | 5d? | 2025-01-06 | 2025-01-10 |  |  |
| 1302 | Provide Training to the Supplier | 5d | 2025-01-06 | 2025-01-10 |  | finish no earlier than 2025-01-10 |
| 1303 | Create Supplier Training Documentation | 5d | 2025-01-06 | 2025-01-10 |  | finish no earlier than 2025-01-10 |
| 1304 | **ServiceNow Portal Testing and Validation** | 8d? | 2025-01-08 | 2025-01-17 |  |  |
| 1305 | Conduct User Acceptance Testing (UAT) | 5d | 2025-01-13 | 2025-01-17 | 1302 | finish no earlier than 2025-01-17 |
| 1306 | Validate Access and Security Controls | 5d | 2025-01-13 | 2025-01-17 | 1302 | finish no earlier than 2025-01-14 |
| 1307 | ServiceNow Support Portal Onboarding (Helix Suppliers& SIT Participants) Completed | 0d | 2025-01-17 | 2025-01-17 | 1296, 1300, 1303, 1306 | start no earlier than 2025-01-17 |
| 1308 | Stage 1 - Helix SIT Operational Readiness Completed | 0d | 2025-01-31 | 2025-01-31 |  | start no earlier than 2025-01-31 |
| 1316 | SITWG paper day | 0d | 2024-11-28 A | 2024-11-28 A | 1315 |  |
| 1318 | SITWG endorse Theme 3 (Batch 2) | 0d | 2024-12-05 A | 2024-12-05 A | 1317 |  |
| 1319 | SITAG paper day | 0d | 2024-12-11 | 2024-12-11 | 1318FS+4d |  |
| 1329 | SITWG paper day | 0d | 2024-11-28 A | 2024-11-28 A | 1328FS+4d |  |
| 1331 | SITWG endorse Theme 3 (Batch 1) | 0d | 2024-12-05 A | 2024-12-05 A | 1330 |  |
| 1332 | SITAG paper day | 0d | 2024-12-11 A | 2024-12-11 A | 1331FS+4d |  |
| 1343 | **Theme 3 Work-off plan** | 76d? | 2025-01-06 | 2025-04-21 |  |  |
| 1344 | Test Scripts updates | 52d | 2025-01-13 | 2025-03-25 | 1340 |  |
| 1345 | RTTM Updated Additional Static RTTM WBS items | 10d | 2025-03-26 | 2025-04-08 | 1344 |  |
| 1346 | Removal of de-scoped TCs from the RTTMs | 5d | 2025-04-02 | 2025-04-08 | 1345FS-5d |  |
| 1347 | Update and stabilisation of all TC ADO IDs | 14d | 2025-04-02 | 2025-04-21 | 1345FS-5d |  |
| 1348 | Addition and integration of Role tags to reqs in the Role RTTMs | 5d | 2025-04-02 | 2025-04-08 | 1345FS-5d |  |
| 1349 | Update of the RTTM All sheet (porting of the individual RTTMs) | 7d | 2025-04-07 | 2025-04-15 | 1345FS-2d |  |
| 1350 | Define Additional ADO Tags | 1d | 2025-04-04 | 2025-04-04 | 1345FS-3d |  |
| 1351 | Upload Operational RTTM to ADO | 0d | 2025-04-15 | 2025-04-15 | 1349 |  |
| 1352 | Further Interative Deepdive on the requirements to testcase mapping | 9d | 2025-04-02 | 2025-04-14 | 1349FS-10d |  |
| 1353 | Internal review | 5d | 2025-04-02 | 2025-04-08 | 1352FS-9d |  |
| 1354 | Issue Static RTTM to Code Bodies | 1d? | 2025-04-10 | 2025-04-10 | 1353FS+1d |  |
| 1355 | Code Body Acceptance of RTTM | 5d | 2025-04-11 | 2025-04-17 | 1354 |  |
| 1356 | **SIT Operational DITL** | 18d | 2025-01-06 | 2025-01-29 |  |  |
| 1357 | DITL Development | 10d | 2025-01-06 | 2025-01-17 |  | start no earlier than 2025-01-06 |
| 1358 | SRO Review | 5d | 2025-01-20 | 2025-01-24 | 1357 |  |
| 1359 | Post-SRO Review Changes | 3d | 2025-01-27 | 2025-01-29 | 1358 |  |
| 1360 | Publish Cycle 3 DITL / Cycle 3 DITL Online Sessions for SIT PPs | 0d | 2025-01-29 | 2025-01-29 | 1359 |  |
| 1367 | **SI SIT Operational Theme 3 (Batch 1) Overarching Test Readiness Report** | 28d | 2024-12-23 | 2025-01-29 |  |  |
| 1368 | Develop Overarching SIT Operational Theme 3 (Batch 1) Overarching Test Readiness Report | 18d | 2024-12-23 | 2025-01-15 | 414 |  |
| 1369 | SRO review | 5d | 2025-01-16 | 2025-01-22 | 1368 |  |
| 1370 | Update Operational Theme 3 (Batch 1) Overarching Test Readiness Report following SRO feedback | 5d | 2025-01-16 | 2025-01-22 | 1369FF, 1307FF |  |
| 1371 | SITAG paper day | 0d | 2025-01-22 | 2025-01-22 | 1370 |  |
| 1372 | SITAG approve Theme 3 (Batch 1) Theme 1 Test Readiness Report | 0d | 2025-01-29 | 2025-01-29 | 1371FS+5d |  |
| 1373 | **SI SIT Operational Theme 1, 2 and 3 (Batch 2) Overarching Test Readiness Report** | 45d | 2025-01-27 | 2025-03-28 |  |  |
| 1374 | Develop Overarching SIT Operational Theme 1, 2 and 3 (Batch 2) Overarching Test Readiness Report | 20d | 2025-01-27 | 2025-02-21 | 397FS+25d | start no earlier than 2025-01-20 |
| 1375 | SRO review | 5d | 2025-02-24 | 2025-02-28 | 1374 |  |
| 1376 | Update Operational Theme 1, 2 and 3 (Batch 2) Overarching Test Readiness Report following SRO feedback | 8d | 2025-03-03 | 2025-03-12 | 1375 |  |
| 1377 | SITAG paper day | 0d | 2025-03-12 | 2025-03-12 | 1376 |  |
| 1378 | SITAG endorse Operational Theme 1, 2 and 3 (Batch 2) Overarching Test Readiness Report | 0d | 2025-03-19 | 2025-03-19 | 1377FS+5d |  |
| 1379 | eSITAG approve Operational Theme 1, 2 and 3 (Batch 2) Overarching Test Readiness Report | 0d | 2025-03-28 | 2025-03-28 | 1378, 1147, 1148 |  |
| 1380 | **SIT Operational Execution Model** | 43d | 2024-08-05 | 2024-10-02 |  |  |
| 1381 | **Theme 3 (Batch 1)** | 27d | 2024-08-05 | 2024-09-10 |  |  |
| 1382 | Develop execution model Theme 3 (Batch 1) | 3d | 2024-12-16 | 2024-12-18 | 1334FF |  |
| 1383 | SRO provide feedback | 14d | 2024-12-19 | 2025-01-07 | 1382 |  |
| 1384 | Address SRO feedback on execution model | 2d | 2025-01-08 | 2025-01-09 | 1383 |  |
| 1385 | Finalise execution model | 3d | 2025-01-10 | 2025-01-14 | 1384 |  |
| 1386 | SITWG paper day | 0d | 2025-01-14 | 2025-01-14 | 1385 |  |
| 1387 | SITWG update on execution model | 0d | 2025-01-21 | 2025-01-21 | 1386FS+5d |  |
| 1388 | **Theme 1, 2 and 3 (Batch 2)** | 23d | 2024-08-05 | 2024-09-04 |  |  |
| 1389 | Develop execution model Theme 1, 2 and 3 (Batch 2) | 3d | 2025-01-13 | 2025-01-15 | 1334 | start no earlier than 2025-01-13 |
| 1390 | SRO provide feedback | 5d | 2025-01-16 | 2025-01-22 | 1389 |  |
| 1391 | Address SRO feedback on execution model | 2d | 2025-01-23 | 2025-01-24 | 1390 |  |
| 1392 | Finalise execution model | 3d | 2025-01-27 | 2025-01-29 | 1391 |  |
| 1393 | SITWG paper day | 0d | 2025-02-05 | 2025-02-05 | 1392FS+5d |  |
| 1394 | SITWG update on execution model | 0d | 2025-02-12 | 2025-02-12 | 1393FS+5d |  |
| 1395 | **SIT Operational Theme 3 (Batch 1) progress reporting** | 29d? | 2024-12-19 A | 2025-01-28 |  |  |
| 1396 | Determine reporting methodology | 2d? | 2024-12-19 A | 2024-12-20 A |  |  |
| 1397 | Implement reporting | 10d | 2024-12-23 | 2025-01-03 | 1396 |  |
| 1398 | SIT Operational Theme 3 (Batch 1) Testing Preparation Complete | 0d | 2025-01-30 | 2025-01-30 | 1372FS+1d, 1307 |  |
| 1405 | Industry review of approach | 10d | 2025-01-20 | 2025-01-31 | 1404FS+5d |  |
| 1406 | Updates to approach doc on back of industry feedback | 7d | 2025-02-03 | 2025-02-11 | 1405 |  |
| 1407 | eSITWG paper day | 0d | 2025-02-11 | 2025-02-11 | 1406 |  |
| 1408 | eSITWG Recommendation | 0d | 2025-02-18 | 2025-02-18 | 1407FS+5d | start no earlier than 2025-01-20 |
| 1415 | LDP review of Regression Test Suite | 2d | 2025-03-17 | 2025-03-18 | 1414 |  |
| 1417 | Incorporate SRO feedback into regression suite doc | 3d | 2025-03-26 | 2025-03-28 | 1416 |  |
| 1418 | Industry review of Regression Test Suite | 10d | 2025-03-31 | 2025-04-11 | 1417 |  |
| 1419 | Incorporate Industry feedback into regression suite doc | 3d | 2025-04-14 | 2025-04-16 | 1418 |  |
| 1420 | eSITWG paper day | 0d | 2025-04-16 | 2025-04-16 | 1419 |  |
| 1424 | eSITAG (inc SRO) Approval of regression suite doc | 0d | 2025-05-01 | 2025-05-01 | 1423FS+5d |  |
| 1427 | Data Load preparation activities | 30d? | 2025-03-05 | 2025-04-15 |  | start no earlier than 2025-03-05 |
| 1526 | SIT Functional Cycle 3 Complete | 1d? | 2025-04-28 | 2025-04-28 | 1525 |  |
| 1530 | Sprint 5 | 20d? | 2024-10-07 A | 2024-11-01 A |  |  |
| 1531 | Sprint 5 Review (Flexibility Window Checkpoint) | 0d | 2024-11-04 A | 2024-11-04 A | 1530SS+21d |  |
| 1532 | Sprint 6 | 10d? | 2024-11-04 A | 2024-11-15 A | 1530 |  |
| 1533 | Sprint 6 Review (Pre Christmas Contingency Decision Point) | 0d | 2024-11-18 A | 2024-11-18 A | 1532SS+11d |  |
| 1534 | Sprint 7 | 10d? | 2024-11-18 A | 2024-11-29 A | 1532 |  |
| 1535 | Sprint 7 Review (Post Christmas Contingency Decision Point) | 0d | 2024-12-02 A | 2024-12-02 A | 1534SS+11d |  |
| 1536 | Sprint 8 | 15d | 2024-12-02 A | 2024-12-20 A | 1534 |  |
| 1537 | Post-Christmas Stabilisation | 5d | 2025-01-06 | 2025-01-10 | 1536FS+10d |  |
| 1538 | Sprint 9 | 10d | 2025-01-06 | 2025-01-17 | 1536FS+10d |  |
| 1539 | Sprint 9 Review | 0d | 2025-01-20 | 2025-01-20 | 1538FS+1d |  |
| 1540 | Sprint 10 | 10d | 2025-01-20 | 2025-01-31 | 1538 |  |
| 1541 | Sprint 10 Review | 0d | 2025-02-03 | 2025-02-03 | 1540FS+1d |  |
| 1542 | Sprint 11 | 10d | 2025-02-03 | 2025-02-14 | 1540 |  |
| 1543 | Sprint 11 Review | 0d | 2025-02-14 | 2025-02-14 | 1542 |  |
| 1544 | Sprint 12 | 5d | 2025-02-17 | 2025-02-21 | 1543 |  |
| 1545 | End of Settlement Testing Cycle 3 | 0d | 2025-02-21 | 2025-02-21 | 1544 |  |
| 1548 | Regression Test Execution Start | 1d | 2025-06-16 | 2025-06-16 | 1429, 1546 |  |
| 1559 | Programme agreement into Settlement Testing | 1d? | 2025-02-07 | 2025-02-07 |  | start no earlier than 2025-02-07 |
| 1590 | SIT Migration Cycle 3 Complete | 0d | 2025-04-25 | 2025-04-25 | 1589 |  |
| 1765 | **Sandbox Testing Execution (UIT)** | 260d | 2025-09-01 | 2026-08-28 |  |  |
| 1766 | Sandbox Testing Start (UIT) | 0d | 2025-09-01 | 2025-09-01 | 1633, 2204FS+5d, 1764 | start no earlier than 2025-02-10 |
| 1767 | Sandbox Testing Execution (UIT) | 260d | 2025-09-01 | 2026-08-28 | 1766SS-1d | start no earlier than 2024-11-04 |
| 1768 | Sandbox Testing End (UIT) | 0d | 2026-08-28 | 2026-08-28 | 1767 |  |
| 1851 | PIT Execution (Non-Functional and Operational) | 90d | 2024-09-23 A | 2025-01-24 | 1849 |  |
| 1853 | Non-SIT LDSO Participants have submitted non-functional PIT Test Completion Report | 0d | 2025-01-24 | 2025-01-24 | 1851 |  |
| 1884 | LDSO Alpha | 86d | 2025-01-06 | 2025-05-05 | 1883FS-1d |  |
| 1885 | LDSO Bravo | 59d | 2025-01-06 | 2025-03-27 | 1883FS-1d |  |
| 1886 | LDSO Charlie | 88d | 2025-01-06 | 2025-05-07 | 1883FS-1d |  |
| 1887 | LDSO Delta | 83d | 2025-01-06 | 2025-04-30 | 1883FS-1d |  |
| 1888 | LDSO Echo | 69d | 2025-01-06 | 2025-04-10 | 1883FS-1d |  |
| 1889 | LDSO Foxtrot | 44d | 2025-01-20 | 2025-03-20 | 1883FS+9d |  |
| 1890 | LDSO Golf | 66d | 2025-01-06 | 2025-04-07 | 1883FS-1d |  |
| 1891 | LDSO Hotel | 45d | 2025-01-06 | 2025-03-07 | 1883FS-1d |  |
| 1892 | LDSO India | 86d | 2025-01-06 | 2025-05-05 | 1883FS-1d |  |
| 1894 | Potential for non-SIT LDSO QT Regression for Qualification | 70d? | 2025-05-19 | 2025-08-22 | 1893FS+1d |  |
| 2026 | **QT Functional (inc NF and Operational) Test Scenarios and Test Cases** | 63d | 2024-11-05 A | 2025-01-30 |  |  |
| 2027 | Draft Test Scenarios and Test Case list - Batch 3 | 20d | 2024-11-05 A | 2024-12-02 A | 882FS-1d |  |
| 2028 | Issue Batch 3 for Consultation | 10d | 2024-12-03 | 2024-12-16 | 2027 |  |
| 2029 | Update Batch 3 Post Consultation | 20d | 2024-12-17 | 2025-01-13 | 2028 |  |
| 2030 | QWG Endorsement of Batch 3 | 0d | 2025-01-22 | 2025-01-22 | 2029FS+7d |  |
| 2031 | QAG Approval of QT Functional Test Scenarios and Test Cases Batches 3 | 0d | 2025-01-30 | 2025-01-30 | 2030FS+6d |  |
| 2060 | Hub Development Dev/Test | 20d | 2024-06-10 A | 2024-07-05 A | 2059SS+10d |  |
| 2071 | DIP Simulator | 15d | 2024-07-26 A | 2024-08-15 A |  | finish no earlier than 2024-08-15 |
| 2072 | DIP (UIT) Instance available for Onboarding | 1d | 2024-08-05 A | 2024-08-05 A |  | start no earlier than 2024-08-05 |
| 2073 | DIP (UIT) Portal | 1d | 2024-09-03 A | 2024-09-03 A | 2072 | start no earlier than 2024-09-03 |
| 2074 | DIP (UIT) Onboarding for Development (incl. certificates and security compliance) | 39d | 2024-08-06 A | 2024-09-27 A | 2072 | finish no earlier than 2024-09-27 |
| 2075 | DIP (UIT) Onboarding for Development Connection Confirmed | 1d | 2024-09-30 A | 2024-09-30 A | 2074 | start no earlier than 2024-09-30 |
| 2076 | DIP (UIT) Onboarding for Test (incl. certificates and security compliance) | 5d | 2024-10-01 A | 2024-10-07 A | 2075 | finish no earlier than 2024-10-07 |
| 2077 | DIP (UIT) Onboarding for Test Connection Confirmed | 1d | 2024-10-08 A | 2024-10-08 A | 2076 | start no earlier than 2024-10-08 |
| 2078 | DIP (UIT) Onboarding for Prod (incl. certificates and security compliance) | 5d | 2024-10-09 A | 2024-10-15 A | 2077 | finish no earlier than 2024-10-15 |
| 2079 | DIP (UIT) Onboarding for Prod Connection Confirmed | 1d | 2024-10-16 A | 2024-10-16 A | 2078 | start no earlier than 2024-10-16 |
| 2084 | New VPN Connection (Test) | 30d | 2024-08-05 A | 2024-09-13 A | 2083 | start no earlier than 2024-08-05 |
| 2085 | New VPN Connection (Prod) | 30d | 2024-09-16 A | 2024-10-25 A | 2084 | finish no earlier than 2024-10-25 |
| 2087 | **Generate Tooling** | 334d | 2024-04-22 A | 2025-07-31 |  |  |
| 2088 | MPAN Core Generator | 25d | 2024-04-22 A | 2024-05-24 A |  | finish no earlier than 2024-05-24 |
| 2089 | MPAN File Generator | 55d | 2024-05-27 A | 2024-08-09 A | 2088 | finish no earlier than 2024-08-09 |
| 2090 | MPAN Template Loader | 32d | 2024-08-12 A | 2024-09-24 A | 2089 | finish no earlier than 2024-09-24 |
| 2091 | ADO Extract (QTC) From SIT | 30d | 2024-05-06 A | 2024-06-14 A |  | finish no earlier than 2024-06-14 |
| 2092 | Populate QT ADO | 40d | 2024-06-17 A | 2024-08-09 A | 2091 | finish no earlier than 2024-08-09 |
| 2093 | Create QTC Spreadsheets | 20d | 2024-06-03 A | 2024-06-28 A | 2091 | finish no earlier than 2024-06-28 |
| 2094 | Upload QTC Spreadsheets to QTF | 20d | 2024-07-01 A | 2024-07-26 A | 2093 | finish no earlier than 2024-07-26 |
| 2095 | Create QTC Set / Master QTC Loader | 40d | 2024-07-22 A | 2024-09-13 A | 2094 | finish no earlier than 2024-09-13 |
| 2096 | **Test Data** | 15d | 2024-06-10 A | 2024-06-28 A |  |  |
| 2098 | **MPANs, DIP Messages, Settlement, Consumption, Reference** | 423d? | 2024-05-27 A | 2026-01-07 |  |  |
| 2099 | Create MPAN Data | 55d | 2024-05-27 A | 2024-08-09 A | 2088 | finish no earlier than 2024-08-09 |
| 2100 | Create message templates (DIP, CSS, DTN) | 40d | 2024-06-03 A | 2024-07-26 A |  | finish no earlier than 2024-07-26 |
| 2101 | Create Consumption Data Templates | 20d | 2024-09-16 A | 2024-10-11 A |  | finish no earlier than 2024-10-11 |
| 2102 | Load Consumption Data | 25d | 2024-11-11 A | 2024-12-13 A | 2101FS+20d |  |
| 2103 | Create Load Shape and Load Shape Total Templates | 20d | 2024-09-16 A | 2024-10-11 A |  | finish no earlier than 2024-10-11 |
| 2104 | Load Shape and Load Shape Total Data | 25d | 2024-11-11 A | 2024-12-13 A | 2103FS+20d |  |
| 2105 | Create Settlement Report Templates | 20d | 2024-09-16 A | 2024-10-11 A |  | finish no earlier than 2024-10-11 |
| 2106 | Load Settlement Report Data | 25d | 2024-11-11 A | 2024-12-13 A | 2105FS+20d |  |
| 2107 | Market Domain Data (MDD) For Legacy Systems | 25d | 2024-07-29 A | 2024-08-30 A |  | finish no earlier than 2024-08-30 |
| 2110 | Helix Dev Environment migration | 6d | 2024-07-29 A | 2024-08-05 A |  | finish no earlier than 2024-08-05 |
| 2111 | STGi (UK) migration | 5d | 2024-09-09 A | 2024-09-13 A |  | finish no earlier than 2024-09-13 |
| 2112 | Maintenance window between cycle 2 and 3 | 1d | 2024-09-20 A | 2024-09-20 A |  |  |
| 2114 | Second View of Migrated ISD Data (HXT1 (SIT B) migration) | 5d | 2024-09-23 A | 2024-09-27 A |  | start no earlier than 2024-09-23 |
| 2118 | **Industry Standing Data (ISD)** | 71d? | 2024-07-26 A | 2024-11-01 A |  |  |
| 2119 | Dependant on Receiving ISD Agreed Source Data from Helix | 1d | 2024-07-26 A | 2024-07-26 A |  | start no earlier than 2024-07-26 |
| 2120 | Helix Dev Environment migration | 6d | 2024-07-29 A | 2024-08-05 A | 2119 | finish no earlier than 2024-08-05 |
| 2121 | STGi (UK) migration | 5d | 2024-09-09 A | 2024-09-13 A | 2119 | finish no earlier than 2024-09-13 |
| 2122 | Maintenance window between cycle 2 and 3 | 1d | 2024-09-20 A | 2024-09-20 A | 2119 | finish no earlier than 2024-09-20 |
| 2123 | First View of Migrated ISD Data | 5d | 2024-09-23 A | 2024-09-27 A | 2122 | finish no earlier than 2024-09-27 |
| 2124 | Second View of Migrated ISD Data (HXT1 (SIT B) migration) | 5d | 2024-09-23 A | 2024-09-27 A | 2122 | finish no earlier than 2024-09-27 |
| 2125 | Final Cycle 3 Migrated ISD Data | 5d | 2024-10-07 A | 2024-10-11 A | 2123 | finish no earlier than 2024-10-11 |
| 2126 | Create ISD Template inc. DIP ID | 35d? | 2024-09-16 A | 2024-11-01 A | 2122 | finish no earlier than 2024-11-01 |
| 2127 | Publish Qualification ISD | 10d? | 2024-10-14 A | 2024-10-25 A | 2125, 2122 | finish no earlier than 2024-10-25 |
| 2128 | **BETA Testing 1 - Test Data** | 27d | 2024-11-01 A | 2024-12-09 |  |  |
| 2129 | Provide Example MPAN File | 3d | 2024-11-01 A | 2024-11-05 A | 2172SS | finish no earlier than 2024-11-05 |
| 2130 | Load Example MPAN File | 6d | 2024-11-06 A | 2024-11-13 A | 2129 | finish no earlier than 2024-11-13 |
| 2131 | Industry Standing Data (ISD) | 6d | 2024-11-06 A | 2024-11-13 A | 2172SS+3d | finish no earlier than 2024-11-13 |
| 2132 | Market Domain Data (MDD) | 6d | 2024-11-06 A | 2024-11-13 A | 2172SS+3d | finish no earlier than 2024-11-13 |
| 2133 | Load ISD / MDD Data | 1d | 2024-12-06 A | 2024-12-06 A | 2131FS+16d, 2132FS+11d | start no earlier than 2024-11-14 |
| 2134 | Create QTC sets and Test MPANs via QTF | 1d | 2024-12-06 A | 2024-12-06 A | 2130FS+16d | start no earlier than 2024-11-14 |
| 2135 | Create QTC sets in ADO via QTF | 1d | 2024-12-06 A | 2024-12-06 A | 2134SS | start no earlier than 2024-11-14 |
| 2136 | Provide Test MPANs (Suppliers only) allocated to specfic QTC's | 1d | 2024-12-06 A | 2024-12-06 A | 2133SS | start no earlier than 2024-11-14 |
| 2137 | Load Test MPANs | 1d | 2024-12-09 A | 2024-12-09 A | 2136 | start no earlier than 2024-11-15 |
| 2138 | **BETA Testing 2 - Test Data** | 11d | 2025-01-08 | 2025-01-22 |  |  |
| 2139 | Provide Example MPAN File | 3d | 2025-01-08 | 2025-01-10 | 2173SS | start no earlier than 2025-01-08 |
| 2140 | Load Example MPAN File | 6d | 2025-01-13 | 2025-01-20 | 2139 | start no earlier than 2025-01-13 |
| 2141 | Industry Standing Data (ISD) | 6d | 2025-01-08 | 2025-01-15 | 2127, 2173SS | start no earlier than 2025-01-08 |
| 2142 | Market Domain Data (MDD) | 6d | 2025-01-08 | 2025-01-15 | 2101, 2173SS | start no earlier than 2025-01-08 |
| 2143 | Load ISD / MDD Data | 1d | 2025-01-16 | 2025-01-16 | 2141, 2142, 2173SS | start no earlier than 2025-01-16 |
| 2144 | Create QTC sets and Test MPANs via QTF | 1d | 2025-01-21 | 2025-01-21 | 2140 | start no earlier than 2025-01-21 |
| 2145 | Create QTC sets in ADO via QTF | 1d | 2025-01-21 | 2025-01-21 | 2144SS | start no earlier than 2025-01-21 |
| 2146 | Provide Test MPANs (Suppliers only) allocated to specfic QTC's | 1d | 2025-01-21 | 2025-01-21 | 2144SS | start no earlier than 2025-01-21 |
| 2147 | Load Test MPANs | 1d | 2025-01-22 | 2025-01-22 | 2146 | start no earlier than 2025-01-22 |
| 2172 | BETA Testing | 33d | 2024-11-01 | 2024-12-17 |  | finish no earlier than 2024-12-17 |
| 2173 | BETA Testing 2 | 58d | 2025-01-08 | 2025-03-28 | 2172 | start no earlier than 2025-01-08 |
| 2174 | Qualification Testing Framework Readiness Confirmed | 0d | 2025-03-28 | 2025-03-28 | 2173 | start no earlier than 2025-03-28 |
| 2472 | MCAG Paper Day | 0d | 2025-02-25 | 2025-02-25 | 2471FS+2d |  |
| 2474 | **Consultation 4** | 87d? | 2025-01-07 | 2025-05-07 |  |  |
| 2475 | **Prepare Artefacts** | 87d? | 2025-01-07 | 2025-05-07 |  |  |
| 2476 | Test Approach | 20d? | 2025-01-07 | 2025-02-03 |  | start no earlier than 2025-01-07 |
| 2477 | Test Plan | 20d? | 2025-02-04 | 2025-03-03 | 2476 |  |
| 2478 | Other Framework items | 47d? | 2025-03-04 | 2025-05-07 | 2477 |  |
| 2479 | Industry Consultation | 10d? | 2025-03-12 | 2025-03-25 |  | start no earlier than 2025-03-12 |
| 2480 | Triage Response | 10d? | 2025-03-26 | 2025-04-08 | 2479 |  |
| 2481 | Assurance and MCAG Approval | 10d? | 2025-04-09 | 2025-04-22 | 2480 |  |
| 2482 | Consultation 4 Approved | 0d | 2025-04-22 | 2025-04-22 | 2481 |  |
| 2483 | Framework Baselined at MCAG | 0d | 2025-04-22 | 2025-04-22 | 2482 |  |
| 2489 | Schedule Production v1 | 25d? | 2024-11-18 | 2024-12-20 |  | start no earlier than 2024-11-18 |
| 2490 | Schedule Production v2 | 80d? | 2025-03-31 | 2025-07-18 |  | start no earlier than 2025-03-31 |
| 2492 | **MCC Stood up** | 265d? | 2024-11-18 | 2025-11-21 |  |  |
| 2493 | **MPMT Delivered** | 265d? | 2024-11-18 | 2025-11-21 |  |  |
| 2494 | **Migration Planning Tool - Delivery** | 265d? | 2024-11-18 | 2025-11-21 |  |  |
| 2495 | MPMT Build Sprints - MVP | 120d? | 2025-01-06 | 2025-06-20 |  | start no earlier than 2025-01-06 |
| 2496 | Delivery Activity | 265d? | 2024-11-18 | 2025-11-21 |  |  |
| 2497 | MCC - Pilot | 0d | 2024-11-20 | 2024-11-20 |  | start no earlier than 2024-11-20 |
| 2498 | MCC Stood up complete | 1d? | 2024-11-18 | 2024-11-18 |  |  |
| 2772 | SIT non-MVC S&As Create Certificates and Test Connectivity | 1d? | 2025-12-23 | 2025-12-23 | 2771 |  |
| 2775 | SIT non-MVC S&As to update systems with ISD | 1d? | 2025-12-29 | 2025-12-29 | 2774 |  |

Removed: 856 SRO Walkthrough; 857 SRO Approval; 882 Cycle 3 Test Case Rationalisation (Functional and Migration); 883 Review Cycle 3 scope and identify candidates for rationalisation; 884 Define proposal for rationalisation of test cases; 886 Present proposed approach; 887 Incorporate feedback; 888 Publish proposed approach ahead of Cycle 3 start; 938 Regression Test data (SIT A); 939 Prepare, Generate and Allocate Test Data; 940 Transmit Data Sets to PPs; 941 PP's Iterative load and data integrity check; 942 Regression - PP's confirmation that test data is ready for SIT Functional; 1074 PP SIT Non-Functional Test Readiness Report; 1075 Develop draft Test Readiness Report and submit to Programme for assurance; 1076 Placing Reliance Stage 2 Review; 1077 Finalise Test Readiness Report and submit to Programme for assurance; 1079 Assure Test Participants' Test Readiness Reports; 1081 Artefact review (via SITAG / SRO) and updates; 1108 Elexon Service Now Build and Implementation; 1111 Helix Knowledge Articles; 1146 PP SIT Operational Test Readiness Report; 1147 Test Readiness Report submitted to Programme for assurance; 1148 SI SIT Operational Test Readiness Report; 1149 Assure Test Participants' Test Readiness Reports; 1150 Develop Overarching SIT Operational Test Readiness Report; 1151 Artefact review (via SITAG) and updates; 1268 Defect resolution, assurance, review, data & environments maintenance; 1601 Non-SIT LDSO QT - Migration Testing; 1602 Non-SIT LDSO QT - Functional Testing; 1603 Non-SIT LDSO QT - Operational Testing; 1604 Non-SIT LDSO QT - Non-Functional Testing; 1605 Non-SIT LDSO QT - Regression Testing; 1614 BSC PAB & REC Manager approval of Qualification for Non-SIT LDSOs (Start of Migration for Qualification Participants); 1739 QT Non-Functional Test Scenarios and Test Cases; 1740 Draft Test Scenarios and Test Case list - Batch 2; 1741 Issue Batch 2 for Consultation; 1742 Update Batch 2 Post Consultation; 1743 QWG Endorsement of Batch 2; 1744 QAG Approval of QT Non-Functional Test Scenarios and Test Cases Batch 2; 1745 QT Operational Test Scenarios and Test Cases; 1746 Draft QT Operational Test Cases - Batch 1; 1747 Issue Batch 1 for Consultation; 1748 Update Batch 1 Post Consultation; 1749 QWG Endorsement of Batch 1; 1750 QAG Approval of QT Operational Test Scenarios and Test Cases Batch 1; 1751 Draft QT Operational Test Cases - Batch 2; 1752 Issue Batch 2 for Consultation; 1753 Update Batch 2 Post Consultation; 1754 QWG Endorsement of Batch 2; 1755 QAG Approval of QT Operational Test Scenarios and Test Cases Batch 2; 1770 DIP (SIT-A) Onboarding for Development inc. Test Stubs; 1771 DTN Onboarding for Development inc. Test Stubs; 1796 DIP available for Onboarding; 1797 Qualification Testing for Non-SIT S&A Participants' environments) Ready to start DIP onboarding (incl. certificates and security compliance); 1798 Non-SIT S&A QTF Environments Connection Confirmed to UIT Environment; 1803 New VPN Connection; 1805 Test Data (MPANs, DIP Messages, Settlement, Consumption, Reference); 1807 Test Data Templates and generator tools ready

Changed:

| ID | Task | Start | Finish | Duration | Complete | Total float | Predecessors | Other |
| --- | --- | --- | --- | --- | --- | --- | --- | --- |
| 1 | **PROGRAMME PLAN.** |  |  |  | 51% → 53% | 0d → none |  |  |
| 45 | **DESIGN, BUILD & TEST (PIT)** |  |  |  | 78% → 79% | 123d → 31696d |  |  |
| 96 | **Design Artefact Releases** |  | 2024-11-13 → 2025-01-27 (+75d) | 451d → 504d? | 99% → 97% | 811d → 32331d |  |  |
| 136 | **Interim release 8** |  | 2024-11-13 → 2025-01-27 (+75d) | 196d → 249d? | 99% → 84% | 811d → 32331d |  |  |
| 139 | **Interim Release 8.3 - Maintenance Window** | 2024-10-07 A | 2024-10-21 A |  | 0% → 100% | 16d → none |  |  |
| 140 | Interim Release 8.3 'effective from date' to SIT A | 2024-10-21 A | 2024-10-21 A |  | 0% → 100% | 5d → none |  |  |
| 141 | Interim Release 8.3 'effective from date' to SIT B | 2024-10-07 A | 2024-10-07 A |  | 0% → 100% | 38d → none |  |  |
| 142 | **Interim Release 8.4** |  | 2024-11-13 → 2024-12-02 A (+19d) | 36d → 49d | 99% → 100% | 811d → none |  |  |
| 144 | Interim Release 8.4 Published | 2024-10-16 A | 2024-10-16 A |  | 0% → 100% | 811d → none |  | was named Interim release 8.4 Published |
| 145 | Interim Release 8.4 Deployed to SIT by Participants | 2024-11-13 → 2024-11-25 A (+12d) | 2024-11-13 → 2024-12-02 A (+19d) | 0d → 6d | 0% → 100% | 811d → none | 144FS+20d → 144FS+25d |  |
| 175 | **PP Design, Build & Test (DBT)** |  |  |  | 82% → 83% | 123d → 31696d |  |  |
| 187 | **Design Handover** |  |  |  | 2% → 6% | 123d → 31696d |  |  |
| 188 | **Creation of the Configuration Management Database** | 2024-09-02 A | 2024-09-19 A |  | 0% → 100% | 850d → none |  |  |
| 189 | Identify all baselined design artefacts | 2024-09-02 A | 2024-09-12 A |  | 0% → 100% | 850d → none |  |  |
| 190 | Create CMBD | 2024-09-13 A | 2024-09-19 A |  | 0% → 100% | 850d → none |  |  |
| 213 | **iServer** |  |  |  |  |  |  | was named Iserver |
| 312 | **SIT Participants DBT** |  | 2024-12-20 → 2025-02-21 (+63d) | 356d → 401d |  | 125d → 32307d |  |  |
| 347 | **All SIT Programme Participants PIT (SIT Functional)** |  | 2024-12-20 → 2025-02-21 (+63d) | 286d → 331d |  | 125d → 32307d |  |  |
| 381 | **All SIT Programme Participants PIT (SIT Non Functional)** |  | 2024-12-20 → 2025-02-21 (+63d) | 116d → 161d |  | 125d → 32307d |  |  |
| 383 | SIT Non-Functional PIT Test Approach & Plan (PIT) submitted to Programme for assurance |  | 2024-09-27 A |  | 75% → 100% | 0d → none |  |  |
| 388 | SIT Non-Functional PIT RTTM submitted to Programme for assurance |  | 2024-11-01 A |  | 75% → 100% | 140d → none |  |  |
| 390 | **Test Scenarios** | 2024-11-01 A |  |  |  | 0d → 31625d |  |  |
| 391 | SIT Non-Functional PIT test scenarios submitted to Programme for assurance | 2024-11-01 A | 2024-11-01 A |  | 0% → 100% | 0d → none |  |  |
| 393 | **PIT execution** |  | 2024-12-20 → 2025-02-21 (+63d) | 116d → 161d |  | 125d → 32307d |  |  |
| 397 | SIT Non-Functional PIT Completion Report Theme 1 MHHS Review Completed | 2024-12-20 A |  |  | 0% → 50% | 125d → 31610d |  | was named SIT Non-Functional PIT Completion Report MHHS Review Completed |
| 399 | **All SIT Programme Participants PIT (SIT Operational)** |  | 2024-12-20 → 2025-01-10 (+21d) | 116d → 131d |  | 87d → 31659d |  |  |
| 400 | **Test Approach & Plan** | 2024-09-27 A |  |  |  | 0d → 31695d |  |  |
| 401 | SIT Operational PIT Test Approach & Plan (PIT) submitted to Programme for assurance | 2024-09-27 A | 2024-09-27 A |  | 0% → 100% | 0d → none |  |  |
| 405 | **Requirements to test Traceability Matrix (RTTM)** | 2024-11-01 A |  |  |  | 102d → 31689d |  |  |
| 406 | SIT Operational PIT RTTM submitted to Programme for assurance | 2024-11-01 A | 2024-11-01 A |  | 0% → 100% | 102d → none |  |  |
| 408 | **Test Scenarios** | 2024-11-01 A |  |  |  | 0d → 31689d |  |  |
| 409 | SIT Operational PIT test scenarios submitted to Programme for assurance | 2024-11-01 A | 2024-11-01 A |  | 0% → 100% | 0d → none |  |  |
| 411 | **PIT execution** |  | 2024-12-20 → 2025-01-10 (+21d) | 116d → 131d |  | 87d → 31659d |  |  |
| 414 | SIT Operational PIT Completion Report submitted to Programme for assurance | 2024-11-29 → 2024-12-20 (+21d) | 2024-11-29 → 2024-12-20 (+21d) |  |  | 87d → 31633d | 412, 413 → 412, 413FS+15d |  |
| 415 | SIT Operational PIT Completion Report MHHS Review Completed | 2024-12-20 → 2025-01-10 (+21d) | 2024-12-20 → 2025-01-10 (+21d) |  |  | 87d → 31633d |  |  |
| 467 | **DBT Monitoring and Assurance** |  |  |  | 64% → 69% | 502d → 32075d |  |  |
| 472 | **Design Assurance** |  |  |  | 71% → 80% | 621d → 32194d |  |  |
| 503 | **Non-SIT PPs design assurance** |  |  |  | 33% → 53% | 621d → 32194d |  |  |
| 504 | Non-SIT PPs design assurance (risk-based sample) |  |  |  | 33% → 53% | 621d → 32194d |  |  |
| 505 | **Test Assurance** |  |  |  | 63% → 71% | 648d → 32221d |  |  |
| 506 | Non-SIT PPs test assurance |  |  |  | 63% → 71% | 648d → 32221d |  |  |
| 514 | **SIT Preparation** |  |  |  | 81% → 88% | 679d → 32252d |  |  |
| 595 | **SIT Stage-Specific Preparation** |  |  |  | 77% → 85% | 679d → 32252d |  |  |
| 836 | **SIT Functional Preparation** |  | 2025-04-07 → 2025-02-07 (-59d) | 636d? → 595d? | 85% → 99% | 708d → 32322d |  |  |
| 853 | **Test cases** |  |  |  | 84% → 98% | 749d → 32322d |  |  |
| 860 | **SIT Functional Programme RTTM** |  | 2024-10-11 → 2024-11-07 (+27d) | 55d? → 74d? | 95% → 96% | 834d → 32388d |  |  |
| 861 | **RTTM Development** |  |  |  | 99% → 89% | 849d → 32422d |  |  |
| 864 | Development of Automated SIT Functional RTTM |  | 2024-09-20 A → 2024-09-20 |  | 100% → 80% | none → 32422d |  |  |
| 866 | **Gap analysis** |  | 2024-10-11 → 2024-11-07 A (+27d) | 35d? → 54d? | 86% → 100% | 834d → none |  |  |
| 867 | Identify gaps in test case coverage following RTTM review |  |  |  |  |  |  | was named Identify gaps in test case coverage following RTTM review. |
| 868 | Address gaps in test case coverage following RTTM review |  | 2024-10-04 → 2024-10-11 A (+7d) | 20d → 25d | 80% → 100% | 834d → none |  | was named Address gaps in test case coverage following RTTM review. |
| 869 | Gap analysis complete | 2024-10-11 A | 2024-10-11 A |  | 0% → 100% | 834d → none | SRO ApprovalFS+2d → 868 |  |
| 883 | **Cycle 3 Test Evidence Capturing Approach** |  | 2024-10-18 A |  | 93% → 100% | 3d → none |  |  |
| 888 | Incorporate feedback |  | 2024-10-17 A |  | 80% → 100% | 3d → none |  |  |
| 889 | Publish proposed approach ahead of Cycle 3 start | 2024-10-18 A | 2024-10-18 A |  | 0% → 100% | 3d → none |  |  |
| 890 | **DITL Cycle 3 Pack Development** |  | 2024-10-17 A |  | 31% → 100% | 830d → none |  |  |
| 892 | Post-retro DITL Changes |  | 2024-10-11 A |  | 50% → 100% | 830d → none |  |  |
| 893 | SRO Review | 2024-10-14 A | 2024-10-15 A |  | 0% → 100% | 830d → none |  |  |
| 894 | Post-SRO Review Changes | 2024-10-16 A | 2024-10-16 A |  | 0% → 100% | 830d → none |  |  |
| 895 | Publish Cycle 3 DITL / Cycle 3 DITL Online Sessions for SIT PPs | 2024-10-17 A | 2024-10-17 A |  | 0% → 100% | 830d → none |  |  |
| 896 | **Test Script Exit Points** |  | 2025-02-07 A |  | 7% → 100% | 749d → none |  |  |
| 897 | Implement exit points for Sprint 5 |  | 2024-10-18 A |  | 60% → 100% | 829d → none |  | was named Identify exit points for Sprint 5 |
| 898 | Identify exit points for Sprint 6 | 2024-10-21 → 2024-11-07 A (+17d) | 2024-10-25 → 2024-11-13 A (+19d) |  | 0% → 100% | 824d → none |  |  |
| 899 | Identify exit points for Sprint 7 | 2024-11-04 → 2024-11-08 A (+4d) | 2024-11-08 → 2024-11-14 A (+6d) |  | 0% → 100% | 814d → none |  | constraint none → start no earlier than 2024-11-08 |
| 900 | Identify exit points for Sprint 8 | 2024-11-18 A | 2024-11-22 A |  | 0% → 100% | 804d → none |  |  |
| 901 | Identify exit points for Sprint 9 | 2024-12-02 A | 2024-12-06 A |  | 0% → 100% | 794d → none |  |  |
| 902 | Identify exit points for Sprint 10 | 2024-12-23 A | 2024-12-27 A |  | 0% → 100% | 779d → none |  |  |
| 903 | Identify exit points for Sprint 11 | 2025-01-06 A | 2025-01-10 A |  | 0% → 100% | 769d → none |  |  |
| 904 | Identify exit points for Sprint 12 | 2025-01-20 A | 2025-01-24 A |  | 0% → 100% | 759d → none |  |  |
| 905 | Identify exit points for Sprint 13 | 2025-02-03 A | 2025-02-07 A |  | 0% → 100% | 749d → none |  |  |

| ID | Task | Start | Finish | Duration | Complete | Total float | Predecessors | Other |
| --- | --- | --- | --- | --- | --- | --- | --- | --- |
| 924 | **Test data (SIT A)** |  | 2025-04-07 → 2024-10-21 A (-168d) | 341d? → 221d? | 57% → 100% | 708d → none |  |  |
| 935 | **Cycle 3 Test data (SIT A) (2)** |  | 2024-10-21 A |  | 80% → 100% | 828d → none |  |  |
| 950 | New MPAN creation and load through DCC and St Clements |  | 2024-10-11 A |  | 95% → 100% | 834d → none |  |  |
| 951 | Share files with PP's and central parties | 2024-10-11 A | 2024-10-11 A |  | 0% → 100% | 834d → none |  |  |
| 952 | Avanade to load data | 2024-10-14 A | 2024-10-21 A |  | 0% → 100% | 828d → none |  |  |
| 953 | Helix to load data | 2024-10-14 A | 2024-10-21 A |  | 0% → 100% | 828d → none |  |  |
| 954 | PP's and central parties to load all Cycle 3 data | 2024-10-14 A | 2024-10-21 A |  | 0% → 100% | 828d → none |  |  |
| 955 | All parties to finalise data load | 2024-10-21 A | 2024-10-21 A |  | 0% → 100% | 34d → none |  |  |
| 966 | **SIT Migration Testing Preparation** |  | 2024-10-04 → 2025-01-31 (+119d) | 505d? → 590d? | 98% → 91% | 839d → 32327d |  |  |
| 977 | **Test scenarios & Test Cases** |  | 2024-10-04 → 2025-01-31 (+119d) | 207d? → 292d? | 93% → 74% | 839d → 32327d |  |  |
| 1001 | **Gap analysis** |  | 2024-10-04 → 2025-01-31 (+119d) | 17d? → 102d? | 60% → 47% | 839d → 32327d |  |  |
| 1003 | Address gaps in test case coverage following RTTM review. |  | 2024-10-04 → 2024-10-11 A (+7d) | 12d → 17d | 20% → 100% | 839d → none |  |  |
| 1004 | Gap analysis complete | 2024-10-04 → 2024-10-11 A (+7d) | 2024-10-04 → 2024-10-11 A (+7d) |  | 0% → 100% | 839d → none |  |  |
| 1071 | **SIT Non-Functional Preparation** |  | 2025-03-14 → 2025-03-28 (+14d) | 337d? → 347d? | 51% → 66% | 724d → 32287d |  |  |
| 1082 | **Test scenarios & Test Cases** |  |  |  | 78% → 81% |  |  |  |
| 1101 | **SIT NFT Programme RTTM** | 2024-09-18 A | 2024-10-16 → 2024-12-04 (+49d) | 21d? → 56d? | 0% → 78% | 831d → 32369d |  |  |
| 1102 | Develop Manual SIT NFT RTTM | 2024-09-18 A | 2024-10-08 → 2024-10-29 A (+21d) | 15d → 30d | 0% → 100% | 831d → none |  | baseline finish 2024-10-08 → 2024-10-29 |
| 1104 | Review with SRO | 2024-10-09 → 2024-11-13 A (+35d) | 2024-10-09 → 2024-11-19 A (+41d) | 1d? → 5d | 0% → 100% | 836d → none | 1102 → 1103 | baseline start 2024-10-09 → 2024-11-13; baseline finish 2024-10-09 → 2024-11-19 |
| 1106 | Manual SIT NFT RTTM Complete | 2024-10-08 → 2024-11-19 (+42d) | 2024-10-08 → 2024-11-19 (+42d) |  |  | 831d → 32369d | 1102 → 1104, 1105 | baseline start 2024-10-08 → 2024-11-19; baseline finish 2024-10-08 → 2024-11-19 |
| 1107 | Develop Automated SIT NFT RTTM | 2024-10-09 → 2024-11-20 (+42d) | 2024-10-15 → 2024-12-03 (+49d) | 5d → 10d |  | 831d → 32369d |  | baseline start 2024-10-09 → 2024-11-20; baseline finish 2024-10-15 → 2024-12-03 |
| 1108 | Review with SRO | 2024-10-16 → 2024-12-04 (+49d) | 2024-10-16 → 2024-12-04 (+49d) |  |  | 831d → 32369d |  | baseline start 2024-10-16 → 2024-12-04; baseline finish 2024-10-16 → 2024-12-04 |
| 1109 | Automated SIT NFT RTTM Complete | 2024-10-15 → 2024-12-03 (+49d) | 2024-10-15 → 2024-12-03 (+49d) |  |  | 832d → 32370d |  | baseline start 2024-10-15 → 2024-12-03; baseline finish 2024-10-15 → 2024-12-03 |
| 1129 | **NFT Performance Tool Theme 1 Setup** |  | 2025-01-10 → 2025-03-12 (+61d) | 225d? → 268d? | 68% → 98% | 769d → 32299d |  |  |
| 1133 | Theme 1 injection tool configuration and validation againast UIT DIP (IR8.1) | 2024-10-02 A | 2024-10-16 A |  | 0% → 100% | 769d → none |  |  |
| 1134 | Theme 1 injection tool configuration and validation against SIT-B DIP (IR8.3) | 2024-10-17 → 2025-03-10 (+144d) | 2025-01-10 → 2025-03-12 (+61d) | 62d? → 3d? |  | 769d → 32299d | 1133 → 1545FS+10d | baseline start 2024-10-17 → 2025-01-06; baseline finish 2025-01-10 → 2025-01-08 |
| 1135 | **Environments (SIT B)** |  | 2025-01-03 → 2025-02-28 (+56d) | 94d? → 134d |  | 774d → 31603d |  |  |
| 1138 | **SI Environments (SIT B)** | 2024-08-27 A | 2024-08-27 A |  | 0% → 100% | 868d → none |  |  |
| 1139 | Coordinate deployment of MHHS solution code to SIT Participants' SIT B environments | 2024-08-27 A | 2024-08-27 A |  | 0% → 100% | 868d → none |  |  |
| 1140 | **Helix and Avanade Environments Upscale** | 2024-12-23 → 2025-02-24 (+63d) | 2025-01-03 → 2025-02-28 (+56d) | 10d? → 5d |  | 60d → 31603d |  |  |
| 1141 | Environment Uplift Window | 2024-12-23 → 2025-02-24 (+63d) | 2025-01-03 → 2025-02-28 (+56d) | 10d? → 5d |  | 60d → 31603d | 1529 → 1545 |  |
| 1142 | **Test Data - Non-Functional and Operational (SIT B)** | 2025-01-06 → 2025-02-24 (+49d) | 2025-03-14 → 2025-03-28 (+14d) | 50d? → 25d? |  | 60d → 31603d |  |  |
| 1143 | **Data Load** | 2025-01-06 → 2025-02-24 (+49d) | 2025-03-14 → 2025-03-28 (+14d) | 50d? → 25d? |  | 60d → 31603d |  |  |
| 1144 | Non-Functional Theme 1 (Avenade) Data Load | 2025-01-06 → 2025-02-24 (+49d) | 2025-01-10 → 2025-02-28 (+49d) |  |  | 60d → 31603d | 1141 → 1545 | was named Non-Functional Theme 1 (Helix & DIP Volume Testing) Data Load; baseline start 2025-01-06 → 2025-02-24; baseline finish 2025-01-10 → 2025-02-28 |
| 1145 | Non-Functional Theme 2 & 3 (Helix, Avenade & PPs) Data Load | 2025-02-03 → 2025-03-24 (+49d) | 2025-02-07 → 2025-03-28 (+49d) |  |  | 70d → 31633d | 1604 → 1604FS+1d | was named Non-Functional Theme 2 & 3 (Helix and DIP) Data Load; baseline start 2025-02-03 → 2025-03-24; baseline finish 2025-02-07 → 2025-03-28 |
| 1146 | Non-Functional Themes 2 & 3 (LDSO's and DCC) Data Load | 2025-01-06 → 2025-03-03 (+56d) | 2025-01-31 → 2025-03-21 (+49d) | 20d? → 15d |  | 100d → 31638d |  | was named Non-Functional Themes 2 & 3 (Central Parties and PPs) Data Load; baseline start 2025-01-06 → 2025-03-03; baseline finish 2025-01-31 → 2025-03-21 |
| 1147 | Operational Themes 1, 2 & 3 (Batch 2) (LDSO's and DCC) Data Load | 2025-01-06 → 2025-03-03 (+56d) | 2025-01-31 → 2025-03-28 (+56d) |  |  | 65d → 31603d |  | was named Operational Themes 1, 2 & 3 (Batch 2) (Central Parties and PPs) Data Load; baseline start 2025-01-06 → 2025-03-03; baseline finish 2025-01-31 → 2025-03-28 |
| 1148 | Operational Themes 1, 2 & 3 (Batch 2) (Helix, Avenade & PPs) Data Load | 2025-02-03 → 2025-03-24 (+49d) | 2025-02-07 → 2025-03-28 (+49d) |  |  | 60d → 31603d | 1604 → 1604FS+1d | was named Operational Themes 1, 2 & 3 (Batch 2) (Helix & DIP) Data Load; baseline start 2025-02-03 → 2025-03-24; baseline finish 2025-02-07 → 2025-03-28 |
| 1149 | Non-Functional and Operational Test Data Preparation Complete | 2025-02-07 → 2025-03-28 (+49d) | 2025-02-07 → 2025-03-28 (+49d) |  |  | 749d → 32287d |  | baseline start 2025-02-07 → 2025-03-28; baseline finish 2025-02-07 → 2025-03-28 |
| 1150 | Non-Functional Theme 2 & 3 PP Preparation | 2025-02-10 → 2025-03-28 (+46d) | 2025-03-14 → 2025-03-28 (+14d) | 25d? → 0d |  | 70d → 32287d |  | baseline start 2025-02-10 → 2025-03-31; baseline finish 2025-03-14 → 2025-05-02 |
| 1151 | **SIT Non-Functional Test Readiness Report** | 2024-06-25 A → 2024-12-23 (+181d) | 2025-03-07 → 2025-03-28 (+21d) | 184d → 70d | 19% → 0% | 70d → 31610d |  |  |
| 1152 | **SIT Non-Functional Theme 1 Overarching Test Readiness Report** | 2024-06-25 A → 2024-12-23 (+181d) | 2025-01-10 → 2025-02-28 (+49d) | 144d → 50d | 22% → 0% | 95d → 31610d |  | was named SI SIT Non-Functional Test Readiness Report |
| 1153 | Develop Overarching SIT Non-Functional Theme 1 Overarching Test Readiness Report | 2024-12-02 A → 2024-12-23 (+21d) | 2024-12-20 → 2025-01-09 (+20d) | 15d → 14d | 47% → 0% | 95d → 31610d | Assure Test Participants' Test Readiness ReportsFS-10d → 397 | was named Develop Overarching SIT Non-Functional Test Readiness Report |
| 1154 | SRO review | 2024-10-21 → 2025-01-10 (+81d) | 2024-10-25 → 2025-01-16 (+83d) |  |  | 818d → 31610d | Define proposal for rationalisation of test cases → 1153 | baseline start 2024-10-21 → 2025-01-10; baseline finish 2024-10-25 → 2025-01-16 |
| 1187 | Implement reporting | 2025-03-07 → 2024-12-23 (-74d) | 2025-03-07 → 2025-01-10 (-56d) | 0d → 15d |  | 70d → 31728d | Artefact review (via SITAG / SRO) and updatesFF+15d, 842, 397, 1088, 1094, 1100, Placing Reliance Stage 2 Review → 842, 397, 1088, 1094, 1100 | was named SIT Non-Functional Testing Preparation Complete; baseline start 2025-03-07 → 2024-12-30; baseline finish 2025-03-07 → 2025-01-10 |
| 1190 | **SIT Operational Preparation** | 2024-02-01 A → 2022-10-31 A (-458d) | 2025-01-31 → 2025-04-21 (+80d) | 262d? → 646d? | 38% → 69% | 754d → 32271d |  |  |
| 1201 | **Test scenarios & Test Cases** |  | 2025-01-31 → 2024-09-06 A (-147d) | 213d? → 108d | 31% → 100% | 754d → none |  |  |
| 1243 | **Elexon / Helix Service Management Test Prep** | 2024-07-15 → 2024-08-01 A (+17d) | 2025-01-31 → 2025-01-14 (-17d) | 145d? → 119d? | 0% → 87% | 115d → 31701d |  |  |
| 1274 | ServiceNow SIT Ops Available | 2024-09-09 → 2025-01-14 (+127d) | 2025-01-31 → 2025-01-14 (-17d) | 105d? → 0d? |  | 115d → 31701d | none → 1248, 1253, 1258, 1263, 1268, 1273 | was named Helix Engagement and Comms; baseline start 2024-09-09 → 2025-01-14; baseline finish 2025-01-31 → 2025-01-14 |
| 1275 | **Helix Service Management Documentation (Service Design Pack)** | 2024-09-09 → 2024-08-01 A (-39d) | 2025-01-31 → 2024-12-20 (-42d) | 105d? → 102d | 0% → 88% | 115d → 31718d |  | was named Helix Service Management Documentation (Service Design Pack and Service User Op Model); constraint start no earlier than 2024-09-09 → none |
| 1309 | **Theme 3 (Batch 2)** |  | 2024-12-11 → 2024-12-18 (+7d) | 60d? → 65d | 26% → 99% | 791d → 31675d |  |  |
| 1310 | Conclude BCDR Scope with SRO, Code Bodies and DIP Manager |  | 2024-10-18 A |  | 50% → 100% | 829d → none |  |  |
| 1312 | Develop DIP Test Scenarios and Test Cases (Batch 2) | 2024-09-19 A | 2024-10-25 A |  | 0% → 100% | 1d → none |  |  |
| 1313 | SRO Review | 2024-10-28 A | 2024-11-01 A |  | 0% → 100% | 1d → none |  |  |
| 1314 | Industry Consultation (Batch 2) | 2024-11-04 A → 2024-11-11 A (+7d) | 2024-11-15 → 2024-11-22 A (+7d) |  | 10% → 100% | 94d → none |  | was named Industry Review Workshop (Batch 2); baseline start 2024-11-04 → 2024-11-11; baseline finish 2024-11-15 → 2024-11-22 |
| 1315 | Review Feedback and Update | 2024-11-18 → 2024-11-25 A (+7d) | 2024-11-22 → 2024-11-28 A (+6d) | 5d → 4d | 0% → 100% | 94d → none |  | baseline start 2024-11-18 → 2024-11-25; baseline finish 2024-11-22 → 2024-11-29 |
| 1317 | Review with SIT WG (Batch 2) | 2024-11-28 → 2024-11-29 A (+1d) | 2024-12-05 A | 6d → 5d | 0% → 100% | 94d → none | 1315FS+3d → 1316 | baseline start 2024-11-28 → 2024-11-29 |
| 1320 | SITAG approve Theme 3 (Batch 2) | 2024-12-11 → 2024-12-18 (+7d) | 2024-12-11 → 2024-12-18 (+7d) | 1d? → 1d |  | 94d → 31670d | 1317FS+3d → 1319FS+4d | was named SITAG Approval (Batch 2); baseline start 2024-12-11 → 2024-12-18; baseline finish 2024-12-11 → 2024-12-18 |
| 1321 | **Theme 3 (Batch 1)** |  | 2024-12-11 → 2024-12-18 A (+7d) | 176d? → 181d? | 75% → 100% | 94d → none |  |  |
| 1324 | Review Feedback and Update |  | 2024-09-26 A |  | 90% → 100% | 7.5d → none |  |  |
| 1325 | Draft Test Cases from Feedback and LLSD |  | 2024-10-18 A |  | 50% → 100% | 94d → none |  |  |
| 1326 | SRO Review | 2024-10-21 A | 2024-10-25 A |  | 0% → 100% | 94d → none |  |  |
| 1327 | Industry Consultation | 2024-10-28 A | 2024-11-08 A |  | 0% → 100% | 94d → none |  |  |
| 1328 | Review Feedback and Update | 2024-11-11 A | 2024-11-15 → 2024-11-22 A (+7d) | 5d → 10d | 0% → 100% | 94d → none |  |  |
| 1330 | Review with SITWG (Batch 1) | 2024-11-28 → 2024-11-29 A (+1d) | 2024-12-04 → 2024-12-05 A (+1d) | 5d? → 5d | 0% → 100% | 94d → none | 1328FS+8d → 1329 | baseline start 2024-11-28 → 2024-11-29; baseline finish 2024-12-04 → 2024-12-05 |
| 1333 | SITAG approve Theme 3 (Batch 1) | 2024-12-11 → 2024-12-18 A (+7d) | 2024-12-11 → 2024-12-18 A (+7d) | 1d → 0d | 0% → 100% | 94d → none | 1330FS+4d → 1332FS+5d | was named SITAG for approval (Batch 1); baseline start 2024-12-11 → 2024-12-18; baseline finish 2024-12-11 → 2024-12-18 |
| 1334 | SIT Operational Scenarios & Test Cases Approved - Theme 3 (Batch 1 + 2) | 2024-12-11 → 2024-12-18 A (+7d) | 2024-12-11 → 2024-12-18 A (+7d) |  | 0% → 100% | 94d → none |  | baseline start 2024-12-11 → 2024-12-18; baseline finish 2024-12-11 → 2024-12-18 |
| 1335 | **Helix SDD and LLSD Development and Approval** | 2024-09-27 A | 2024-09-30 A |  | 0% → 100% | 8.5d → none |  |  |
| 1336 | Development | 2024-09-27 A | 2024-09-27 A |  | 0% → 100% | 845d → none |  |  |
| 1337 | Approval | 2024-09-30 A | 2024-09-30 A |  | 0% → 100% | 7.5d → none |  |  |
| 1338 | **SIT Operational Programme RTTM** | 2024-12-12 → 2024-12-09 A (-3d) |  | 27d? → 30d | 0% → 27% | 764d → 32337d |  |  |

| ID | Task | Start | Finish | Duration | Complete | Total float | Predecessors | Other |
| --- | --- | --- | --- | --- | --- | --- | --- | --- |
| 1339 | Develop Manual SIT Operational RTTM | 2024-12-12 → 2024-12-09 A (-3d) |  | 22d? → 25d | 0% → 32% | 764d → 32271d | 1334 → 1334FF |  |
| 1361 | **Environments (SIT B)** | 2024-10-07 A | 2024-10-07 A |  | 0% → 100% | 38d → none |  |  |
| 1362 | **PP Environments (SIT B)** | 2024-10-07 A | 2024-10-07 A |  | 0% → 100% | 38d → none |  |  |
| 1363 | Deployment of MHHS solution code to SIT B environments | 2024-10-07 A | 2024-10-07 A |  | 0% → 100% | 38d → none |  |  |
| 1364 | **SI Environments (SIT B)** | 2024-10-07 A | 2024-10-07 A |  | 0% → 100% | 38d → none |  |  |
| 1365 | Coordinate deployment of MHHS solution code to SIT Participants' SIT B environments | 2024-10-07 A | 2024-10-07 A |  | 0% → 100% | 38d → none |  |  |
| 1366 | **SIT Operational Overarching Test Readiness Reports** | 2024-08-05 A |  | 33d → 33d? | 0% → 2% |  |  | was named SIT Operational Test Readiness Report |
| 1399 | SIT Operational Theme 1, 2, 3 (Batch 2) Testing Preparation Complete | 2025-01-17 → 2025-03-28 (+70d) | 2025-01-17 → 2025-03-28 (+70d) |  |  | 67d → 31604d | 415, 1207, 1213, 1334, Artefact review (via SITAG) and updates → 415, 1207, 1213, 1334, 1379 | was named SIT Operational Testing Preparation Complete; baseline start 2025-01-17 → 2025-03-31; baseline finish 2025-01-17 → 2025-04-25 |
| 1400 | **Regression Test Preparation** | 2024-09-16 A → 2024-11-18 A (+63d) | 2025-05-16 → 2024-11-19 (-178d) | 175d? → 2d? | 3% → 10% | 679d → none |  | was named Regression Test Preperation |
| 1401 | **Regression Test Approach** | 2024-09-16 A → 2024-11-18 A (+63d) | 2024-11-20 → 2024-11-29 (+9d) | 48d → 10d | 7% → 26% | 119d → none |  |  |
| 1402 | Develop approach doc | 2024-09-16 A → 2024-11-18 A (+63d) | 2024-10-15 → 2024-12-06 A (+52d) | 22d → 15d | 10% → 100% | 119d → none |  | baseline start 2024-09-16 → 2024-11-18; baseline finish 2024-10-15 → 2024-12-13 |
| 1403 | SRO / LDP review of approach doc | 2024-10-16 → 2024-12-09 A (+54d) | 2024-10-18 → 2024-12-20 (+63d) | 3d → 10d | 0% → 3% | 119d → 31614d |  | was named SRO review of approach doc; baseline start 2024-10-16 → 2024-12-16; baseline finish 2024-10-18 → 2024-12-18 |
| 1404 | Incorporate SRO feedback into approach doc | 2024-10-28 → 2024-12-23 (+56d) | 2024-10-29 → 2025-01-10 (+73d) | 2d → 15d |  | 119d → 31614d | 1403FS+5d → 1403 | was named SITWG feedback on approach doc; baseline start 2024-10-28 → 2024-12-19; baseline finish 2024-10-29 → 2024-12-20 |
| 1409 | Incorporate eSITWG feedback into approach doc | 2024-10-30 → 2025-02-19 (+112d) | 2024-10-31 → 2025-02-20 (+112d) |  |  | 119d → 32308d | 1404 → 1408 | was named Incorporate SRO + SITWG feedback into approach doc; baseline start 2024-10-30 → 2025-01-09; baseline finish 2024-10-31 → 2025-01-09 |
| 1410 | eSITAG paper day | 2024-11-07 → 2025-02-20 (+105d) | 2024-11-07 → 2025-02-20 (+105d) | 1d → 0d |  | 119d → 32308d | 1409FS+4d → 1409 | was named SITWG Recommendation; baseline start 2024-11-07 → 2025-01-09; baseline finish 2024-11-07 → 2025-01-09 |
| 1411 | eSITAG (inc SRO) Approval | 2024-11-20 → 2025-02-27 (+99d) | 2024-11-20 → 2025-02-27 (+99d) |  |  | 119d → 32308d | 1410FS+9d → 1410FS+5d | was named SITAG (inc SRO) Approval; baseline start 2024-11-20 → 2025-01-16; baseline finish 2024-11-20 → 2025-01-16 |
| 1412 | SIT Regression Testing Approach and Plan Approval | 2024-11-20 → 2025-02-27 (+99d) | 2024-11-20 → 2025-02-27 (+99d) |  |  | 119d → 32308d |  | baseline start 2024-11-20 → 2025-01-16; baseline finish 2024-11-20 → 2025-01-16 |
| 1413 | **Regression Test Suite** | 2024-11-21 → 2025-02-12 (+83d) | 2025-01-13 → 2025-05-01 (+108d) | 38d? → 57d |  | 119d → 31614d |  | baseline start 2024-11-21 → 2025-01-17; baseline finish 2025-01-13 → 2025-03-18 |
| 1414 | Build Regression Test Suite | 2024-11-21 → 2025-02-12 (+83d) | 2024-12-06 → 2025-03-14 (+98d) | 12d → 23d |  | 119d → 31614d | 1412 → 1407 | baseline start 2024-11-21 → 2025-01-17; baseline finish 2024-12-06 → 2025-02-06 |
| 1416 | SRO Review of regression suite doc | 2024-12-09 → 2025-03-19 (+100d) | 2024-12-20 → 2025-03-25 (+95d) | 10d → 5d |  | 119d → 31614d | 1414 → 1415 | baseline start 2024-12-09 → 2025-02-07; baseline finish 2024-12-20 → 2025-02-20 |
| 1421 | eSITWG endorses regression suite doc | 2024-12-30 → 2025-04-23 (+114d) | 2025-01-03 → 2025-04-23 (+110d) | 5d → 0d |  | 119d → 31614d | 1416FS+5d → 1420FS+5d | was named SITWG Feedback on regression suite doc; baseline start 2024-12-30 → 2025-03-06; baseline finish 2025-01-03 → 2025-03-06 |
| 1422 | Incorporate SITWG feedback into regression suite doc | 2025-01-06 → 2025-04-24 (+108d) | 2025-01-06 → 2025-04-24 (+108d) | 1d? → 1d |  | 119d → 31614d |  | was named Incorporate SRO + SITWG feedback into regression suite doc; baseline start 2025-01-06 → 2025-03-07; baseline finish 2025-01-06 → 2025-03-11 |
| 1423 | eSITAG paper day | 2025-01-06 → 2025-04-24 (+108d) | 2025-01-06 → 2025-04-24 (+108d) |  |  | 119d → 31614d |  | was named SRO Approval; baseline start 2025-01-06 → 2025-03-11; baseline finish 2025-01-06 → 2025-03-11 |
| 1425 | SIT Regression Approval | 2025-01-13 → 2025-05-01 (+108d) | 2025-01-13 → 2025-05-01 (+108d) |  |  | 768d → 32263d | 1423FS+5d → 1424 | was named SIT Regression Suite Approval at SITAG; baseline start 2025-01-13 → 2025-03-18; baseline finish 2025-01-13 → 2025-03-18 |
| 1426 | **Regression Test Data Load Window (SIT Functional and Migration) - SIT A** | 2025-03-14 → 2025-04-28 (+45d) | 2025-03-17 → 2025-04-29 (+43d) |  |  |  |  |  |
| 1428 | Regression Test Data Load Start |  |  |  |  | 5d → 27d | 1585, 1525FS+1d, 1589FS+1d → 1585, 1525FS+1d, 1589FS+1d, 1427 |  |
| 1429 | Regression Test Data Load Window | 2025-04-28 → 2025-04-29 (+1d) |  | 15d? → 14d |  | 5d → 27d | 1428FS-1d → 1428 | constraint none → start no earlier than 2025-04-28 |
| 1430 | **Single Instance ADO** |  |  |  | 86% → 98% | 840d → 32413d |  |  |
| 1431 | **Single ADO Project for all Cohorts - Implementation and Test Phase** |  | 2024-10-01 A |  | 89% → 100% | 842d → none |  |  |
| 1441 | Migrate defects from cohort project to master - Option 2 | 2024-09-23 A | 2024-09-25 A |  | 0% → 100% | 846d → none |  |  |
| 1461 | **Reporting Changes - Daily Excel Extract & PDF** | 2024-09-05 A | 2024-09-06 A |  | 0% → 100% | 859d → none |  |  |
| 1462 | Excel Daily Report changes (Refer to above) | 2024-09-05 A | 2024-09-06 A |  | 0% → 100% | 859d → none |  |  |
| 1463 | PDF Daily Report changes (Refer to Above) | 2024-09-05 A | 2024-09-06 A |  | 0% → 100% | 859d → none |  |  |
| 1464 | **Documentation Updates** |  | 2024-10-02 A |  | 80% → 100% | 841d → none |  |  |
| 1465 | Changes to onboarding process (security) | 2024-09-02 A | 2024-09-13 A |  | 0% → 100% | 854d → none |  |  |
| 1482 | **SIT Execution** |  | 2025-11-27 → 2148-12-31 (+44959d) | 804d? → 32917d? | 15% → 18% | 540d → 0d |  |  |
| 1484 | **SIT Component Integration Testing** |  | 2024-03-11 A → 2148-12-31 (+45585d) | 96d → 32657d | 100% → 8% | none → 0d |  |  |
| 1493 | SIT Component Integration Testing End (incl. confirmation that PPs have submitted their Test Completion Reports to Programme for assurance) |  | 2024-02-23 A → 2148-12-31 (+45602d) | 0d → 1566d | 100% → 0% | none → 0d |  |  |
| 1499 | **SIT - Minimum Viable Cohort (MVC)** |  |  |  | 8% → 31% | 609d → 32182d |  |  |
| 1500 | **SIT Functional Testing (MVC)** |  |  |  | 20% → 44% | 614d → 32187d |  |  |
| 1502 | **SIT Functional Testing Execution (Minimum Viable Cohort)** |  |  |  | 20% → 44% | 614d → 32187d |  |  |
| 1506 | **Cycle 2 (Defect retests and targeted regression testing)** |  | 2024-10-04 A |  | 41% → 100% | 839d → none |  |  |
| 1507 | Test Execution |  | 2024-09-20 A |  | 47% → 100% | 190d → none |  |  |
| 1508 | Defect resolution, assurance, review, data & environments maintenance | 2024-09-23 A | 2024-10-04 A |  | 0% → 100% | 839d → none |  |  |
| 1512 | **Cycle 3 (Defect retests and targeted regression testing)** | 2024-10-21 A |  |  | 0% → 28% |  |  |  |
| 1513 | Sprint 5 | 2024-10-21 A | 2024-11-01 A |  | 0% → 100% | 5d → none |  |  |
| 1514 | Sprint 6 | 2024-11-04 A | 2024-11-15 A |  | 0% → 100% | 5d → none |  |  |
| 1515 | Sprint 7 | 2024-11-18 A | 2024-11-29 A |  | 0% → 100% | 5d → none |  |  |
| 1516 | Sprint 8 | 2024-12-02 A |  |  | 0% → 50% | 5d → 27d |  |  |
| 1527 | **SIT Functional Settlement Testing** |  |  |  | 0% → 30% |  |  |  |
| 1528 | SIT-B Settlement Testing Cycle 2 | 2024-06-17 → 2025-03-10 (+266d) | 2024-09-20 → 2025-06-13 (+266d) |  |  | 849d → 32232d | none → 1545FS+10d | was named Settlement Testing Cycle 1 |
| 1529 | **SIT-B Settlement Testing Cycle 3** | 2024-10-07 A | 2024-12-20 → 2025-02-21 (+63d) | 55d? → 100d? | 0% → 58% | 38d → 32237d |  | was named Settlement Testing Cycle 2 |
| 1546 | SIT-A CoS Settlement Testing |  |  |  |  | 5d → 27d | Regression - PP's confirmation that test data is ready for SIT Functional, 1429 → 1429 | was named Settlement Testing Cycle 3 (CoS Settlement Testing) |
| 1550 | Regression Sprint 2 |  | 2025-07-11 → 2025-07-18 (+7d) | 10d → 15d |  | 5d → 31578d |  | baseline finish 2025-07-11 → 2025-07-18 |
| 1551 | Regression Sprint 3 | 2025-07-14 → 2025-07-21 (+7d) | 2025-08-01 → 2025-08-08 (+7d) |  |  | 5d → 31578d |  | baseline start 2025-07-14 → 2025-07-21; baseline finish 2025-08-01 → 2025-08-08 |
| 1552 | SIT Functional Testing End (Minimum Viable Cohort) (incl. confirmation that PPs have submitted their Test Completion Reports to Programme for assurance) | 2025-08-01 → 2025-08-08 (+7d) | 2025-08-01 → 2025-08-08 (+7d) |  |  | 5d → 31578d |  | baseline start 2025-08-01 → 2025-08-08; baseline finish 2025-08-01 → 2025-08-08 |
| 1553 | Assurance of PPs Test Completion Reports | 2025-06-30 → 2025-07-14 (+14d) | 2025-08-08 → 2025-08-15 (+7d) | 30d → 25d |  | 5d → 31578d |  | baseline start 2025-06-30 → 2025-07-14; baseline finish 2025-08-08 → 2025-08-15 |
| 1554 | **SIT Functional Test Completion Report (Minimum Viable Cohort)** | 2025-07-14 → 2025-07-21 (+7d) |  | 25d → 20d |  | 5d → 31578d |  | baseline start 2025-07-14 → 2025-07-21 |
| 1555 | Develop document | 2025-07-14 → 2025-07-21 (+7d) | 2025-08-01 → 2025-08-08 (+7d) |  |  | 5d → 31578d |  | baseline start 2025-07-14 → 2025-07-21; baseline finish 2025-08-01 → 2025-08-08 |
| 1556 | Review & agree document | 2025-08-04 → 2025-08-11 (+7d) | 2025-08-08 → 2025-08-15 (+7d) |  |  | 5d → 31578d |  | baseline start 2025-08-04 → 2025-08-11; baseline finish 2025-08-08 → 2025-08-15 |
| 1557 | SIT Functional Testing Test Completion Report (Minimum Viable Cohort) Approved |  |  |  |  | 5d → 31578d | 1556FF+5d → 1556FF |  |
| 1558 | **Helix E2E Settlement Testing** | 2025-01-06 → 2025-02-07 (+32d) | 2025-04-04 → 2025-06-06 (+63d) | 65d → 86d? |  | 38d → 32237d |  |  |
| 1560 | Helix E2E Settlement Testing Execution | 2025-01-06 → 2025-03-10 (+63d) | 2025-04-04 → 2025-06-06 (+63d) |  |  | 38d → 32237d |  |  |
| 1561 | Helix E2E Settlement Testing Execution Complete | 2025-04-04 → 2025-06-06 (+63d) | 2025-04-04 → 2025-06-06 (+63d) |  |  | 38d → 32237d |  |  |
| 1562 | MHHSP Helix E2E Testing Assurance | 2025-01-06 → 2025-03-10 (+63d) | 2025-04-04 → 2025-06-06 (+63d) |  |  | 38d → 32237d |  |  |
| 1563 | MHHSP Helix E2E Testing Assurance Complete | 2025-04-04 → 2025-06-06 (+63d) | 2025-04-04 → 2025-06-06 (+63d) |  |  | 38d → 32237d |  |  |
| 1564 | **SIT Migration Testing (MVC)** | 2024-03-11 A |  |  | 0% → 49% | 0d → 32182d |  |  |
| 1566 | **SIT Migration Testing Execution (Minimum Viable Cohort)** | 2024-03-11 A |  |  | 0% → 49% | 0d → 32182d |  |  |
| 1567 | **Cycle 1 (Full Cycle)** | 2024-03-11 A | 2024-06-14 A |  | 0% → 100% |  |  |  |
| 1568 | Test Execution | 2024-03-11 A | 2024-05-24 A |  | 0% → 100% | 934d → none |  | baseline start none → 2024-03-11; baseline finish none → 2024-05-24 |

| ID | Task | Start | Finish | Duration | Complete | Total float | Predecessors | Other |
| --- | --- | --- | --- | --- | --- | --- | --- | --- |
| 1569 | Defect resolution, assurance, review, data& environments maintenance | 2024-05-27 A | 2024-06-14 A |  | 0% → 100% | 819d → none |  | baseline start none → 2024-05-27; baseline finish none → 2024-06-14 |
| 1570 | **Cycle 2 (Defect retests and targeted regression testing)** |  |  |  | 0% → 100% |  |  |  |
| 1571 | Test Execution | 2024-06-17 A | 2024-09-20 A |  | 0% → 100% | 819d → none |  | baseline start none → 2024-06-17; baseline finish none → 2024-09-20 |
| 1572 | Defect resolution, assurance, review, data & environments maintenance | 2024-09-23 A | 2024-10-04 A |  | 0% → 100% | 819d → none |  | baseline start none → 2024-09-23; baseline finish none → 2024-10-04 |
| 1576 | **Cycle 3 (Defect retests and targeted regression testing)** | 2024-10-21 A |  |  | 0% → 28% | 5d → 32267d |  |  |
| 1577 | Sprint 5 | 2024-10-21 A | 2024-11-01 A |  | 0% → 100% | 5d → none |  |  |
| 1578 | Sprint 6 | 2024-11-04 A | 2024-11-15 A |  | 0% → 100% | 5d → none |  |  |
| 1579 | Sprint 7 | 2024-11-18 A | 2024-11-29 A |  | 0% → 100% | 5d → none |  |  |
| 1580 | Sprint 8 | 2024-12-02 A |  |  | 0% → 50% | 5d → 27d |  |  |
| 1602 | **SIT Non-Functional Testing (all SIT PPs)** | 2025-01-13 → 2025-02-28 (+46d) | 2025-06-05 → 2025-06-06 (+1d) | 104d? → 71d? |  | 60d → 31603d |  | baseline start 2025-01-13 → 2025-02-28; baseline finish 2025-06-05 → 2025-07-10 |
| 1603 | Theme 1 (Helix and DIP Volume Testing) Start | 2025-01-13 → 2025-02-28 (+46d) | 2025-01-13 → 2025-02-28 (+46d) |  |  | 60d → 31603d | 1144 → 1144, 1160 | constraint start no earlier than 2025-01-13 → finish no earlier than 2025-01-13; baseline start 2025-01-13 → 2025-02-28; baseline finish 2025-01-13 → 2025-02-28 |
| 1604 | Theme 1 (Helix and DIP Volume Testing) Execution | 2025-01-13 → 2025-02-28 (+46d) | 2025-01-31 → 2025-03-20 (+48d) |  |  | 60d → 31603d | 1603 → 1603FS-1d | baseline start 2025-01-13 → 2025-02-28; baseline finish 2025-01-31 → 2025-03-20 |
| 1605 | Theme 2 SIT Non-Functional Testing Start | 2025-03-14 → 2025-03-31 (+17d) | 2025-03-14 → 2025-03-31 (+17d) |  |  | 70d → 31672d | 1187FS+5d, 1507FS+5d, 1077, 1081, 1088, 1094, 1100, 1146, 1150 → 1187, 1507, 1077, 1081, 1088, 1094, 1100, 1146, 1545, 1169FS+1d | baseline start 2025-03-14 → 2025-03-31; baseline finish 2025-03-14 → 2025-03-31 |
| 1606 | Theme 2 SIT Non-Functional Testing Execution | 2025-03-17 → 2025-03-31 (+14d) | 2025-05-09 → 2025-05-23 (+14d) |  |  | 70d → 31633d | 1605SS → 1605SS-1d | baseline start 2025-03-17 → 2025-05-01; baseline finish 2025-05-09 → 2025-06-25 |
| 1607 | Theme 3 SIT Non-Functional Testing Start | 2025-03-17 → 2025-03-31 (+14d) | 2025-03-17 → 2025-03-31 (+14d) |  |  | 70d → 31633d | 1146, 1150 → 1146, 1169 | baseline start 2025-03-17 → 2025-05-02; baseline finish 2025-03-17 → 2025-05-02 |
| 1608 | Theme 3 SIT Non-Functional Testing Execution | 2025-03-17 → 2025-03-31 (+14d) | 2025-05-09 → 2025-05-23 (+14d) |  |  | 70d → 31633d |  | baseline start 2025-03-17 → 2025-05-02; baseline finish 2025-05-09 → 2025-06-26 |
| 1610 | Assurance of PPs Test Completion Reports | 2025-05-02 → 2025-05-05 (+3d) | 2025-05-29 → 2025-05-30 (+1d) |  |  | 61d → 31633d |  | baseline start 2025-05-02 → 2025-05-05; baseline finish 2025-05-29 → 2025-05-30 |
| 1611 | **SIT Non-Functional Testing Test Completion Report (all SIT PPs)** | 2025-05-02 → 2025-05-05 (+3d) | 2025-05-29 → 2025-05-30 (+1d) |  |  | 61d → 31633d |  |  |
| 1612 | Develop document | 2025-05-02 → 2025-05-05 (+3d) |  |  |  | 61d → 31633d |  | baseline start 2025-05-02 → 2025-05-05 |
| 1613 | Review & agree document | 2025-05-23 → 2025-05-26 (+3d) | 2025-05-29 → 2025-05-30 (+1d) |  |  | 61d → 31633d |  | baseline start 2025-05-23 → 2025-05-26; baseline finish 2025-05-29 → 2025-05-30 |
| 1614 | SIT Non-Functional Testing Test Completion Report (all SIT PPs) Approved | 2025-06-05 → 2025-06-06 (+1d) | 2025-06-05 → 2025-06-06 (+1d) |  |  | 61d → 31633d |  | baseline start 2025-06-05 → 2025-06-06; baseline finish 2025-06-05 → 2025-06-06 |
| 1615 | **SIT Operational Testing (all SIT PPs)** |  | 2025-06-06 → 2025-07-18 (+42d) | 90d? → 120d? |  | 60d → 31603d |  |  |
| 1617 | SIT Operational Testing Start (Theme 3 - Batch 1 (Service Management)) |  |  |  |  | 115d → 31688d | 1334, Elexon Service Now Build and Implementation, 1274, 1275, Helix Knowledge Articles, 1333 → 1334, 1274, 1275 |  |
| 1619 | **SIT B Testing** | 2025-02-07 → 2025-03-31 (+52d) | 2025-05-16 → 2025-07-04 (+49d) |  |  | 60d → 31603d |  |  |
| 1620 | SIT Operational Testing Start (SIT B) | 2025-02-07 → 2025-03-31 (+52d) | 2025-02-07 → 2025-03-31 (+52d) |  |  | 60d → 31603d | 1399FS+8d, 1196, 1200, 1207, 1213, 1334, 1147, 1148 → 1399, 1196, 1200, 1207, 1213, 1334, 1147, 1148, 1379FS+1d | baseline start 2025-02-07 → 2025-03-31; baseline finish 2025-02-07 → 2025-03-31 |
| 1621 | SIT Operational Testing Execution Theme 3 Batch 2 | 2025-02-10 → 2025-03-31 (+49d) | 2025-03-14 → 2025-05-02 (+49d) |  |  | 60d → 31603d | 1620, 1320 → 1620FS-1d, 1320 | baseline start 2025-02-10 → 2025-03-31; baseline finish 2025-03-14 → 2025-05-02 |
| 1622 | SIT Operational Testing Execution Theme 1 | 2025-03-17 → 2025-05-05 (+49d) | 2025-04-18 → 2025-06-06 (+49d) |  |  | 60d → 31603d |  | baseline start 2025-03-17 → 2025-05-05; baseline finish 2025-04-18 → 2025-06-06 |
| 1623 | SIT Operational Testing Execution Theme 2 | 2025-04-21 → 2025-06-09 (+49d) | 2025-05-16 → 2025-07-04 (+49d) |  |  | 60d → 31603d |  | baseline start 2025-04-21 → 2025-06-09; baseline finish 2025-05-16 → 2025-07-04 |
| 1624 | SIT Operational Testing End (all SIT PPs) (incl. confirmation that PPs have submitted their Test Completion Reports to Programme for assurance) | 2025-05-23 → 2025-07-04 (+42d) | 2025-05-23 → 2025-07-04 (+42d) |  |  | 60d → 31603d | 1623FS+5d, 1618 → 1623, 1618 | baseline start 2025-05-23 → 2025-07-11; baseline finish 2025-05-23 → 2025-07-11 |
| 1625 | Assurance of PPs Test Completion Reports | 2025-04-21 → 2025-06-02 (+42d) | 2025-05-30 → 2025-07-11 (+42d) |  |  | 60d → 31603d |  | baseline start 2025-04-21 → 2025-06-09; baseline finish 2025-05-30 → 2025-07-18 |
| 1626 | **SIT Operational Testing Test Completion Report (all SIT PPs)** | 2025-05-05 → 2025-06-16 (+42d) | 2025-05-30 → 2025-07-11 (+42d) |  |  | 60d → 31603d |  | baseline start 2025-05-05 → 2025-06-23; baseline finish 2025-05-30 → 2025-07-18 |
| 1627 | Develop document | 2025-05-05 → 2025-06-16 (+42d) | 2025-05-23 → 2025-07-04 (+42d) |  |  | 60d → 31603d |  | baseline start 2025-05-05 → 2025-06-23; baseline finish 2025-05-23 → 2025-07-11 |
| 1628 | Review & agree document | 2025-05-26 → 2025-07-07 (+42d) | 2025-05-30 → 2025-07-11 (+42d) |  |  | 60d → 31603d |  | baseline start 2025-05-26 → 2025-07-14; baseline finish 2025-05-30 → 2025-07-18 |
| 1629 | SIT Operational Testing Test Completion Report (all SIT PPs) Approved | 2025-06-06 → 2025-07-18 (+42d) | 2025-06-06 → 2025-07-18 (+42d) |  |  | 60d → 31603d |  | baseline start 2025-06-06 → 2025-07-25; baseline finish 2025-06-06 → 2025-07-25 |
| 1630 | **SIT MVC Test Exit Report** | 2025-07-14 → 2025-07-21 (+7d) | 2025-08-08 → 2025-08-15 (+7d) |  |  | 619d → 32187d |  |  |
| 1631 | Develop document | 2025-07-14 → 2025-07-21 (+7d) | 2025-08-01 → 2025-08-08 (+7d) |  |  | 619d → 32187d |  |  |
| 1632 | Review & agree document | 2025-08-04 → 2025-08-11 (+7d) | 2025-08-08 → 2025-08-15 (+7d) |  |  | 619d → 32187d |  |  |
| 1645 | Test Execution (Cycle 3 Completion and Regression Testing) |  |  |  |  | 25d → 31602d |  | baseline start 2025-05-05 → 2025-06-16; baseline finish 2025-09-17 → 2025-10-24 |
| 1646 | SIT Migration Testing End (non-MVC) (incl. confirmation that PPs have submitted their Test Completion Reports to Programme for assurance) |  |  |  |  | 25d → 31602d |  | baseline start 2025-09-17 → 2025-10-24; baseline finish 2025-09-17 → 2025-10-24 |
| 1647 | Assurance of PPs Test Completion Reports |  |  |  |  | 25d → 31602d |  | baseline start 2025-09-25 → 2025-11-03; baseline finish 2025-10-01 → 2025-11-07 |
| 1648 | **SIT Migration Testing Test Completion Report (non-MVC)** |  |  |  |  | 25d → 31602d |  | baseline start 2025-08-28 → 2025-10-06; baseline finish 2025-10-01 → 2025-11-07 |
| 1649 | Develop document |  |  |  |  | 30d → 31607d |  | baseline start 2025-08-28 → 2025-10-06; baseline finish 2025-09-17 → 2025-10-24 |
| 1650 | Review & agree document |  |  |  |  | 25d → 31602d |  | baseline start 2025-09-25 → 2025-11-03; baseline finish 2025-10-01 → 2025-11-07 |
| 1651 | SIT Migration Testing Test Completion Report (non-MVC Approved) |  |  |  |  | 25d → 31602d |  | baseline start 2025-10-08 → 2025-11-14; baseline finish 2025-10-08 → 2025-11-14 |
| 1656 | **UIT Environment Preparation** |  |  |  | 46% → 48% | 644d → 32217d |  |  |
| 1662 | Update E2E Sandbox guidance to reflect CR55 |  |  |  |  | 718d → 32291d |  | baseline start none → 2025-01-13; baseline finish none → 2025-02-20 |
| 1663 | Internal SI review |  |  |  |  | 718d → 32291d |  | baseline start none → 2025-02-21; baseline finish none → 2025-02-27 |
| 1664 | SRO / Code Bodies review |  |  |  |  | 718d → 32291d |  | baseline start none → 2025-02-28; baseline finish none → 2025-03-06 |
| 1665 | Submit version to QWG |  |  |  |  | 718d → 32291d |  | baseline start none → 2025-03-07; baseline finish none → 2025-03-11 |
| 1666 | Artefact Approval (via QWG) |  |  |  |  | 718d → 32291d |  | baseline start none → 2025-03-11; baseline finish none → 2025-03-11 |
| 1667 | Final Document updates post QWG review |  |  | 1d? → 1d |  | 718d → 32291d |  | baseline start none → 2025-03-13; baseline finish none → 2025-03-13 |
| 1668 | Submit final version to QAG |  |  |  |  | 718d → 32291d |  | baseline start none → 2025-03-17; baseline finish none → 2025-03-17 |
| 1669 | E2E Sandbox guidance update approved |  |  |  |  | 718d → 32291d |  | baseline start none → 2025-03-24; baseline finish none → 2025-03-24 |
| 1671 | Develop document |  |  |  |  | 701d → 32274d |  | baseline start 2023-12-05 → 2025-01-13; baseline finish 2024-03-15 → 2025-02-18 |
| 1672 | Internal SI review and updates |  |  |  |  | 701d → 32274d |  | baseline start 2024-03-11 → 2025-02-19; baseline finish 2024-03-15 → 2025-02-25 |
| 1673 | SRO / Code Bodies review |  |  |  |  | 701d → 32274d |  | baseline start 2024-03-18 → 2025-02-26; baseline finish 2024-03-22 → 2025-03-04 |
| 1676 | Final updates prior to consultation |  |  |  |  | 701d → 32274d |  | baseline start 2024-03-25 → 2025-03-12; baseline finish 2024-03-29 → 2025-03-17 |
| 1677 | Industry Consultation for E2E Sandbox Test Data Approach and Plan document |  |  |  |  | 701d → 32274d |  | baseline start 2024-04-01 → 2025-03-18; baseline finish 2024-04-12 → 2025-03-31 |
| 1678 | Document updates post Industry Consultation |  |  |  |  | 701d → 32274d |  | baseline start 2024-04-15 → 2025-04-01; baseline finish 2024-04-22 → 2025-04-03 |
| 1679 | Submit Proposed Version to QWG |  |  |  |  | 701d → 32274d |  | baseline start 2024-04-23 → 2025-04-04; baseline finish 2024-04-23 → 2025-04-08 |
| 1680 | Artefact Approval (via QWG) |  |  |  |  | 701d → 32274d |  | baseline start 2024-04-30 → 2025-04-08; baseline finish 2024-04-30 → 2025-04-08 |
| 1681 | Final Document updates post QWG review |  |  |  |  | 701d → 32274d |  | baseline start 2024-05-01 → 2025-04-09; baseline finish 2024-05-01 → 2025-04-09 |
| 1682 | Submit final version to QAG |  |  |  |  | 701d → 32274d |  | baseline start 2024-05-02 → 2025-04-10; baseline finish 2024-05-02 → 2025-04-10 |
| 1683 | E2E Sandbox Test Data Approach and Plan |  |  |  |  | 701d → 32274d |  | baseline start 2024-05-09 → 2025-04-16; baseline finish 2024-05-09 → 2025-04-16 |
| 1684 | **UIT Stub Specification and Delivery** |  | 2024-10-18 → 2024-11-29 A (+42d) | 230d → 260d | 89% → 100% | 829d → none |  |  |
| 1685 | **Qualification Test Stubs** |  | 2024-10-18 → 2024-11-29 A (+42d) | 230d → 260d | 89% → 100% | 829d → none |  |  |
| 1687 | Build & Test |  | 2024-08-16 A |  | 90% → 100% | 33.75d → none |  |  |
| 1688 | Prepare for release |  | 2024-10-18 → 2024-11-29 A (+42d) | 45d → 75d | 75% → 100% | 829d → none |  | baseline finish 2024-10-18 → 2024-11-29 |
| 1689 | Non-SIT LDSO Test Harness Released | 2024-10-18 → 2024-11-29 A (+42d) | 2024-10-18 → 2024-11-29 A (+42d) |  | 0% → 100% | 829d → none |  | baseline start 2024-10-18 → 2024-11-29; baseline finish 2024-10-18 → 2024-11-29 |
| 1690 | **Environments (UIT)** |  |  |  | 44% → 46% | 644d → 32217d |  |  |

| ID | Task | Start | Finish | Duration | Complete | Total float | Predecessors | Other |
| --- | --- | --- | --- | --- | --- | --- | --- | --- |
| 1691 | **Central Party (Avanade) Environments (UIT)** |  |  |  | 97% → 99% | 844d → 32417d |  | was named Central Party (Avenade) Environments (UIT) |
| 1692 | Central Party (Avandae) environment preparation (incl. security certificates and security compliance) |  |  |  |  |  |  | was named Central Party (Avendae) environment preparation (incl. security certificates and security compliance) |
| 1694 | Central Party (Avanade) UIT environment connectivity proving | 2024-08-26 A | 2024-09-27 A |  | 0% → 100% | 843d → none |  | was named Central Party (Avenade) UIT environment connectivity proving |
| 1695 | Deployment of MHHS solution code to UIT environments | 2024-07-29 A | 2024-07-30 A |  | 0% → 100% | 886d → none |  |  |
| 1696 | Central Party (Avanade) UIT environment Regression Testing |  |  |  |  | 886d → 32459d |  | was named Central Party (Avenade) UIT environment Regression Testing |
| 1703 | **SI Environments (UIT)** |  |  |  | 69% → 71% | 644d → 32217d |  |  |
| 1707 | Coordinate Central Parties' UIT environment connectivity proving | 2024-08-26 A | 2024-09-30 A |  | 0% → 100% | 843d → none |  |  |
| 1769 | **SIT PPs Early Sandbox Testing Execution (SIT-A)** | 2025-02-07 → 2025-08-08 (+182d) | 2026-04-24 → 2025-10-24 (-182d) | 316d → 56d |  | 434d → 32137d |  | was named SIT PPs Early Sandbox Testing Execution |
| 1770 | SIT PPs E2E Sandbox Testing Start | 2025-02-10 → 2025-08-08 (+179d) | 2025-02-10 → 2025-08-08 (+179d) |  |  | 749d → 32192d | 1764FS+5d → 1764FS+5d, 1551 | baseline start 2025-02-10 → 2025-08-08; baseline finish 2025-02-10 → 2025-08-08 |
| 1771 | SIT PPs E2E Sandbox Testing Execution | 2025-02-07 → 2025-08-08 (+182d) | 2026-04-24 → 2025-10-24 (-182d) | 316d → 56d |  | 434d → 32137d |  |  |
| 1774 | Central systems ready for migrating MPANs (M10) |  |  |  |  | 5d → 31578d | 1633FS+20d, 2898, 2653FS+2d, 2650, 2665, 2652, 2632, 2636 → 1633FS+20d, 2898, 2653FS+2d, 2650, 2665, 2632, 2636 | constraint start no earlier than 2025-08-13 → none |
| 1786 | **NON SIT LDSO QUALIFICATION** |  | 2025-08-22 → 2025-09-19 (+28d) | 469d? → 489d? | 67% → 63% | 609d → 32162d |  |  |
| 1816 | **Test Execution Schedule** |  | 2024-11-29 A |  | 99% → 100% | 799d → none |  |  |
| 1822 | Qualification Testing for Non-SIT LDSOs (Functional, Migration, NFT, Operational) Test Execution Schedule Complete | 2024-11-29 A | 2024-11-29 A |  | 0% → 100% | 799d → none |  |  |
| 1832 | **Test Data** |  |  |  | 44% → 65% | 679d → 32252d |  |  |
| 1839 | Test Data Loaded | 2024-08-12 A |  |  | 0% → 90% | 679d → 32252d |  |  |
| 1846 | **Pre-Integration Testing** |  | 2024-11-29 → 2025-01-24 (+56d) | 218d → 258d | 90% → 78% | 799d → 32332d |  |  |
| 1850 | PIT Execution (Functional and Migration) |  |  |  | 16% → 36% |  |  | was named PIT Execution |
| 1852 | Non-SIT LDSO Participants have submitted functional PIT Test Completion Report & evidence for QT Entry​ |  |  |  |  | 799d → 32372d |  | was named Non-SIT LDSO Participants have submitted PIT Test Completion Report & evidence for QT Entry​ |
| 1866 | **Test Environment** |  | 2024-11-29 A |  | 37% → 100% | 67d → none |  |  |
| 1868 | Central System (DIP Env & Helix Test Harness) Test Environment DBT |  | 2024-11-29 A |  | 47% → 100% | 67d → none |  |  |
| 1869 | Coordinate LDSO Environment Preparation |  | 2024-11-29 A |  | 14% → 100% | 67d → none |  |  |
| 1872 | LDSO Test Environments Connection Confirmed to UIT Environment | 2024-11-29 A | 2024-11-29 A |  | 0% → 100% | 67d → none |  |  |
| 1873 | **Test Readiness** |  |  |  | 31% → 90% | 784d → 32357d |  |  |
| 1876 | LDSO Update Readiness Report & Final Assurance by Programme |  |  |  | 20% → 95% | 42d → 7d |  |  |
| 1881 | **Test Window** |  | 2025-05-16 → 2025-08-22 (+98d) | 94d? → 165d? |  | 42d → 7d |  |  |
| 1882 | **All Non-SIT LDSOs Qualification Testing** |  |  | 94d? → 94d |  | 42d → 1d |  |  |
| 1893 | Qualification Testing for Non-SIT LDSOs (Functional, Migration, NFT, Operational) 1 End |  |  |  |  | 38d → 1d | Non-SIT LDSO QT - Regression Testing → 1884, 1885, 1886, 1887, 1888, 1889, 1890, 1891, 1892 |  |
| 1899 | **Non-SIT LDSO Qualification Closure** | 2025-05-30 → 2025-08-25 (+87d) | 2025-08-22 → 2025-09-19 (+28d) | 61d → 20d |  | 22d → 32162d |  |  |
| 1900 | Non-SIT LDSO Qualification Learned Captured | 2025-05-30 → 2025-08-25 (+87d) | 2025-06-19 → 2025-09-12 (+85d) |  |  | 38d → 32162d | 1898 → 1898, 1991 |  |
| 1901 | Non-SIT LDSO Qualification Closure Down | 2025-06-20 → 2025-09-15 (+87d) | 2025-06-26 → 2025-09-19 (+85d) |  |  | 38d → 32162d |  |  |
| 1902 | **S & A QUALIFICATION** |  |  | 843d → 843d? | 32% → 51% | 235d → 31808d |  |  |
| 1903 | **MHHS Qualification - Qualification Deliverables** |  |  |  | 60% → 94% | 615d → 32178d |  |  |
| 1904 | **BSC & REC Assessment Criteria** |  | 2025-08-14 A |  | 23% → 100% | 615d → none |  |  |
| 1910 | Assessment Criteria (Functional, Non-Functional, Migration, Operational) Approved by REC PAB and BSC PAB | 2024-08-29 A | 2025-08-14 A |  | 0% → 100% | 615d → none |  |  |
| 1931 | **Qualification Assessment Document** |  | 2025-03-07 → 2025-04-18 (+42d) | 316d → 346d | 81% → 85% | 633d → 32262d |  |  |
| 1950 | **Qualification Assessment Document Portal** |  | 2025-03-07 → 2025-04-18 (+42d) | 285d → 315d | 65% → 72% | 633d → 32262d |  |  |
| 1956 | SIT Participant QAD Application Creation in Portal | 2024-08-12 → 2024-12-09 A (+119d) | 2024-08-23 → 2024-12-20 (+119d) |  | 0% → 60% | 773d → 32347d | 1954FS+35d → 1954FS+120d | baseline start 2024-08-12 → 2024-12-09; baseline finish 2024-08-23 → 2024-12-20 |
| 1957 | Non-SIT LDSO Participant QAD Application Creation in Portal | 2024-08-12 → 2024-12-09 A (+119d) | 2024-08-23 → 2024-12-20 (+119d) |  | 0% → 60% | 773d → 32346d | 1954FS+35d → 1954FS+120d | baseline start 2024-08-12 → 2024-12-09; baseline finish 2024-08-23 → 2024-12-20 |
| 1958 | QT Wave 1 Participant QAD Application Creation in Portal | 2024-09-23 → 2025-04-07 (+196d) | 2024-10-04 → 2025-04-18 (+196d) |  |  | 36d → 31579d | 1954FS+65d → 1954FS+205d | baseline start 2024-09-23 → 2025-04-07; baseline finish 2024-10-04 → 2025-04-18 |
| 1964 | **MHHS Qualification - SIT Participants** |  | 2025-12-22 → 2025-12-18 (-4d) | 251d → 249d |  | 60d → 31633d |  |  |
| 1965 | Initial QAD Submission Window opens |  |  |  |  | 773d → 32347d | 1956FS+96d → 1956FS+10d |  |
| 1971 | SIT MVC Participants submit Final QAD (exc Test Reports) |  |  |  |  | 60d → 31633d |  | was named SIT MVC Participants submit Final QAD |
| 1972 | Completion of Code Bodies review of Final QAD (MVC) |  |  |  |  | 60d → 31633d | 1971, 1624FF → 1971 |  |
| 1973 | QAD Sign Off Deadline (MVC) + Test Reports |  |  |  |  | 5d → 31578d | 1633, 1972 → 1633, 1972, 1624 | was named QAD Sign Off Deadline (MVC) |
| 1975 | **MHHS Qualification - SIT Non-MVC Participants** |  | 2025-12-22 → 2025-12-18 (-4d) | 156d → 154d |  | 25d → 31602d |  |  |
| 1980 | REC Code Manager / BSC PAB Approval of Qualification (Non-MVC) | 2025-12-22 → 2025-12-18 (-4d) | 2025-12-22 → 2025-12-18 (-4d) |  |  | 25d → 31602d | 1979FS+16d → 1979FS+14d |  |
| 1981 | **MHHS Qualification - Non-SIT LDSO** |  | 2025-09-11 → 2025-09-10 (-1d) | 179d → 178d |  | 71d → 31631d |  |  |
| 1982 | Initial QAD Submission window opens |  |  |  |  | 773d → 32346d | 1957FS+96d → 1957FS+11d |  |
| 1991 | QAD Sign Off Deadline (Non-SIT LDSOs) |  |  |  |  | 22d → 31582d | 1990FS+5d, 1633 → 1990FS+5d, 1633, 1893 |  |
| 1992 | BSC PAB & REC Manager approval of Qualification for Non-SIT LDSOs | 2025-09-11 → 2025-09-10 (-1d) | 2025-09-11 → 2025-09-10 (-1d) |  |  | 595d → 31582d | 1893, 1991FS+14d → 1991FS+13d | was named BSC PAB & REC Manager approval of Qualification for Non-SIT LDSOs (Start of Migration for Qualification Participants) |
| 1993 | **MHHS Qualification - Qualification Waves** |  |  | 814d → 814d? | 29% → 48% | 235d → 31808d |  |  |
| 1994 | **Qualification Wave Prep** |  | 2025-12-26 → 2026-01-08 (+13d) | 530d → 539d? | 55% → 76% | 519d → 32083d |  |  |
| 2032 | **Qualification Testing Framework (Test Stubs and Supporting UI)** |  | 2025-12-26 → 2026-01-08 (+13d) | 500d → 509d? | 50% → 74% | 519d → 32083d |  | baseline finish 2025-12-26 → 2026-01-08 |
| 2033 | Proof of Concept for QTF Completion |  |  |  |  |  |  | constraint start no earlier than 2024-01-22 → finish no earlier than 2024-03-29 |
| 2034 | Discovery and Mobilisation |  |  |  |  |  |  | constraint none → finish no earlier than 2024-05-03 |
| 2037 | UI Wireframe |  |  |  |  |  | 1999FS+2d → none | constraint none → finish no earlier than 2024-06-28 |
| 2038 | UI Standards |  |  |  |  |  | 2037SS+13d → 2037FS+13d | constraint none → finish no earlier than 2024-06-28 |
| 2039 | Elexon Branding Sylesheet |  |  | 1d → 2d |  |  | 2034FS+10d → 2038FS+10d | constraint none → finish no earlier than 2024-05-20 |
| 2040 | Elexon Branding QTF Logo |  |  | 1d → 2d |  |  | 2034FS+20d → 2039FS+20d | constraint none → finish no earlier than 2024-06-03 |
| 2042 | Core UI Screens |  |  |  |  |  |  | constraint none → finish no earlier than 2024-08-02 |
| 2043 | Tooling (Trigger Files / Template Generators) |  |  |  |  |  |  | constraint none → finish no earlier than 2024-08-16 |
| 2044 | Database Schema |  |  |  |  |  |  | constraint none → finish no earlier than 2024-07-19 |
| 2045 | Core API's |  |  |  |  |  |  | constraint none → finish no earlier than 2024-08-02 |
| 2046 | QTF Test Cases DBT Refinement, Execution and Results Validation, Defect Management, Error Handling | 2024-07-03 → 2024-11-05 A (+125d) | 2025-01-01 → 2025-01-31 (+30d) | 131d → 64d | 0% → 30% | 762d → 32308d | 2025FF, QAG Approval of QT Non-Functional Test Scenarios and Test Cases Batch 2FF, QAG Approval of QT Operational Test Scenarios and Test Cases Batch 1FF, QAG Approval of QT Operational Test Scenarios and Test Cases Batch 2FF → 2031FF, 2025FF, 2027SS | baseline start 2024-07-03 → 2024-11-05; baseline finish 2025-01-01 → 2025-01-31 |
| 2047 | **Environments** |  | 2025-01-21 → 2025-07-31 (+191d) | 202d → 339d | 54% → 98% | 762d → 32198d |  | baseline finish 2025-01-21 → 2025-07-31 |
| 2048 | **Azure Devops** |  | 2024-09-27 → 2024-12-11 A (+75d) | 120d → 173d | 42% → 100% | 216d → none |  | baseline finish 2024-09-27 → 2024-12-11 |
| 2050 | Elexon Instance Setup for QTF Build |  |  |  |  |  |  | constraint none → finish no earlier than 2024-04-19 |
| 2051 | Configuration and User Access |  |  |  |  |  |  | constraint none → finish no earlier than 2024-05-03 |
| 2052 | **MHHSP ADO Instance** |  | 2024-09-27 → 2024-12-11 A (+75d) | 49d → 102d | 24% → 100% | 216d → none |  | baseline finish 2024-09-27 → 2024-12-11 |

| ID | Task | Start | Finish | Duration | Complete | Total float | Predecessors | Other |
| --- | --- | --- | --- | --- | --- | --- | --- | --- |
| 2053 | MHHSP Instance Setup for QTF Production |  | 2024-08-30 A |  | 41% → 100% | 216d → none |  | constraint none → finish no earlier than 2024-08-30 |
| 2054 | Configuration and User Access | 2024-09-02 A | 2024-09-27 → 2024-12-11 A (+75d) | 20d → 73d | 0% → 100% | 216d → none | 2053, 2170 → 2053 | constraint none → finish no earlier than 2024-09-27; baseline finish 2024-09-27 → 2024-12-11 |
| 2056 | Design |  |  |  |  |  |  | constraint none → finish no earlier than 2024-05-03 |
| 2057 | Build and Deployment |  |  |  |  |  |  | constraint none → finish no earlier than 2024-05-31 |
| 2058 | **Dev, Test & Prod Environment Requirements + Design** |  | 2024-10-18 → 2024-11-29 A (+42d) | 105d → 135d | 58% → 100% | 829d → none |  | baseline finish 2024-10-18 → 2024-11-29 |
| 2059 | Design (including Security Review) |  | 2024-08-30 → 2024-11-29 A (+91d) | 70d → 135d | 76% → 100% | 864d → none |  | constraint none → finish no earlier than 2024-08-30; baseline finish 2024-08-30 → 2024-11-29 |
| 2061 | Hub Deployment |  |  |  |  |  | 2059SS+10d → 2059FS+10d, 2060 | constraint none → finish no earlier than 2024-07-05 |
| 2062 | Development Envn. Deployment |  | 2024-08-30 → 2024-09-19 A (+20d) | 40d → 53.8d | 58% → 100% | 815d → none |  | constraint none → finish no earlier than 2024-08-30; baseline finish 2024-08-30 → 2024-09-19 |
| 2063 | Test Envn. Deployment | 2024-09-02 → 2024-09-19 A (+17d) | 2024-09-13 → 2024-10-03 A (+20d) |  | 0% → 100% | 815d → none |  | constraint none → finish no earlier than 2024-09-13; baseline start 2024-09-02 → 2024-09-19; baseline finish 2024-09-13 → 2024-10-03 |
| 2064 | Production Envn. Deployment | 2024-09-16 → 2024-10-03 A (+17d) | 2024-10-18 → 2024-11-07 A (+20d) |  | 0% → 100% | 815d → none |  | constraint none → finish no earlier than 2024-10-18; baseline start 2024-09-16 → 2024-10-03; baseline finish 2024-10-18 → 2024-11-07 |
| 2065 | **QTF Deployment into Production** | 2025-01-02 → 2025-02-03 (+32d) | 2025-01-21 → 2025-02-27 (+37d) | 14d → 19d |  | 762d → 32308d |  | baseline start 2025-01-02 → 2025-02-03; baseline finish 2025-01-21 → 2025-04-25 |
| 2066 | App Deployment | 2025-01-02 → 2025-02-03 (+32d) | 2025-01-02 → 2025-02-07 (+36d) | 1d → 5d |  | 762d → 32308d |  | constraint none → start no earlier than 2025-02-03; baseline start 2025-01-02 → 2025-02-03; baseline finish 2025-01-02 → 2025-04-25 |
| 2067 | Smoke Test | 2025-01-02 → 2025-02-10 (+39d) | 2025-01-03 → 2025-02-11 (+39d) |  |  | 762d → 32308d | 2066SS → 2066 | constraint none → finish no earlier than 2025-02-04; baseline start 2025-01-02 → 2025-02-03; baseline finish 2025-01-03 → 2025-02-04 |
| 2068 | PEN Test | 2025-01-06 → 2025-02-12 (+37d) | 2025-01-07 → 2025-02-13 (+37d) |  |  | 762d → 32308d |  | constraint none → finish no earlier than 2025-02-06; baseline start 2025-01-06 → 2025-02-05; baseline finish 2025-01-07 → 2025-02-06 |
| 2069 | Regression Test | 2025-01-08 → 2025-02-14 (+37d) | 2025-01-21 → 2025-02-27 (+37d) |  |  | 762d → 32308d |  | constraint none → finish no earlier than 2025-02-20; baseline start 2025-01-08 → 2025-02-07; baseline finish 2025-01-21 → 2025-02-20 |
| 2070 | **DIP Onboarding (UIT)** | 2024-08-05 A → 2024-07-26 A (-10d) | 2024-09-24 → 2024-12-13 A (+80d) | 37d → 101d | 46% → 100% | 847d → none |  | baseline start 2024-08-05 → 2024-07-26; baseline finish 2024-09-24 → 2024-11-29 |
| 2080 | DIP UIT Test Stubs | 2024-08-28 → 2024-10-31 A (+64d) | 2024-09-24 → 2024-12-13 A (+80d) | 20d → 32d | 0% → 100% | 847d → none | Non-SIT S&A QTF Environments Connection Confirmed to UIT Environment → 2075, 2077, 2079 | constraint none → start no earlier than 2024-10-31; baseline start 2024-08-28 → 2024-10-17; baseline finish 2024-09-24 → 2024-11-29 |
| 2081 | **DTN Onboarding** |  | 2024-09-27 → 2024-10-25 A (+28d) | 95d → 115d | 47% → 100% | 844d → none |  | baseline finish 2024-09-27 → 2024-10-25 |
| 2082 | DTN Request Raised for Onboarding |  |  |  |  |  | 2056FS+10d → none | constraint none → start no earlier than 2024-05-20 |
| 2083 | Setup, configuration of New Host and Test Flags |  |  |  |  |  |  | constraint none → start no earlier than 2024-06-24 |
| 2086 | DTN Test Stubs | 2024-09-16 A | 2024-09-27 A |  | 0% → 100% | 844d → none | New VPN Connection → 2084 | constraint none → start no earlier than 2024-09-16 |
| 2097 | Sample MPAN Data + Attributes from Suppliers |  |  |  |  |  | 2006 → none | constraint none → finish no earlier than 2024-06-28 |
| 2108 | **Industry Standing Data (ISD)** | 2024-07-26 A → 2024-07-26 | 2024-09-10 → 2024-11-01 (+52d) | 33d → 71d | 6% → 100% | 857d → none |  | baseline finish 2024-09-10 → 2024-11-01 |
| 2109 | Dependant on Receiving ISD Agreed Source Data from Helix | 2024-07-26 A → 2024-08-23 A (+28d) | 2024-07-26 A → 2024-08-23 A (+28d) |  |  |  |  | constraint start no earlier than 2024-07-26 → finish no earlier than 2024-07-26; baseline start 2024-07-26 → 2024-08-23; baseline finish 2024-07-26 → 2024-08-23 |
| 2113 | First View of Migrated ISD Data | 2024-08-19 → 2024-08-21 A (+2d) | 2024-08-19 → 2024-09-27 A (+39d) | 1d → 28d | 0% → 100% | 857d → none | 2109 → none | constraint start no earlier than 2024-08-19 → finish no earlier than 2024-09-27; baseline start 2024-08-19 → 2024-08-21; baseline finish 2024-08-19 → 2024-09-27 |
| 2115 | Final Cycle 3 Migrated ISD Data | 2024-08-20 → 2024-06-10 A (-71d) | 2024-08-20 → 2024-06-14 A (-67d) | 1d → 5d | 0% → 100% | 857d → none | 2113 → none | baseline start 2024-08-20 → 2024-06-10; baseline finish 2024-08-20 → 2024-06-14 |
| 2116 | Create ISD Template inc. DIP ID | 2024-08-21 → 2024-06-10 A (-72d) | 2024-08-27 → 2024-07-26 A (-32d) | 5d → 35d | 0% → 100% | 857d → none | 2115 → none | baseline start 2024-08-21 → 2024-06-10; baseline finish 2024-08-27 → 2024-07-26 |
| 2117 | Publish Qualification ISD | 2024-08-28 → 2024-10-14 A (+47d) | 2024-09-10 → 2024-10-25 A (+45d) |  | 0% → 100% | 857d → none | 2116 → none | baseline start 2024-08-28 → 2024-10-14; baseline finish 2024-09-10 → 2024-10-25 |
| 2148 | **Wave 1 Test Data** |  | 2025-07-14 → 2025-07-15 (+1d) |  |  | 35d → none | none → 2134SS | baseline finish 2025-07-14 → 2025-07-15 |
| 2149 | Test Data Request + Templates Completed | 2025-05-12 → 2025-04-21 (-21d) | 2025-06-02 → 2025-05-12 (-21d) |  |  | 35d → 32226d | 2195 → 2133SS | constraint none → finish no earlier than 2025-05-12; baseline start 2025-05-12 → 2025-04-21; baseline finish 2025-06-02 → 2025-05-12 |
| 2150 | Test Data Generated | 2025-06-03 → 2025-05-21 (-13d) | 2025-06-16 → 2025-06-03 (-13d) |  |  | 35d → 32220d | 2149 → 2136, 2149 | constraint none → finish no earlier than 2025-06-03; baseline start 2025-06-03 → 2025-05-21; baseline finish 2025-06-16 → 2025-06-03 |
| 2151 | Test Data Loaded into QP Systems | 2025-06-17 → 2025-06-04 (-13d) | 2025-07-14 → 2025-07-01 (-13d) |  |  | 35d → 32220d |  | constraint none → finish no earlier than 2025-06-17; baseline start 2025-06-17 → 2025-06-04; baseline finish 2025-07-14 → 2025-07-01 |
| 2152 | Test Data Loaded into QTF + ADO | 2025-06-17 → 2025-06-04 (-13d) | 2025-07-11 → 2025-06-30 (-11d) |  |  | 36d → 32221d |  | constraint none → finish no earlier than 2025-06-17; baseline start 2025-06-17 → 2025-06-04; baseline finish 2025-07-11 → 2025-06-30 |
| 2153 | **Wave 2 Test Data** |  | 2025-09-02 → 2025-09-03 (+1d) |  |  | 39d → none |  | baseline finish 2025-09-02 → 2025-09-03 |
| 2154 | Test Data Request + Templates Completed | 2025-07-07 → 2025-06-16 (-21d) | 2025-07-28 → 2025-07-07 (-21d) |  |  | 39d → 32190d | 2225 → none | constraint none → finish no earlier than 2025-07-07; baseline start 2025-07-07 → 2025-06-16; baseline finish 2025-07-28 → 2025-07-07 |
| 2155 | Test Data Generated | 2025-07-29 → 2025-07-16 (-13d) | 2025-08-11 → 2025-07-29 (-13d) |  |  | 39d → 32184d |  | constraint none → finish no earlier than 2025-07-29; baseline start 2025-07-29 → 2025-07-16; baseline finish 2025-08-11 → 2025-07-29 |
| 2156 | Test Data Loaded into QP Systems | 2025-08-12 → 2025-07-30 (-13d) | 2025-09-02 → 2025-08-20 (-13d) |  |  | 39d → 32184d |  | constraint none → finish no earlier than 2025-08-12; baseline start 2025-08-12 → 2025-07-30; baseline finish 2025-09-02 → 2025-08-20 |
| 2157 | Test Data Loaded into QTF + ADO | 2025-08-12 → 2025-07-30 (-13d) | 2025-09-02 → 2025-08-20 (-13d) |  |  | 39d → 32184d |  | constraint none → finish no earlier than 2025-08-12; baseline start 2025-08-12 → 2025-07-30; baseline finish 2025-09-02 → 2025-08-20 |
| 2158 | **Wave 3 Test Data** |  | 2025-11-07 → 2025-11-10 (+3d) |  |  | 29d → none |  | baseline finish 2025-11-07 → 2025-11-10 |
| 2159 | Test Data Request + Templates Completed | 2025-09-08 → 2025-08-19 (-20d) | 2025-09-26 → 2025-09-08 (-18d) |  |  | 29d → 32141d | 2255 → none | constraint none → finish no earlier than 2025-09-08; baseline start 2025-09-08 → 2025-08-19; baseline finish 2025-09-26 → 2025-09-08 |
| 2160 | Test Data Generated | 2025-09-29 → 2025-09-16 (-13d) | 2025-10-10 → 2025-09-29 (-11d) |  |  | 29d → 32136d |  | constraint none → finish no earlier than 2025-09-29; baseline start 2025-09-29 → 2025-09-16; baseline finish 2025-10-10 → 2025-09-29 |
| 2161 | Test Data Loaded into QP Systems | 2025-10-13 → 2025-09-30 (-13d) | 2025-11-07 → 2025-10-27 (-11d) |  |  | 29d → 32136d |  | constraint none → finish no earlier than 2025-10-13; baseline start 2025-10-13 → 2025-09-30; baseline finish 2025-11-07 → 2025-10-27 |
| 2162 | Test Data Loaded into QTF + ADO | 2025-10-13 → 2025-09-30 (-13d) | 2025-11-07 → 2025-10-27 (-11d) |  |  | 29d → 32136d |  | constraint none → finish no earlier than 2025-10-13; baseline start 2025-10-13 → 2025-09-30; baseline finish 2025-11-07 → 2025-10-27 |
| 2163 | **Wave 4 Test Data** | 2025-10-27 → 2025-11-06 (+10d) | 2025-12-26 → 2026-01-08 (+13d) |  |  | 49d → none |  | baseline start 2025-10-27 → 2025-11-06; baseline finish 2025-12-26 → 2026-01-08 |
| 2164 | Test Data Request + Templates Completed | 2025-10-27 → 2025-10-17 (-10d) | 2025-11-14 → 2025-11-06 (-8d) |  |  | 49d → 32098d | 2285 → none | constraint none → finish no earlier than 2025-11-06; baseline start 2025-10-27 → 2025-10-17; baseline finish 2025-11-14 → 2025-11-06 |
| 2165 | Test Data Generated | 2025-11-17 → 2025-11-14 (-3d) | 2025-11-28 → 2025-11-27 (-1d) |  |  | 49d → 32093d |  | constraint none → finish no earlier than 2025-11-27; baseline start 2025-11-17 → 2025-11-14; baseline finish 2025-11-28 → 2025-11-27 |
| 2166 | Test Data Loaded into QP Systems | 2025-12-01 → 2025-11-28 (-3d) | 2025-12-26 → 2025-12-25 (-1d) |  |  | 49d → 32093d |  | constraint none → finish no earlier than 2025-12-11; baseline start 2025-12-01 → 2025-11-28; baseline finish 2025-12-26 → 2025-12-25 |
| 2167 | Test Data Loaded into QTF + ADO | 2025-12-01 → 2025-11-28 (-3d) | 2025-12-26 → 2025-12-25 (-1d) |  |  | 49d → 32093d |  | constraint none → finish no earlier than 2025-12-11; baseline start 2025-12-01 → 2025-11-28; baseline finish 2025-12-26 → 2025-12-25 |
| 2168 | **Governance** |  | 2024-12-27 → 2025-03-28 (+91d) | 130d → 195d | 29% → 6% | 779d → 32287d |  | baseline finish 2024-12-27 → 2024-12-20 |
| 2169 | Onboarding Strategy and Develop Training Requirements & Materials Inc. Day in the Life | 2024-07-01 A → 2024-07-01 | 2024-09-27 → 2024-12-13 (+77d) | 65d → 120d | 43% → 0% | 844d → 32362d |  | constraint none → finish no earlier than 2024-12-13; baseline finish 2024-09-27 → 2024-11-29 |
| 2170 | Design Approach & Set-Up ADO Tool for Test & Defect Management Tool |  | 2024-08-30 → 2024-07-26 A (-35d) | 45d → 20d | 62% → 100% | 216d → none |  | baseline finish 2024-08-30 → 2024-07-26 |
| 2171 | Knowledge Transfer, Training, Demonstrations, Documentation, Governance | 2024-09-02 → 2024-08-30 (-3d) | 2024-12-27 → 2024-12-17 (-10d) | 85d → 78d |  | 176d → 32360d | 2169SS+45d → 2169SS+44d | baseline start 2024-09-02 → 2024-08-30; baseline finish 2024-12-27 → 2024-12-17 |
| 2175 | Qualification Testing Wave Readiness Confirmed | 2024-12-27 → 2025-08-21 (+237d) | 2024-12-27 → 2025-08-21 (+237d) |  |  | 176d → 32184d | 2171 → 2203FS-2d | constraint none → finish no earlier than 2025-05-30; baseline start 2024-12-27 → 2025-08-21; baseline finish 2024-12-27 → 2025-08-21 |
| 2184 | **Qualification Wave 1** | 2025-03-24 → 2025-05-05 (+42d) | 2026-04-10 → 2026-04-15 (+5d) | 275d → 248d |  | 5d → 31578d |  |  |
| 2185 | **Qualification Wave 1 QAD Prep** | 2025-03-24 → 2025-05-05 (+42d) | 2025-07-11 → 2025-08-22 (+42d) |  |  | 36d → 31579d |  |  |
| 2186 | Initial QAD Submission window opens | 2025-03-24 → 2025-05-05 (+42d) | 2025-03-24 → 2025-05-05 (+42d) |  |  | 36d → 31579d | 2183, 1958FS+121d → 2183, 1958FS+11d | constraint none → start no earlier than 2025-03-24; baseline start 2025-03-24 → 2025-05-05; baseline finish 2025-03-24 → 2025-05-05 |
| 2187 | Qualification Wave 1 Participants Submit Initial QAD | 2025-03-24 → 2025-05-05 (+42d) | 2025-05-30 → 2025-07-11 (+42d) |  |  | 36d → 31579d |  | baseline start 2025-03-24 → 2025-05-05; baseline finish 2025-05-30 → 2025-07-11 |
| 2188 | Qualification Wave 1 Participants have submitted their initial QAD | 2025-06-02 → 2025-07-14 (+42d) | 2025-06-02 → 2025-07-14 (+42d) |  |  | 36d → 31579d |  | baseline start 2025-06-02 → 2025-07-14; baseline finish 2025-06-02 → 2025-07-14 |
| 2189 | Code Bodies review of Wave 1 Participants Initial QAD | 2025-06-02 → 2025-07-14 (+42d) | 2025-07-11 → 2025-08-22 (+42d) |  |  | 36d → 31579d |  | baseline start 2025-06-02 → 2025-07-14; baseline finish 2025-07-11 → 2025-08-22 |
| 2190 | Completion of Code Bodies review of Initial QAD | 2025-07-11 → 2025-08-22 (+42d) | 2025-07-11 → 2025-08-22 (+42d) |  |  | 36d → 31579d |  | baseline start 2025-07-11 → 2025-08-22; baseline finish 2025-07-11 → 2025-08-22 |
| 2191 | **Qualification Wave 1 Test Prep** | 2025-04-14 → 2025-05-26 (+42d) | 2025-07-04 → 2025-08-15 (+42d) |  |  | 41d → 31584d |  |  |
| 2192 | Confirmation from Qualification Wave 1 Participants that DIP onboarding has commenced | 2025-04-14 → 2025-05-26 (+42d) | 2025-04-14 → 2025-05-26 (+42d) |  |  | 61d → 31604d |  | constraint start no earlier than 2025-04-14 → start no earlier than 2025-05-26; baseline start 2025-04-14 → 2025-05-26; baseline finish 2025-04-14 → 2025-05-26 |
| 2193 | Qualification Wave 1 Participants DIP Onboarding Window | 2025-04-14 → 2025-05-26 (+42d) | 2025-05-30 → 2025-07-11 (+42d) |  |  | 61d → 31604d |  | baseline start 2025-04-14 → 2025-05-26; baseline finish 2025-05-30 → 2025-07-11 |
| 2194 | Confirmation from Qualification Wave 1 Participants that DIP onboarding has completed | 2025-05-30 → 2025-07-11 (+42d) | 2025-05-30 → 2025-07-11 (+42d) |  |  | 61d → 31604d |  | baseline start 2025-05-30 → 2025-07-11; baseline finish 2025-05-30 → 2025-07-11 |
| 2195 | Qualification Wave 1 Participants' to provide status of PIT completion and submit QT Test Plan | 2025-05-12 → 2025-06-13 (+32d) | 2025-05-12 → 2025-06-13 (+32d) |  |  | 35d → 31610d |  | constraint start no earlier than 2025-05-12 → start no earlier than 2025-06-13; baseline start 2025-05-12 → 2025-06-16; baseline finish 2025-05-12 → 2025-06-16 |
| 2196 | Review of Participants' PIT Status and QT Test Plan | 2025-05-12 → 2025-06-13 (+32d) | 2025-05-30 → 2025-07-03 (+34d) |  |  | 61d → 31610d |  | baseline start 2025-05-12 → 2025-06-16; baseline finish 2025-05-30 → 2025-07-04 |
| 2197 | Qualification Test Plans for Wave 1 Participants approved | 2025-05-30 → 2025-07-03 (+34d) | 2025-05-30 → 2025-07-03 (+34d) |  |  | 61d → 31610d |  | baseline start 2025-05-30 → 2025-07-04; baseline finish 2025-05-30 → 2025-07-04 |
| 2198 | Qualification Wave 1 Participants have submitted PIT Test Completion Report and evidence for QT Entry | 2025-06-02 → 2025-07-14 (+42d) | 2025-06-02 → 2025-07-14 (+42d) |  |  | 36d → 31579d |  | constraint start no earlier than 2025-06-02 → start no earlier than 2025-07-14; baseline start 2025-06-02 → 2025-07-14; baseline finish 2025-06-02 → 2025-07-14 |
| 2199 | Review of Participants PIT Test Completion Report | 2025-06-02 → 2025-07-14 (+42d) | 2025-07-04 → 2025-08-15 (+42d) |  |  | 36d → 31579d |  | baseline start 2025-06-02 → 2025-07-14; baseline finish 2025-07-04 → 2025-08-15 |
| 2200 | Onboarding to QTF & ADO | 2025-06-02 → 2025-07-14 (+42d) | 2025-07-04 → 2025-08-15 (+42d) |  |  | 41d → 31584d | 2199SS, 2054 → 2199SS | baseline start 2025-06-02 → 2025-07-14; baseline finish 2025-07-04 → 2025-08-15 |

| ID | Task | Start | Finish | Duration | Complete | Total float | Predecessors | Other |
| --- | --- | --- | --- | --- | --- | --- | --- | --- |
| 2201 | **Qualification Wave 1 QT Execution** | 2025-07-07 → 2025-08-18 (+42d) | 2026-01-02 → 2026-01-09 (+7d) | 130d → 105d |  | 10d → 31579d |  | baseline start 2025-07-07 → 2025-08-18; baseline finish 2026-01-02 → 2026-01-09 |
| 2202 | Review Entry Criteria Evidence for each Wave 1 Participant | 2025-07-07 → 2025-08-18 (+42d) | 2025-07-11 → 2025-08-22 (+42d) |  |  | 36d → 31579d |  | baseline start 2025-07-07 → 2025-08-18; baseline finish 2025-07-11 → 2025-08-22 |
| 2203 | Qualification Wave 1 Participant Test Readiness Confirmed | 2025-07-14 → 2025-08-22 (+39d) | 2025-07-14 → 2025-08-22 (+39d) |  |  | 35d → 31579d | 2189, 2190, 2202FF, 2151, 2152 → 2189, 2190, 2202FF | baseline start 2025-07-14 → 2025-08-22; baseline finish 2025-07-14 → 2025-08-22 |
| 2204 | Qualification Wave 1 QT Execution Start |  |  |  |  | 5d → 31578d | 2203, 2175, 2200, 1557FS+6d → 2203, 2200, 1557FS+6d |  |
| 2205 | Qualification Wave 1 QT Execution Window |  | 2026-01-02 → 2026-01-09 (+7d) | 95d → 100d |  | 10d → 31583d |  | baseline finish 2026-01-02 → 2026-01-09 |
| 2206 | Qualification Wave 1 QT Projected Execution End | 2026-01-02 → 2026-01-09 (+7d) | 2026-01-02 → 2026-01-09 (+7d) |  |  | 10d → 31583d |  | baseline start 2026-01-02 → 2026-01-09; baseline finish 2026-01-02 → 2026-01-09 |
| 2207 | **Qualification Wave 1 Exit** |  | 2026-04-10 → 2026-04-15 (+5d) | 165d → 168d |  | 5d → 31578d |  | baseline finish 2026-04-10 → 2026-04-15 |
| 2209 | Qualification Wave 1 Participants submit their Final QAD |  | 2026-01-09 → 2026-01-16 (+7d) | 100d → 105d |  | 5d → 31578d |  | baseline finish 2026-01-09 → 2026-01-16 |
| 2210 | Qualification Wave 1 Participants have submitted their final QAD | 2026-01-09 → 2026-01-16 (+7d) | 2026-01-09 → 2026-01-16 (+7d) |  |  | 5d → 31578d |  | baseline start 2026-01-09 → 2026-01-16; baseline finish 2026-01-09 → 2026-01-16 |
| 2211 | Completion of Code Bodies review of Final QAD | 2026-01-12 → 2026-01-19 (+7d) | 2026-02-27 → 2026-03-06 (+7d) |  |  | 5d → 31578d |  | baseline start 2026-01-12 → 2026-01-19; baseline finish 2026-02-27 → 2026-03-06 |
| 2212 | QAD Sign Off deadline | 2026-03-13 → 2026-03-20 (+7d) | 2026-03-13 → 2026-03-20 (+7d) |  |  | 5d → 31578d |  | baseline start 2026-03-13 → 2026-03-20; baseline finish 2026-03-13 → 2026-03-20 |
| 2213 | Qualification Wave 1 Participants Qualification approved by BSC PAB and REC Manager | 2026-04-10 → 2026-04-15 (+5d) | 2026-04-10 → 2026-04-15 (+5d) |  |  | 5d → 31578d | 2212FS+20d → 2212FS+18d | baseline start 2026-04-10 → 2026-04-15; baseline finish 2026-04-10 → 2026-04-15 |
| 2214 | **Qualification Wave 2** |  | 2026-05-27 → 2026-05-28 (+1d) | 253d → 254d |  | 6d → 31578d |  | baseline finish 2026-05-27 → 2026-05-28 |
| 2221 | **Qualification Wave 2 Test Prep** | 2025-06-09 → 2025-07-21 (+42d) | 2025-08-29 → 2025-10-10 (+42d) |  |  | 42d → 31584d |  | baseline start 2025-06-09 → 2025-07-21; baseline finish 2025-08-29 → 2025-10-10 |
| 2222 | Confirmation from Qualification Wave 2 Participants that DIP Onboarding has commenced | 2025-06-09 → 2025-07-21 (+42d) | 2025-06-09 → 2025-07-21 (+42d) |  |  | 61d → 31603d |  | constraint start no earlier than 2025-06-09 → start no earlier than 2025-07-21; baseline start 2025-06-09 → 2025-07-21; baseline finish 2025-06-09 → 2025-07-21 |
| 2223 | Qualification Wave 2 Participants DIP Onboarding Window | 2025-06-09 → 2025-07-21 (+42d) | 2025-07-25 → 2025-09-05 (+42d) |  |  | 61d → 31603d |  | baseline start 2025-06-09 → 2025-07-21; baseline finish 2025-07-25 → 2025-09-05 |
| 2224 | Confirmation from Qualificiation Wave 2 Participants that DIP onboarding has completed | 2025-07-25 → 2025-09-05 (+42d) | 2025-07-25 → 2025-09-05 (+42d) |  |  | 61d → 31603d |  | baseline start 2025-07-25 → 2025-09-05; baseline finish 2025-07-25 → 2025-09-05 |
| 2225 | Qualification Wave 2 Participants' to provide status of PIT completion and submit QT Test Plan | 2025-07-07 → 2025-08-18 (+42d) | 2025-07-07 → 2025-08-18 (+42d) |  |  | 39d → 31603d |  | constraint start no earlier than 2025-07-07 → start no earlier than 2025-08-18; baseline start 2025-07-07 → 2025-08-18; baseline finish 2025-07-07 → 2025-08-18 |
| 2226 | Review of Participants' PIT Status and QT Test Plan | 2025-07-07 → 2025-08-18 (+42d) | 2025-07-25 → 2025-09-05 (+42d) |  |  | 61d → 31603d |  | baseline start 2025-07-07 → 2025-08-18; baseline finish 2025-07-25 → 2025-09-05 |
| 2227 | Qualification Test Plans for Wave 2 Participants approved | 2025-07-25 → 2025-09-05 (+42d) | 2025-07-25 → 2025-09-05 (+42d) |  |  | 61d → 31603d |  | baseline start 2025-07-25 → 2025-09-05; baseline finish 2025-07-25 → 2025-09-05 |
| 2228 | Qualification Wave 2 Participants have submitted PIT Test Completion Report and evidence for QT entry | 2025-07-28 → 2025-09-08 (+42d) | 2025-07-28 → 2025-09-08 (+42d) |  |  | 36d → 31578d |  | constraint start no earlier than 2025-07-28 → start no earlier than 2025-09-08; baseline start 2025-07-28 → 2025-09-08; baseline finish 2025-07-28 → 2025-09-08 |
| 2229 | Review of Participants' PIT Test Completion Report | 2025-07-28 → 2025-09-08 (+42d) | 2025-08-29 → 2025-10-10 (+42d) |  |  | 36d → 31578d |  | baseline start 2025-07-28 → 2025-09-08; baseline finish 2025-08-29 → 2025-10-10 |
| 2230 | Onboarding to QTF & ADO | 2025-07-28 → 2025-09-08 (+42d) | 2025-08-29 → 2025-10-10 (+42d) |  |  | 42d → 31584d |  | baseline start 2025-07-28 → 2025-09-08; baseline finish 2025-08-29 → 2025-10-10 |
| 2233 | Qualification Wave 2 Participant Test Readiness Confirmed |  |  |  |  | 6d → 31578d | 2232, 2220, 2156, 2157 → 2232, 2220 |  |
| 2237 | **Qualification Wave 2 Exit** |  | 2026-05-27 → 2026-05-28 (+1d) | 158d → 159d |  | 6d → 31578d |  | baseline finish 2026-05-27 → 2026-05-28 |
| 2243 | Qualification Wave 2 Participants Qualification approved by BSC PAB and REC Manager | 2026-05-27 → 2026-05-28 (+1d) | 2026-05-27 → 2026-05-28 (+1d) |  |  | 6d → 31578d | 2242FS+27d → 2242FS+28d | baseline start 2026-05-27 → 2026-05-28; baseline finish 2026-05-27 → 2026-05-28 |
| 2244 | **Qualification Wave 3** | 2025-08-04 → 2025-08-11 (+7d) | 2026-07-23 → 2026-07-30 (+7d) |  |  | 5d → 60d |  | baseline start 2025-08-04 → 2025-08-11; baseline finish 2026-07-23 → 2026-07-30 |
| 2251 | **Qualification Wave 3 Test Prep** | 2025-08-04 → 2025-09-15 (+42d) | 2025-10-31 → 2025-12-12 (+42d) |  |  | 54d → 31612d |  | baseline start 2025-08-04 → 2025-09-15; baseline finish 2025-10-31 → 2025-12-12 |
| 2252 | Confirmation from Qualification Wave 3 Participants that DIP Onboarding has commenced | 2025-08-04 → 2025-09-15 (+42d) | 2025-08-04 → 2025-09-15 (+42d) |  |  | 60d → 31612d |  | constraint start no earlier than 2025-08-04 → start no earlier than 2025-09-15; baseline start 2025-08-04 → 2025-09-15; baseline finish 2025-08-04 → 2025-09-15 |
| 2253 | Qualification Wave 3 Participants DIP Onboarding window | 2025-08-04 → 2025-09-15 (+42d) | 2025-09-19 → 2025-10-31 (+42d) |  |  | 60d → 31612d |  | baseline start 2025-08-04 → 2025-09-15; baseline finish 2025-09-19 → 2025-10-31 |
| 2254 | Confirmation from Qualification Wave 3 Participants that DIP onboarding has completed | 2025-09-22 → 2025-10-31 (+39d) | 2025-09-22 → 2025-10-31 (+39d) |  |  | 60d → 31612d |  | baseline start 2025-09-22 → 2025-10-31; baseline finish 2025-09-22 → 2025-10-31 |
| 2255 | Qualification Wave 3 Participants' to provide status of PIT completion and submit QT Test Plan | 2025-09-08 → 2025-10-20 (+42d) | 2025-09-08 → 2025-10-20 (+42d) |  |  | 29d → 32127d |  | constraint start no earlier than 2025-09-08 → start no earlier than 2025-10-20; baseline start 2025-09-08 → 2025-10-20; baseline finish 2025-09-08 → 2025-10-20 |
| 2256 | Review of Participants' PIT Status and QT Test Plan | 2025-09-08 → 2025-10-20 (+42d) | 2025-09-26 → 2025-11-07 (+42d) |  |  | 584d → 32127d |  | baseline start 2025-09-08 → 2025-10-20; baseline finish 2025-09-26 → 2025-11-07 |
| 2257 | Qualification Test Plans for Wave 3 Participants approved | 2025-09-26 → 2025-11-07 (+42d) | 2025-09-26 → 2025-11-07 (+42d) |  |  | 584d → 32127d |  | baseline start 2025-09-26 → 2025-11-07; baseline finish 2025-09-26 → 2025-11-07 |
| 2258 | Qualification Wave 3 Participants have submitted PIT Test Completion Report and evidence for QT Entry | 2025-09-29 → 2025-11-10 (+42d) | 2025-09-29 → 2025-11-10 (+42d) |  |  | 30d → 31582d |  | constraint start no earlier than 2025-09-29 → start no earlier than 2025-11-10; baseline start 2025-09-29 → 2025-11-10; baseline finish 2025-09-29 → 2025-11-10 |
| 2259 | Review of Participants' PIT Test Completion Report | 2025-09-29 → 2025-11-10 (+42d) | 2025-10-31 → 2025-12-12 (+42d) |  |  | 30d → 31582d |  | baseline start 2025-09-29 → 2025-11-10; baseline finish 2025-10-31 → 2025-12-12 |
| 2260 | Onboarding to QTF & ADO | 2025-09-29 → 2025-11-10 (+42d) | 2025-10-31 → 2025-12-12 (+42d) |  |  | 30d → 31582d |  | baseline start 2025-09-29 → 2025-11-10; baseline finish 2025-10-31 → 2025-12-12 |
| 2263 | Qualification Wave 3 Participant Test Readiness confirmed |  |  |  |  | 0d → 31582d | 2254, 2262FS-1d, 2161, 2162 → 2254, 2262 |  |
| 2264 | Qualification Wave 3 Execution Start | 2026-01-05 → 2026-01-12 (+7d) | 2026-01-05 → 2026-01-12 (+7d) |  |  | 0d → 31582d | 2263FS+12d, 2260FS+1d → 2263FS+16d, 2260FS+1d | baseline start 2026-01-05 → 2026-01-12; baseline finish 2026-01-05 → 2026-01-12 |
| 2265 | Qualification Wave 3 QT Execution Window | 2026-01-05 → 2026-01-12 (+7d) |  | 95d → 90d |  | 5d → 31587d |  | baseline start 2026-01-05 → 2026-01-12 |
| 2267 | **Qualification Wave 3 Exit** | 2026-01-05 → 2026-01-12 (+7d) | 2026-07-23 → 2026-07-30 (+7d) |  |  | 0d → 31582d |  | baseline start 2026-01-05 → 2026-01-12; baseline finish 2026-07-23 → 2026-07-30 |
| 2268 | Final QAD Submission window opens | 2026-01-05 → 2026-01-12 (+7d) | 2026-01-05 → 2026-01-12 (+7d) |  |  | 0d → 31582d |  | baseline start 2026-01-05 → 2026-01-12; baseline finish 2026-01-05 → 2026-01-12 |
| 2269 | Qualification Wave 3 Participants submit their Final QAD | 2026-01-05 → 2026-01-12 (+7d) |  | 100d → 95d |  | 0d → 31582d |  | baseline start 2026-01-05 → 2026-01-12 |
| 2273 | Qualification Wave 3 Participants Qualification approved by BSC PAB and REC Manager | 2026-07-23 → 2026-07-30 (+7d) | 2026-07-23 → 2026-07-30 (+7d) |  |  | 0d → 31582d | 2272FS+19d → 2272FS+24d | baseline start 2026-07-23 → 2026-07-30; baseline finish 2026-07-23 → 2026-07-30 |
| 2274 | **Qualification Wave 4** | 2025-09-22 → 2025-10-20 (+28d) |  | 354d → 334d |  | 24d → 31573d |  | baseline start 2025-09-22 → 2025-10-20 |
| 2281 | **Qualification Wave 4 Test Prep** | 2025-09-22 → 2025-11-03 (+42d) | 2025-12-19 → 2026-02-13 (+56d) | 65d → 75d |  | 60d → 31589d |  | baseline start 2025-09-22 → 2025-11-03; baseline finish 2025-12-19 → 2026-02-13 |
| 2282 | Confirmation from Qualification 4 Participants that DIP Onboarding has commenced | 2025-09-22 → 2025-11-03 (+42d) | 2025-09-22 → 2025-11-03 (+42d) |  |  | 79d → 31623d |  | constraint start no earlier than 2025-09-22 → start no earlier than 2025-11-03; baseline start 2025-09-22 → 2025-11-03; baseline finish 2025-09-22 → 2025-11-03 |
| 2283 | Qualification Wave 4 Participants DIP Onboarding Window | 2025-09-22 → 2025-11-03 (+42d) | 2025-11-07 → 2025-12-19 (+42d) |  |  | 79d → 31623d |  | baseline start 2025-09-22 → 2025-11-03; baseline finish 2025-11-07 → 2025-12-19 |
| 2284 | Confirmation from Qualification Wave 4 Participants that DIP onboarding has completed | 2025-11-07 → 2025-12-19 (+42d) | 2025-11-07 → 2025-12-19 (+42d) |  |  | 79d → 31623d |  | baseline start 2025-11-07 → 2025-12-19; baseline finish 2025-11-07 → 2025-12-19 |
| 2285 | Qualification Wave 4 Participants' to provide status of PIT completion and submit QT Test Plan | 2025-10-27 → 2025-12-08 (+42d) | 2025-10-27 → 2025-12-08 (+42d) |  |  | 49d → 31589d |  | constraint start no earlier than 2025-10-27 → start no earlier than 2025-12-08; baseline start 2025-10-27 → 2025-12-08; baseline finish 2025-10-27 → 2025-12-08 |
| 2286 | Review of Participants' PIT Status and QT Test Plan | 2025-10-27 → 2025-12-08 (+42d) | 2025-11-14 → 2026-01-09 (+56d) | 15d → 25d |  | 60d → 31589d |  | baseline start 2025-10-27 → 2025-12-08; baseline finish 2025-11-14 → 2026-01-09 |
| 2287 | Qualification Test Plans for Qualification Wave 4 Participants approved | 2025-11-14 → 2026-01-09 (+56d) | 2025-11-14 → 2026-01-09 (+56d) |  |  | 60d → 31589d |  | baseline start 2025-11-14 → 2026-01-09; baseline finish 2025-11-14 → 2026-01-09 |
| 2288 | Qualification Wave 4 Participants have submitted PIT Test Completion Report and evidence for QT entry | 2025-11-14 → 2026-01-09 (+56d) | 2025-11-14 → 2026-01-09 (+56d) |  |  | 60d → 31589d |  | baseline start 2025-11-14 → 2026-01-09; baseline finish 2025-11-14 → 2026-01-09 |
| 2289 | Review of Participants' PIT Test Completion Report | 2025-11-17 → 2026-01-12 (+56d) | 2025-12-19 → 2026-02-13 (+56d) |  |  | 60d → 31589d |  | baseline start 2025-11-17 → 2026-01-12; baseline finish 2025-12-19 → 2026-02-13 |
| 2290 | Onboarding to QTF & ADO | 2025-11-24 → 2026-01-12 (+49d) | 2025-12-19 → 2026-02-13 (+56d) | 20d → 25d |  | 55d → 31589d |  | baseline start 2025-11-24 → 2026-01-12; baseline finish 2025-12-19 → 2026-02-13 |
| 2291 | **Qualification Wave 4 QT Execution** | 2026-02-23 → 2026-03-02 (+7d) | 2026-07-10 → 2026-07-17 (+7d) |  |  | 4d → 31573d |  | baseline start 2026-02-23 → 2026-03-02; baseline finish 2026-07-10 → 2026-07-17 |
| 2292 | Review Entry Criteria Evidence for each Wave 4 Participant | 2026-02-23 → 2026-03-02 (+7d) | 2026-02-27 → 2026-03-06 (+7d) |  |  | 4d → 31573d | 2280FF, 2284 → 2280FF+5d, 2284 | constraint start no earlier than 2026-01-05 → none; baseline start 2026-02-23 → 2026-03-02; baseline finish 2026-02-27 → 2026-03-06 |
| 2293 | Qualification Wave 4 Participant Test Readiness Confirmed | 2026-02-27 → 2026-03-06 (+7d) | 2026-02-27 → 2026-03-06 (+7d) |  |  | 4d → 31573d | 2284, 2292, 2166, 2167 → 2284, 2292 | baseline start 2026-02-27 → 2026-03-06; baseline finish 2026-02-27 → 2026-03-06 |
| 2294 | Qualification Wave 4 QT Execution Start | 2026-03-02 → 2026-03-09 (+7d) | 2026-03-02 → 2026-03-09 (+7d) |  |  | 4d → 31573d |  | baseline start 2026-03-02 → 2026-03-09; baseline finish 2026-03-02 → 2026-03-09 |
| 2295 | Qualification Wave 4 QT Execution Window | 2026-03-02 → 2026-03-09 (+7d) | 2026-07-10 → 2026-07-17 (+7d) |  |  | 9d → 31578d |  | baseline start 2026-03-02 → 2026-03-09; baseline finish 2026-07-10 → 2026-07-17 |
| 2296 | Qualification Wave 4 Projected Execution End | 2026-07-10 → 2026-07-17 (+7d) | 2026-07-10 → 2026-07-17 (+7d) |  |  | 9d → 31578d |  | baseline start 2026-07-10 → 2026-07-17; baseline finish 2026-07-10 → 2026-07-17 |
| 2297 | **Qualification Wave 4 Exit** | 2026-03-02 → 2026-03-09 (+7d) | 2026-09-18 → 2026-09-24 (+6d) | 145d → 144d |  | 4d → 31573d |  | baseline start 2026-03-02 → 2026-03-09; baseline finish 2026-09-18 → 2026-09-24 |
| 2298 | Final QAD Submission window opens | 2026-03-02 → 2026-03-09 (+7d) | 2026-03-02 → 2026-03-09 (+7d) |  |  | 4d → 31573d |  | baseline start 2026-03-02 → 2026-03-09; baseline finish 2026-03-02 → 2026-03-09 |
| 2299 | Qualification Wave 4 Participants submit their Final QAD | 2026-03-02 → 2026-03-09 (+7d) | 2026-07-17 → 2026-07-24 (+7d) |  |  | 4d → 31573d |  | baseline start 2026-03-02 → 2026-03-09; baseline finish 2026-07-17 → 2026-07-24 |
| 2300 | Qualification Wave 4 Participants have submitted their Final QAD | 2026-07-17 → 2026-07-24 (+7d) | 2026-07-17 → 2026-07-24 (+7d) |  |  | 4d → 31573d |  | baseline start 2026-07-17 → 2026-07-24; baseline finish 2026-07-17 → 2026-07-24 |
| 2301 | Completion of Code Bodies review of Final QAD | 2026-07-20 → 2026-07-27 (+7d) | 2026-08-14 → 2026-08-21 (+7d) |  |  | 4d → 31573d |  | baseline start 2026-07-20 → 2026-07-27; baseline finish 2026-08-14 → 2026-08-21 |
| 2302 | QAD Sign Off deadline | 2026-08-21 → 2026-08-28 (+7d) | 2026-08-21 → 2026-08-28 (+7d) |  |  | 4d → 31573d |  | baseline start 2026-08-21 → 2026-08-28; baseline finish 2026-08-21 → 2026-08-28 |
| 2303 | Qualification Wave 4 Participants Qualification approved by BSC PAB and REC Manager | 2026-09-18 → 2026-09-24 (+6d) | 2026-09-18 → 2026-09-24 (+6d) |  |  | 4d → 31573d | 2302FS+20d → 2302FS+19d | baseline start 2026-09-18 → 2026-09-24; baseline finish 2026-09-18 → 2026-09-24 |
| 2305 | All suppliers must be able to access MPANs under the new TOM (M14) |  |  |  |  | 235d → 31808d | 2303FS+28d → 2303FS+24d |  |
| 2307 | **REGULATORY** |  |  |  | 93% → 99% | 521d → 32094d |  |  |

| ID | Task | Start | Finish | Duration | Complete | Total float | Predecessors | Other |
| --- | --- | --- | --- | --- | --- | --- | --- | --- |
| 2412 | **Ofgem preparation and enactment of SCR powers** |  | 2024-12-13 A |  | 71% → 100% | 789d → none |  |  |
| 2413 | **Preparation and enactment of SCR Powers** |  | 2024-12-11 A |  | 72% → 100% | 726d → none |  |  |
| 2421 | Each Code Body sends Modification Proposal Forms to Panel to approve Mod to go to consultation |  | 2024-09-16 A |  | 33% → 100% | 726d → none |  |  |
| 2422 | Modification Proposal approved by Panel for Consultation | 2024-09-17 A | 2024-09-17 A |  | 0% → 100% | 726d → none |  |  |
| 2423 | Draft Modification Report issued for consultation | 2024-09-18 A | 2024-09-18 A |  | 0% → 100% | 726d → none |  |  |
| 2424 | Consultation Close-out for representations | 2024-09-19 A | 2024-10-09 A |  | 0% → 100% | 726d → none |  |  |
| 2425 | Each Code Body reviews consultation response and drafts Modification Report | 2024-10-10 A | 2024-10-23 A |  | 0% → 100% | 726d → none |  |  |
| 2426 | Final Modification Report sent to Panel for decision with recommendation to approve | 2024-10-24 A | 2024-10-24 A |  | 0% → 100% | 726d → none |  |  |
| 2427 | Modification Panel decision | 2024-11-07 A | 2024-11-07 A |  | 0% → 100% | 726d → none |  |  |
| 2428 | Code Bodies Submit Final Modification/Change Reports | 2024-11-08 A | 2024-11-08 A |  | 0% → 100% | 726d → none |  |  |
| 2429 | Ofgem Reviews Final Modification/Change Reports | 2024-11-11 A | 2024-11-22 A |  | 0% → 100% | 726d → none |  |  |
| 2430 | Ofgem Drafts Decision/Direction Letters | 2024-11-18 A | 2024-12-10 A |  | 0% → 100% | 726d → none |  |  |
| 2431 | Ofgem Internally Signs Off the Decision/Direction Letters and Sends Them to the Code Bodies | 2024-12-11 A | 2024-12-11 A |  | 0% → 100% | 726d → none |  |  |
| 2432 | Ofgem decisions on M6 baselined code modification proposals (M7) | 2024-12-11 A | 2024-12-11 A |  | 0% → 100% | 726d → none |  |  |
| 2433 | Ofgem Publishes the Decisions/Directions | 2024-12-12 A | 2024-12-13 A |  | 0% → 100% | 789d → none |  |  |
| 2434 | **Deliver MHHS Code Changes** | 2024-11-12 A |  |  | 0% → 84% | 521d → 32094d |  |  |
| 2435 | **Releases** | 2024-11-12 A |  |  | 0% → 84% | 521d → 32094d |  |  |
| 2436 | Impacted codes make resourcing provisions and prepare to implement new Code via internal code body change processes | 2024-11-12 A |  |  | 0% → 90% | 735d → 32308d |  |  |
| 2446 | **MIGRATION** |  |  | 1246d → 1246d? | 35% → 36% | 98d → 31671d |  |  |
| 2451 | **Migration Framework Agreed and Implemented** |  | 2025-01-23 → 2025-05-07 (+104d) | 256d → 330d? | 62% → 52% | 121d → 32259d |  |  |
| 2466 | **Consultation 3 - Parameters** | 2024-07-09 A → 2024-11-18 A (+132d) | 2025-01-23 → 2025-02-25 (+33d) | 143d → 72d | 18% → 40% | 121d → 32222d |  | baseline start 2024-07-09 → 2024-11-18; baseline finish 2025-01-23 → 2025-02-25 |
| 2467 | Prepare Artefacts for Consultation | 2024-07-09 A → 2024-11-18 A (+132d) | 2024-11-18 → 2024-12-19 A (+31d) | 95d → 24d | 23% → 100% | 121d → none | 2485SS+6d → none | was named Prepare Artefacts (9) for Consultation; baseline start 2024-07-09 → 2024-11-18; baseline finish 2024-11-18 → 2024-12-19 |
| 2468 | Industry Consultation | 2024-11-19 → 2024-12-20 A (+31d) | 2024-12-02 → 2025-01-17 (+46d) | 10d → 21d | 0% → 5% | 121d → 32222d |  | baseline start 2024-11-19 → 2024-12-20; baseline finish 2024-12-02 → 2025-01-17 |
| 2469 | Triage Response | 2024-12-03 → 2025-01-20 (+48d) | 2024-12-16 → 2025-01-31 (+46d) |  |  | 121d → 32222d |  | was named Triage and Action Comments; baseline start 2024-12-03 → 2025-01-20; baseline finish 2024-12-16 → 2025-01-31 |
| 2470 | Industry Assurance Review | 2024-12-17 → 2025-02-03 (+48d) | 2024-12-25 → 2025-02-11 (+48d) |  |  | 121d → 32222d |  | baseline start 2024-12-17 → 2025-02-03; baseline finish 2024-12-25 → 2025-02-11 |
| 2471 | MWG Recommendation | 2025-01-06 → 2025-02-21 (+46d) | 2025-01-06 → 2025-02-21 (+46d) |  |  | 121d → 32222d |  | baseline start 2025-01-06 → 2025-02-21; baseline finish 2025-01-06 → 2025-02-21 |
| 2473 | MCAG Approval of Migration Framework Artefacts (Baselined) | 2025-01-23 → 2025-02-25 (+33d) | 2025-01-23 → 2025-02-25 (+33d) |  |  | 121d → 32222d | 2486, 2471FS+13d → 2486, 2471, 2472 | baseline start 2025-01-23 → 2025-02-25; baseline finish 2025-01-23 → 2025-02-25 |
| 2484 | **Migration Schedule Agreed and Maintained** |  | 2026-01-30 → 2025-07-18 (-196d) | 415d → 275d? | 14% → 44% | 494d → 32207d |  |  |
| 2486 | Supplier Submissions |  | 2024-10-02 A |  | 11% → 100% | 202d → none |  |  |
| 2487 | Team Assess Responses | 2024-10-03 A | 2024-10-16 A |  | 0% → 100% | 552d → none |  |  |
| 2488 | Discuss and Agree Approach with Participants where necessary | 2024-10-17 A | 2024-10-22 A |  | 0% → 100% | 552d → none |  |  |
| 2491 | V1.0 of Migration Schedule Baseline Approved at MCAG | 2025-01-10 → 2025-07-18 (+189d) | 2025-01-10 → 2025-07-18 (+189d) |  |  | 494d → 31932d | 2507, 2488 → 2490 | baseline start 2025-01-10 → 2025-07-18; baseline finish 2025-01-10 → 2025-07-18 |
| 2499 | Sprint Planning (Cycle 1) | 2025-06-16 → 2025-12-22 (+189d) | 2025-08-08 → 2026-02-13 (+189d) |  |  | 494d → 31932d |  |  |
| 2500 | Sprint Planning (Cycle 2) | 2025-09-15 → 2026-03-23 (+189d) | 2025-11-07 → 2026-05-15 (+189d) |  |  | 494d → 31932d |  |  |
| 2501 | Sprint Planning (Cycle 3) | 2025-12-08 → 2026-06-15 (+189d) | 2026-01-30 → 2026-08-07 (+189d) |  |  | 494d → 31932d |  |  |
| 2502 | **Migration Control Centre Tooling** |  |  |  | 30% → 66% | 112d → 32236d |  |  |
| 2503 | Data Source Definition |  | 2024-10-23 A |  | 46% → 100% | 112d → none |  |  |
| 2504 | Scheduling and Data Requirements |  | 2024-10-23 A |  | 46% → 100% | 112d → none |  |  |
| 2510 | **Migration Control Centre Mobilised and Ready** |  | 2025-04-14 → 2025-05-02 (+18d) | 185d → 199d |  | 112d → 32222d |  |  |
| 2515 | Dress Rehearsal | 2025-04-14 → 2025-05-02 (+18d) | 2025-04-14 → 2025-05-02 (+18d) |  |  | 112d → 32222d |  |  |
| 2516 | **PP's Prepared for Migration** |  | 2025-03-31 → 2025-05-01 (+31d) | 196d → 219d |  | 121d → 32222d |  |  |
| 2519 | Guides Creation | 2025-01-28 → 2025-02-28 (+31d) | 2025-03-31 → 2025-05-01 (+31d) |  |  | 121d → 32222d |  |  |
| 2520 | Support Channels | 2025-01-28 → 2025-02-28 (+31d) | 2025-03-31 → 2025-05-01 (+31d) |  |  | 121d → 32222d |  |  |
| 2521 | **Migration Artefact Development and Publication** |  | 2025-09-03 → 2025-10-15 (+42d) | 743d → 773d | 80% → 88% | 601d → 32144d |  |  |
| 2564 | **Data Cleanse Plan** |  | 2025-09-03 → 2025-10-15 (+42d) | 655d → 685d | 65% → 80% | 601d → 32144d |  |  |
| 2568 | Monitor Programme Participant adherence to Data Cleanse Plan |  |  |  | 64% → 76% | 714d → 32287d |  |  |
| 2569 | **MTDs** |  | 2025-01-31 → 2025-01-24 (-7d) | 120d → 115d | 45% → 95% | 754d → 32332d |  |  |
| 2570 | **ESME ID** |  |  |  | 0% → 94% | 784d → 32357d |  |  |
| 2572 | LDSO ‘full refresh’ between their Registration Service and the EES (ESME ID) | 2024-10-21 A | 2024-11-11 A |  | 0% → 100% | 784d → none |  |  |
| 2575 | **Meter Location and Number of Displayed Register Digits** |  | 2025-01-31 → 2025-01-24 (-7d) | 101d → 96d | 78% → 96% | 754d → 32332d |  |  |
| 2577 | LDSO ‘full refresh’ between their Registration Service and the EES (Meter Location and Number of Displayed Register Digits) | 2024-10-28 A → 2024-10-21 A (-7d) | 2024-11-18 → 2024-11-15 A (-3d) |  | 75% → 100% | 754d → none |  |  |
| 2578 | Suppliers complete investigation of exceptions and resolution of exceptions | 2025-01-31 → 2025-01-24 (-7d) | 2025-01-31 → 2025-01-24 (-7d) |  |  | 754d → 32332d | 2577FS+53d → 2577FS+49d |  |
| 2579 | Meter Location and Number of Displayed Register Digits Complete | 2025-01-31 → 2025-01-24 (-7d) | 2025-01-31 → 2025-01-24 (-7d) |  |  | 754d → 32332d |  |  |
| 2580 | **Registration Data** |  | 2025-09-03 → 2025-10-15 (+42d) | 259d → 289d | 5% → 81% | 601d → 32144d |  |  |
| 2581 | **Connection Type** |  | 2024-11-11 A |  | 6% → 100% | 813d → none |  |  |
| 2587 | Full MPAN refresh to ESS | 2024-10-21 A | 2024-11-11 A |  | 0% → 100% | 813d → none |  |  |
| 2588 | Connection Type Complete | 2024-11-11 A | 2024-11-11 A |  | 0% → 100% | 813d → none |  |  |
| 2589 | **Domestic Premises Indicator** | 2025-08-08 → 2025-09-19 (+42d) | 2025-09-03 → 2025-10-15 (+42d) |  |  | 601d → 32144d |  |  |
| 2590 | The DCC to extract Domestic Premises Indicator from the CSS and provide a file to each LDSO and EES. | 2025-08-08 → 2025-09-19 (+42d) | 2025-08-11 → 2025-09-22 (+42d) |  |  | 601d → 32144d | none → 1774FS-4d | baseline start 2025-08-08 → 2025-09-19; baseline finish 2025-08-11 → 2025-09-22 |
| 2591 | Each LDSO notifies the DCC of any exceptions | 2025-08-12 → 2025-09-23 (+42d) | 2025-08-12 → 2025-09-23 (+42d) |  |  | 601d → 32144d |  | baseline start 2025-08-12 → 2025-09-23; baseline finish 2025-08-12 → 2025-09-23 |
| 2592 | Each LDSO and DCC completes investigation and resolution of exceptions | 2025-09-03 → 2025-10-15 (+42d) | 2025-09-03 → 2025-10-15 (+42d) |  |  | 601d → 32144d |  | baseline start 2025-09-03 → 2025-10-15; baseline finish 2025-09-03 → 2025-10-15 |
| 2593 | Domestic Premises Indicator Complete | 2025-09-03 → 2025-10-15 (+42d) | 2025-09-03 → 2025-10-15 (+42d) |  |  | 601d → 32144d |  | baseline start 2025-09-03 → 2025-10-15; baseline finish 2025-09-03 → 2025-10-15 |
| 2594 | **Export / Import MPANs** |  | 2024-10-18 A |  | 99% → 100% | 829d → none |  |  |
| 2595 | **Linking of Export / Import MPANS** |  | 2024-10-18 A |  | 99% → 100% | 829d → none |  |  |
| 2599 | Each LDSO has linked al relevant import/export MPANS | 2024-10-18 A | 2024-10-18 A |  | 0% → 100% | 829d → none |  |  |
| 2600 | Linking of Export / Import MPANS Complete | 2024-10-18 A | 2024-10-18 A |  | 0% → 100% | 829d → none |  |  |
| 2624 | **Preparation for Cutover to Live** |  | 2025-10-22 → 2025-10-17 (-5d) | 344d → 341d |  | 566d → 32142d |  |  |
| 2627 | **Development of Comms Approach and Declaration Guidance** | 2025-03-03 → 2025-04-28 (+56d) | 2025-06-19 → 2025-08-14 (+56d) |  |  | 74d → 31607d |  |  |
| 2628 | Draft Cutover Comms Approach | 2025-03-03 → 2025-04-28 (+56d) | 2025-05-22 → 2025-07-17 (+56d) |  |  | 74d → 31607d |  | constraint start no earlier than 2025-03-03 → start no earlier than 2025-04-28; baseline start 2025-03-03 → 2025-04-28; baseline finish 2025-05-22 → 2025-07-17 |
| 2629 | Draft Cutover Comms Approach shared | 2025-05-22 → 2025-07-17 (+56d) | 2025-05-22 → 2025-07-17 (+56d) |  |  | 74d → 31607d |  | baseline start 2025-05-22 → 2025-07-17; baseline finish 2025-05-22 → 2025-07-17 |

| ID | Task | Start | Finish | Duration | Total float | Predecessors | Other |
| --- | --- | --- | --- | --- | --- | --- | --- |
| 2630 | Development of Implementation Group | 2025-03-03 → 2025-04-28 (+56d) | 2025-05-22 → 2025-07-17 (+56d) |  | 74d → 31607d |  | constraint start no earlier than 2025-03-03 → start no earlier than 2025-04-28; baseline start 2025-03-03 → 2025-04-28; baseline finish 2025-05-22 → 2025-07-17 |
| 2631 | Implementation Group Established | 2025-05-22 → 2025-07-17 (+56d) | 2025-05-22 → 2025-07-17 (+56d) |  | 74d → 31607d |  | baseline start 2025-05-22 → 2025-07-17; baseline finish 2025-05-22 → 2025-07-17 |
| 2632 | Finalised Cutover Comms Approach shared | 2025-06-19 → 2025-08-14 (+56d) | 2025-06-19 → 2025-08-14 (+56d) |  | 74d → 31607d |  | baseline start 2025-06-19 → 2025-08-14; baseline finish 2025-06-19 → 2025-08-14 |
| 2633 | **Development of Cutover Plan requirements with Participants** | 2025-03-03 → 2025-04-28 (+56d) | 2025-08-06 → 2025-09-04 (+29d) | 113d → 94d | 40d → 31592d |  |  |
| 2634 | Development of SIT Participant Cutover Plans | 2025-03-03 → 2025-04-28 (+56d) | 2025-05-22 → 2025-07-17 (+56d) |  | 40d → 31592d |  | constraint start no earlier than 2025-03-03 → start no earlier than 2025-04-28; baseline start 2025-03-03 → 2025-04-28; baseline finish 2025-05-22 → 2025-07-17 |
| 2635 | SIT Participant Cutover Plans Ready | 2025-05-22 → 2025-07-17 (+56d) | 2025-05-22 → 2025-07-17 (+56d) |  | 40d → 31592d |  | baseline start 2025-05-22 → 2025-07-17; baseline finish 2025-05-22 → 2025-07-17 |
| 2636 | Programme SIT Participant Cutover Plan Assurance | 2025-06-06 → 2025-07-18 (+42d) | 2025-08-06 → 2025-09-04 (+29d) | 44d → 35d | 40d → 31592d | 2635FS+10d → 2635 | baseline start 2025-06-06 → 2025-07-18; baseline finish 2025-08-06 → 2025-09-17 |
| 2637 | **M10/M11 Cutover Activities** | 2025-04-14 → 2025-09-05 (+144d) |  | 119d → 15d | 112d → 31585d |  |  |
| 2651 | MCC Tested and Ready to Operate | 2025-04-14 → 2025-09-19 (+158d) | 2025-04-14 → 2025-09-19 (+158d) |  | 112d → 32163d | 2515 → none | constraint none → start no earlier than 2025-09-19; baseline start 2025-04-14 → 2025-09-19; baseline finish 2025-04-14 → 2025-09-19 |
| 2652 | MCC Operational | 2025-04-14 → 2025-09-19 (+158d) | 2025-04-14 → 2025-09-19 (+158d) |  | 122d → 32163d |  | baseline start 2025-04-14 → 2025-09-19; baseline finish 2025-04-14 → 2025-09-19 |
| 2655 | **Cutover Governance M10** | 2025-07-30 → 2025-09-10 (+42d) |  | 41d → 11d | 39d → 31581d |  |  |
| 2656 | Confirmation that Pre-migration Data Cleanse Activities have successfully taken place | 2025-07-30 → 2025-09-10 (+42d) | 2025-07-30 → 2025-09-10 (+42d) |  | 41d → 31583d |  | constraint start no earlier than 2025-07-30 → start no earlier than 2025-09-10; baseline start 2025-07-30 → 2025-09-10; baseline finish 2025-07-30 → 2025-09-10 |
| 2657 | Confirmation of Helix E2E Settlement Testing Complete | 2025-08-01 → 2025-09-15 (+45d) | 2025-08-01 → 2025-09-15 (+45d) |  | 38d → 31580d | 1561FS+85d → none | constraint none → start no earlier than 2025-09-15; baseline start 2025-08-01 → 2025-09-15; baseline finish 2025-08-01 → 2025-09-15 |
| 2658 | Confirmation of assurance of Helix E2E Settlement Testing | 2025-08-01 → 2025-09-15 (+45d) | 2025-08-01 → 2025-09-15 (+45d) |  | 38d → 31580d | 1563FS+85d → none | constraint none → start no earlier than 2025-09-15; baseline start 2025-08-01 → 2025-09-15; baseline finish 2025-08-01 → 2025-09-15 |
| 2659 | Confirmation of Qualification Status for SIT MVC | 2025-09-12 → 2025-09-15 (+3d) | 2025-09-12 → 2025-09-15 (+3d) |  | 6d → 31580d | 1633FS+15d → none | constraint none → start no earlier than 2025-09-15; baseline start 2025-09-12 → 2025-09-15; baseline finish 2025-09-12 → 2025-09-15 |
| 2660 | Confirmation of Qualification Status for Non-SIT LDSOs |  |  |  | 594d → 31580d | 2665FS-5d → none | constraint none → start no earlier than 2025-09-15 |
| 2661 | Confirmation of Qualification Status of at least one Supplier and their contracted Agents | 2025-09-12 → 2025-09-15 (+3d) | 2025-09-12 → 2025-09-15 (+3d) |  | 6d → 31580d | 2659 → none | constraint none → start no earlier than 2025-09-15; baseline start 2025-09-12 → 2025-09-15; baseline finish 2025-09-12 → 2025-09-15 |
| 2662 | Declaration from all Central Services and LDSOs that they are in a position to move forwards |  |  |  | 594d → 31581d | 2665FS-5d, 1561, 1563 → none | constraint none → start no earlier than 2025-09-15 |
| 2663 | Market-wide Participant MHHS Migration Supporting Functionality is Live |  |  |  | 594d → 31581d | 2641 → none | constraint none → start no earlier than 2025-09-15 |
| 2664 | TORWG (Recommendation from TORWG that the Programme should enter M10) | 2025-09-16 → 2025-09-17 (+1d) | 2025-09-16 → 2025-09-17 (+1d) |  | 6d → 31578d | 2656, 2659FS+2d, 2661FS+2d, 2638, 2639, 2747, 2657, 2658 → 2656FS+1d, 2659FS+1d, 2661FS+1d, 2638FS+1d, 2639FS+1d, 2747FS+1d, 2657FS+1d, 2658FS+1d, 2660FS+1d, 2662, 2663 | baseline start 2025-09-16 → 2025-09-17; baseline finish 2025-09-16 → 2025-09-17 |
| 2672 | **Cutover Governance M11** |  | 2025-10-22 → 2025-10-17 (-5d) | 19d → 16d | 5d → 31581d |  |  |
| 2677 | MCAG (Provide recommendation to PSG on M11 decision) | 2025-10-17 → 2025-10-15 (-2d) | 2025-10-17 → 2025-10-15 (-2d) |  | 5d → 31581d | 2676FS+4d → 2676FS+2d | baseline start 2025-10-17 → 2025-10-15; baseline finish 2025-10-17 → 2025-10-15 |
| 2678 | PSG (OFGEM and PSG Decision to Confirm M11 and M12) | 2025-10-22 → 2025-10-17 (-5d) | 2025-10-22 → 2025-10-17 (-5d) |  | 5d → 31581d | 2677FS+3d → 2677FS+2d | baseline start 2025-10-22 → 2025-10-17; baseline finish 2025-10-22 → 2025-10-17 |
| 2679 | **UMS / Advanced Migration** |  | 2027-05-07 → 2027-05-06 (-1d) | 402d → 401d | 0d → 31574d |  |  |
| 2681 | SIT Non-MVC UMS / Advanced Migration | 2026-01-02 → 2025-12-29 (-4d) | 2027-04-02 → 2027-03-29 (-4d) |  | 25d → 31602d |  |  |
| 2683 | Wave 2 UMS / Advanced Migration | 2026-07-01 → 2026-07-02 (+1d) | 2027-04-29 → 2027-04-30 (+1d) |  | 6d → 31578d |  |  |
| 2684 | Wave 3 UMS / Advanced Migration | 2026-08-27 → 2026-08-14 (-13d) | 2027-05-07 → 2027-04-26 (-11d) |  | 0d → 31582d |  |  |
| 2685 | Wave 4 UMS / Advanced Migration | 2026-10-23 → 2026-10-29 (+6d) | 2027-04-30 → 2027-05-06 (+6d) |  | 5d → 31574d |  |  |
| 2686 | **Smart / Non-Smart Migration** |  | 2027-05-07 → 2027-05-06 (-1d) | 402d → 401d | 0d → 31574d |  |  |
| 2688 | SIT Non-MVC Smart / Non-Smart Migration | 2026-01-02 → 2025-12-29 (-4d) | 2027-04-02 → 2027-03-29 (-4d) |  | 25d → 31602d |  |  |
| 2690 | Wave 2 Smart / Non-Smart Migration | 2026-07-01 → 2026-07-02 (+1d) | 2027-04-29 → 2027-04-30 (+1d) |  | 6d → 31578d |  |  |
| 2691 | Wave 3 Smart / Non-Smart Migration | 2026-08-27 → 2026-08-14 (-13d) | 2027-05-07 → 2027-04-26 (-11d) |  | 0d → 31582d |  |  |
| 2692 | Wave 4 Smart / Non-Smart Migration | 2026-10-23 → 2026-10-29 (+6d) | 2027-04-30 → 2027-05-06 (+6d) |  | 4d → 31573d |  |  |
| 2730 | **Service Activation** |  | 2026-10-22 → 2026-10-28 (+6d) | 1039d? → 1043d? | 305d → 31874d |  |  |
| 2731 | **SIT MVC** | 2025-02-03 → 2022-10-31 (-826d) | 2025-09-22 → 2025-10-10 (+18d) | 166d? → 770d? | 163d → 32147d |  |  |
| 2743 | MHHSP Confirms SIT MVC PPs MHHS Enabled | 2025-04-15 → 2022-10-31 (-897d) | 2025-04-15 → 2022-10-31 (-897d) |  | 112d → 32326d | 2651 → none |  |
| 2745 | Add EFD to DIP |  |  |  | 5d → 31578d |  | was named Add EDF to DIP |
| 2754 | **SIT MVC Service Activation Implementation MDD** | 2025-03-06 → 2025-09-22 (+200d) | 2025-03-25 → 2025-10-10 (+199d) | 14d → 15d | 717d → 32147d |  |  |
| 2755 | MDD Manual Load | 2025-03-06 → 2025-09-22 (+200d) | 2025-03-14 → 2025-09-30 (+200d) |  | 724d → 32147d | none → 2750 |  |
| 2756 | MDD Update | 2025-03-14 → 2025-10-01 (+201d) | 2025-03-25 → 2025-10-10 (+199d) |  | 717d → 32147d | none → 2755 |  |
| 2757 | SIT MVC Service Activation Implementation MDD Complete | 2025-03-25 → 2025-10-10 (+199d) | 2025-03-25 → 2025-10-10 (+199d) |  | 717d → 32147d | none → 2756 |  |
| 2758 | **SIT MVC Service Activation Hypercare** | 2025-03-03 → 2025-09-12 (+193d) | 2025-03-26 → 2025-10-10 (+198d) | 18d → 21d | 716d → 32147d |  |  |
| 2759 | Service & Process Monitoring | 2025-03-03 → 2025-09-12 (+193d) | 2025-03-26 → 2025-10-07 (+195d) |  | 716d → 32150d | none → 2745SS |  |
| 2760 | Daily Reporting | 2025-03-03 → 2025-09-12 (+193d) | 2025-03-26 → 2025-10-07 (+195d) |  | 716d → 32150d | none → 2745SS |  |
| 2761 | Issue Management | 2025-03-03 → 2025-09-12 (+193d) | 2025-03-26 → 2025-10-07 (+195d) |  | 716d → 32150d | none → 2745SS |  |
| 2762 | SA Hypercare Close Down Activities | 2025-03-03 → 2025-09-12 (+193d) | 2025-03-26 → 2025-10-07 (+195d) |  | 716d → 32147d | none → 2745SS |  |
| 2763 | Handover to MHHSP | 2025-03-21 → 2025-10-08 (+201d) | 2025-03-25 → 2025-10-10 (+199d) |  | 717d → 32147d | none → 2762 |  |
| 2764 | SIT MVC Service Activation Hypercare Complete | 2025-03-25 → 2025-10-10 (+199d) | 2025-03-25 → 2025-10-10 (+199d) |  | 717d → 32147d | none → 2763 |  |
| 2765 | **SIT Non-MVC** |  | 2026-01-01 → 2026-01-19 (+18d) | 829d → 841d? | 515d → 32076d |  |  |
| 2766 | **SIT Non-MVC Service Activation Preparation Tasks** |  | 2022-10-31 → 2025-02-28 (+851d) | 1d → 610d | 845d → 32307d |  |  |
| 2767 | Helix Preparatory Activities Complete | 2022-10-31 → 2025-02-28 (+851d) | 2022-10-31 → 2025-02-28 (+851d) |  | 1344d → 32307d | none → 2742 |  |
| 2769 | **SIT Non-MVC Service Activation Implementation** | 2025-12-23 → 2025-12-19 (-4d) | 2026-01-01 → 2025-12-29 (-3d) | 8d → 7d? | 25d → 31602d |  |  |
| 2770 | Add EDF to DIP | 2025-12-23 → 2025-12-19 (-4d) | 2025-12-24 → 2025-12-19 (-5d) | 2d → 1d | 25d → 31602d |  |  |
| 2771 | DIP Promoted to Production | 2025-12-25 → 2025-12-22 (-3d) | 2025-12-26 → 2025-12-22 (-4d) | 2d → 1d | 25d → 31602d |  |  |
| 2773 | Create M16 in Customer Solution | 2025-12-29 → 2025-12-23 (-6d) | 2025-12-30 → 2025-12-24 (-6d) |  | 25d → 31602d |  |  |
| 2774 | Publish ISD | 2025-12-31 → 2025-12-25 (-6d) | 2026-01-01 → 2025-12-26 (-6d) |  | 25d → 31602d |  |  |
| 2776 | SIT Non-MVC Service Activation Implementation Complete | 2026-01-01 → 2025-12-26 (-6d) | 2026-01-01 → 2025-12-26 (-6d) |  | 25d → 31602d |  |  |
| 2777 | **SIT Non-MVC Service Activation Implementation MDD** | 2025-06-05 → 2025-12-29 (+207d) | 2025-06-24 → 2026-01-16 (+206d) | 14d → 15d | 652d → 32077d |  |  |
| 2778 | MDD Manual Load | 2025-06-05 → 2025-12-29 (+207d) | 2025-06-13 → 2026-01-06 (+207d) |  | 659d → 32077d | none → 2774 |  |
| 2779 | MDD Update | 2025-06-13 → 2026-01-07 (+208d) | 2025-06-24 → 2026-01-16 (+206d) |  | 652d → 32077d | none → 2778 |  |
| 2780 | SIT Non-MVC Service Activation Implementation MDD Complete | 2025-06-24 → 2026-01-16 (+206d) | 2025-06-24 → 2026-01-16 (+206d) |  | 652d → 32077d | none → 2779 |  |
| 2781 | **Non-SIT MVC Service Activation Hypercare** | 2025-06-02 → 2025-12-19 (+200d) | 2025-06-26 → 2026-01-19 (+207d) | 19d → 22d | 650d → 32076d |  |  |
| 2782 | Service& Process Monitoring | 2025-06-02 → 2025-12-19 (+200d) | 2025-06-25 → 2026-01-13 (+202d) |  | 651d → 32080d | none → 2770SS |  |
| 2783 | Daily Reporting | 2025-06-02 → 2025-12-19 (+200d) | 2025-06-25 → 2026-01-13 (+202d) |  | 651d → 32080d | none → 2770SS |  |
| 2784 | Issue Management | 2025-06-02 → 2025-12-19 (+200d) | 2025-06-25 → 2026-01-13 (+202d) |  | 651d → 32080d | none → 2770SS |  |
| 2785 | SA Hypercare Close Down Activities | 2025-06-02 → 2025-12-19 (+200d) | 2025-06-25 → 2026-01-13 (+202d) |  | 651d → 32076d | none → 2770SS |  |
| 2786 | Handover to MHHSP | 2025-06-23 → 2026-01-14 (+205d) | 2025-06-26 → 2026-01-19 (+207d) |  | 650d → 32076d | none → 2785 |  |
| 2787 | Non-SIT MVC Service Activation Hypercare Complete (M) | 2025-06-25 → 2026-01-19 (+208d) | 2025-06-25 → 2026-01-19 (+208d) |  | 651d → 32076d | none → 2786 |  |
| 2792 | Wave 1 Service Activation | 2026-04-13 → 2026-04-16 (+3d) |  | 24d → 21d | 5d → 31578d |  |  |
| 2793 | **Wave 1 - Service Activation Implementation** |  | 2025-09-05 → 2026-04-27 (+234d) | 5d → 171d | 599d → 32006d |  |  |

| ID | Task | Start | Finish | Duration | Total float | Predecessors | Other |
| --- | --- | --- | --- | --- | --- | --- | --- |
| 2794 | MHHSP Enabled Confirmation |  |  |  | 602d → 32175d | none → 2768 |  |
| 2795 | PAB Approval | 2025-09-01 → 2026-04-16 (+227d) | 2025-09-02 → 2026-04-17 (+227d) |  | 602d → 32012d | none → 2213 |  |
| 2796 | Add EFD to DIP | 2025-09-02 → 2026-04-16 (+226d) | 2025-09-03 → 2026-04-17 (+226d) |  | 601d → 31995d | none → 2213 | was named Add EDF to DIP |
| 2797 | DIP Promoted to Production | 2025-09-03 → 2026-04-20 (+229d) | 2025-09-04 → 2026-04-21 (+229d) |  | 600d → 31995d | none → 2796 |  |
| 2798 | Create M16 in Customer Solution | 2025-09-04 → 2026-04-22 (+230d) | 2025-09-05 → 2026-04-23 (+230d) |  | 599d → 31995d | none → 2797 |  |
| 2799 | Publish ISD | 2025-09-04 → 2026-04-24 (+232d) | 2025-09-05 → 2026-04-27 (+234d) |  | 599d → 31995d | none → 2798 |  |
| 2800 | Wave 1 - Service Activation Implementation Complete (M) | 2025-09-05 → 2026-04-27 (+234d) | 2025-09-05 → 2026-04-27 (+234d) |  | 599d → 32006d | none → 2799 |  |
| 2801 | **Wave 1 - Service Activation Implementation MDD** | 2025-09-04 → 2026-04-28 (+236d) | 2025-09-17 → 2026-05-12 (+237d) | 10d → 11d | 591d → 31995d |  |  |
| 2802 | MDD Manual Load | 2025-09-04 → 2026-04-28 (+236d) | 2025-09-10 → 2026-05-04 (+236d) |  | 596d → 31995d | none → 2799 |  |
| 2803 | MDD Update | 2025-09-10 → 2026-05-05 (+237d) | 2025-09-17 → 2026-05-12 (+237d) |  | 591d → 31995d | none → 2802 |  |
| 2804 | Wave 1 - Service Activation Implementation MDD Complete (M) | 2025-09-17 → 2026-05-12 (+237d) | 2025-09-17 → 2026-05-12 (+237d) |  | 591d → 31995d | none → 2803 |  |
| 2805 | **Wave 1 - Service Activation Hypercare** | 2022-10-31 → 2025-09-01 (+1036d) | 2025-09-18 → 2026-05-05 (+229d) | 754d → 177d | 590d → 32000d |  |  |
| 2806 | Service& Process Monitoring | 2025-09-01 → 2026-04-16 (+227d) | 2025-09-18 → 2026-05-05 (+229d) |  | 590d → 32000d | none → 2796SS |  |
| 2807 | Daily Reporting | 2025-09-01 → 2026-04-16 (+227d) | 2025-09-18 → 2026-05-05 (+229d) |  | 590d → 32000d | none → 2796SS |  |
| 2808 | Issue Management | 2025-09-01 → 2026-04-16 (+227d) | 2025-09-18 → 2026-05-05 (+229d) |  | 590d → 32000d | none → 2796SS |  |
| 2810 | Handover to MHHSP | 2025-09-15 → 2025-09-19 (+4d) | 2025-09-18 → 2025-09-24 (+6d) |  | 590d → 32159d | none → 2809 |  |
| 2811 | Non-SIT LDSO Service Activation Hypercare Complete (M) | 2022-10-31 → 2025-09-24 (+1059d) | 2022-10-31 → 2025-09-24 (+1059d) |  | 1344d → 32159d | none → 2810 |  |
| 2812 | **Wave 2** |  | 2026-06-30 → 2026-07-01 (+1d) | 957d → 958d | 387d → 31959d |  |  |
| 2813 | **SIT Non-MVC Service Activation Preparation Tasks** |  | 2026-06-30 → 2026-07-01 (+1d) | 957d → 958d | 387d → 31959d |  |  |
| 2816 | Wave 2 Service Activation | 2026-05-28 → 2026-05-29 (+1d) | 2026-06-30 → 2026-07-01 (+1d) |  | 6d → 31578d |  |  |
| 2817 | **Wave 2 - Service Activation Implementation** |  | 2025-11-07 → 2026-06-09 (+214d) | 5d → 157d | 554d → 31975d |  |  |
| 2819 | PAB Approval | 2025-11-03 → 2026-05-29 (+207d) | 2025-11-04 → 2026-06-01 (+209d) |  | 557d → 31981d | none → 2243 |  |
| 2820 | Add EFD to DIP | 2025-11-04 → 2026-05-29 (+206d) | 2025-11-05 → 2026-06-01 (+208d) |  | 556d → 31975d | none → 2243 | was named Add EDF to DIP |
| 2821 | DIP Promoted to Production | 2025-11-05 → 2026-06-02 (+209d) | 2025-11-06 → 2026-06-03 (+209d) |  | 555d → 31975d | none → 2820 |  |
| 2822 | Create M16 in Customer Solution | 2025-11-06 → 2026-06-04 (+210d) | 2025-11-07 → 2026-06-05 (+210d) |  | 554d → 31975d | none → 2821 |  |
| 2823 | Publish ISD | 2025-11-06 → 2026-06-08 (+214d) | 2025-11-07 → 2026-06-09 (+214d) |  | 554d → 31975d | none → 2822 |  |
| 2824 | Wave 2 - Service Activation Implementation Complete (M) | 2025-11-07 → 2026-06-09 (+214d) | 2025-11-07 → 2026-06-09 (+214d) |  | 554d → 31975d | none → 2823 |  |
| 2836 | **Wave 3** |  | 2026-08-26 → 2026-08-13 (-13d) | 998d → 989d | 346d → 31928d |  |  |
| 2837 | **SIT Non-MVC Service Activation Preparation Tasks** |  | 2026-08-26 → 2026-08-13 (-13d) | 998d → 989d | 346d → 31928d |  |  |
| 2840 | Wave 3 Service Activation | 2026-07-24 → 2026-07-31 (+7d) | 2026-08-26 → 2026-08-13 (-13d) | 24d → 10d | 0d → 31582d |  |  |
| 2841 | **Wave 3 - Service Activation Implementation** |  | 2025-12-30 → 2026-08-13 (+226d) | 7d → 169d | 517d → 31928d |  |  |
| 2843 | PAB Approval | 2025-12-22 → 2026-07-31 (+221d) | 2025-12-23 → 2026-08-03 (+223d) |  | 522d → 31928d | none → 2273 |  |
| 2844 | Add EFD to DIP | 2025-12-23 → 2026-08-04 (+224d) | 2025-12-24 → 2026-08-05 (+224d) |  | 521d → 31928d | none → 2273, 2843 | was named Add EDF to DIP |
| 2845 | DIP Promoted to Production | 2025-12-29 → 2026-08-06 (+220d) | 2025-12-30 → 2026-08-07 (+220d) |  | 517d → 31928d | none → 2844 |  |
| 2846 | Create M16 in Customer Solution | 2025-12-29 → 2026-08-10 (+224d) | 2025-12-30 → 2026-08-11 (+224d) |  | 517d → 31928d | none → 2845 |  |
| 2847 | Publish ISD | 2025-12-29 → 2026-08-12 (+226d) | 2025-12-30 → 2026-08-13 (+226d) |  | 517d → 31928d | none → 2846 |  |
| 2848 | Wave 3 - Service Activation Implementation Complete (M) | 2025-12-30 → 2026-08-13 (+226d) | 2025-12-30 → 2026-08-13 (+226d) |  | 517d → 31928d | none → 2847 |  |
| 2860 | **Wave 4** |  | 2026-10-22 → 2026-10-28 (+6d) | 1039d → 1043d | 305d → 31874d |  |  |
| 2861 | **SIT Non-MVC Service Activation Preparation Tasks** |  | 2026-10-22 → 2026-10-28 (+6d) | 1039d → 1043d | 305d → 31874d |  |  |
| 2864 | Wave 4 Service Activation | 2026-09-21 → 2026-09-25 (+4d) | 2026-10-22 → 2026-10-28 (+6d) |  | 4d → 31573d |  |  |
| 2865 | **Wave 4 - Service Activation Implementation** | 2025-03-03 → 2026-03-02 (+364d) | 2026-03-06 → 2026-10-07 (+215d) | 265d → 158d | 469d → 31889d |  |  |
| 2867 | PAB Approval | 2025-03-03 → 2026-09-25 (+571d) | 2025-03-03 → 2026-09-25 (+571d) |  | 733d → 31889d | none → 2303 |  |
| 2868 | Add EFD to DIP | 2026-03-03 → 2026-09-28 (+209d) | 2026-03-04 → 2026-09-29 (+209d) |  | 471d → 31889d | none → 2867 | was named Add EDF to DIP |
| 2869 | DIP Promoted to Production | 2026-03-04 → 2026-09-30 (+210d) | 2026-03-05 → 2026-10-01 (+210d) |  | 470d → 31889d | none → 2868 |  |
| 2870 | Create M16 in Customer Solution | 2026-03-05 → 2026-10-02 (+211d) | 2026-03-06 → 2026-10-05 (+213d) |  | 469d → 31889d | none → 2869 |  |
| 2871 | Publish ISD | 2026-03-05 → 2026-10-06 (+215d) | 2026-03-06 → 2026-10-07 (+215d) |  | 469d → 31889d | none → 2870 |  |
| 2872 | Wave 4 - Service Activation Implementation Complete (M) | 2026-03-06 → 2026-10-07 (+215d) | 2026-03-06 → 2026-10-07 (+215d) |  | 469d → 31889d | none → 2871 |  |
| 2884 | **Non-SIT LDSO** |  | 2025-09-01 → 2025-09-18 (+17d) | 741d → 754d | 603d → 32163d |  |  |
| 2895 | **SIT Non-MVC Service Activation Preparation Tasks** |  | 2025-09-01 → 2025-09-18 (+17d) | 741d → 754d | 603d → 32163d |  |  |
| 2898 | Non-SIT LDSO Service Activation | 2025-08-25 → 2025-09-11 (+17d) | 2025-09-01 → 2025-09-18 (+17d) |  | 22d → 31582d | BSC PAB & REC Manager approval of Qualification for Non-SIT LDSOs (Start of Migration for Qualification Participants), 2897 → 2897, 1992 |  |
| 2902 | Add EFD to DIP |  |  |  | 736d → 32309d |  | was named Add EDF to DIP |
| 2919 | **Implement Early Life Support Plan** | 2025-01-06 → 2025-07-07 (+182d) | 2025-03-07 → 2025-09-19 (+196d) | 45d → 55d | 729d → 32162d |  | baseline start 2025-01-06 → 2025-07-07; baseline finish 2025-03-07 → 2025-09-19 |
| 2920 | Implement Early Life Support Plan | 2025-01-06 → 2025-07-07 (+182d) | 2025-03-07 → 2025-09-19 (+196d) | 45d → 55d | 729d → 32162d | 2726 → none | constraint start no earlier than 2025-01-06 → start no earlier than 2025-07-07; baseline start 2025-01-06 → 2025-07-07; baseline finish 2025-03-07 → 2025-09-19 |

## Version 3 (data date 2025-04-22, saved 2025-04-23, file MHHS-DEL1139 - MHHS Plan v6.23.mpp)

Last finish 2148-12-31 → 2027-12-23 (-44203d). Complete tasks 1371 → 1756.

Added:

| ID | Task | Duration | Start | Finish | Predecessors | Constraint |
| --- | --- | --- | --- | --- | --- | --- |
| 158 | **Interim Release 8.8** | 26d | 2025-02-05 A | 2025-03-12 A |  |  |
| 159 | Update baselined artefacts | 4d | 2025-02-05 A | 2025-02-10 A |  | start no earlier than 2025-02-05 |
| 160 | Interim Release 8.8 Published | 1d | 2025-02-12 A | 2025-02-12 A | 159FS+1d |  |
| 161 | Interim Release 8.8 Deployed to SIT by Participants | 20d | 2025-02-13 A | 2025-03-12 A | 160 |  |
| 162 | **Interim Release 8.9** | 45d | 2025-02-05 A | 2025-04-08 A |  |  |
| 163 | Update baselined artefacts | 4d | 2025-02-05 A | 2025-02-10 A |  | start no earlier than 2025-02-05 |
| 164 | Interim Release 8.9 Published | 0d | 2025-03-11 A | 2025-03-11 A | 163FS+1d | finish no earlier than 2025-03-26 |
| 165 | Interim Release 8.9 Deployed to SIT by Participants | 20d | 2025-03-12 A | 2025-04-08 A | 164 |  |
| 166 | **Interim Release 8.10** | 56d | 2025-02-05 A | 2025-04-23 A |  |  |
| 167 | Update baselined artefacts | 4d | 2025-02-05 A | 2025-02-10 A |  | start no earlier than 2025-02-05 |
| 168 | Interim Release 8.10 Published | 1d | 2025-03-26 A | 2025-03-26 A | 167FS+1d | finish no earlier than 2025-03-26 |
| 169 | Interim Release 8.10 Deployed to SIT by Participants | 20d | 2025-03-27 A | 2025-04-23 A | 168 | finish no earlier than 2025-03-27 |
| 227 | Inform Orbus of iServer support termination | 1d? | 2025-07-03 A | 2025-07-03 A | 226 |  |
| 228 | Produce iServer decomissioning pack | 4d | 2025-07-04 A | 2025-07-09 A | 227 |  |
| 229 | Publish iServer decommising pack on the Clock | 1d? | 2025-07-31 | 2025-07-31 | 228FS+15d |  |
| 431 | **SIT Programme Participants PIT (SIT Operational Theme 3 (Batch 1))** | 76d | 2024-09-27 A | 2025-01-10 |  |  |
| 432 | **Test Approach & Plan** | 40d | 2024-09-27 A | 2024-11-21 A |  |  |
| 433 | SIT Operational PIT Test Approach& Plan (PIT) submitted to Programme for assurance | 0d | 2024-09-27 A | 2024-09-27 A |  | start no earlier than 2024-09-27 |
| 434 | SIT Operational Test approach and plan MHHS Review Completed | 0d | 2024-11-21 A | 2024-11-21 A | 433FS+40d |  |
| 435 | **Test Readiness Report** | 13d | 2024-10-04 | 2024-10-22 |  |  |
| 436 | Test readiness reporting | 13d | 2024-10-04 | 2024-10-22 | 433FS+5d |  |
| 437 | **Requirements to test Traceability Matrix (RTTM)** | 20d | 2024-11-01 A | 2024-11-29 A |  |  |
| 438 | SIT Operational PIT RTTM submitted to Programme for assurance | 0d | 2024-11-01 A | 2024-11-01 A | 433FS+26d |  |
| 439 | SIT Operational RTTM MHHS Review Completed | 0d | 2024-11-29 A | 2024-11-29 A | 438FS+20d |  |
| 440 | **Test Scenarios** | 20d | 2024-11-01 A | 2024-11-29 A |  |  |
| 441 | SIT Operational PIT test scenarios submitted to Programme for assurance | 0d | 2024-11-01 A | 2024-11-01 A | 433FS+26d |  |
| 442 | SIT Operational Test scenarios MHHS Review Completed | 0d | 2024-11-29 A | 2024-11-29 A | 441FS+20d |  |
| 443 | **PIT execution** | 58d | 2024-10-23 A | 2025-01-10 |  |  |
| 444 | PIT Test Execution Progress Report | 40d | 2024-10-23 | 2024-12-17 | 436 |  |
| 445 | PIT Execution | 39d | 2024-11-04 | 2024-12-26 | 441 |  |
| 446 | SIT Operational Theme 3 (Batch 1) PIT Completion Report submitted to Programme for assurance | 0d | 2025-01-10 A | 2025-01-10 A | 427, 428FS+30d |  |
| 447 | SIT Operational Theme 3 (Batch 1) PIT Completion Report MHHS Review Completed | 0d | 2025-01-10 A | 2025-01-10 A | 451, 456, 459, 463, 446 |  |
| 1066 | Update requirements / test case analysis doc | 29d | 2024-12-05 A | 2025-01-14 A | 1064 |  |
| 1135 | DIP Manager / Code Bodies / Full SRO acceptance of RTTM | 0d | 2024-11-19 A | 2024-11-19 A | 1134 |  |
| 1161 | NFTWG paper day | 0d | 2025-02-11 A | 2025-02-11 A | 1160FS+4d |  |
| 1162 | NFTWG update on execution model | 0d | 2025-02-18 A | 2025-02-18 A | 1161FS+5d |  |
| 1164 | Develop execution model Theme 2 & 3 | 3d | 2025-01-20 A | 2025-01-22 A |  | start no earlier than 2025-01-20 |
| 1168 | NFTWG paper day | 0d | 2025-03-11 A | 2025-03-11 A | 1167FS+24d |  |
| 1169 | NFTWG update on execution model | 0d | 2025-03-18 A | 2025-03-18 A | 1168FS+5d |  |
| 1180 | FTIG Recommendation | 0d | 2025-02-21 A | 2025-02-21 A | 1178FS+3d |  |
| 1189 | GLIG Recommendation | 0d | 2025-03-21 A | 2025-03-21 A | 1187FS+3d |  |
| 1190 | eSITAG paper day | 0d | 2025-03-26 A | 2025-03-26 A | 1188, 1189 | start no earlier than 2025-03-21 |
| 1317 | **Theme 3 Test Cases Approved** | 246d? | 2024-04-10 A | 2025-03-19 A |  |  |
| 1344 | **Theme 3 (Batch 2) Supplementary** | 33d | 2025-02-03 A | 2025-03-19 A |  |  |
| 1345 | Conclude DIP Onboarding / Offboarding Scope with DIP Manager | 5d | 2025-02-03 A | 2025-02-07 A |  | start no earlier than 2025-02-03 |
| 1346 | Develop DIP Onboarding / Offboarding Test Scenarios & Test Cases (Batch 2) Supplementary | 2d | 2025-02-10 A | 2025-02-11 A | 1345 |  |
| 1347 | SRO Review | 5d | 2025-02-12 A | 2025-02-18 A | 1346 |  |
| 1348 | Industry Consultation (Batch 2) Supplementary | 10d | 2025-02-19 A | 2025-03-04 A | 1347 |  |
| 1349 | SITWG Paper Day | 0d | 2025-02-27 A | 2025-02-27 A | 1348SS+7d, 1347FS+7d |  |
| 1350 | Review Feedback and Update | 1d | 2025-03-05 A | 2025-03-05 A | 1348 |  |
| 1351 | SITWG endorse Theme 3 (Batch 2) Supplementary | 0d | 2025-03-06 A | 2025-03-06 A | 1348, 1349, 1350FS+1d |  |
| 1353 | SITAG approve Theme 3 (Batch 2) Supplementary | 0d | 2025-03-19 A | 2025-03-19 A | 1352FS+5d |  |
| 1359 | SRO review of SIT Operational Theme 3 (Batch 1) RTTM | 5d | 2025-01-13 A | 2025-01-17 A | 1358 |  |
| 1360 | DIP Manager / Code Bodies / Full SRO to review | 5d | 2025-01-20 A | 2025-01-24 A | 1359 |  |
| 1361 | DIP Manager / Code Bodies / Full SRO acceptance of Theme 3 (Batch 1) Operational RTTM | 0d | 2025-01-24 A | 2025-01-24 A | 1360 |  |
| 1363 | **SIT Operational Programme RTTM (Theme 1, 2 & 3 (Batch 2))** | 80d | 2025-01-06 A | 2025-04-25 |  |  |
| 1364 | Develop SIT Operational (Theme 1, 2 & 3 (Batch 2)) RTTM | 36d | 2025-01-06 A | 2025-02-24 A |  | start no earlier than 2025-01-06 |
| 1365 | SRO review of SIT Operational (Theme 1, 2 & 3 (Batch 2)) RTTM | 9d | 2025-02-25 A | 2025-03-07 A | 1364 |  |
| 1366 | DIP Manager / Code Bodies / Full SRO to review | 34d | 2025-03-10 A | 2025-04-24 | 1365 |  |
| 1367 | Incorporate feedback | 34d | 2025-03-10 A | 2025-04-24 | 1366FF |  |
| 1368 | DIP Manager / Code Bodies / SRO acceptance of (Theme 1, 2 & 3 (Batch 2)) Operational RTTM | 0d | 2025-04-25 | 2025-04-25 | 1366FS+1d |  |
| 1369 | SIT Operational (Theme 1, 2 & 3 (Batch 2)) RTTM Complete | 0d | 2025-04-25 | 2025-04-25 | 1368 | start no earlier than 2025-03-28 |
| 1374 | Familiarisation session Service Management test case schedule + mapping | 0d | 2025-01-24 A | 2025-01-24 A | 1373 |  |
| 1376 | **SIT Operational Theme 1, 2 & 3 (Batch 2) DITL** | 23d | 2025-02-24 A | 2025-03-26 A |  |  |
| 1377 | DITL + Familiarisation session development | 15d | 2025-02-24 A | 2025-03-14 A |  | start no earlier than 2025-02-24 |
| 1378 | SRO Review | 5d | 2025-03-17 A | 2025-03-21 A | 1377 |  |
| 1379 | Post-SRO Review Changes | 3d | 2025-03-24 A | 2025-03-26 A | 1378 |  |
| 1380 | Familiarisation session Service Management test case schedule + mapping | 0d | 2025-03-26 A | 2025-03-26 A | 1379 |  |
| 1381 | Publish Cycle 3 DITL / Cycle 3 DITL Online Sessions for SIT PPs | 0d | 2025-03-26 A | 2025-03-26 A | 1380 |  |
| 1382 | **SIT Operational Defect Management** | 15d? | 2025-01-06 A | 2025-01-24 A |  |  |
| 1383 | Develop defect management approach | 10d? | 2025-01-06 A | 2025-01-17 A |  | start no earlier than 2025-01-06 |
| 1384 | Defect management approach agreed | 5d? | 2025-01-20 A | 2025-01-24 A | 1383 |  |
| 1398 | Execution Model shared with industry | 0d | 2025-03-17 A | 2025-03-17 A | 1397 |  |
| 1406 | SITWG Paper day | 0d | 2025-01-14 A | 2025-01-14 A | 1405 | finish no earlier than 2025-01-14 |
| 1407 | SITWG review the Operational Theme 3 (Batch 1) Overarching Test Readiness Report | 0d | 2025-01-21 A | 2025-01-21 A | 1406FS+5d | finish no earlier than 2025-01-21 |
| 1410 | FTIG recommendation | 0d | 2025-01-24 A | 2025-01-24 A | 1408FS+2d |  |
| 1411 | Republish Operational Theme 3 (Batch 1) Overarching Test Readiness Report with latest data and evidence | 1d? | 2025-01-27 A | 2025-01-27 A | 1409FS+2d |  |
| 1416 | SITWG Paper day | 0d | 2025-02-27 A | 2025-02-27 A |  | finish no earlier than 2025-02-27 |
| 1417 | SITWG review the Operational Theme 1, 2 and 3 (Batch 2) Overarching Test Readiness Report | 0d | 2025-03-06 A | 2025-03-06 A | 1416SS+5d |  |
| 1419 | GLIG recommendation | 0d | 2025-03-21 A | 2025-03-21 A | 1417FS+11d |  |
| 1420 | eSITAG paper day | 0d | 2025-03-26 A | 2025-03-26 A | 1418 | finish no earlier than 2025-03-26 |
| 1428 | Non-Functional Themes 2 & 3 (LDSO's) Data Load | 15d | 2025-03-03 A | 2025-03-21 A | 1154 |  |
| 1429 | Operational Themes 1, 2 & 3 (Batch 2) (LDSO's) Data Load | 20d? | 2025-03-03 A | 2025-03-28 A | 1154 | start no earlier than 2025-01-06 |
| 1446 | Build Regression Core Pack | 17d | 2025-02-12 A | 2025-03-06 A | 1439, 1449FF | start no earlier than 2025-02-12 |
| 1449 | SITWG provides feedback on Regression Framework approach | 0d | 2025-03-06 A | 2025-03-06 A | 1448FS+5d |  |
| 1454 | Regression Test Framework Core Pack - PP Walkthrough | 1d? | 2025-03-20 A | 2025-03-20 A | 1453SS | start no earlier than 2025-03-20 |
| 1455 | Regression Test Framework Core Pack - Q&A Drop in session | 1d? | 2025-03-27 A | 2025-03-27 A | 1453SS | start no earlier than 2025-03-27 |
| 1457 | Second industry review of Regression Core Pack | 5d | 2025-04-03 A | 2025-04-09 A | 1456 |  |
| 1460 | SITWG endorses regression Core Pack | 0d | 2025-04-15 A | 2025-04-15 A | 1459FS+3d | finish no earlier than 2025-04-15 |
| 1461 | Incorporate SITWG feedback into regression Core Pack | 2d | 2025-04-16 A | 2025-04-17 A | 1460 | start no earlier than 2025-04-16 |
| 1462 | Regression Test Approach and Plan Uplift | 0d | 2025-04-16 A | 2025-04-16 A | 1460 | start no earlier than 2025-04-16 |
| 1463 | Industry Review on the Uplifted Test Approach and Plan | 5d | 2025-04-17 A | 2025-04-23 A | 1462 | finish no earlier than 2025-04-23 |
| 1565 | **SIT Scope Traceability** | 64d | 2025-01-27 A | 2025-04-24 |  |  |
| 1566 | Draft Scope Tracability document | 10d | 2025-01-27 A | 2025-02-07 A |  | start no earlier than 2025-01-27 |
| 1567 | LDP review | 2d | 2025-02-10 A | 2025-02-11 A | 1566 |  |
| 1568 | SRO review | 5d | 2025-02-12 A | 2025-02-18 A | 1567 |  |
| 1569 | Updates to reflect SRO feedback | 5d | 2025-02-12 A | 2025-02-18 A | 1568FF |  |
| 1570 | Industry Review | 10d | 2025-02-19 A | 2025-03-04 A | 1569 |  |
| 1572 | SITWG recommends Scope Tracability document | 0d | 2025-04-15 A | 2025-04-15 A | 1571FS+5d |  |
| 1573 | Update document to reflect industry consultation views | 8d | 2025-03-05 A | 2025-03-14 A | 1570 |  |
| 1575 | SITAG approve SIT Scope Traceability document | 0d | 2025-04-24 | 2025-04-24 | 1574FS+5d |  |
| 1576 | SIT Scope Traceability Approved | 0d | 2025-04-24 | 2025-04-24 | 1575 |  |
| 1597 | SIT-A Settlement Testing Start | 0d | 2025-05-19 | 2025-05-19 | 1470FS+1d |  |
| 1598 | SIT-A Settlement Testing | 20d | 2025-05-20 | 2025-06-16 | 1597 |  |
| 1599 | SIT-A Settlement Decision Point Exit Criteria | 0d | 2025-06-13 | 2025-06-13 | 1598FS-2d |  |
| 1600 | SIT-A Settlement Testing Completed | 0d | 2025-06-13 | 2025-06-13 | 1599 |  |
| 1603 | Regression Execution | 5d | 2025-06-16 | 2025-06-20 | 1602FS-1d |  |
| 1607 | Regression Contingency Week | 5d | 2025-08-04 | 2025-08-08 | 1606 |  |
| 1615 | **Test design** | 125d | 2024-09-02 A | 2025-02-21 A |  |  |
| 1616 | SAT tests (Review and finalise) | 95d | 2024-09-02 A | 2025-01-10 A |  | start no earlier than 2024-09-02 |
| 1617 | Test Automation and Supporting Tools | 80d | 2024-11-04 A | 2025-02-21 A |  | start no earlier than 2024-11-04 |
| 1618 | SAT tests batch 3 | 50d | 2024-12-16 A | 2025-02-21 A |  | start no earlier than 2024-12-16 |
| 1619 | **Data and environment** | 120d? | 2024-08-19 A | 2025-01-31 A |  |  |
| 1620 | Data and environment requirements | 55d | 2024-08-19 A | 2024-11-01 A |  | start no earlier than 2024-08-19 |
| 1621 | Data sourcing | 95d | 2024-09-02 A | 2025-01-10 A |  | start no earlier than 2024-09-02 |
| 1622 | Environment data check | 15d? | 2025-01-13 A | 2025-01-31 A | 1621 |  |
| 1623 | **Execution** | 169d | 2024-11-11 A | 2025-07-03 |  |  |
| 1624 | Trial test runs | 50d | 2024-11-11 A | 2025-01-17 A |  | start no earlier than 2024-11-11 |
| 1625 | Test planning prioritisation | 14d | 2025-01-20 A | 2025-02-06 A | 1624 |  |
| 1626 | Programme agreement to start SAT testing | 0d | 2025-02-06 A | 2025-02-06 A | 1625 |  |
| 1627 | SAT Testing Start | 0d | 2025-02-06 A | 2025-02-06 A | 1626 |  |
| 1628 | SAT first run | 39d | 2025-02-07 A | 2025-04-02 | 1627 |  |
| 1629 | First run complete | 0d | 2025-04-02 | 2025-04-02 | 1628 |  |
| 1630 | SAT test second run | 30d | 2025-04-03 | 2025-05-14 | 1629 |  |
| 1631 | Second run complete | 0d | 2025-05-14 | 2025-05-14 | 1630 |  |
| 1632 | **Contingency test time** | 48d | 2025-04-07 | 2025-06-11 |  |  |
| 1633 | Demand Disconnection Event (DDE) | 20d | 2025-05-15 | 2025-06-11 | 1631 |  |
| 1634 | Trading Disputes | 20d | 2025-05-15 | 2025-06-11 | 1631 |  |
| 1635 | **NESO** | 48d | 2025-04-07 | 2025-06-11 |  |  |
| 1636 | P210 Test files to NESO | 0d | 2025-04-07 | 2025-04-07 |  | start no earlier than 2025-04-07 |
| 1637 | NESO | 20d | 2025-05-15 | 2025-06-11 | 1631 |  |
| 1638 | Estimated all SAT tests completed | 0d | 2025-06-11 | 2025-06-11 | 1633, 1634, 1637 |  |
| 1639 | Test Completion Report Drafting | 11d | 2025-06-12 | 2025-06-26 | 1638 |  |
| 1640 | Test Completion Report/Recommendation | 0d | 2025-06-26 | 2025-06-26 | 1639 |  |
| 1641 | SAT is signed off by the SAA Value Stream Lead / Head of Product (SAT complete) | 0d | 2025-07-03 | 2025-07-03 | 1640FS+5d |  |
| 1642 | **MHHS Programme Assurance of Helix E2E SAT** | 219d | 2024-09-02 A | 2025-07-03 |  |  |
| 1643 | MHHS Programme Assurance Start | 0d | 2024-09-02 A | 2024-09-02 A | 1616SS |  |
| 1644 | Ongoing MHHS Programme Assurance | 219d | 2024-09-02 | 2025-07-03 | 1643 |  |
| 1645 | MHHS Programme Assurance End | 0d | 2025-07-03 | 2025-07-03 | 1644, 1641 |  |
| 1674 | Regression Test Execution Start | 0d | 2025-06-16 | 2025-06-16 | 1600FS+2d |  |
| 1675 | Regression Execution | 5d | 2025-06-16 | 2025-06-20 | 1674FS-1d |  |
| 1679 | Regression Contingency Week | 5d | 2025-08-04 | 2025-08-08 | 1678 |  |
| 1754 | Discussion at QWG to reconfirm value provided from E2E Sandbox (UIT) | 0d | 2025-03-11 A | 2025-03-11 A |  | finish no earlier than 2025-03-11 |
| 1755 | Create PPIR to request PP responses on subject to gather views | 5d | 2025-03-10 A | 2025-03-14 A |  | finish no earlier than 2025-03-14 |
| 1756 | PPIR shared to industry | 9d | 2025-03-24 A | 2025-04-03 A | 1755 | start no earlier than 2025-03-24 |
| 1757 | Evaluate PPIR responses | 2d | 2025-04-04 A | 2025-04-07 A |  | start no earlier than 2025-04-04 |
| 1758 | Discuss PPIR results at QWG | 1d | 2025-04-08 A | 2025-04-08 A | 1757SF-5d | finish no earlier than 2025-04-08 |
| 1830 | SIT PPs E2E Sandbox Testing End | 0d | 2025-10-24 | 2025-10-24 | 1829 |  |
| 1833 | **M10 Readiness** | 50d? | 2025-01-06 A | 2025-03-14 A |  |  |
| 1834 | Define guiding principles and approach | 15d? | 2025-01-06 A | 2025-01-24 A |  | start no earlier than 2025-01-06 |
| 1835 | Engage IPA | 10d | 2025-01-13 A | 2025-01-24 A |  | start no earlier than 2025-01-13 |
| 1836 | Mobilise Get to Go-Live Group | 10d | 2025-01-27 A | 2025-02-07 A | 1834, 1835 |  |
| 1837 | Progress against the M10 Readiness Criteria | 25d? | 2025-02-10 A | 2025-03-14 A | 1836 |  |
| 1838 | **Downstream milestone feasibility assessment** | 50d? | 2025-01-06 A | 2025-03-14 A |  |  |
| 1839 | Define guiding principles and approach to addressing points 1 - 3 | 20d? | 2025-01-06 A | 2025-01-31 A |  | start no earlier than 2025-01-06 |
| 1840 | Assess capacity within migration envelopes (Point 1 - Bringing M15 forwards) | 20d | 2025-01-20 A | 2025-02-14 A | 1839FF | start no earlier than 2025-01-20 |
| 1841 | Review M16 process (Point 3 - Bringing M16 forwards) | 25d? | 2025-01-20 A | 2025-02-21 A | 1839FF | start no earlier than 2025-01-20 |
| 1842 | Develop M16 process review findings | 10d | 2025-02-24 A | 2025-03-07 A | 1841 |  |
| 1843 | Agree M16 process review findings with Code Bodies | 5d | 2025-03-10 A | 2025-03-14 A | 1842 |  |
| 1844 | Agree M16 process review findings with PAB | 5d | 2025-03-10 A | 2025-03-14 A | 1842 |  |
| 1845 | Run PPIR with impacted parties (Point 2 - Bringing M14 forwards) | 10d | 2025-03-03 A | 2025-03-14 A | 1840FS+10d |  |
| 1846 | **Checkpoint governance** | 21d | 2025-03-05 A | 2025-04-02 A |  |  |
| 1847 | PSG Updated on progress | 0d | 2025-03-05 A | 2025-03-05 A | 1837SS | start no earlier than 2025-03-05 |
| 1848 | Review final M10 Readiness outputs with IPA | 5d | 2025-03-17 A | 2025-03-21 A | 1843, 1844, 1845, 1837 |  |
| 1849 | Review final M10 Readiness outputs with Ofgem | 8d | 2025-03-17 A | 2025-03-26 A | 1843, 1844, 1845, 1837, 1848SS |  |
| 1850 | QAG paper day | 0d | 2025-03-13 A | 2025-03-13 A | 1837SS | start no earlier than 2025-03-13 |
| 1851 | QAG recommend M10 Checkpoint | 0d | 2025-03-20 A | 2025-03-20 A | 1850FS+6d |  |
| 1852 | MCAG paper day | 0d | 2025-03-24 A | 2025-03-24 A | 1837FS+6d |  |
| 1853 | MCAG recommend M10 Checkpoint | 0d | 2025-04-01 A | 2025-04-01 A | 1852FS+6d |  |
| 1854 | PSG paper day | 0d | 2025-03-26 A | 2025-03-26 A | 1849 |  |
| 1855 | PSG M10 Checkpoint Meeting | 0d | 2025-04-02 A | 2025-04-02 A | 1854FS+5d, 1853, 1851, 1848, 1849 |  |
| 1856 | M10 Checkpoint 1 complete | 0d | 2025-04-02 A | 2025-04-02 A | 1891FS-126d, 1855 |  |
| 1857 | M10 Checkpoint 2 Complete | 0d | 2025-07-02 | 2025-07-02 |  | finish no earlier than 2025-07-02 |
| 1858 | **M10 Acceptance Criteria** | 358d | 2024-05-28 A | 2025-10-10 |  |  |
| 1859 | End of SIT MVC testing | 0d | 2025-08-22 | 2025-08-22 | 1716 | finish no earlier than 2025-08-22 |
| 1860 | IPA M10 Assurance Report developed and agreed | 0d | 2025-09-19 | 2025-09-19 |  | finish no earlier than 2025-09-19 |
| 1861 | Non-SIT LDSO Qualification Testing complete | 0d | 2025-05-16 | 2025-05-16 | 2010 | finish no earlier than 2025-05-16 |
| 1862 | A minimum of 1 supplier & required contracted agents are qualified and ready to operate under new MHHS arrangements | 0d | 2025-09-12 | 2025-09-12 |  | finish no earlier than 2025-09-12 |
| 1863 | All LDSOs qualified | 0d | 2025-09-10 | 2025-09-10 |  | finish no earlier than 2025-09-10 |
| 1864 | All pre-migration data cleanse activities complete | 0d | 2025-08-13 | 2025-08-13 |  | finish no earlier than 2025-08-13 |
| 1865 | All data migration activities set out in the cutover plan complete | 0d | 2025-09-24 | 2025-09-24 |  | finish no earlier than 2025-09-24 |
| 1866 | ISD fully populated by Elexon | 0d | 2025-09-22 | 2025-09-22 |  | finish no earlier than 2025-09-22 |
| 1867 | Significant Code Review Powers (SCR) enacted by Ofgem (M7) and updates to regulatory code ready to be implemented at M8 | 0d | 2024-12-11 A | 2024-12-11 A | 2561 | finish no earlier than 2024-12-11 |
| 1868 | Migration Schedule approved | 0d | 2025-08-19 | 2025-08-19 |  | finish no earlier than 2025-08-19 |
| 1869 | Migration Framework approved | 0d | 2025-04-30 | 2025-04-30 |  | finish no earlier than 2025-04-30 |
| 1870 | Migration Control Centre (MCC) delegation of authority approved | 0d | 2025-04-30 | 2025-04-30 |  | finish no earlier than 2025-04-30 |
| 1871 | Migration incentives implemented | 0d | 2025-04-30 | 2025-04-30 |  | finish no earlier than 2025-04-30 |
| 1872 | MCC tested and ready to operate | 0d | 2025-09-19 | 2025-09-19 |  | finish no earlier than 2025-09-19 |
| 1873 | Service Delivery Operating Model in place | 0d | 2025-09-19 | 2025-09-19 |  | finish no earlier than 2025-09-19 |
| 1874 | Service Delivery Operating Model in place (Self-Certification) | 0d | 2025-07-03 | 2025-07-03 |  | finish no earlier than 2025-07-03 |
| 1875 | Early Life Support Model defined | 0d | 2025-04-29 | 2025-04-29 | 2983 | finish no earlier than 2025-03-31 |
| 1876 | Early Life Support Model arrangements in place and operational | 0d | 2025-09-12 | 2025-09-12 |  | finish no earlier than 2025-09-12 |
| 1877 | Early Life Support Model arrangements in place and operational (Self-Certification) | 0d | 2025-09-12 | 2025-09-12 |  | finish no earlier than 2025-09-12 |
| 1878 | M10/M11 Cutover Plan in place | 0d | 2024-05-28 | 2024-05-28 |  | finish no earlier than 2024-05-28 |
| 1879 | Central Programme Party Cutover Plans in place | 0d | 2025-07-15 | 2025-07-15 |  | finish no earlier than 2025-07-15 |
| 1880 | Production environment in place for LDSOs and Central Parties | 0d | 2025-09-22 | 2025-09-22 |  | finish no earlier than 2025-09-22 |
| 1881 | Service activation complete to DIP Production environment for Central Parties and LDSOs | 0d | 2025-10-10 | 2025-10-10 |  | finish no earlier than 2025-10-10 |
| 1882 | Cutover Plan executed | 0d | 2025-09-23 | 2025-09-23 |  | finish no earlier than 2025-09-23 |
| 1883 | M10 Risk Assessment undertaken | 0d | 2025-09-03 | 2025-09-03 |  | finish no earlier than 2025-09-03 |
| 1884 | Roles and responsibilities post-M10 agreed and accepted | 0d | 2025-09-19 | 2025-09-19 |  | finish no earlier than 2025-09-19 |
| 1885 | M10 Work off plan agreed (if required) | 0d | 2025-09-19 | 2025-09-19 |  | finish no earlier than 2025-09-19 |
| 1886 | Qualification Operating Model in place and operational for all post-M10 activities | 0d | 2025-09-19 | 2025-09-19 |  | finish no earlier than 2025-09-19 |
| 1887 | Programme Governance updated to reflect required changes to support Programme delivery post-M10. | 0d | 2025-07-01 | 2025-07-01 |  | finish no earlier than 2025-07-01 |
| 1888 | All Suppliers and Agents have made the necessary changes to support losing an MPAN via the Forward Migration Process and gaining an MPAN via the Reverse Migration Process. | 0d | 2025-09-19 | 2025-09-19 |  | finish no earlier than 2025-09-19 |
| 1889 | Performance Assurance measures are understood and in place to maintain BAU performance during the Migration period. | 0d | 2025-09-12 | 2025-09-12 |  | finish no earlier than 2025-09-12 |
| 1890 | Programme monitoring, assurance and escalation process for beyond M10 is in place and operational | 0d | 2025-09-12 | 2025-09-12 |  | finish no earlier than 2025-09-12 |
| 2017 | Non-SIT LDSO Regression Testing | 26d | 2025-05-16 | 2025-06-20 | 2014 |  |
| 2414 | **PAB dates** | 235d | 2025-01-23 A | 2025-12-18 |  |  |
| 2415 | PAB288 | 0d | 2025-01-23 A | 2025-01-23 A |  | start no earlier than 2025-01-23 |
| 2416 | PAB289 | 2d | 2025-02-26 A | 2025-02-27 A |  | start no earlier than 2025-02-26 |
| 2417 | PAB290 | 0d | 2025-03-12 A | 2025-03-12 A |  | start no earlier than 2025-03-12 |
| 2418 | PAB291 | 0d | 2025-03-27 A | 2025-03-27 A |  | start no earlier than 2025-03-27 |
| 2419 | PAB292 | 0d | 2025-04-09 A | 2025-04-09 A |  | start no earlier than 2025-04-09 |
| 2420 | PAB293 | 0d | 2025-04-24 | 2025-04-24 |  | start no earlier than 2025-04-24 |
| 2421 | PAB294 | 0d | 2025-05-14 | 2025-05-14 |  | start no earlier than 2025-05-14 |
| 2422 | PAB295 | 0d | 2025-05-29 | 2025-05-29 |  | start no earlier than 2025-05-29 |
| 2423 | PAB296 | 0d | 2025-06-11 | 2025-06-11 |  | start no earlier than 2025-06-11 |
| 2424 | PAB297 | 0d | 2025-06-26 | 2025-06-26 |  | start no earlier than 2025-06-26 |
| 2425 | PAB298 | 0d | 2025-07-16 | 2025-07-16 |  | start no earlier than 2025-07-16 |
| 2426 | PAB299 | 0d | 2025-07-31 | 2025-07-31 |  | start no earlier than 2025-07-31 |
| 2427 | PAB300 | 0d | 2025-08-13 | 2025-08-13 |  | start no earlier than 2025-08-13 |
| 2428 | PAB301 | 0d | 2025-08-28 | 2025-08-28 |  | start no earlier than 2025-08-28 |
| 2429 | PAB302 | 0d | 2025-09-10 | 2025-09-10 |  | start no earlier than 2025-09-10 |
| 2430 | PAB303 | 0d | 2025-09-25 | 2025-09-25 |  | start no earlier than 2025-09-25 |
| 2431 | PAB304 | 0d | 2025-10-15 | 2025-10-15 |  | start no earlier than 2025-10-15 |
| 2432 | PAB305 | 0d | 2025-10-30 | 2025-10-30 |  | start no earlier than 2025-10-30 |
| 2433 | PAB306 | 0d | 2025-11-12 | 2025-11-12 |  | start no earlier than 2025-11-12 |
| 2434 | PAB307 | 0d | 2025-11-27 | 2025-11-27 |  | start no earlier than 2025-11-27 |
| 2435 | PAB308 | 0d | 2025-12-18 | 2025-12-18 |  | start no earlier than 2025-12-18 |
| 2566 | **M8 Code Change Preperation** | 155d | 2025-01-31 A | 2025-09-05 |  |  |
| 2567 | Resources confirmed | 0d | 2025-01-31 A | 2025-01-31 A |  | finish no earlier than 2025-01-31 |
| 2568 | CDWG Endorsement | 0d | 2025-06-10 | 2025-06-10 |  | finish no earlier than 2025-06-10 |
| 2569 | CCAG Endorsement | 0d | 2025-06-25 | 2025-06-25 |  | finish no earlier than 2025-06-25 |
| 2570 | Send to Ofgem for SCR Direction | 0d | 2025-06-25 | 2025-06-25 |  | finish no earlier than 2025-06-25 |
| 2571 | Freeze M8 Change Control Log 1.0 and create V2.0 | 0d | 2025-07-02 | 2025-07-02 |  | finish no earlier than 2025-07-02 |
| 2572 | Agree Fast Track Code Change Process | 0d | 2025-07-02 | 2025-07-02 |  | finish no earlier than 2025-07-02 |
| 2573 | Ofgem direct SCR Code change | 0d | 2025-07-03 | 2025-07-03 |  | finish no earlier than 2025-07-03 |
| 2574 | Present to Panel | 0d | 2025-07-10 | 2025-07-10 |  | finish no earlier than 2025-07-10 |
| 2575 | Code Change Industry Consultation | 0d | 2025-07-29 | 2025-07-29 |  | finish no earlier than 2025-07-29 |
| 2576 | Panel Recommendation | 0d | 2025-08-14 | 2025-08-14 |  | finish no earlier than 2025-08-14 |
| 2577 | Ofgem Decision | 0d | 2025-09-05 | 2025-09-05 |  | finish no earlier than 2025-09-05 |
| 2610 | MWG paper day | 0d | 2025-02-06 A | 2025-02-06 A | 2609 | start no earlier than 2025-02-06 |
| 2616 | Book MWG | 0d | 2025-02-07 A | 2025-02-07 A | 2615 |  |
| 2617 | Prepare Consultation 4 content | 9d | 2025-02-10 A | 2025-02-20 A | 2616 |  |
| 2618 | MWG paper day | 0d | 2025-02-20 A | 2025-02-20 A | 2617 |  |
| 2619 | MWG recommend Consultation 4 content go for industry consultation | 0d | 2025-03-04 A | 2025-03-04 A | 2618FS+8d |  |
| 2622 | Respond to comments and issue artefacts | 10d? | 2025-03-31 A | 2025-04-11 A | 2621 | finish no earlier than 2025-04-11 |
| 2624 | MCAG paper day | 0d | 2025-04-22 A | 2025-04-22 A | 2623 | finish no earlier than 2025-04-22 |
| 2629 | Schedule Production Complete | 0d | 2024-12-20 A | 2024-12-20 A | 2628 |  |
| 2630 | **V1.0 of Migration Schedule Baseline** | 81d | 2025-04-01 A | 2025-07-22 |  |  |
| 2631 | Confirm Supplier Migration start dates, MPID groups (SIT & NonSIT) | 0d | 2025-04-01 A | 2025-04-01 A |  | start no earlier than 2025-04-01 |
| 2633 | **Supplier Commission 2** | 102d? | 2025-03-03 A | 2025-07-22 |  |  |
| 2634 | Confirm / validate contacts for all Suppliers | 22d | 2025-03-03 A | 2025-04-01 A |  | start no earlier than 2025-03-03 |
| 2635 | Supplier submission issued | 0d | 2025-04-25 | 2025-04-25 | 2634FS+18d | start no earlier than 2025-04-25 |
| 2636 | Supplier submission deadline | 0d | 2025-06-20 | 2025-06-20 | 2635FS+40d |  |
| 2637 | Second Supplier Submission complete | 0d | 2025-06-20 | 2025-06-20 | 2636 |  |
| 2638 | Publish and baseline Migration Schedule | 1d? | 2025-07-22 | 2025-07-22 | 2637FS+21d |  |
| 2639 | **Supplier Submission Support** | 29d? | 2025-04-25 | 2025-06-04 |  |  |
| 2640 | Support guides issued | 1d? | 2025-04-25 | 2025-04-25 |  | start no earlier than 2025-04-25 |
| 2641 | Envelope webinar | 0d | 2025-05-02 | 2025-05-02 | 2640FS+5d |  |
| 2642 | De-minimus webinar | 0d | 2025-05-02 | 2025-05-02 | 2641 |  |
| 2643 | Drop-in session 1 | 0d | 2025-05-14 | 2025-05-14 | 2642FS+8d |  |
| 2644 | Drop-in session 2 | 0d | 2025-05-28 | 2025-05-28 | 2643FS+10d |  |
| 2645 | Drop-in session 3 | 0d | 2025-06-04 | 2025-06-04 | 2644FS+5d |  |
| 2646 | Q+A documents from sessions published | 0d | 2025-06-04 | 2025-06-04 | 2645 |  |
| 2650 | **MCC Dress Rehersal 1 - Initialise Schedule (Weekly) Drop 1, 2** | 60d | 2025-04-23 | 2025-07-15 |  |  |
| 2651 | Issue Dress Rehearsal support information to Participants | 0d | 2025-04-23 | 2025-04-23 |  | start no earlier than 2025-04-23 |
| 2652 | Kestrel Webinar 1 | 0d | 2025-04-23 | 2025-04-23 | 2651 |  |
| 2653 | Onboard and connectivity testing - Dress Rehearsal with Suppliers (All SIT and Wave 1 mandatory) | 0d | 2025-04-25 | 2025-04-25 | 2652FS+3d |  |
| 2654 | Dress rehearsal start | 0d | 2025-04-28 | 2025-04-28 | 2653FS+1d |  |
| 2655 | Test execution report (weekly) | 0d | 2025-07-15 | 2025-07-15 | 2654FS+56d |  |
| 2656 | Dress rehearsal completion report | 0d | 2025-07-15 | 2025-07-15 | 2655 |  |
| 2657 | MCC Dress Rehersal 1 - complete | 0d | 2025-07-15 | 2025-07-15 | 2656 |  |
| 2658 | **MCC Dress Rehersal 2 - complete** | 35d | 2025-07-14 | 2025-08-29 |  |  |
| 2659 | Issue Dress Rehearsal support information to Participants | 0d | 2025-07-14 | 2025-07-14 |  | start no earlier than 2025-07-14 |
| 2660 | Kestrel Webinar 2 | 0d | 2025-07-14 | 2025-07-14 | 2659 |  |
| 2661 | Onboard and connectivity testing - Dress Rehearsal with Suppliers (remaining suppliers and non-supplier PPs) | 0d | 2025-07-21 | 2025-07-21 | 2660FS+6d |  |
| 2662 | Dress rehearsal start | 0d | 2025-07-21 | 2025-07-21 | 2661 |  |
| 2663 | Test execution report (weekly) | 0d | 2025-08-29 | 2025-08-29 | 2662FS+29d |  |
| 2664 | Dress rehearsal completion report | 0d | 2025-08-29 | 2025-08-29 | 2663 |  |
| 2665 | MCC Dress Rehersal 2 - complete | 0d | 2025-08-29 | 2025-08-29 | 2664 |  |
| 2666 | MCC Operational Complete | 0d | 2025-08-29 | 2025-08-29 | 2658, 2665 |  |
| 2725 | Suppliers complete Work Off plans | 105d | 2024-12-23 A | 2025-05-16 | 2724 | start no earlier than 2024-12-23 |
| 2731 | Suppliers complete Work Off plans | 123d | 2025-01-29 A | 2025-07-18 | 2730 | finish no earlier than 2025-07-18 |
| 2747 | **Connection Type and Meter Type Misalignments** | 433d | 2025-03-03 A | 2026-10-28 |  |  |
| 2748 | **Traditional Meters installed on Current Transformers** | 433d | 2025-03-03 A | 2026-10-28 |  |  |
| 2749 | Suppliers investigate all MPANs with Traditional Meters installed on a Current Transformer Connection Type | 65d | 2025-03-03 A | 2025-05-30 |  | finish no earlier than 2025-05-30 |
| 2750 | Suppliers to raise the relevant SDEP cases with LDSOs in pot 3 | 0d | 2025-05-30 | 2025-05-30 |  | finish no earlier than 2025-05-30 |
| 2751 | Suppliers to have ensured that Meter Operators have sent the necessary D0312s for MPANs in pot 2 | 21d | 2025-06-02 | 2025-06-30 | 2749 | start no earlier than 2025-06-02 |
| 2752 | LDSOs will be required to have corrected all of these Connection Types in pot 3 | 40d | 2025-06-02 | 2025-07-25 | 2750 | start no earlier than 2025-06-02 |
| 2753 | Suppliers to have completed meter exchanges for those MPANs in pot 1 | 368d | 2025-06-02 | 2026-10-28 | 2749 | start no earlier than 2025-06-02 |
| 2754 | Traditional Meters installed on Current Transformers complete | 0d | 2026-10-28 | 2026-10-28 | 2753 | finish no earlier than 2026-10-28 |
| 2755 | **CHECK Meters** | 66d | 2025-03-03 A | 2025-06-02 |  |  |
| 2756 | Suppliers and their appointed Meter Operator investigate MPANs within their portfolio that have incorrectly populated meters with the Meter Type CHECK within MPRS. Meter Operators are required to send a D0312 to remove the CHECK meter from MPRS. | 65d | 2025-03-03 A | 2025-05-30 |  | finish no earlier than 2025-05-30 |
| 2757 | Once CHECK meters are either removed from MPRS or the Meter Type is changed to a valid Meter Type, the LDSO should check that the Connection Type assigned to the MPAN is still valid. | 65d | 2025-03-03 A | 2025-05-30 |  | finish no earlier than 2025-05-30 |
| 2758 | Suppliers confirm to the Programme that they have completed this activity | 0d | 2025-06-02 | 2025-06-02 | 2756 | finish no earlier than 2025-06-02 |
| 2759 | CHECK Meters complete | 0d | 2025-06-02 | 2025-06-02 | 2757 | finish no earlier than 2025-06-02 |
| 2760 | **Smart Meter Types installed on CT Connection Types** | 90d | 2025-03-21 A | 2025-07-25 |  |  |
| 2761 | Programme shares data via email with LDSOs and Suppliers on the total number of misalignments to inform work they will have to complete | 0d | 2025-03-21 A | 2025-03-21 A |  | finish no earlier than 2025-03-21 |
| 2762 | LDSOs investigate Connection Type misalignments and correct where appropriate | 50d | 2025-03-24 A | 2025-05-30 | 2761 | finish no earlier than 2025-05-30 |
| 2763 | LDSOs raise SDEP queries with Suppliers where they believe there is an issue | 0d | 2025-05-30 | 2025-05-30 | 2762 | finish no earlier than 2025-05-30 |
| 2764 | Suppliers resolve all issues | 40d | 2025-06-02 | 2025-07-25 | 2763 | finish no earlier than 2025-07-25 |
| 2765 | Smart Meter Types installed on CT Connection Types complete | 0d | 2025-07-25 | 2025-07-25 | 2764 | finish no earlier than 2025-07-25 |
| 2766 | **Linked Import / Export MPANs** | 105d | 2025-03-03 A | 2025-07-25 |  |  |
| 2767 | LDSOs review and correct linked Import / Export MPANs with Different Connection Types | 105d | 2025-03-03 A | 2025-07-25 |  | finish no earlier than 2025-07-25 |
| 2768 | LDSOs, Import and Export Suppliers review and correct linked Import / Export MPANs with meters in the Advanced and Traditional or Smart Meter Groups | 105d | 2025-03-03 A | 2025-07-25 |  | finish no earlier than 2025-07-25 |
| 2769 | Linked Import / Export MPANs complete | 0d | 2025-07-25 | 2025-07-25 | 2767, 2768 | finish no earlier than 2025-07-25 |
| 2770 | **Related MPANs** | 105d | 2025-03-03 A | 2025-07-25 |  |  |
| 2771 | LDSOs review and correct related MPANs with different Connection Types | 80d | 2025-03-03 A | 2025-06-20 |  |  |
| 2772 | Suppliers unrelate any MPANs required | 25d | 2025-06-23 | 2025-07-25 | 2771 | finish no earlier than 2025-07-25 |
| 2773 | Suppliers should investigate Related MPANs within different meter groups and verify that they are correct or request that their Meter Operators update the Meter Types where they are incorrect | 105d | 2025-03-03 A | 2025-07-25 |  | start no earlier than 2025-03-03 |
| 2774 | Related MPANs complete | 0d | 2025-07-25 | 2025-07-25 | 2772, 2773 | finish no earlier than 2025-07-25 |
| 2817 | Central Party Cutover Plan Assurance | 45d | 2025-04-14 A | 2025-06-13 | 2815FF | start no earlier than 2025-04-14 |
| 2818 | Consolidated MHHS Cutover Plan Developed | 20d | 2025-05-19 | 2025-06-13 | 2815 | start no earlier than 2025-05-19 |
| 2819 | LDSO Cutover Plan Assurance | 15d | 2025-06-30 | 2025-07-18 | 2816FF | start no earlier than 2025-06-30 |
| 2820 | SIT Supplier and SIT Agent Cutover Plan Assurance | 40d | 2025-06-30 | 2025-08-22 | 2816FF | start no earlier than 2025-06-30 |
| 2841 | Confirmation that all LDSOs have deployed MPRS 9 to production | 0d | 2025-09-01 | 2025-09-01 |  | finish no earlier than 2025-09-01 |
| 2842 | Confirmation that population of Domestic Premises Indicator is complete | 0d | 2025-09-08 | 2025-09-08 | 2841 | finish no earlier than 2025-09-08 |
| 2844 | Confirmation that Market Segment has been populated for 95% of LDSO portfolios | 0d | 2025-09-12 | 2025-09-12 |  | finish no earlier than 2025-09-12 |
| 2867 | **Migration Sprints** | 420d | 2025-09-25 | 2027-05-05 |  |  |
| 2868 | **Migration Sprint 0** | 94d | 2025-09-25 | 2026-02-03 |  |  |
| 2869 | Sprint 0 Planning start date | 6d | 2025-09-25 | 2025-10-02 |  | start no earlier than 2025-09-25 |
| 2870 | Issue Envelope | 0d | 2025-10-02 | 2025-10-02 | 2869 |  |
| 2871 | Supplier Submission Deadline | 0d | 2025-10-09 | 2025-10-09 | 2870FS+5d |  |
| 2872 | Baseline Schedule Publication | 0d | 2025-10-16 | 2025-10-16 | 2871FS+5d |  |
| 2873 | Migration Sprint 0 Schedule Baselined | 0d | 2025-10-16 | 2025-10-16 | 2872 |  |
| 2874 | Sprint Execution Start | 0d | 2025-10-23 | 2025-10-23 | 2873FS+5d, 3011, 2966 |  |
| 2875 | Sprint Execution | 73d | 2025-10-24 | 2026-02-03 | 2874 |  |
| 2876 | Sprint Execution End | 0d | 2026-02-03 | 2026-02-03 | 2875 |  |
| 2877 | **Migration Sprint 1** | 60d | 2026-01-07 | 2026-03-31 |  |  |
| 2878 | Sprint 1 Planning start date | 6d | 2026-01-07 | 2026-01-14 |  | start no earlier than 2026-01-07 |
| 2879 | Issue Envelope | 0d | 2026-01-14 | 2026-01-14 | 2878 |  |
| 2880 | Supplier Submission Deadline | 0d | 2026-01-21 | 2026-01-21 | 2879FS+5d |  |
| 2881 | Baseline Schedule Publication | 0d | 2026-01-28 | 2026-01-28 | 2880FS+5d |  |
| 2882 | Migration Sprint 1 Schedule Baselined | 0d | 2026-01-28 | 2026-01-28 | 2881 |  |
| 2883 | Sprint Execution Start | 0d | 2026-02-04 | 2026-02-04 | 2882FS+5d |  |
| 2884 | Sprint Execution | 39d | 2026-02-05 | 2026-03-31 | 2883 |  |
| 2885 | Sprint Execution End | 0d | 2026-03-31 | 2026-03-31 | 2884 |  |
| 2886 | **Migration Sprint 2** | 65d | 2026-03-04 | 2026-06-02 |  |  |
| 2887 | Sprint 2 Planning start date | 6d | 2026-03-04 | 2026-03-11 |  | start no earlier than 2026-03-04 |
| 2888 | Issue Envelope | 0d | 2026-03-11 | 2026-03-11 | 2887 |  |
| 2889 | Supplier Submission Deadline | 0d | 2026-03-18 | 2026-03-18 | 2888FS+5d |  |
| 2890 | Baseline Schedule Publication | 0d | 2026-03-25 | 2026-03-25 | 2889FS+5d |  |
| 2891 | Migration Sprint 2 Schedule Baselined | 0d | 2026-03-25 | 2026-03-25 | 2890 |  |
| 2892 | Sprint Execution Start | 0d | 2026-04-01 | 2026-04-01 | 2891FS+5d |  |
| 2893 | Sprint Execution | 44d | 2026-04-02 | 2026-06-02 | 2892 |  |
| 2894 | Non-SIT Participants Migration Start | 0d | 2026-05-15 | 2026-05-15 | 3050FS+1d |  |
| 2895 | Sprint Execution End | 0d | 2026-06-02 | 2026-06-02 | 2893 |  |
| 2896 | **Migration Sprint 3** | 65d | 2026-05-06 | 2026-08-04 |  |  |
| 2897 | Sprint 3 Planning start date | 6d | 2026-05-06 | 2026-05-13 |  | start no earlier than 2026-05-06 |
| 2898 | Issue Envelope | 0d | 2026-05-13 | 2026-05-13 | 2897 |  |
| 2899 | Supplier Submission Deadline | 0d | 2026-05-20 | 2026-05-20 | 2898FS+5d |  |
| 2900 | Baseline Schedule Publication | 0d | 2026-05-27 | 2026-05-27 | 2899FS+5d |  |
| 2901 | Migration Sprint 3 Schedule Baselined | 0d | 2026-05-27 | 2026-05-27 | 2900 |  |
| 2902 | Sprint Execution Start | 0d | 2026-06-03 | 2026-06-03 | 2901FS+5d |  |
| 2903 | Sprint Execution | 44d | 2026-06-04 | 2026-08-04 | 2902 |  |
| 2904 | Sprint Execution End | 0d | 2026-08-04 | 2026-08-04 | 2903 |  |
| 2905 | **Migration Sprint 4** | 65d | 2026-07-08 | 2026-10-06 |  |  |
| 2906 | Sprint 4 Planning start date | 6d | 2026-07-08 | 2026-07-15 |  | start no earlier than 2026-07-08 |
| 2907 | Issue Envelope | 0d | 2026-07-15 | 2026-07-15 | 2906 |  |
| 2908 | Supplier Submission Deadline | 0d | 2026-07-22 | 2026-07-22 | 2907FS+5d |  |
| 2909 | Baseline Schedule Publication | 0d | 2026-07-29 | 2026-07-29 | 2908FS+5d |  |
| 2910 | Migration Sprint 4 Schedule Baselined | 0d | 2026-07-29 | 2026-07-29 | 2909 |  |
| 2911 | Sprint Execution Start | 0d | 2026-08-05 | 2026-08-05 | 2910FS+5d |  |
| 2912 | Sprint Execution | 44d | 2026-08-06 | 2026-10-06 | 2911 |  |
| 2913 | Sprint Execution End | 0d | 2026-10-06 | 2026-10-06 | 2912 |  |
| 2914 | **Migration Sprint 5** | 60d | 2026-09-09 | 2026-12-01 |  |  |
| 2915 | Sprint 5 Planning start date | 6d | 2026-09-09 | 2026-09-16 |  | start no earlier than 2026-09-09 |
| 2916 | Issue Envelope | 0d | 2026-09-16 | 2026-09-16 | 2915 |  |
| 2917 | Supplier Submission Deadline | 0d | 2026-09-23 | 2026-09-23 | 2916FS+5d |  |
| 2918 | Baseline Schedule Publication | 0d | 2026-09-30 | 2026-09-30 | 2917FS+5d |  |
| 2919 | Migration Sprint 5 Schedule Baselined | 0d | 2026-09-30 | 2026-09-30 | 2918 |  |
| 2920 | Sprint Execution Start | 0d | 2026-10-07 | 2026-10-07 | 2919FS+5d |  |
| 2921 | Sprint Execution | 39d | 2026-10-08 | 2026-12-01 | 2920 |  |
| 2922 | Sprint Execution End | 0d | 2026-12-01 | 2026-12-01 | 2921 |  |
| 2923 | **Migration Sprint 6** | 65d | 2026-11-04 | 2027-02-02 |  |  |
| 2924 | Sprint 6 Planning start date | 6d | 2026-11-04 | 2026-11-11 |  | start no earlier than 2026-11-04 |
| 2925 | Issue Envelope | 0d | 2026-11-11 | 2026-11-11 | 2924 |  |
| 2926 | Supplier Submission Deadline | 0d | 2026-11-18 | 2026-11-18 | 2925FS+5d |  |
| 2927 | Baseline Schedule Publication | 0d | 2026-11-25 | 2026-11-25 | 2926FS+5d |  |
| 2928 | Migration Sprint 6 Schedule Baselined | 0d | 2026-11-25 | 2026-11-25 | 2927 |  |
| 2929 | Sprint Execution Start | 0d | 2026-12-02 | 2026-12-02 | 2928FS+5d |  |
| 2930 | Sprint Execution | 44d | 2026-12-03 | 2027-02-02 | 2929 |  |
| 2931 | Sprint Execution End | 0d | 2027-02-02 | 2027-02-02 | 2930 |  |
| 2932 | **Migration Sprint 7** | 65d | 2027-01-06 | 2027-04-06 |  |  |
| 2933 | Sprint 6 Planning start date | 6d | 2027-01-06 | 2027-01-13 |  | start no earlier than 2027-01-06 |
| 2934 | Issue Envelope | 0d | 2027-01-13 | 2027-01-13 | 2933 |  |
| 2935 | Supplier Submission Deadline | 0d | 2027-01-20 | 2027-01-20 | 2934FS+5d |  |
| 2936 | Baseline Schedule Publication | 0d | 2027-01-27 | 2027-01-27 | 2935FS+5d |  |
| 2937 | Migration Sprint 7 Schedule Baselined | 0d | 2027-01-27 | 2027-01-27 | 2936 |  |
| 2938 | Sprint Execution Start | 0d | 2027-02-03 | 2027-02-03 | 2937FS+5d |  |
| 2939 | Sprint Execution | 44d | 2027-02-04 | 2027-04-06 | 2938 |  |
| 2940 | Sprint Execution End | 0d | 2027-04-06 | 2027-04-06 | 2939 |  |
| 2941 | **Migration Sprint 8** | 48d | 2027-03-01 | 2027-05-05 |  |  |
| 2942 | Sprint 8 Planning start date | 6d | 2027-03-01 | 2027-03-08 |  | start no earlier than 2027-03-01 |
| 2943 | Issue Envelope | 0d | 2027-03-08 | 2027-03-08 | 2942 |  |
| 2944 | Supplier Submission Deadline | 0d | 2027-03-15 | 2027-03-15 | 2943FS+5d |  |
| 2945 | Baseline Schedule Publication | 0d | 2027-03-22 | 2027-03-22 | 2944FS+5d |  |
| 2946 | Migration Sprint 8 Schedule Baselined | 0d | 2027-03-22 | 2027-03-22 | 2945 |  |
| 2947 | Sprint Execution Start | 0d | 2027-03-29 | 2027-03-29 | 2946FS+5d |  |
| 2948 | Sprint Execution | 27d | 2027-03-30 | 2027-05-05 | 2947 |  |
| 2949 | Sprint Execution End | 0d | 2027-05-05 | 2027-05-05 | 2948 |  |
| 2988 | **Phase 1 - Preparation** | 840d? | 2022-10-31 | 2026-01-16 |  |  |

Removed: 864 Development of Automated SIT Functional RTTM; 865 Automated SIT Functional RTTM Complete; 999 Develop Automated SIT Migration RTTM; 1000 Automated SIT Migration RTTM Complete; 1107 Develop Automated SIT NFT RTTM; 1108 Review with SRO; 1109 Automated SIT NFT RTTM Complete; 1110 Production of NFT RTTM; 1111 Test Script updates identified; 1112 Test Scripts updates; 1113 RTTM Updated Additional Static RTTM WBS items; 1114 Removal of de-scoped TCs from the RTTMs; 1115 Update and stabilisation of all TC ADO IDs; 1116 Addition and integration of Role tags to reqs in the Role RTTMs; 1117 Update of the RTTM All sheet (porting of the individual RTTMs); 1118 Define Additional ADO Tags; 1119 Non-Functional RTTM ready for import into ADO; 1120 Further Interative Deepdive on the requirements to testcase mapping; 1121 Internal review; 1122 Issue Static RTTM to Code Bodies; 1123 Code Body Acceptance of RTTM; 1146 Non-Functional Themes 2 & 3 (LDSO's and DCC) Data Load; 1147 Operational Themes 1, 2 & 3 (Batch 2) (LDSO's and DCC) Data Load; 1150 Non-Functional Theme 2 & 3 PP Preparation; 1159 SITAG endorse Non-Functional Theme 1 Overarching Test Readiness Report; 1168 SITAG endorse Non-Functional Overarching Test Readiness Report Theme 2 & 3; 1179 Develop execution model Theme 2& 3; 1184 SITWG update on execution model; 1278 Elexon Service Panel Review; 1341 Develop Automated SIT Operational RTTM; 1342 Automated SIT Operational RTTM Complete; 1343 Theme 3 Work-off plan; 1344 Test Scripts updates; 1345 RTTM Updated Additional Static RTTM WBS items; 1346 Removal of de-scoped TCs from the RTTMs; 1347 Update and stabilisation of all TC ADO IDs; 1348 Addition and integration of Role tags to reqs in the Role RTTMs; 1349 Update of the RTTM All sheet (porting of the individual RTTMs); 1350 Define Additional ADO Tags; 1351 Upload Operational RTTM to ADO; 1352 Further Interative Deepdive on the requirements to testcase mapping; 1353 Internal review; 1354 Issue Static RTTM to Code Bodies; 1355 Code Body Acceptance of RTTM; 1378 SITAG endorse Operational Theme 1, 2 and 3 (Batch 2) Overarching Test Readiness Report; 1387 SITWG update on execution model; 1394 SITWG update on execution model; 1420 eSITWG paper day; 1421 eSITWG endorses regression suite doc; 1458 Publish (QIP); 1459 Review & UAT; 1460 QIP Training Material & User Guides; 1559 Programme agreement into Settlement Testing; 1560 Helix E2E Settlement Testing Execution; 1561 Helix E2E Settlement Testing Execution Complete; 1562 MHHSP Helix E2E Testing Assurance; 1563 MHHSP Helix E2E Testing Assurance Complete; 1607 Theme 3 SIT Non-Functional Testing Start; 1608 Theme 3 SIT Non-Functional Testing Execution; 1710 Environments (Non-SIT LDSO); 1711 Coordinate Qualification Participants' environment preparation; 1712 Coordinate deployment of MHHS solution code to Qualification Participants' UIT environments; 1713 Qualification Testing Tranche 1 Participants' UIT environments ready to start connectivity proving (incl. certificates and security compliance); 1714 Coordinate Qualification Participants' connectivity proving (Non-SIT LDSO); 1715 Assurance of Qualification Participants' connectivity proving; 1716 Environments (S&A) Wave 1; 1717 Coordinate Qualification Participants' environment preparation; 1718 Coordinate deployment of MHHS solution code to Qualification Participants' UIT environments; 1719 Qualification Testing Wave 1 Participants' UIT environments ready to start connectivity proving (incl. certificates and security compliance); 1720 Coordinate Qualification Participants' connectivity proving (S&A); 1721 Assurance of Qualification Participants' connectivity proving; 1722 Environments (S&A) Wave 2; 1723 Coordinate Qualification Participants' environment preparation; 1724 Coordinate deployment of MHHS solution code to Qualification Participants' UIT environments; 1725 Qualification Testing Wave 2 Participants' UIT environments ready to start connectivity proving (incl. certificates and security compliance); 1726 Coordinate Qualification Participants' connectivity proving (S&A); 1727 Assurance of Qualification Participants' connectivity proving; 1728 Environments (S&A) Wave 3; 1729 Coordinate Qualification Participants' environment preparation; 1730 Coordinate deployment of MHHS solution code to Qualification Participants' UIT environments; 1731 Qualification Testing Wave 3 Participants' UIT environments ready to start connectivity proving (incl. certificates and security compliance); 1732 Coordinate Qualification Participants' connectivity proving (S&A); 1733 Assurance of Qualification Participants' connectivity proving; 1734 Environments (S&A) Wave 4; 1735 Coordinate Qualification Participants' environment preparation; 1736 Coordinate deployment of MHHS solution code to Qualification Participants' UIT environments; 1737 Qualification Testing Wave 4 Participants' UIT environments ready to start connectivity proving (incl. certificates and security compliance); 1738 Coordinate Qualification Participants' connectivity proving (S&A); 1739 Assurance of Qualification Participants' connectivity proving; 1896 LDSOs Develop & Submit Test Report (QT Test Completion Report); 2108 Industry Standing Data (ISD); 2109 Dependant on Receiving ISD Agreed Source Data from Helix; 2110 Helix Dev Environment migration; 2111 STGi (UK) migration; 2112 Maintenance window between cycle 2 and 3; 2113 First View of Migrated ISD Data; 2114 Second View of Migrated ISD Data (HXT1 (SIT B) migration); 2115 Final Cycle 3 Migrated ISD Data; 2116 Create ISD Template inc. DIP ID; 2117 Publish Qualification ISD; 2447 Migration Period Plan Review 1 Completed; 2470 Industry Assurance Review; 2476 Test Approach; 2477 Test Plan; 2478 Other Framework items; 2485 Indicative Envelopes Issued; 2486 Supplier Submissions; 2487 Team Assess Responses; 2488 Discuss and Agree Approach with Participants where necessary; 2490 Schedule Production v2; 2494 Migration Planning Tool - Delivery; 2495 MPMT Build Sprints - MVP; 2496 Delivery Activity; 2497 MCC - Pilot; 2499 Sprint Planning (Cycle 1); 2500 Sprint Planning (Cycle 2); 2501 Sprint Planning (Cycle 3); 2502 Migration Control Centre Tooling; 2503 Data Source Definition; 2504 Scheduling and Data Requirements; 2505 Tool Phase 1; 2506 Data Requirements; 2507 Tool Phase 2; 2508 Data Source Provision; 2509 Tool - Internal and External Testing; 2510 Migration Control Centre Mobilised and Ready; 2511 Migration Control Centre TOM Definition; 2512 Access to Data; 2513 Migration Control Centre Delegation of Authority; 2514 Recruit and Train; 2515 Dress Rehearsal; 2679 UMS / Advanced Migration; 2680 SIT MVC UMS / Advanced Migration; 2681 SIT Non-MVC UMS / Advanced Migration; 2682 Wave 1 UMS / Advanced Migration; 2683 Wave 2 UMS / Advanced Migration; 2684 Wave 3 UMS / Advanced Migration; 2685 Wave 4 UMS / Advanced Migration; 2686 Smart / Non-Smart Migration; 2687 SIT MVC Smart / Non-Smart Migration; 2688 SIT Non-MVC Smart / Non-Smart Migration; 2689 Wave 1 Smart / Non-Smart Migration; 2690 Wave 2 Smart / Non-Smart Migration; 2691 Wave 3 Smart / Non-Smart Migration; 2692 Wave 4 Smart / Non-Smart Migration

Changed:

| ID | Task | Start | Finish | Duration | Complete | Total float | Predecessors | Other |
| --- | --- | --- | --- | --- | --- | --- | --- | --- |
| 1 | **PROGRAMME PLAN.** |  |  |  | 53% → 66% |  |  |  |
| 3 | **PROGRAMME MANAGEMENT** |  |  |  | 44% → 57% | 31828d → 255d |  |  |
| 4 | **Programme Management** |  |  |  | 43% → 56% | 31828d → 255d |  |  |
| 5 | Sprint-based prioritisation planning and execution |  |  |  | 43% → 56% | 31828d → 255d |  |  |
| 6 | Programme governance secretariat |  |  |  | 43% → 56% | 31828d → 255d |  |  |
| 7 | RAID management and reporting |  |  |  | 43% → 56% | 31828d → 255d |  |  |
| 8 | Tracking against Programme outcomes and KPIs |  |  |  | 43% → 56% | 31828d → 255d |  |  |
| 9 | Change control and reporting |  |  |  | 43% → 56% | 31828d → 255d |  |  |
| 10 | Ongoing identification of lessons learned relating to the PMO and implementation of improvements |  |  |  | 43% → 56% | 31828d → 255d |  |  |
| 11 | **Programme Internal Assurance Reviews** |  |  |  | 43% → 56% | 31828d → 255d |  |  |
| 12 | Programme Internal Assurance Reviews |  |  |  | 43% → 56% | 31828d → 255d |  |  |
| 13 | **Engagement with PPs** |  |  |  | 43% → 56% | 31828d → 255d |  |  |
| 14 | Ongoing PP liaison activities |  |  |  | 43% → 56% | 31828d → 255d |  |  |
| 15 | Milestone and Control Point objective setting |  |  |  | 43% → 56% | 31828d → 255d |  |  |
| 16 | Reporting |  |  |  | 43% → 56% | 31828d → 255d |  |  |
| 17 | **PP Engagement Events** |  |  |  | 43% → 56% | 31828d → 255d |  |  |
| 18 | Bilateral meetings |  |  |  | 43% → 56% | 31828d → 255d |  |  |
| 19 | Monthly webinars |  |  |  | 43% → 56% | 31828d → 255d |  |  |
| 20 | Open days |  |  |  | 43% → 56% | 31828d → 255d |  |  |
| 21 | **PP Communications** |  |  |  | 43% → 56% | 31829d → 256d |  |  |
| 22 | The Clock updates (weekly) |  |  |  | 43% → 56% | 31829d → 256d |  |  |
| 23 | Maintain and update content on public-facing Portal (and ongoing feedback reviews to identify and implement Portal improvements) |  |  |  | 43% → 56% | 31829d → 256d |  |  |
| 24 | **Code Change Support / Other Programme Alignment** |  |  |  | 43% → 56% | 31828d → 255d |  |  |
| 25 | Support DCC/BEIS on SEC change |  |  |  | 43% → 56% | 31828d → 255d |  |  |
| 26 | Support on Smart Meters Act changes |  |  |  | 43% → 56% | 31828d → 255d |  |  |
| 27 | Support DCC/RECCo on CSS change |  |  |  | 43% → 56% | 31828d → 255d |  |  |
| 28 | Support Elexon on BSC change |  |  |  | 43% → 56% | 31828d → 255d |  |  |
| 29 | Support code change inside & outside CCIAG |  |  |  | 43% → 56% | 31828d → 255d |  |  |
| 30 | Support code change inside & outside CCAG |  |  |  | 43% → 56% | 31828d → 255d |  |  |
| 45 | **DESIGN, BUILD & TEST (PIT)** |  |  |  | 79% → 84% | 31696d → 123d |  |  |
| 46 | **Design Baseline & Enduring PP Support** |  |  |  | 71% → 79% | 31816d → 243d |  |  |
| 56 | **Establish Design Change Management Processes** |  |  |  | 36% → 54% | 31816d → 243d |  |  |
| 61 | Maintain E2E MHHS Design (post-M5 design change management processes operational) |  |  |  | 34% → 52% | 31816d → 243d |  |  |
| 96 | **Design Artefact Releases** |  | 2025-01-27 → 2025-04-23 A (+86d) | 504d? → 566d? | 97% → 100% | 32331d → none |  |  |
| 136 | **Interim release 8** |  | 2025-01-27 → 2025-04-23 A (+86d) | 249d? → 311d? | 84% → 100% | 32331d → none |  |  |
| 146 | **Interim Release 8.5** |  | 2025-01-22 A |  | 73% → 100% | 32334d → none |  |  |
| 149 | Interim Release 8.5 Deployed to SIT by Participants | 2025-01-20 A | 2025-01-22 A |  | 0% → 100% | 32334d → none |  |  |
| 150 | **Interim Release 8.6** |  | 2025-01-22 A |  | 50% → 100% | 32334d → none |  |  |
| 153 | Interim Release 8.6 Deployed to SIT by Participants | 2025-01-20 A | 2025-01-22 A |  | 0% → 100% | 32334d → none |  |  |
| 154 | **Interim Release 8.7** | 2025-01-20 A | 2025-01-27 → 2025-01-24 A (-3d) | 6d → 5d | 0% → 100% | 32331d → none |  | was named Interim Release 8.7 Placeholder |
| 155 | Update baselined artefacts | 2025-01-20 A | 2025-01-21 A |  | 0% → 100% | 32331d → none |  |  |
| 156 | Interim Release 8.7 Published | 2025-01-22 A | 2025-01-22 A |  | 0% → 100% | 32331d → none |  |  |
| 157 | Interim Release 8.7 Deployed to SIT by Participants | 2025-01-23 → 2025-01-22 A (-1d) | 2025-01-27 → 2025-01-24 A (-3d) |  | 0% → 100% | 32331d → none | 156 → 156FS-1d |  |
| 187 | **PP Design, Build & Test (DBT)** |  |  |  | 83% → 77% | 31696d → 123d |  |  |
| 199 | **Design Handover** | 2024-09-02 A → 2024-04-02 A (-153d) |  | 741d? → 850d? | 6% → 17% | 31696d → 123d |  |  |
| 203 | **Knowledge Transfer** | 2024-09-02 → 2025-01-06 A (+126d) | 2024-10-28 → 2025-05-05 (+189d) | 41d? → 86d? | 0% → 10% | 32396d → 688d |  |  |
| 204 | Elexon to document knowledge transfer requirements | 2024-09-02 → 2025-01-06 A (+126d) | 2024-09-12 → 2025-01-09 A (+119d) | 9d? → 4d | 0% → 100% | 32407d → none |  | baseline start 2024-09-02 → 2025-01-06; baseline finish 2024-09-12 → 2025-01-09 |
| 205 | Review Requirements | 2024-09-13 → 2025-01-10 A (+119d) | 2024-09-19 → 2025-01-16 A (+119d) |  | 0% → 100% | 32407d → none |  | baseline start 2024-09-13 → 2025-01-10; baseline finish 2024-09-19 → 2025-01-16 |
| 206 | Agree Success Criteria | 2024-09-20 → 2025-01-17 (+119d) | 2024-10-03 → 2025-02-28 (+148d) | 10d → 31d |  | 32407d → 688d |  | baseline start 2024-09-20 → 2025-01-17; baseline finish 2024-10-03 → 2025-02-28 |
| 207 | Identify Key personel with Elexon | 2024-10-04 → 2025-03-03 (+150d) | 2024-10-08 → 2025-03-05 (+148d) |  |  | 32407d → 688d |  | baseline start 2024-10-04 → 2025-03-03; baseline finish 2024-10-08 → 2025-03-05 |
| 208 | Draft Agenda for initial meeting | 2024-10-09 → 2025-03-06 (+148d) | 2024-10-09 → 2025-03-06 (+148d) |  |  | 32407d → 688d |  | baseline start 2024-10-09 → 2025-03-06; baseline finish 2024-10-09 → 2025-03-06 |
| 209 | Define cadence for handover sessions | 2024-10-10 → 2025-03-07 (+148d) | 2024-10-11 → 2025-03-10 (+150d) |  |  | 32407d → 688d |  | baseline start 2024-10-10 → 2025-03-07; baseline finish 2024-10-11 → 2025-03-10 |
| 210 | Share Design Information | 2024-09-02 → 2025-03-11 (+190d) | 2024-09-27 → 2025-04-07 (+192d) |  |  | 32417d → 688d | none → 209 | baseline start 2024-09-02 → 2025-03-11; baseline finish 2024-09-27 → 2025-04-07 |
| 211 | Conduct Initial Handover Session | 2024-10-01 → 2025-04-08 (+189d) | 2024-10-28 → 2025-05-05 (+189d) |  |  | 32396d → 688d | none → 210 | baseline start 2024-10-01 → 2025-04-08; baseline finish 2024-10-28 → 2025-05-05 |
| 212 | **Triage Sessions** | 2024-10-01 → 2024-04-02 (-182d) | 2025-04-01 → 2025-09-30 (+182d) | 131d? → 391d |  | 32285d → 582d |  |  |
| 213 | Design Triage Sessions |  | 2025-04-01 → 2025-09-30 (+182d) | 131d? → 261d |  | 32285d → 582d |  | baseline finish 2025-04-01 → 2025-09-30 |
| 214 | Test Triage Sessions | 2024-10-01 → 2024-04-02 (-182d) |  | 131d? → 261d |  | 32285d → 712d |  |  |
| 218 | **FreshDesk** | 2025-02-03 → 2025-08-20 (+198d) | 2025-03-14 → 2025-09-24 (+194d) | 30d? → 26d? |  | 32297d → 586d |  | baseline start 2025-02-03 → 2025-08-20; baseline finish 2025-03-14 → 2025-09-24 |
| 219 | Agree Indicative Handover of FreshDesk Calls to Service Now | 2025-02-03 → 2025-08-20 (+198d) | 2025-02-06 → 2025-08-25 (+200d) |  |  | 32323d → 586d |  | constraint start no earlier than 2025-02-03 → start no earlier than 2025-08-20; baseline start 2025-02-03 → 2025-08-20; baseline finish 2025-02-06 → 2025-08-25 |
| 220 | Prepare Comms to Industry | 2025-02-07 → 2025-08-26 (+200d) | 2025-02-20 → 2025-09-08 (+200d) |  |  | 32313d → 586d | none → 219 | baseline start 2025-02-07 → 2025-08-26; baseline finish 2025-02-20 → 2025-09-08 |
| 221 | Issue Comms to Industry | 2025-02-21 → 2025-09-09 (+200d) | 2025-02-21 → 2025-09-09 (+200d) |  |  | 32312d → 586d | none → 220 | baseline start 2025-02-21 → 2025-09-09; baseline finish 2025-02-21 → 2025-09-09 |
| 222 | Redirect Design Mailbox to Service Now | 2025-03-03 → 2025-09-10 (+191d) | 2025-03-03 → 2025-09-10 (+191d) |  |  | 32306d → 586d | none → 221 | baseline start 2025-03-03 → 2025-09-10; baseline finish 2025-03-03 → 2025-09-10 |
| 223 | Archive Freshdesk calls | 2025-03-03 → 2025-09-11 (+192d) | 2025-03-07 → 2025-09-17 (+194d) |  |  | 32302d → 586d | none → 222 | baseline start 2025-03-03 → 2025-09-11; baseline finish 2025-03-07 → 2025-09-17 |
| 224 | Decommission FreshDesk | 2025-03-10 → 2025-09-18 (+192d) | 2025-03-14 → 2025-09-24 (+194d) |  |  | 32297d → 586d | none → 223 | baseline start 2025-03-10 → 2025-09-18; baseline finish 2025-03-14 → 2025-09-24 |
| 225 | **iServer** |  |  |  | 5% → 88% |  |  |  |
| 226 | Gather Licensing information |  | 2025-03-03 A → 2025-07-02 A (+121d) | 1d? → 88d? |  |  |  | baseline finish 2025-03-03 → 2025-07-02 |
| 230 | Clear down old information |  | 2025-03-07 → 2025-03-03 (-4d) | 5d → 1d? |  | 32288d → 731d |  | baseline start 2025-03-03 → 2025-08-11; baseline finish 2025-03-07 → 2025-08-11 |
| 231 | Clear down accounts |  |  |  |  | 32288d → 727d |  | baseline start 2025-03-10 → 2025-08-12; baseline finish 2025-03-11 → 2025-08-13 |
| 232 | Identify Collaboration Base Design Dependencies on iServer | 2025-04-01 A | 2025-04-02 A |  | 0% → 100% | 32274d → none |  | baseline start 2025-04-01 → 2025-08-14; baseline finish 2025-04-02 → 2025-08-15 |
| 233 | Remove Design dependencies | 2025-04-03 A |  |  | 0% → 20% | 32274d → 701d |  | baseline start 2025-04-03 → 2025-08-18; baseline finish 2025-04-09 → 2025-08-22 |

| ID | Task | Start | Finish | Duration | Complete | Total float | Predecessors | Other |
| --- | --- | --- | --- | --- | --- | --- | --- | --- |
| 234 | Close down iServer |  |  |  |  | 32274d → 701d |  | baseline start 2025-04-10 → 2025-08-25; baseline finish 2025-04-16 → 2025-08-29 |
| 362 | **All SIT Programme Participants PIT (SIT Functional)** |  |  |  | 77% → 78% | 32307d → 739d |  |  |
| 396 | **All SIT Programme Participants PIT (SIT Non Functional)** |  |  |  | 63% → 98% | 32307d → 739d |  |  |
| 397 | **Test Approach & Plan** |  | 2024-11-22 A |  | 0% → 100% | 31630d → none |  |  |
| 399 | SIT Non-Functional Test approach and plan MHHS Review Completed |  | 2024-11-22 A |  | 0% → 100% | 31630d → none |  |  |
| 402 | **Requirements to test Traceability Matrix (RTTM)** |  | 2024-11-29 A |  | 0% → 100% | 31625d → none |  |  |
| 404 | SIT Non-Functional RTTM MHHS Review Completed | 2024-11-29 A | 2024-11-29 A |  | 0% → 100% | 31738d → none |  |  |
| 405 | **Test Scenarios** |  | 2024-11-29 A |  | 0% → 100% | 31625d → none |  |  |
| 407 | SIT Non-Functional Test scenarios MHHS Review Completed | 2024-11-29 A | 2024-11-29 A |  | 0% → 100% | 31738d → none |  |  |
| 408 | **PIT execution** |  | 2025-02-21 A |  | 61% → 100% | 32307d → none |  |  |
| 409 | PIT Test Execution Progress Report |  | 2024-11-21 A |  | 56% → 100% | 31616d → none |  |  |
| 410 | PIT Execution |  | 2024-11-29 A |  | 66% → 100% | 31610d → none |  |  |
| 411 | SIT Non-Functional PIT Completion Report submitted to Programme for assurance | 2024-11-29 A | 2024-11-29 A |  | 0% → 100% | 31723d → none |  |  |
| 412 | SIT Non-Functional PIT Completion Report Theme 1 MHHS Review Completed |  | 2024-12-20 A |  | 50% → 100% | 31610d → none |  |  |
| 413 | SIT Non-Functional PIT Completion Report Theme 2 & 3 MHHS Review Completed | 2025-02-21 A | 2025-02-21 A |  | 0% → 100% | 32307d → none |  | baseline start none → 2025-02-21; baseline finish none → 2025-02-21 |
| 414 | **SIT Programme Participants PIT (SIT Operational Theme 1, 2, 3 (Batch 2))** |  | 2025-01-10 → 2025-01-31 (+21d) | 131d → 146d | 46% → 90% | 31659d → 754d |  | was named All SIT Programme Participants PIT (SIT Operational) |
| 418 | **Test Readiness Report** |  |  |  | 42% → 90% | 0d → 18d |  |  |
| 419 | Test readiness reporting |  |  |  | 42% → 90% | 0d → 18d |  |  |
| 420 | **Requirements to test Traceability Matrix (RTTM)** | 2024-11-01 A → 2024-11-01 |  |  |  | 31689d → 799d |  |  |
| 421 | SIT Operational PIT RTTM submitted to Programme for assurance | 2024-11-01 A → 2024-11-01 | 2024-11-01 A → 2024-11-01 |  | 100% → 0% | none → 799d |  |  |
| 423 | **Test Scenarios** | 2024-11-01 A → 2024-11-01 |  |  |  | 31689d → 16.1d |  |  |
| 424 | SIT Operational PIT test scenarios submitted to Programme for assurance | 2024-11-01 A → 2024-11-01 | 2024-11-01 A → 2024-11-01 |  | 100% → 0% | none → 16.1d |  |  |
| 426 | **PIT execution** |  | 2025-01-10 → 2025-01-31 (+21d) | 131d → 146d | 47% → 90% | 31659d → 754d |  |  |
| 427 | PIT Test Execution Progress Report |  |  |  | 45% → 90% | 31680d → 792d |  |  |
| 428 | PIT Execution |  |  |  | 49% → 90% | 31659d → 754d |  |  |
| 429 | SIT Operational Theme 1, 2, 3 (Batch 2) PIT Completion Report submitted to Programme for assurance | 2024-12-20 → 2025-01-14 (+25d) | 2024-12-20 → 2025-01-14 (+25d) |  |  | 31633d → 754d | 427, 428FS+15d → 427, 428FS+32d | was named SIT Operational PIT Completion Report submitted to Programme for assurance |
| 430 | SIT Operational Theme 1, 2, 3 (Batch 2) PIT Completion Report MHHS Review Completed | 2025-01-10 → 2025-01-31 (+21d) | 2025-01-10 → 2025-01-31 (+21d) |  |  | 31633d → 754d | 417, 422, 425, 429FS+15d → 417, 422, 425, 429FS+13d | was named SIT Operational PIT Completion Report MHHS Review Completed; baseline start 2024-12-20 → 2025-01-31; baseline finish 2024-12-20 → 2025-01-31 |
| 499 | **DBT Monitoring and Assurance** |  |  |  | 69% → 85% | 32075d → 502d |  |  |
| 500 | **Planning and DBT Progress Monitoring of PPs** |  |  |  | 67% → 89% | 32221d → 648d |  |  |
| 501 | Monitor Non-SIT PPs Planning and DBT1 progress (to inform confirmation of Qualification Testing Tranche participants milestones) |  |  |  | 67% → 89% | 32221d → 648d |  |  |
| 502 | **DBT Progress Monitoring of Consequential Change** |  |  |  | 51% → 74% | 32075d → 502d |  |  |
| 503 | Monitor & report data cleanse progress |  |  |  | 51% → 74% | 32075d → 502d |  |  |
| 504 | **Design Assurance** |  |  |  | 80% → 89% | 32194d → 621d |  |  |
| 535 | **Non-SIT PPs design assurance** |  |  |  | 53% → 75% | 32194d → 621d |  |  |
| 536 | Non-SIT PPs design assurance (risk-based sample) |  |  |  | 53% → 75% | 32194d → 621d |  |  |
| 537 | **Test Assurance** |  |  |  | 71% → 87% | 32221d → 648d |  |  |
| 538 | Non-SIT PPs test assurance |  |  |  | 71% → 87% | 32221d → 648d |  |  |
| 545 | **SYSTEMS INTEGRATION TESTING (SIT)** |  |  |  | 62% → 78% |  |  |  |
| 546 | **SIT Preparation** |  |  |  | 88% → 99% | 32252d → 679d |  |  |
| 547 | **Test Artefact Development** |  | 2024-08-21 A |  | 99% → 100% | 32445d → none |  |  |
| 573 | **Test Traceability** |  | 2024-01-17 A |  | 98% → 100% | 32599d → none |  |  |
| 577 | SIT Functional Full Traceability & Coverage complete |  | 2024-01-17 A |  | 96% → 100% | 32599d → none |  |  |
| 627 | **SIT Stage-Specific Preparation** |  |  |  | 85% → 99% | 32252d → 679d |  |  |
| 868 | **SIT Functional Preparation** |  | 2025-02-07 A |  | 99% → 100% | 32322d → none |  |  |
| 885 | **Test cases** |  | 2025-02-07 A |  | 98% → 100% | 32322d → none |  |  |
| 892 | **SIT Functional Programme RTTM** |  | 2024-11-07 A |  | 96% → 100% | 32388d → none |  |  |
| 893 | **RTTM Development** |  | 2024-09-20 → 2024-09-06 A (-14d) | 40d? → 30d? | 89% → 100% | 32422d → none |  |  |
| 897 | Identify gaps in test case coverage following RTTM review |  |  |  |  |  | Development of Automated SIT Functional RTTMSS+20d → none |  |
| 996 | **SIT Migration Testing Preparation** |  | 2025-01-31 → 2025-02-07 A (+7d) | 590d? → 595d? | 91% → 100% | 32327d → none |  |  |
| 1007 | **Test scenarios & Test Cases** |  | 2025-01-31 → 2025-02-07 A (+7d) | 292d? → 297d? | 74% → 100% | 32327d → none |  |  |
| 1026 | **RTTM Development** |  | 2024-10-04 → 2024-09-20 A (-14d) | 27d? → 17d | 84% → 100% | 32412d → none |  |  |
| 1029 | **Gap analysis** |  | 2025-01-31 → 2025-02-07 A (+7d) | 102d? → 107d? | 47% → 100% | 32327d → none |  |  |
| 1056 | **Test Case Rationalisation (Functional + Migration)** |  | 2025-01-31 → 2025-02-07 A (+7d) | 62d → 67d | 4% → 100% | 32327d → none |  | was named Test Case Rationalisation (Fuctional + Migration) |
| 1058 | Baseline RTTMs |  | 2024-11-13 A |  | 90% → 100% | 32384d → none |  |  |
| 1060 | Produce requirements / test case analysis doc |  |  |  |  |  |  | was named Produce requirements / test case analysis |
| 1061 | Internal finalisation rationalisation workshop 2 |  | 2024-12-03 A |  | 4% → 100% | 32369d → none |  | baseline finish 2024-11-15 → 2024-12-03 |
| 1062 | SRO walkthrough | 2024-12-04 A | 2024-12-04 A |  | 0% → 100% | 32369d → none |  | baseline start 2024-11-21 → 2024-12-04; baseline finish 2024-11-21 → 2024-12-04 |
| 1063 | Code Bodies walkthrough | 2024-12-04 A | 2024-12-04 A |  | 0% → 100% | 32369d → none |  | baseline start 2024-11-26 → 2024-12-04; baseline finish 2024-11-26 → 2024-12-04 |
| 1064 | Send invites to PPs for walkthrough |  |  |  |  |  |  | baseline start 2024-11-26 → 2024-12-04; baseline finish 2024-11-26 → 2024-12-04 |
| 1065 | PP walkthrough | 2024-12-17 A | 2024-12-17 A |  | 0% → 100% | 32327d → none |  | baseline start 2024-12-03 → 2024-12-17; baseline finish 2024-12-03 → 2024-12-17 |
| 1067 | SITWG Paper Day | 2025-01-14 A | 2025-01-14 A |  | 0% → 100% | 32327d → none | 1076 → 1066 | baseline start 2024-12-20 → 2025-01-14; baseline finish 2024-12-20 → 2025-01-14 |
| 1068 | SITWG recommendation on requirements / test case analysis doc | 2025-01-21 A | 2025-01-21 A |  | 0% → 100% | 32327d → none |  | was named SITWG recommendation; baseline start 2025-01-08 → 2025-01-21; baseline finish 2025-01-08 → 2025-01-21 |
| 1069 | Issue to SITAG / SITAG paper day | 2025-01-22 A | 2025-01-22 A |  | 0% → 100% | 32327d → none | 1074, 1068FS+1d → 1068FS+1d | baseline start 2024-12-11 → 2025-01-22; baseline finish 2024-12-11 → 2025-01-22 |
| 1070 | Prepare ADO update | 2025-01-15 → 2025-01-22 A (+7d) | 2025-01-22 → 2025-01-29 A (+7d) |  | 0% → 100% | 32334d → none | 1076 → 1068 | baseline start 2024-12-11 → 2025-01-22; baseline finish 2024-12-18 → 2025-01-29 |
| 1071 | Sign off by SITAG | 2025-01-29 A | 2025-01-29 A |  | 0% → 100% | 32327d → none |  | baseline start 2024-12-18 → 2025-01-29; baseline finish 2024-12-18 → 2025-01-29 |
| 1072 | Update ADO | 2025-01-30 A | 2025-01-31 → 2025-02-07 A (+7d) | 2d → 7d | 0% → 100% | 32327d → none |  | baseline start 2024-12-19 → 2025-01-30; baseline finish 2024-12-20 → 2025-02-07 |
| 1073 | Update all ADO reporting | 2025-01-30 A | 2025-01-31 → 2025-02-07 A (+7d) | 2d → 7d | 0% → 100% | 32327d → none |  | baseline start 2024-12-19 → 2025-01-30; baseline finish 2024-12-20 → 2025-02-07 |
| 1074 | Update test cases | 2024-12-18 → 2025-01-30 A (+43d) | 2025-01-14 → 2025-02-07 A (+24d) | 20d → 7d | 0% → 100% | 32333d → none | 1065 → 1071 | baseline start 2024-12-04 → 2025-01-30; baseline finish 2024-12-10 → 2025-02-07 |
| 1075 | Update RTTM | 2024-12-18 → 2025-01-30 A (+43d) | 2025-01-14 → 2025-02-07 A (+24d) | 20d → 7d | 0% → 100% | 32340d → none | 1065 → 1071 | baseline start 2024-12-04 → 2025-01-30; baseline finish 2024-12-10 → 2025-02-07 |
| 1076 | Update master test case spreadsheet | 2024-12-18 → 2025-01-30 A (+43d) | 2025-01-14 → 2025-02-07 A (+24d) | 20d → 7d | 0% → 100% | 32327d → none | 1065 → 1071 | baseline start 2024-12-04 → 2025-01-30; baseline finish 2024-12-10 → 2025-02-07 |

| ID | Task | Start | Finish | Duration | Complete | Total float | Predecessors | Other |
| --- | --- | --- | --- | --- | --- | --- | --- | --- |
| 1077 | Test Case Rationalisation complete | 2025-01-31 → 2025-02-07 A (+7d) | 2025-01-31 → 2025-02-07 A (+7d) |  | 0% → 100% | 32327d → none | 1072, 1073 → 1072, 1073, 1071, 1074, 1075, 1076 | baseline start 2024-12-20 → 2025-02-07; baseline finish 2024-12-20 → 2025-02-07 |
| 1100 | **SIT Non-Functional Preparation** |  | 2025-03-28 A |  | 66% → 100% | 32287d → none |  |  |
| 1111 | **Test scenarios & Test Cases** |  |  |  | 81% → 100% |  |  |  |
| 1130 | **SIT NFT Programme RTTM** |  | 2024-12-04 → 2024-11-19 A (-15d) | 56d? → 45d | 78% → 100% | 32369d → none |  |  |
| 1134 | DIP Manager / Code Bodies / Full SRO to review |  | 2024-11-19 A |  | 50% → 100% | 32369d → none |  |  |
| 1136 | Manual SIT NFT RTTM Complete | 2024-11-19 A | 2024-11-19 A |  | 0% → 100% | 32369d → none |  |  |
| 1137 | **NFT (Theme 1, 2 and 3) DITL** | 2025-02-03 A | 2025-02-26 A |  | 0% → 100% | 32309d → none |  |  |
| 1138 | DITL Development | 2025-02-03 A | 2025-02-14 A |  | 0% → 100% | 32309d → none |  |  |
| 1139 | SRO Review | 2025-02-17 A | 2025-02-21 A |  | 0% → 100% | 32309d → none |  |  |
| 1140 | Post-SRO Review Changes | 2025-02-24 A | 2025-02-26 A |  | 0% → 100% | 32309d → none |  |  |
| 1141 | Programme DITL walkthrough with PPs on Theme 1, 2 and 3 | 2025-02-26 A | 2025-02-26 A |  | 0% → 100% | 32309d → none |  | was named Programme walkthrough with Theme 1 PPs on DITL |
| 1142 | **NFT Performance Tool Theme 1 Setup** |  | 2025-03-12 A |  | 98% → 100% | 32299d → none |  |  |
| 1147 | Theme 1 injection tool configuration and validation against SIT-B DIP (IR8.4) | 2025-03-10 A | 2025-03-12 A |  | 0% → 100% | 32299d → none |  | was named Theme 1 injection tool configuration and validation against SIT-B DIP (IR8.3) |
| 1148 | **Environments (SIT B)** |  | 2025-02-28 A |  | 0% → 100% | 31603d → none |  |  |
| 1153 | **Helix and Avanade Environments Upscale** | 2025-02-24 A | 2025-02-28 A |  | 0% → 100% | 31603d → none |  |  |
| 1154 | Environment Uplift Window (Technical Check) | 2025-02-24 A | 2025-02-28 A |  | 0% → 100% | 31603d → none |  | was named Environment Uplift Window; baseline start 2024-12-23 → 2025-02-24; baseline finish 2025-01-03 → 2025-02-28 |
| 1155 | **SIT Non-Functional Execution Model** | 2024-12-23 → 2025-01-20 A (+28d) | 2025-02-12 → 2025-03-18 A (+34d) | 38d → 42d | 0% → 100% | 31728d → none |  |  |
| 1156 | **Theme 1** | 2025-01-20 A | 2025-02-12 → 2025-02-18 A (+6d) | 18d → 22d | 0% → 100% | 32319d → none |  |  |
| 1157 | Develop execution model Theme 1 | 2025-01-20 A | 2025-01-22 A |  | 0% → 100% | 32319d → none |  |  |
| 1158 | SRO provide feedback | 2025-01-23 A | 2025-01-29 A |  | 0% → 100% | 32319d → none |  |  |
| 1159 | Address SRO feedback on execution model | 2025-01-30 A | 2025-01-31 A |  | 0% → 100% | 32319d → none |  |  |
| 1160 | Finalise execution model | 2025-02-03 A | 2025-02-05 A |  | 0% → 100% | 32319d → none |  |  |
| 1163 | **Theme 2 & 3** | 2025-01-20 A | 2025-02-12 → 2025-03-18 A (+34d) | 18d → 42d | 0% → 100% | 32319d → none |  |  |
| 1165 | SRO provide feedback | 2025-01-23 A | 2025-01-29 A |  | 0% → 100% | 32319d → none | Develop execution model Theme 2& 3 → 1164 |  |
| 1166 | Address SRO feedback on execution model | 2025-01-30 A | 2025-01-31 A |  | 0% → 100% | 32319d → none |  |  |
| 1167 | Finalise execution model | 2025-02-03 A | 2025-02-05 A |  | 0% → 100% | 32319d → none |  |  |
| 1170 | **SIT Non-Functional Progress reporting** | 2024-12-23 → 2025-01-23 A (+31d) | 2025-01-24 → 2025-02-21 A (+28d) | 25d → 22d | 0% → 100% | 31728d → none |  |  |
| 1171 | Determine reporting methodology | 2025-01-23 A | 2025-01-24 A |  | 0% → 100% | 32332d → none | Develop execution model Theme 2& 3, 1157 → 1157, 1164 |  |
| 1172 | Implement reporting | 2024-12-23 → 2025-01-27 A (+35d) | 2025-01-10 → 2025-02-21 A (+42d) | 15d → 20d | 0% → 100% | 31728d → none | 874, 412, 1117, 1123, 1129 → 1171, 874, 412, 1117, 1123, 1129 | baseline start 2024-12-30 → 2025-01-27; baseline finish 2025-01-10 → 2025-02-14 |
| 1173 | **SIT Non-Functional Test Readiness Report** | 2024-12-23 → 2025-01-21 A (+29d) | 2025-03-28 A | 70d → 48d | 0% → 100% | 31610d → none |  |  |
| 1174 | **SIT Non-Functional Theme 1 Overarching Test Readiness Report** | 2024-12-23 → 2025-01-21 A (+29d) | 2025-02-28 A | 50d → 29d | 0% → 100% | 31610d → none |  |  |
| 1175 | Develop Overarching SIT Non-Functional Theme 1 Overarching Test Readiness Report | 2024-12-23 → 2025-01-21 A (+29d) | 2025-01-09 → 2025-02-04 A (+26d) | 14d → 11d | 0% → 100% | 31610d → none |  | constraint none → finish no earlier than 2025-02-04; baseline start 2024-12-02 → 2025-01-21; baseline finish 2024-12-20 → 2025-02-04 |
| 1176 | SRO review | 2025-01-10 → 2025-02-05 A (+26d) | 2025-01-16 → 2025-02-11 A (+26d) |  | 0% → 100% | 31610d → none |  | constraint none → finish no earlier than 2025-02-10; baseline start 2025-01-10 → 2025-02-05; baseline finish 2025-01-16 → 2025-02-11 |
| 1177 | NFTWG paper day | 2025-01-16 → 2025-02-11 A (+26d) | 2025-01-16 → 2025-02-11 A (+26d) |  | 0% → 100% | 32333d → none |  | constraint none → finish no earlier than 2025-02-11; baseline start 2025-01-16 → 2025-02-11; baseline finish 2025-01-16 → 2025-02-11 |
| 1178 | NFTWG review the Non-Functional Theme 1 Overarching Test Readiness Report | 2025-01-23 → 2025-02-18 A (+26d) | 2025-01-23 → 2025-02-18 A (+26d) |  | 0% → 100% | 32333d → none |  | baseline start 2025-01-23 → 2025-02-18; baseline finish 2025-01-23 → 2025-02-18 |
| 1179 | Update Non-Functional Theme 1 Overarching Test Readiness Report following SRO / NFTWG feedback | 2025-01-17 → 2025-02-19 A (+33d) | 2025-02-12 → 2025-02-26 A (+14d) | 19d → 6d | 0% → 100% | 31610d → none | 1176 → 1176, 1178 | constraint none → finish no earlier than 2025-02-26; baseline start 2025-01-17 → 2025-02-19; baseline finish 2025-02-12 → 2025-02-26 |
| 1181 | eSITAG paper day | 2025-04-24 → 2025-02-26 A (-57d) | 2025-04-24 → 2025-02-26 A (-57d) |  | 0% → 100% | 31614d → none | 1458 → 1179 | constraint none → finish no earlier than 2025-02-21; baseline start 2025-03-11 → 2025-02-26; baseline finish 2025-03-11 → 2025-02-26 |
| 1182 | eSITAG approve Non-Functional Theme 1 Overarching Test Readiness Report | 2025-02-28 A | 2025-02-28 A |  | 0% → 100% | 31603d → none | 1426, SITAG endorse Non-Functional Theme 1 Overarching Test Readiness Report → 1426 |  |
| 1183 | **SIT Non-Functional Overarching Test Readiness Report Theme 2 & 3** | 2025-01-13 → 2025-02-18 A (+36d) | 2025-03-28 A | 55d → 28d | 0% → 100% | 31688d → none |  | baseline start 2025-01-13 → 2025-02-18 |
| 1184 | Develop Overarching SIT Non-Functional Overarching Test Readiness Report Theme 2 & 3 | 2025-01-13 → 2025-02-18 A (+36d) | 2025-02-04 → 2025-03-04 A (+28d) | 17d → 11d | 0% → 100% | 32294d → none |  | constraint start no earlier than 2025-01-13 → finish no earlier than 2025-03-04; baseline start 2025-01-13 → 2025-02-18; baseline finish 2025-02-04 → 2025-03-04 |
| 1185 | SRO review | 2025-02-05 → 2025-03-05 A (+28d) | 2025-02-11 → 2025-03-11 A (+28d) |  | 0% → 100% | 32294d → none | 1184 → 1184SS | constraint none → start no earlier than 2025-03-05; baseline start 2025-02-05 → 2025-03-05; baseline finish 2025-02-11 → 2025-03-11 |
| 1186 | NFTWG paper day | 2025-02-11 → 2025-03-11 A (+28d) | 2025-02-11 → 2025-03-11 A (+28d) |  | 0% → 100% | 32294d → none |  | constraint none → finish no earlier than 2025-03-11; baseline start 2025-02-11 → 2025-03-11; baseline finish 2025-02-11 → 2025-03-11 |
| 1187 | NFTWG review the Non-Functional Overarching Test Readiness Report Theme 2 & 3 | 2025-02-18 → 2025-03-18 A (+28d) | 2025-02-18 → 2025-03-18 A (+28d) |  | 0% → 100% | 32294d → none |  | constraint none → finish no earlier than 2025-03-18; baseline start 2025-02-18 → 2025-03-18; baseline finish 2025-02-18 → 2025-03-18 |
| 1188 | Update Non-Functional Overarching Test Readiness Report Theme 2 & 3 following SRO / NFTWG feedback | 2025-02-19 → 2025-03-19 A (+28d) | 2025-03-12 → 2025-03-26 A (+14d) | 16d → 6d | 0% → 100% | 32294d → none | 1187 → 1185, 1187 | baseline start 2025-02-19 → 2025-03-19; baseline finish 2025-03-12 → 2025-03-26 |
| 1191 | eSITAG approve Non-Functional Overarching Test Readiness Report Theme 2 & 3 | 2025-03-28 A | 2025-03-28 A |  | 0% → 100% | 31633d → none | 1427, Non-Functional Themes 2 & 3 (LDSO's and DCC) Data Load → 1190, 1427FS-1d, 1428 |  |
| 1192 | SIT Non-Functional Testing Preparation Complete Theme 1 | 2025-02-28 A | 2025-02-28 A |  | 0% → 100% | 32307d → none |  |  |
| 1193 | SIT Non-Functional Testing Preparation Complete Theme 2 & 3 | 2025-03-28 A | 2025-03-28 A |  | 0% → 100% | 32287d → none | 1427, Non-Functional Themes 2 & 3 (LDSO's and DCC) Data Load, 413FS+5d → 413FS+5d, 1427, 1428, 1169, 1172, 1147, 1141, 1136 |  |
| 1194 | **SIT Operational Preparation** | 2022-10-31 A → 2022-10-31 | 2025-04-21 → 2025-04-25 (+4d) | 646d? → 650d? | 69% → 97% | 32271d → 694d |  |  |
| 1205 | **Theme 1 & 2 Test Cases Approved** |  |  |  |  |  |  | was named Test scenarios & Test Cases |
| 1223 | **SIT Operations Manual** | 2022-10-31 A → 2022-10-31 | 2025-01-31 A | 589d? → 590d? | 72% → 100% | 32328d → none |  |  |
| 1244 | **Version 3 (Final) SIT Operations Manual** |  | 2025-01-28 A |  | 70% → 100% | 32330d → none |  |  |
| 1245 | Update SIT Operations Manual (Final) Version 3 (with Comments Received From Version 2) [Pre-Christmas Furlough] |  | 2024-12-20 A |  | 90% → 100% | 32330d → none |  |  |
| 1246 | Update SIT Operations Manual (Final) Version 3 (with Comments Received From Version 2) [Post-Christmas Furlough] | 2025-01-02 A | 2025-01-08 A |  | 0% → 100% | 32330d → none |  |  |
| 1247 | SIT Operations Manual (Final) Version 3 Completed | 2025-01-08 A | 2025-01-08 A |  | 0% → 100% | 32330d → none |  |  |
| 1248 | January TORWG Paper Day | 2025-01-08 A | 2025-01-08 A |  | 0% → 100% | 32330d → none |  |  |
| 1249 | January TORWG (SIT Operations Manual Agreement) [Assurance Meeting] | 2025-01-15 A | 2025-01-15 A |  | 0% → 100% | 32330d → none |  |  |
| 1250 | January MCAG Paper Day (Final SIT Operations Manual Submitted) | 2025-01-21 A | 2025-01-21 A |  | 0% → 100% | 32330d → none |  |  |
| 1251 | January MCAG (Final SIT Operations Manual Endorsement) [Advisory Group Sign-off] | 2025-01-28 A | 2025-01-28 A |  | 0% → 100% | 32330d → none |  |  |
| 1252 | **Elexon / Helix Service Now Test Prep** |  | 2025-01-14 A |  | 87% → 100% | 31701d → none |  | was named Elexon / Helix Service Management Test Prep |
| 1257 | Incident Management Build & Configuration Complete |  |  |  |  |  |  | baseline start none → 2024-11-15; baseline finish none → 2024-11-15 |
| 1262 | Major Incident Management Build & Configuration Complete |  |  |  |  |  |  | baseline start none → 2025-01-14; baseline finish none → 2025-01-14 |
| 1267 | Knowledge Management Build & Configuration Complete |  |  |  |  |  |  | baseline start none → 2025-01-14; baseline finish none → 2025-01-14 |
| 1268 | **Problem Management Build & Configuration** |  |  |  | 73% → 100% |  |  |  |
| 1271 | Deploy | 2024-12-18 A | 2025-01-14 A |  | 0% → 100% | 31701d → none |  |  |
| 1272 | Problem Management Build & Configuration Complete | 2025-01-14 A | 2025-01-14 A |  | 0% → 100% | 31701d → none |  | baseline start none → 2025-01-14; baseline finish none → 2025-01-14 |
| 1273 | **Change Management Build & Configuration** |  | 2025-01-14 A |  | 73% → 100% |  |  |  |
| 1276 | Deploy | 2024-12-18 A | 2025-01-14 A |  | 0% → 100% | 31701d → none |  |  |
| 1277 | Change Management Build & Configuration Complete | 2025-01-14 A | 2025-01-14 A |  | 0% → 100% | 31701d → none |  | baseline start none → 2025-01-14; baseline finish none → 2025-01-14 |
| 1278 | **Service Catalogue Management Build & Configuration** |  | 2025-01-14 A |  | 73% → 100% |  |  |  |
| 1281 | Deploy | 2024-12-18 A | 2025-01-14 A |  | 0% → 100% | 31701d → none |  |  |

| ID | Task | Start | Finish | Duration | Complete | Total float | Predecessors | Other |
| --- | --- | --- | --- | --- | --- | --- | --- | --- |
| 1282 | Service Catalogue Management Build & Configuration Complete | 2025-01-14 A | 2025-01-14 A |  | 0% → 100% | 31701d → none |  | baseline start none → 2025-01-14; baseline finish none → 2025-01-14 |
| 1283 | ServiceNow SIT Ops Available | 2025-01-14 A | 2025-01-14 A |  | 0% → 100% | 31701d → none |  |  |
| 1284 | **Helix Service Management Documentation (Service Design Pack)** |  | 2024-12-20 → 2025-01-08 A (+19d) | 102d → 115d | 88% → 100% | 31718d → none |  |  |
| 1285 | Document Drafting |  | 2024-12-11 A |  | 95% → 100% | 31722d → none |  |  |
| 1286 | Internal Elexon Review | 2024-12-12 → 2025-01-06 A (+25d) | 2024-12-16 → 2025-01-08 A (+23d) |  | 0% → 100% | 31722d → none |  |  |
| 1287 | Elexon Service Panel Sign off | 2024-12-20 → 2025-01-08 A (+19d) | 2024-12-20 → 2025-01-08 A (+19d) |  | 0% → 100% | 31718d → none | Elexon Service Panel Review → 1286 |  |
| 1288 | **Incident Management Support** |  |  |  | 0% → 100% |  |  | baseline start none → 2022-10-31; baseline finish none → 2022-10-31 |
| 1289 | Identify Relevant Stakeholders to Support Incident Management Process | 2024-12-02 A | 2024-12-13 A |  | 0% → 100% | 32337d → none |  |  |
| 1290 | Schedule Time to Upskill Stakeholders | 2024-12-16 A | 2024-12-20 A |  | 0% → 100% | 32337d → none |  |  |
| 1291 | Helix Stakeholders Attendance at MHHS Defect Triage Meetings [Meeting Dates to be Confirmed] | 2025-01-06 A | 2025-01-17 A |  | 0% → 100% | 32337d → none |  |  |
| 1292 | SIT Service Readiness (Elexon & Helix) Completed | 2025-01-17 A | 2025-01-17 A |  | 0% → 100% | 32337d → none |  |  |
| 1293 | **SIT Service Readiness (External Parties)** | 2024-09-30 A → 2024-10-07 A (+7d) | 2025-01-06 → 2025-01-31 A (+25d) | 71d → 85d | 13% → 100% | 32346d → none |  |  |
| 1294 | **Helix Engagement & Comms** | 2024-09-30 A → 2024-10-07 A (+7d) | 2025-01-06 → 2025-01-13 A (+7d) |  | 23% → 100% | 32346d → none |  | constraint start no earlier than 2024-09-30 → none |
| 1295 | Engagement Execution |  | 2025-01-06 → 2025-01-13 A (+7d) | 66d → 71d | 17% → 100% | 32346d → none |  | constraint start no earlier than 2024-10-07 → finish no earlier than 2025-01-13 |
| 1296 | Information Gathering | 2024-10-31 → 2024-11-29 A (+29d) | 2024-12-13 → 2025-01-13 A (+31d) |  | 0% → 100% | 32362d → none |  | constraint start no earlier than 2024-10-31 → finish no earlier than 2025-01-13 |
| 1297 | SIT Participants Preparation | 2024-11-22 → 2024-11-28 A (+6d) | 2025-01-06 → 2024-12-10 A (-27d) | 32d → 9d | 0% → 100% | 32338d → none |  | constraint start no earlier than 2024-11-22 → start no earlier than 2024-11-28 |
| 1298 | SIT Service Readiness (External Parties) Completed | 2025-01-06 → 2025-01-31 A (+25d) | 2025-01-06 → 2025-01-31 A (+25d) |  | 0% → 100% | 32346d → none | 1294, 1295, 1296, 1297 → 1295FS+9d, 1296, 1297, 1315 |  |
| 1299 | **ServiceNow Support Portal Onboarding (Helix Suppliers & SIT Participants)** |  |  |  | 53% → 100% |  |  |  |
| 1305 | **ServiceNow Portal System Configuration** | 2024-11-27 A | 2025-01-07 → 2025-01-31 A (+24d) | 30d? → 48d? | 0% → 100% |  |  |  |
| 1306 | Create Supplier User Accounts | 2024-11-27 A | 2024-12-16 → 2025-01-31 A (+46d) | 14d → 48d | 0% → 100% | 32335d → none | 1304, 1297SS → 1304 | constraint finish no earlier than 2024-12-10 → finish no earlier than 2025-01-31 |
| 1307 | Assign appropriate access based on the supplier’s needs and security requirements (e.g., read-only access, submit requests, etc.). | 2024-12-17 → 2024-12-30 A (+13d) | 2024-12-30 → 2025-01-31 A (+32d) | 10d? → 25d? | 0% → 100% | 32335d → none | 1306 → 1306FF |  |
| 1308 | Configure Access Controls | 2024-12-31 → 2024-12-30 A (-1d) | 2025-01-13 → 2025-01-31 A (+18d) | 10d? → 25d? | 0% → 100% | 32335d → none | 1307 → 1307FF |  |
| 1309 | **ServiceNow Portal Training and Documentation** | 2025-01-06 A | 2025-01-10 → 2025-01-31 A (+21d) | 5d? → 20d? | 0% → 100% |  |  |  |
| 1310 | Provide Training to the Supplier | 2025-01-06 → 2025-01-31 A (+25d) | 2025-01-10 → 2025-01-31 A (+21d) | 5d → 1d | 0% → 100% | 32331d → none |  | constraint finish no earlier than 2025-01-10 → finish no earlier than 2025-01-31 |
| 1311 | Create Supplier Training Documentation | 2025-01-06 A | 2025-01-10 → 2025-01-31 A (+21d) | 5d → 20d | 0% → 100% | 32336d → none |  | constraint finish no earlier than 2025-01-10 → finish no earlier than 2025-01-31 |
| 1312 | **ServiceNow Portal Testing and Validation** |  | 2025-01-17 → 2025-01-31 A (+14d) | 8d? → 18d | 0% → 100% |  |  |  |
| 1313 | Conduct User Acceptance Testing (UAT) | 2025-01-13 → 2025-01-31 A (+18d) | 2025-01-17 → 2025-01-31 A (+14d) | 5d → 1d | 0% → 100% | 32337d → none | 1310 → 1310SS |  |
| 1314 | Validate Access and Security Controls | 2025-01-13 → 2025-01-28 A (+15d) | 2025-01-17 → 2025-01-31 A (+14d) | 5d → 4d | 0% → 100% | 32331d → none | 1310 → none | constraint finish no earlier than 2025-01-14 → finish no earlier than 2025-01-31 |
| 1315 | ServiceNow Support Portal Onboarding (Helix Suppliers& SIT Participants) Completed | 2025-01-17 → 2025-01-31 A (+14d) | 2025-01-17 → 2025-01-31 A (+14d) |  | 0% → 100% | 32331d → none | 1304, 1308, 1311, 1314 → 1304, 1308, 1311, 1314, 1310 |  |
| 1316 | Stage 1 - Helix SIT Operational Readiness Completed | 2025-01-31 A | 2025-01-31 A |  | 0% → 100% | 32328d → none | none → 1298, 1283, 1251 |  |
| 1318 | **Theme 3 (Batch 2)** |  | 2024-12-18 A | 65d → 64d | 99% → 100% | 31675d → none |  |  |
| 1328 | SITAG paper day | 2024-12-11 A | 2024-12-11 A |  | 0% → 100% | 31670d → none |  |  |
| 1329 | SITAG approve Theme 3 (Batch 2) | 2024-12-18 A | 2024-12-18 A | 1d → 0d | 0% → 100% | 31670d → none | 1328FS+4d → 1328FS+5d |  |
| 1352 | SITAG paper day | 2025-02-12 → 2025-03-12 A (+28d) | 2025-02-12 → 2025-03-12 A (+28d) |  | 0% → 100% | 31610d → none | 1179 → 1351FS+4d | baseline start 2025-02-12 → 2025-03-12; baseline finish 2025-02-12 → 2025-03-12 |
| 1357 | **SIT Operational Programme RTTM (Theme 3 (Batch 1))** |  | 2025-01-17 → 2025-01-24 A (+7d) | 30d → 35d | 27% → 100% | 32337d → none |  | was named SIT Operational Programme RTTM |
| 1358 | Develop SIT Operational Theme 3 (Batch 1) RTTM |  | 2025-01-10 A |  | 32% → 100% | 32271d → none |  | was named Develop Manual SIT Operational RTTM |
| 1362 | SIT Operational Theme 3 (Batch 1) RTTM Complete | 2025-01-10 → 2025-01-24 A (+14d) | 2025-01-10 → 2025-01-24 A (+14d) |  | 0% → 100% | 32271d → none | 1358 → 1358, 1361 | was named Manual SIT Operational RTTM Complete |
| 1370 | **SIT Operational Theme 3 (Batch 1) DITL** | 2025-01-06 A | 2025-01-29 → 2025-01-28 A (-1d) | 18d → 17d | 0% → 100% | 32329d → none |  | was named SIT Operational DITL |
| 1371 | DITL + Familiarisation session development | 2025-01-06 A | 2025-01-17 → 2025-01-15 A (-2d) | 10d → 8d | 0% → 100% | 32329d → none |  | was named DITL Development |
| 1372 | SRO Review | 2025-01-20 → 2025-01-16 A (-4d) | 2025-01-24 → 2025-01-22 A (-2d) |  | 0% → 100% | 32329d → none |  |  |
| 1373 | Post-SRO Review Changes | 2025-01-27 → 2025-01-23 A (-4d) | 2025-01-29 → 2025-01-24 A (-5d) | 3d → 2d | 0% → 100% | 32329d → none |  | baseline start 2025-01-27 → 2025-01-23; baseline finish 2025-01-29 → 2025-01-24 |
| 1375 | Publish Cycle 3 DITL / Cycle 3 DITL Online Sessions for SIT PPs | 2025-01-29 → 2025-01-28 A (-1d) | 2025-01-29 → 2025-01-28 A (-1d) |  | 0% → 100% | 32329d → none | 1373 → 1374FS+2d | baseline start 2025-01-29 → 2025-01-28; baseline finish 2025-01-29 → 2025-01-28 |
| 1385 | **SIT Operational Execution Model** |  |  | 43d → 43d? | 0% → 100% |  |  |  |
| 1386 | **Theme 3 (Batch 1)** |  |  |  | 0% → 100% |  |  |  |
| 1387 | Develop execution model Theme 3 (Batch 1) | 2024-12-16 A | 2024-12-18 A |  | 0% → 100% | 32335d → none |  |  |
| 1388 | SRO provide feedback | 2024-12-19 A | 2025-01-07 A |  | 0% → 100% | 32335d → none |  |  |
| 1389 | Address SRO feedback on execution model | 2025-01-08 A | 2025-01-09 A |  | 0% → 100% | 32335d → none |  |  |
| 1390 | Finalise execution model | 2025-01-10 A | 2025-01-14 A |  | 0% → 100% | 32335d → none |  |  |
| 1391 | SITWG paper day | 2025-02-05 → 2025-01-14 A (-22d) | 2025-02-05 → 2025-01-14 A (-22d) |  | 0% → 100% | 32319d → none | 1160 → 1390 | baseline start 2025-02-05 → 2025-01-14; baseline finish 2025-02-05 → 2025-01-14 |
| 1392 | SITWG update on execution model | 2025-02-12 → 2025-01-21 A (-22d) | 2025-02-12 → 2025-01-21 A (-22d) |  | 0% → 100% | 32319d → none |  | baseline start 2025-02-12 → 2025-01-21; baseline finish 2025-02-12 → 2025-01-21 |
| 1393 | **Theme 1, 2 and 3 (Batch 2)** |  |  | 23d → 23d? | 0% → 100% |  |  |  |
| 1394 | Develop execution model Theme 1, 2 and 3 (Batch 2) | 2025-01-13 → 2025-02-03 A (+21d) | 2025-01-15 → 2025-02-14 A (+30d) | 3d → 10d | 0% → 100% | 32319d → none |  | constraint start no earlier than 2025-01-13 → start no earlier than 2025-02-03; baseline start 2025-01-13 → 2025-02-03; baseline finish 2025-01-15 → 2025-02-14 |
| 1395 | SRO provide feedback | 2025-01-16 → 2025-02-25 A (+40d) | 2025-01-22 → 2025-03-03 A (+40d) |  | 0% → 100% | 32319d → none |  | constraint none → finish no earlier than 2025-01-21; baseline start 2025-01-16 → 2025-02-17; baseline finish 2025-01-22 → 2025-02-21 |
| 1396 | Address SRO feedback on execution model | 2025-01-23 → 2025-03-04 A (+40d) | 2025-01-24 → 2025-03-10 A (+45d) | 2d → 5d | 0% → 100% | 32319d → none |  | baseline start 2025-01-23 → 2025-02-17; baseline finish 2025-01-24 → 2025-02-21 |
| 1397 | Finalise execution model | 2025-01-27 → 2025-03-11 A (+43d) | 2025-01-29 → 2025-03-17 A (+47d) | 3d → 5d | 0% → 100% | 32319d → none |  | baseline start 2025-01-27 → 2025-02-24; baseline finish 2025-01-29 → 2025-02-27 |
| 1399 | **SIT Operational Theme 3 (Batch 1) progress reporting** |  |  |  | 17% → 100% |  |  |  |
| 1401 | Implement reporting | 2024-12-23 A | 2025-01-03 → 2025-01-24 A (+21d) | 10d → 25d | 0% → 100% | 32347d → none |  |  |
| 1402 | **SIT Operational Overarching Test Readiness Reports** | 2024-08-05 A → 2024-08-05 |  |  | 2% → 100% |  |  |  |
| 1403 | **SI SIT Operational Theme 3 (Batch 1) Overarching Test Readiness Report** | 2024-12-23 → 2024-12-18 A (-5d) | 2025-01-29 A | 28d → 31d? | 0% → 100% | 32328d → none |  |  |
| 1404 | Develop Overarching SIT Operational Theme 3 (Batch 1) Overarching Test Readiness Report | 2024-12-23 → 2024-12-18 A (-5d) | 2025-01-15 → 2025-01-14 A (-1d) | 18d → 20d | 0% → 100% | 32328d → none | 429 → 429FF | constraint none → finish no earlier than 2025-01-14; baseline start 2024-12-23 → 2024-12-18; baseline finish 2025-01-15 → 2025-01-14 |
| 1405 | SRO review | 2025-01-16 → 2025-01-08 A (-8d) | 2025-01-22 → 2025-01-14 A (-8d) |  | 0% → 100% | 32328d → none | 1404 → 1404FF | constraint none → finish no earlier than 2025-01-13; baseline start 2025-01-16 → 2025-01-08; baseline finish 2025-01-22 → 2025-01-14 |
| 1408 | Update Operational Theme 3 (Batch 1) Overarching Test Readiness Report following SRO / SITWG feedback | 2025-01-16 → 2025-01-22 A (+6d) | 2025-01-22 A | 5d → 1d | 0% → 100% | 32328d → none | 1405FF, 1315FF → 1407 | was named Update Operational Theme 3 (Batch 1) Overarching Test Readiness Report following SRO feedback; constraint none → start no earlier than 2025-01-22; baseline start 2025-01-16 → 2025-01-22 |
| 1409 | SITAG paper day | 2025-01-22 A | 2025-01-22 A |  | 0% → 100% | 32328d → none |  | constraint none → finish no earlier than 2025-01-22 |
| 1412 | SITAG approve Theme 3 (Batch 1) Test Readiness Report | 2025-01-29 A | 2025-01-29 A |  | 0% → 100% | 32328d → none | 1409FS+5d → 1409FS+5d, 1251, 1411 | was named SITAG approve Theme 3 (Batch 1) Theme 1 Test Readiness Report; constraint none → finish no earlier than 2025-01-29 |
| 1413 | **SI SIT Operational Theme 1, 2 and 3 (Batch 2) Overarching Test Readiness Report** | 2025-01-27 A | 2025-03-28 A |  | 0% → 100% | 31603d → none |  |  |
| 1414 | Develop Overarching SIT Operational Theme 1, 2 and 3 (Batch 2) Overarching Test Readiness Report | 2025-01-27 A | 2025-02-21 A |  | 0% → 100% | 31610d → none |  |  |
| 1415 | SRO review | 2025-02-24 A | 2025-02-28 A |  | 0% → 100% | 31610d → none |  |  |
| 1418 | Update Operational Theme 1, 2 and 3 (Batch 2) Overarching Test Readiness Report following SRO feedback | 2025-03-03 → 2025-03-07 A (+4d) | 2025-03-12 → 2025-03-25 A (+13d) | 8d → 13d | 0% → 100% | 31610d → none | 1415 → 1417 | constraint none → start no earlier than 2025-03-07; baseline start 2025-03-03 → 2025-03-07; baseline finish 2025-03-12 → 2025-03-25 |
| 1421 | eSITAG approve Operational Theme 1, 2 and 3 (Batch 2) Overarching Test Readiness Report | 2025-03-28 A | 2025-03-28 A |  | 0% → 100% | 31603d → none | SITAG endorse Operational Theme 1, 2 and 3 (Batch 2) Overarching Test Readiness Report, Operational Themes 1, 2 & 3 (Batch 2) (LDSO's and DCC) Data Load, 1430 → 1419, 1429, 1430 |  |
| 1422 | SIT Operational Theme 3 (Batch 1) Testing Preparation Complete | 2025-01-30 → 2025-01-31 A (+1d) | 2025-01-30 → 2025-01-31 A (+1d) |  | 0% → 100% | 32328d → none | 1412FS+1d, 1315 → 1412, 1315 | baseline start 2025-01-17 → 2025-01-31; baseline finish 2025-01-17 → 2025-01-31 |

| ID | Task | Start | Finish | Duration | Complete | Total float | Predecessors | Other |
| --- | --- | --- | --- | --- | --- | --- | --- | --- |
| 1423 | SIT Operational Theme 1, 2, 3 (Batch 2) Testing Preparation Complete | 2025-03-28 A | 2025-03-28 A |  | 0% → 100% | 31604d → none | 430, 1211, 1217, 1343, 1421 → 430, 1211, 1217, 1343, 1421, 1401, 1381, 1353 |  |
| 1424 | **Test Data - Non-Functional and Operational (SIT B)** | 2025-02-24 A | 2025-03-28 A |  | 0% → 100% | 31603d → none |  |  |
| 1425 | **Data Load** | 2025-02-24 A | 2025-03-28 A |  | 0% → 100% | 31603d → none |  |  |
| 1426 | Non-Functional Theme 1 (Avenade) Data Load | 2025-02-24 A | 2025-02-28 A |  | 0% → 100% | 31603d → none |  |  |
| 1427 | Non-Functional Theme 2 & 3 (Helix, Avenade & PPs) Data Load | 2025-03-24 A | 2025-03-28 A |  | 0% → 100% | 31633d → none | 1689FS+1d → 1689 |  |
| 1430 | Operational Themes 1, 2 & 3 (Batch 2) (Helix, Avenade & PPs) Data Load | 2025-03-24 A | 2025-03-28 A |  | 0% → 100% | 31603d → none | 1689FS+1d → 1689 |  |
| 1431 | Non-Functional and Operational Test Data Preparation Complete | 2025-03-28 A | 2025-03-28 A |  | 0% → 100% | 32287d → none |  |  |
| 1432 | **Regression Test Preparation** |  |  |  | 10% → 90% |  |  | baseline start 2024-09-16 → 2024-11-18; baseline finish 2025-05-16 → 2024-11-19 |
| 1433 | **Regression Test Approach** |  |  |  | 26% → 100% |  |  | baseline start 2024-09-16 → 2024-11-18; baseline finish 2024-11-20 → 2024-11-29 |
| 1434 | Develop approach doc |  | 2024-12-06 A → 2025-01-17 A (+42d) | 15d → 45d |  |  |  | baseline finish 2024-12-13 → 2025-01-17 |
| 1435 | SRO / LDP review of approach doc | 2024-12-09 A → 2025-01-20 A (+42d) | 2024-12-20 → 2025-01-24 A (+35d) | 10d → 5d | 3% → 100% | 31614d → none |  | baseline start 2024-12-16 → 2025-01-20; baseline finish 2024-12-18 → 2025-01-24 |
| 1436 | Incorporate SRO feedback into approach doc | 2024-12-23 → 2025-01-20 A (+28d) | 2025-01-10 → 2025-01-24 A (+14d) | 15d → 5d | 0% → 100% | 31614d → none | 1435 → 1435FF | baseline start 2024-12-19 → 2025-01-20; baseline finish 2024-12-20 → 2025-01-24 |
| 1437 | Industry review of approach | 2025-01-20 → 2025-01-27 A (+7d) | 2025-01-31 → 2025-02-07 A (+7d) |  | 0% → 100% | 31614d → none | 1436FS+5d → 1436 | baseline start 2025-01-20 → 2025-01-27; baseline finish 2025-01-31 → 2025-02-07 |
| 1438 | Updates to approach doc on back of industry feedback | 2025-02-03 → 2025-02-10 A (+7d) | 2025-02-11 A | 7d → 2d | 0% → 100% | 31614d → none |  | baseline start 2025-02-03 → 2025-02-10 |
| 1439 | eSITWG paper day | 2025-02-11 A | 2025-02-11 A |  | 0% → 100% | 31614d → none |  | baseline start 2024-12-20 → 2025-02-11; baseline finish 2024-12-20 → 2025-02-11 |
| 1440 | eSITWG Recommendation | 2025-02-18 A | 2025-02-18 A |  | 0% → 100% | 32308d → none |  | baseline start 2025-01-08 → 2025-02-18; baseline finish 2025-01-08 → 2025-02-18 |
| 1441 | Incorporate eSITWG feedback into approach doc | 2025-02-19 A | 2025-02-20 A |  | 0% → 100% | 32308d → none |  | baseline start 2025-01-09 → 2025-02-19; baseline finish 2025-01-09 → 2025-02-20 |
| 1442 | eSITAG paper day | 2025-02-20 A | 2025-02-20 A |  | 0% → 100% | 32308d → none |  | baseline start 2025-01-09 → 2025-02-20; baseline finish 2025-01-09 → 2025-02-20 |
| 1443 | eSITAG (inc SRO) Approval | 2025-02-27 → 2025-02-28 A (+1d) | 2025-02-27 → 2025-02-28 A (+1d) |  | 0% → 100% | 32308d → none |  | constraint none → finish no earlier than 2025-02-28; baseline start 2025-01-16 → 2025-02-28; baseline finish 2025-01-16 → 2025-02-28 |
| 1444 | SIT Regression Testing Approach and Plan Approval | 2025-02-27 → 2025-02-28 A (+1d) | 2025-02-27 → 2025-02-28 A (+1d) |  | 0% → 100% | 32308d → none |  | baseline start 2025-01-16 → 2025-02-28; baseline finish 2025-01-16 → 2025-02-28 |
| 1445 | **Regression Core Test Pack** | 2025-02-12 A | 2025-05-01 → 2025-04-24 (-7d) | 57d → 52d? | 0% → 99% | 31614d → 7d |  | was named Regression Test Suite; baseline start 2025-01-17 → 2025-02-12; baseline finish 2025-03-18 → 2025-04-16 |
| 1447 | Build Regression Framework | 2025-02-12 A | 2025-03-14 → 2025-02-27 A (-15d) | 23d → 12d | 0% → 100% | 31614d → none |  | was named Build Regression Test Suite; baseline start 2025-01-17 → 2025-02-12; baseline finish 2025-02-06 → 2025-02-28 |
| 1448 | SITWG paper day | 2025-02-05 → 2025-02-27 A (+22d) | 2025-02-05 → 2025-02-27 A (+22d) |  | 0% → 100% | 32319d → none | 1167 → 1447 | constraint none → start no earlier than 2025-02-27; baseline start 2025-02-05 → 2025-02-27; baseline finish 2025-02-05 → 2025-02-27 |
| 1450 | LDP walkthrough of Regression Core Pack | 2025-03-17 → 2025-02-27 A (-18d) | 2025-03-18 → 2025-03-03 A (-15d) | 2d → 3d | 0% → 100% | 31614d → none | 1447 → 1446SS | was named LDP review of Regression Test Suite; constraint none → start no earlier than 2025-02-27; baseline start 2025-03-17 → 2025-02-28; baseline finish 2025-03-18 → 2025-02-28 |
| 1451 | SRO Review of Regression Core Pack | 2025-03-19 → 2025-03-07 A (-12d) | 2025-03-25 → 2025-03-14 A (-11d) | 5d → 6d | 0% → 100% | 31614d → none | 1450 → 1446SS | was named SRO Review of regression suite doc; constraint none → start no earlier than 2025-03-07; baseline start 2025-02-07 → 2025-03-03; baseline finish 2025-02-20 → 2025-03-07 |
| 1452 | Incorporate SRO feedback into Regression Core Pack | 2025-03-26 → 2025-03-07 A (-19d) | 2025-03-28 → 2025-03-14 A (-14d) | 3d → 6d | 0% → 100% | 31614d → none | 1451 → 1451SS | was named Incorporate SRO feedback into regression suite doc; baseline start 2025-02-21 → 2025-03-03; baseline finish 2025-02-27 → 2025-03-07 |
| 1453 | Industry review of Regression Core Pack | 2025-03-31 → 2025-03-17 A (-14d) | 2025-04-11 → 2025-03-28 A (-14d) |  | 0% → 100% | 31614d → none | 1452 → 1452, 1446 | was named Industry review of Regression Test Suite; constraint none → start no earlier than 2025-03-13; baseline start 2025-03-31 → 2025-03-17; baseline finish 2025-04-11 → 2025-03-28 |
| 1456 | Incorporate Industry feedback into Regression Core Pack | 2025-04-14 → 2025-03-31 A (-14d) | 2025-04-16 → 2025-04-02 A (-14d) |  | 0% → 100% | 31614d → none | 1453 → 1453, 1454, 1455 | was named Incorporate Industry feedback into regression suite doc; baseline start 2025-04-14 → 2025-03-31; baseline finish 2025-04-16 → 2025-04-02 |
| 1458 | Incorporate industry feedback into regression Core Pack | 2025-04-24 → 2025-04-10 A (-14d) | 2025-04-24 → 2025-04-10 A (-14d) |  | 0% → 100% | 31614d → none | eSITWG endorses regression suite doc → 1457 | was named Incorporate SITWG feedback into regression suite doc; baseline start 2025-03-07 → 2025-04-10; baseline finish 2025-03-11 → 2025-04-10 |
| 1459 | SITWG paper day | 2025-01-14 → 2025-04-08 A (+84d) | 2025-01-14 → 2025-04-08 A (+84d) |  | 0% → 100% | 32335d → none | 1390 → none | constraint none → finish no earlier than 2025-04-08; baseline start 2025-01-14 → 2025-04-10; baseline finish 2025-01-14 → 2025-04-10 |
| 1464 | SITAG paper day | 2025-03-12 → 2025-04-17 A (+36d) | 2025-03-12 → 2025-04-17 A (+36d) |  | 0% → 100% | 32294d → none | 1188 → none | constraint none → finish no earlier than 2025-04-17; baseline start 2025-03-12 → 2025-04-17; baseline finish 2025-03-12 → 2025-04-17 |
| 1465 | SITAG (inc SRO) Approval of regression Core Pack | 2025-05-01 → 2025-04-24 (-7d) | 2025-05-01 → 2025-04-24 (-7d) |  |  | 32263d → 7d | 1181FS+5d → 1464FS+5d, 1463 | was named eSITAG (inc SRO) Approval of regression suite doc; constraint none → start no earlier than 2025-04-24; baseline start 2025-03-18 → 2025-04-24; baseline finish 2025-03-18 → 2025-04-24 |
| 1466 | SIT Regression Approval | 2025-05-01 → 2025-04-24 (-7d) | 2025-05-01 → 2025-04-24 (-7d) |  |  | 32263d → 7d |  | baseline start 2025-03-18 → 2025-04-24; baseline finish 2025-03-18 → 2025-04-24 |
| 1467 | **Regression Test Data Load Window (SIT Functional and Migration) - SIT A** |  |  |  | 0% → 50% |  |  |  |
| 1468 | Data Load preparation activities | 2025-03-05 → 2025-03-31 A (+26d) | 2025-04-15 → 2025-04-25 (+10d) | 30d? → 20d | 0% → 85% | 36d → 6d | none → 1427 | constraint start no earlier than 2025-03-05 → start no earlier than 2025-03-17; baseline start 2025-03-05 → 2025-03-31; baseline finish 2025-04-15 → 2025-04-25 |
| 1469 | Regression Test Data Load Start |  |  | 0d? → 0d |  | 27d → 5d | 1667, 1563FS+1d, 1671FS+1d, 1468 → 1667, 1563FS+1d, 1671FS+1d, 1468, 1466 |  |
| 1471 | **Single Instance ADO** |  | 2024-10-03 A |  | 98% → 100% | 32413d → none |  |  |
| 1491 | **Reporting Changes - PowerBI & QIP** |  | 2024-09-24 A |  | 70% → 100% | 32420d → none |  |  |
| 1520 | **SIT Execution** | 2022-10-31 A → 2023-10-30 A (+364d) | 2148-12-31 → 2025-11-26 (-44960d) | 32917d? → 543d? | 18% → 57% | 0d → 541d |  |  |
| 1522 | **SIT Component Integration Testing** |  | 2148-12-31 → 2024-03-11 A (-45585d) | 32657d → 96d | 8% → 100% | 0d → none |  |  |
| 1531 | SIT Component Integration Testing End (incl. confirmation that PPs have submitted their Test Completion Reports to Programme for assurance) |  | 2148-12-31 → 2024-02-23 A (-45602d) | 1566d → 0d | 0% → 100% | 0d → none |  | constraint none → finish no earlier than 2024-02-23 |
| 1537 | **SIT - Minimum Viable Cohort (MVC)** | 2022-10-31 A → 2024-03-11 A (+497d) |  | 735d? → 380d? | 31% → 61% | 32182d → 609d |  |  |
| 1538 | **SIT Functional Testing (MVC)** | 2022-10-31 A → 2024-03-11 A (+497d) |  | 730d? → 375d? | 44% → 71% | 32187d → 614d |  |  |
| 1540 | **SIT Functional Testing Execution (Minimum Viable Cohort)** | 2022-10-31 A → 2024-03-11 A (+497d) | 2025-08-15 → 2025-04-28 A (-109d) | 730d? → 296d? | 44% → 100% | 32187d → none |  |  |
| 1547 | **SIT Functional Testing back-up progress risk-assessment** | 2022-10-31 → 2024-10-07 A (+707d) | 2022-10-31 → 2024-10-15 A (+715d) | 0d → 7d? | 0% → 100% | 32917d → none |  |  |
| 1548 | Back-up risk-assessment of SIT Functional progress to assess whether Qualification Execution can start early | 2024-10-07 A | 2024-10-25 → 2024-10-07 A (-18d) | 15d → 1d? | 0% → 100% | 32392d → none |  | baseline finish 2024-10-25 → 2024-10-07 |
| 1549 | Back-up SITAG decision on early Qualification Testing Execution start | 2024-11-01 → 2024-10-15 A (-17d) | 2024-11-01 → 2024-10-15 A (-17d) | 0d → 1d? | 0% → 100% | 32392d → none |  | baseline start 2024-11-01 → 2024-10-15; baseline finish 2024-11-01 → 2024-10-15 |
| 1550 | **Cycle 3 (Defect retests and targeted regression testing)** |  |  |  | 28% → 100% |  |  |  |
| 1554 | Sprint 8 |  | 2024-12-20 A |  | 50% → 100% | 27d → none |  |  |
| 1555 | Christmas downtime | 2024-12-23 A | 2025-01-03 A |  | 0% → 100% | 27d → none |  |  |
| 1556 | Sprint 9 | 2025-01-06 A | 2025-01-17 A |  | 0% → 100% | 27d → none |  |  |
| 1557 | Sprint 10 | 2025-01-20 A | 2025-01-31 A |  | 0% → 100% | 27d → none |  |  |
| 1558 | Sprint 11 | 2025-02-03 A | 2025-02-14 A |  | 0% → 100% | 27d → none |  |  |
| 1559 | Sprint 12 | 2025-02-17 A | 2025-02-28 A |  | 0% → 100% | 27d → none |  |  |
| 1560 | Sprint 13 (RTTM Gap Analysis + CR056) | 2025-03-03 A | 2025-03-14 A |  | 0% → 100% | 27d → none |  |  |
| 1561 | Sprint 14 (RTTM Gap Analysis + CR056) | 2025-03-17 A | 2025-03-28 A |  | 0% → 100% | 27d → none |  |  |
| 1562 | Sprint 15 (Contingency 1) | 2025-03-31 A | 2025-04-11 A |  | 0% → 100% | 27d → none |  |  |
| 1563 | Sprint 16 (Contingency 2) | 2025-04-14 A | 2025-04-25 A |  | 0% → 100% | 27d → none |  |  |
| 1564 | SIT Functional Cycle 3 Complete | 2025-04-28 A | 2025-04-28 A |  | 0% → 100% | 32266d → none |  | baseline start none → 2025-04-28; baseline finish none → 2025-04-28 |
| 1571 | SITWG paper day | 2025-02-05 → 2025-04-08 A (+62d) | 2025-02-05 → 2025-04-08 A (+62d) |  | 0% → 100% | 32319d → none | 1397FS+5d → 1569FS+35d | constraint none → start no earlier than 2025-04-08; baseline start 2025-02-05 → 2025-04-08; baseline finish 2025-02-05 → 2025-04-08 |
| 1574 | SITAG paper day | 2025-03-12 → 2025-04-17 A (+36d) | 2025-03-12 → 2025-04-17 A (+36d) |  | 0% → 100% | 31610d → none | 1418 → 1572FS+2d, 1573 | baseline start 2025-03-12 → 2025-04-17; baseline finish 2025-03-12 → 2025-04-17 |
| 1577 | **SIT Functional Settlement Testing** |  |  |  | 30% → 36% |  |  |  |
| 1578 | SIT-B Settlement Testing Cycle 2 | 2025-03-10 A |  |  | 0% → 5% | 32232d → 659d |  | baseline start 2024-06-17 → 2025-03-10; baseline finish 2024-09-20 → 2025-06-13 |
| 1579 | **SIT-B Settlement Testing Cycle 3** |  | 2025-02-21 A |  | 58% → 100% | 32237d → none | 1222 → none |  |
| 1580 | Sprint 5 |  |  |  |  |  | none → 1222 |  |
| 1587 | Post-Christmas Stabilisation | 2025-01-06 A | 2025-01-10 A |  | 0% → 100% | 32267d → none |  |  |
| 1588 | Sprint 9 | 2025-01-06 A | 2025-01-17 A |  | 0% → 100% | 31603d → none |  |  |
| 1589 | Sprint 9 Review | 2025-01-20 A | 2025-01-20 A |  | 0% → 100% | 32261d → none |  |  |
| 1590 | Sprint 10 | 2025-01-20 A | 2025-01-31 A |  | 0% → 100% | 31603d → none |  |  |
| 1591 | Sprint 10 Review | 2025-02-03 A | 2025-02-03 A |  | 0% → 100% | 32251d → none |  |  |

| ID | Task | Start | Finish | Duration | Complete | Total float | Predecessors | Other |
| --- | --- | --- | --- | --- | --- | --- | --- | --- |
| 1592 | Sprint 11 | 2025-02-03 A | 2025-02-14 A |  | 0% → 100% | 31603d → none |  |  |
| 1593 | Sprint 11 Review | 2025-02-14 A | 2025-02-14 A |  | 0% → 100% | 31603d → none |  |  |
| 1594 | Sprint 12 | 2025-02-17 A | 2025-02-21 A |  | 0% → 100% | 31603d → none |  |  |
| 1595 | End of Settlement Testing Cycle 3 | 2025-02-21 A | 2025-02-21 A |  | 0% → 100% | 31603d → none |  |  |
| 1596 | **SIT-A Settlement Testing** |  | 2025-06-13 → 2025-06-16 (+3d) | 20d? → 20d |  | 27d → 5d | 1470 → none | was named SIT-A CoS Settlement Testing |
| 1602 | Regression Test Execution Start |  |  | 1d → 0d |  | 32231d → 5d | 1470, 1596 → 1470FS+2d, 1600FS+2d |  |
| 1604 | Regression Sprint 1 | 2025-06-16 → 2025-06-23 (+7d) | 2025-06-27 → 2025-07-04 (+7d) |  |  | 31578d → 5d | 1596, 1181 → 1603 | baseline start 2025-06-16 → 2025-06-23; baseline finish 2025-06-27 → 2025-07-04 |
| 1605 | Regression Sprint 2 | 2025-06-30 → 2025-07-07 (+7d) |  | 15d → 10d |  | 31578d → 5d |  | baseline start 2025-06-30 → 2025-07-07 |
| 1606 | Regression Sprint 3 |  | 2025-08-08 → 2025-08-01 (-7d) | 15d → 10d |  | 31578d → 5d |  | baseline finish 2025-08-08 → 2025-08-01 |
| 1608 | SIT Functional Testing End (Minimum Viable Cohort) (incl. confirmation that PPs have submitted their Test Completion Reports to Programme for assurance) |  |  |  |  | 31578d → 5d | 1606 → 1607 |  |
| 1611 | Develop document |  |  |  |  | 31578d → 5d |  | constraint none → start no earlier than 2025-07-21 |
| 1614 | **Helix E2E Settlement Assurance Testing (SAT)** | 2025-02-07 → 2024-08-19 A (-172d) | 2025-06-06 → 2025-07-03 (+27d) | 86d? → 229d? | 0% → 60% | 32237d → 645d |  | was named Helix E2E Settlement Testing |
| 1646 | **SIT Migration Testing (MVC)** |  |  |  | 49% → 77% | 32182d → 609d |  |  |
| 1647 | SIT Migration Testing Start | 2024-03-11 A | 2024-03-11 A |  | 0% → 100% | 32562d → none |  |  |
| 1648 | **SIT Migration Testing Execution (Minimum Viable Cohort)** |  |  |  | 49% → 77% | 32182d → 609d |  |  |
| 1655 | **SIT Migration Testing back-up progress risk-assessment** |  |  |  | 0% → 100% |  |  | was named SIT Functional Testing back-up progress risk-assessment |
| 1656 | Back-up risk-assessment of SIT Migration progress to assess whether Qualification Execution can start early | 2024-10-07 A | 2024-10-25 A |  | 0% → 100% | 32392d → none |  |  |
| 1657 | Back-up SITAG decision on early Qualification Testing Execution start | 2024-11-01 A | 2024-11-01 A |  | 0% → 100% | 32392d → none |  |  |
| 1658 | **Cycle 3 (Defect retests and targeted regression testing)** |  | 2025-04-25 A |  | 28% → 100% | 32267d → none |  |  |
| 1662 | Sprint 8 |  | 2024-12-20 A |  | 50% → 100% | 27d → none |  |  |
| 1663 | Christmas downtime | 2024-12-23 A | 2025-01-03 A |  | 0% → 100% | 27d → none |  |  |
| 1664 | Sprint 9 | 2025-01-06 A | 2025-01-17 A |  | 0% → 100% | 27d → none |  |  |
| 1665 | Sprint 10 | 2025-01-20 A | 2025-01-31 A |  | 0% → 100% | 27d → none |  |  |
| 1666 | Sprint 11 | 2025-02-03 A | 2025-02-14 A |  | 0% → 100% | 27d → none |  |  |
| 1667 | Sprint 12 | 2025-02-17 A | 2025-02-28 A |  | 0% → 100% | 27d → none |  |  |
| 1668 | Sprint 13 | 2025-03-03 A | 2025-03-14 A |  | 0% → 100% | 27d → none |  |  |
| 1669 | Sprint 14 (RTTM Gap Analysis + CR056) | 2025-03-17 A | 2025-03-28 A |  | 0% → 100% | 27d → none |  |  |
| 1670 | Sprint 15 (Contingency 1) | 2025-03-31 A | 2025-04-11 A |  | 0% → 100% | 27d → none |  |  |
| 1671 | Sprint 16 (Contingency 2) | 2025-04-14 A | 2025-04-25 A |  | 0% → 100% | 27d → none |  |  |
| 1672 | SIT Migration Cycle 3 Complete | 2025-04-25 A | 2025-04-25 A |  | 0% → 100% | 32267d → none |  |  |
| 1673 | **SIT Migration MVC Regression Testing (code freeze)** |  | 2025-08-01 → 2025-08-08 (+7d) | 35d? → 40d? |  | 32182d → 614d |  |  |
| 1676 | Regression Sprint 1 | 2025-06-16 → 2025-06-23 (+7d) | 2025-06-27 → 2025-07-04 (+7d) | 10d? → 10d |  | 32182d → 614d | 1596 → 1675 | baseline start 2025-06-16 → 2025-06-23; baseline finish 2025-06-27 → 2025-07-04 |
| 1677 | Regression Sprint 2 | 2025-06-30 → 2025-07-07 (+7d) | 2025-07-11 → 2025-07-18 (+7d) |  |  | 32182d → 614d |  | baseline start 2025-06-30 → 2025-07-07; baseline finish 2025-07-11 → 2025-07-18 |
| 1678 | Regression Sprint 3 | 2025-07-14 → 2025-07-21 (+7d) |  | 15d? → 10d |  | 32182d → 619d |  | baseline start 2025-07-14 → 2025-07-21 |
| 1680 | SIT Migration Testing End (Minimum Viable Cohort) (incl. confirmation that PPs have submitted their Test Completion Reports to Programme for assurance) | 2025-08-01 → 2025-08-08 (+7d) | 2025-08-01 → 2025-08-08 (+7d) |  |  | 32182d → 619d | 1678 → 1679 | baseline start 2025-08-01 → 2025-08-08; baseline finish 2025-08-01 → 2025-08-08 |
| 1682 | Develop document |  |  |  |  | 32182d → 609d | 1680FF → 1677SS | constraint none → start no earlier than 2025-07-14 |
| 1687 | **SIT Non-Functional Testing (all SIT PPs)** | 2025-02-28 → 2025-03-03 A (+3d) |  | 71d? → 70d? | 0% → 37% | 31603d → 60d |  |  |
| 1688 | Theme 1 (Helix and DIP Volume Testing) Start | 2025-02-28 → 2025-03-03 A (+3d) | 2025-02-28 → 2025-03-03 A (+3d) |  | 0% → 100% | 31603d → none | 1426, 1182 → 1182FS+1d, 1426 | baseline start 2025-02-28 → 2025-03-03; baseline finish 2025-02-28 → 2025-03-03 |
| 1689 | Theme 1 (Helix and DIP Volume Testing) Execution | 2025-02-28 → 2025-03-03 A (+3d) | 2025-03-20 → 2025-03-21 A (+1d) |  | 0% → 100% | 31603d → none |  | baseline start 2025-02-28 → 2025-03-03; baseline finish 2025-03-20 → 2025-03-21 |
| 1690 | Theme 2 & 3 SIT Non-Functional Testing Start | 2025-03-31 A | 2025-03-31 A |  | 0% → 100% | 31672d → none | 1172, 1545, 1106, 1110, 1117, 1123, 1129, Non-Functional Themes 2 & 3 (LDSO's and DCC) Data Load, 1595, 1191FS+1d → 1545, 1106, 1110, 1117, 1123, 1129, 1595, 1191FS+2d, 1428, 1172 | was named Theme 2 SIT Non-Functional Testing Start |
| 1691 | Theme 2 & 3 SIT Non-Functional Testing Execution | 2025-03-31 A |  |  | 0% → 50% | 31633d → 60d |  | was named Theme 2 SIT Non-Functional Testing Execution; baseline start 2025-05-01 → 2025-03-31; baseline finish 2025-06-25 → 2025-05-23 |
| 1692 | SIT Non-Functional Testing End (all SIT PPs) (incl. confirmation that PPs have submitted their Test Completion Reports to Programme for assurance) |  |  |  |  | 31633d → 60d | 1691FF, Theme 3 SIT Non-Functional Testing ExecutionFF → 1691FF |  |
| 1698 | **SIT Operational Testing (all SIT PPs)** | 2025-02-03 A |  |  | 0% → 24% | 31603d → 30d |  |  |
| 1699 | **Non-SIT B Testing** | 2025-02-03 A | 2025-03-07 A |  | 0% → 100% | 31688d → none |  |  |
| 1700 | SIT Operational Testing Start (Theme 3 - Batch 1 (Service Management)) | 2025-02-03 A | 2025-02-03 A |  | 0% → 100% | 31688d → none |  |  |
| 1701 | SIT Operational Testing Execution Window (Theme 3 - Batch 1 (Service Management)) | 2025-02-03 A | 2025-03-07 A |  | 0% → 100% | 31688d → none |  |  |
| 1702 | **SIT B Testing** | 2025-03-31 A |  | 70d? → 70d | 0% → 18% | 31603d → 30d |  |  |
| 1703 | SIT Operational Testing Start (SIT B) | 2025-03-31 A | 2025-03-31 A |  | 0% → 100% | 31603d → none | 1423, 1200, 1204, 1211, 1217, 1343, Operational Themes 1, 2 & 3 (Batch 2) (LDSO's and DCC) Data Load, 1430, 1421FS+1d → 1423, 1200, 1204, 1211, 1217, 1343, 1421FS+1d, 1429, 1430 |  |
| 1704 | SIT Operational Testing Execution Theme 1 | 2025-05-05 → 2025-03-31 A (-35d) | 2025-06-06 → 2025-07-04 (+28d) | 25d? → 70d | 0% → 35% | 31603d → 30d | 1706 → 1703FS-1d | constraint none → finish no earlier than 2025-07-04; baseline start 2025-05-05 → 2025-03-31; baseline finish 2025-06-06 → 2025-07-04 |
| 1705 | SIT Operational Testing Execution Theme 2 | 2025-06-09 → 2025-05-05 (-35d) |  | 20d? → 45d |  | 31603d → 30d | 1704 → 1703 | constraint none → finish no earlier than 2025-07-04; baseline start 2025-06-09 → 2025-05-05 |
| 1706 | SIT Operational Testing Execution Theme 3 Batch 2 | 2025-03-31 → 2025-06-09 (+70d) | 2025-05-02 → 2025-07-04 (+63d) | 25d? → 20d |  | 31603d → 30d | 1703FS-1d, 1329 → 1703 | constraint none → start no earlier than 2025-06-09; baseline start 2025-03-31 → 2025-06-09; baseline finish 2025-05-02 → 2025-07-04 |
| 1707 | SIT Operational Testing End (all SIT PPs) (incl. confirmation that PPs have submitted their Test Completion Reports to Programme for assurance) |  |  |  |  | 31603d → 30d | 1705, 1701 → 1701, 1704, 1705, 1706 |  |
| 1717 | **SIT (non-MVC)** | 2025-06-16 A → 2025-06-13 (-3d) | 2025-11-27 → 2025-11-26 (-1d) |  | 10% → 0% | 31602d → 505d |  |  |
| 1718 | **SIT Functional Testing (non-MVC)** | 2025-06-16 → 2025-06-13 (-3d) | 2025-11-14 → 2025-11-13 (-1d) |  |  | 31602d → 505d |  |  |
| 1719 | **SIT Functional Testing Execution (non-MVC)** | 2025-06-16 → 2025-06-13 (-3d) | 2025-10-24 → 2025-10-23 (-1d) |  |  | 31602d → 505d |  |  |
| 1720 | Test Execution (Cycle 3 Completion and Regression Testing) | 2025-06-16 → 2025-06-13 (-3d) | 2025-10-24 → 2025-10-23 (-1d) |  |  | 31602d → 505d | 1596 → 1600 |  |
| 1721 | SIT Functional Testing End (non-MVC) (incl. confirmation that PPs have submitted their Test Completion Reports to Programme for assurance) | 2025-10-24 → 2025-10-23 (-1d) | 2025-10-24 → 2025-10-23 (-1d) |  |  | 31602d → 505d |  |  |
| 1722 | Assurance of PPs Test Completion Reports | 2025-11-03 → 2025-10-31 (-3d) | 2025-11-07 → 2025-11-06 (-1d) |  |  | 31602d → 505d |  |  |
| 1723 | **SIT Functional Testing Test Completion Report (non-MVC)** | 2025-10-06 → 2025-10-03 (-3d) | 2025-11-07 → 2025-11-06 (-1d) |  |  | 31602d → 505d |  |  |
| 1724 | Develop document | 2025-10-06 → 2025-10-03 (-3d) | 2025-10-24 → 2025-10-23 (-1d) |  |  | 31607d → 510d |  |  |
| 1725 | Review & agree document | 2025-11-03 → 2025-10-31 (-3d) | 2025-11-07 → 2025-11-06 (-1d) |  |  | 31602d → 505d |  |  |
| 1726 | SIT Functional Testing Test Completion Report (non-MVC) Approved | 2025-11-14 → 2025-11-13 (-1d) | 2025-11-14 → 2025-11-13 (-1d) |  |  | 31602d → 505d |  |  |
| 1727 | **SIT Migration Testing (non-MVC)** | 2025-06-16 A → 2025-06-13 (-3d) | 2025-11-14 → 2025-11-13 (-1d) |  | 23% → 0% | 31602d → 505d |  |  |
| 1728 | Test Execution (Cycle 3 Completion and Regression Testing) | 2025-06-16 A → 2025-06-13 (-3d) | 2025-10-24 → 2025-10-23 (-1d) |  | 28% → 0% | 31602d → 505d | 1596 → 1600 |  |
| 1729 | SIT Migration Testing End (non-MVC) (incl. confirmation that PPs have submitted their Test Completion Reports to Programme for assurance) | 2025-10-24 → 2025-10-23 (-1d) | 2025-10-24 → 2025-10-23 (-1d) |  |  | 31602d → 505d |  |  |
| 1730 | Assurance of PPs Test Completion Reports | 2025-11-03 → 2025-10-31 (-3d) | 2025-11-07 → 2025-11-06 (-1d) |  |  | 31602d → 505d |  |  |
| 1731 | **SIT Migration Testing Test Completion Report (non-MVC)** | 2025-10-06 → 2025-10-03 (-3d) | 2025-11-07 → 2025-11-06 (-1d) |  |  | 31602d → 505d |  |  |
| 1732 | Develop document | 2025-10-06 → 2025-10-03 (-3d) | 2025-10-24 → 2025-10-23 (-1d) |  |  | 31607d → 510d |  |  |
| 1733 | Review & agree document | 2025-11-03 → 2025-10-31 (-3d) | 2025-11-07 → 2025-11-06 (-1d) |  |  | 31602d → 505d |  |  |
| 1734 | SIT Migration Testing Test Completion Report (non-MVC Approved) | 2025-11-14 → 2025-11-13 (-1d) | 2025-11-14 → 2025-11-13 (-1d) |  |  | 31602d → 505d |  |  |

| ID | Task | Start | Finish | Duration | Complete | Total float | Predecessors | Other |
| --- | --- | --- | --- | --- | --- | --- | --- | --- |
| 1735 | **SIT non-MVC Test Exit Report** | 2025-10-27 → 2025-10-24 (-3d) | 2025-11-21 → 2025-11-20 (-1d) |  |  | 31602d → 505d |  |  |
| 1736 | Develop document | 2025-10-27 → 2025-10-24 (-3d) | 2025-11-14 → 2025-11-13 (-1d) |  |  | 31602d → 505d |  |  |
| 1737 | Review & agree document | 2025-11-17 → 2025-11-14 (-3d) | 2025-11-21 → 2025-11-20 (-1d) |  |  | 31602d → 505d |  |  |
| 1738 | SIT non-MVC Complete | 2025-11-27 → 2025-11-26 (-1d) | 2025-11-27 → 2025-11-26 (-1d) |  |  | 31602d → 505d |  |  |
| 1739 | **UIT Environment Preparation** |  | 2025-07-04 → 2025-06-06 (-28d) | 700d? → 680d? | 48% → 52% | 32217d → 664d |  |  |
| 1740 | **Test Artefact Development** |  | 2025-04-16 → 2025-04-17 (+1d) | 556d? → 557d? | 51% → 74% | 32274d → 700d |  |  |
| 1741 | **E2E Sandbox Guidance** |  | 2025-03-24 → 2025-04-17 (+24d) | 539d? → 557d? | 71% → 96% | 32291d → 700d |  |  |
| 1745 | Update E2E Sandbox guidance to reflect CR055 | 2025-01-13 A | 2025-02-20 → 2025-03-14 A (+22d) | 29d → 45d | 0% → 100% | 32291d → none |  | was named Update E2E Sandbox guidance to reflect CR55; constraint start no earlier than 2025-01-13 → finish no earlier than 2025-03-14; baseline finish 2025-02-20 → 2025-03-14 |
| 1746 | Internal SI review | 2025-02-21 → 2025-03-17 A (+24d) | 2025-02-27 → 2025-03-21 A (+22d) |  | 0% → 100% | 32291d → none |  | constraint none → start no earlier than 2025-03-17; baseline start 2025-02-21 → 2025-03-17; baseline finish 2025-02-27 → 2025-03-21 |
| 1747 | SRO / Code Bodies review | 2025-02-28 → 2025-03-24 A (+24d) | 2025-03-06 → 2025-03-28 (+22d) |  | 0% → 40% | 32291d → 713d |  | constraint none → finish no earlier than 2025-03-28; baseline start 2025-02-28 → 2025-03-24; baseline finish 2025-03-06 → 2025-03-28 |
| 1748 | Submit version to QWG | 2025-03-07 → 2025-04-01 (+25d) | 2025-03-11 → 2025-04-01 (+21d) | 3d → 0d |  | 32291d → 711d |  | constraint none → finish no earlier than 2025-04-01; baseline start 2025-03-07 → 2025-04-01; baseline finish 2025-03-11 → 2025-04-01 |
| 1749 | Artefact Recommendation for Approval (via QWG) | 2025-03-11 → 2025-04-08 (+28d) | 2025-03-11 → 2025-04-08 (+28d) |  |  | 32291d → 706d |  | was named Artefact Approval (via QWG); constraint none → finish no earlier than 2025-04-08; baseline start 2025-03-11 → 2025-04-08; baseline finish 2025-03-11 → 2025-04-08 |
| 1750 | Final Document updates post QWG review | 2025-03-13 → 2025-04-09 (+27d) | 2025-03-13 → 2025-04-09 (+27d) |  |  | 32291d → 706d | 1749FS+1d → 1749 | constraint none → start no earlier than 2025-04-09; baseline start 2025-03-13 → 2025-04-09; baseline finish 2025-03-13 → 2025-04-09 |
| 1751 | Submit final version to QAG | 2025-03-17 → 2025-04-10 (+24d) | 2025-03-17 → 2025-04-10 (+24d) |  |  | 32291d → 701d | 1750FS+1d → none | constraint none → finish no earlier than 2025-04-10; baseline start 2025-03-17 → 2025-04-10; baseline finish 2025-03-17 → 2025-04-10 |
| 1752 | E2E Sandbox guidance update approved at QAG | 2025-03-24 → 2025-04-17 (+24d) | 2025-03-24 → 2025-04-17 (+24d) |  |  | 32291d → 700d | 1751FS+4d → 1751FS+3d | was named E2E Sandbox guidance update approved; constraint none → finish no earlier than 2025-04-17; baseline start 2025-03-24 → 2025-04-17; baseline finish 2025-03-24 → 2025-04-17 |
| 1753 | **E2E Sandbox Test Data Approach & Plan** | 2025-01-13 A |  |  | 0% → 23% | 32274d → 701d |  |  |
| 1778 | **Environments (UIT)** |  | 2025-07-04 → 2025-06-06 (-28d) | 700d → 680d | 46% → 50% | 32217d → 664d |  |  |
| 1779 | **Central Party (Avanade) Environments (UIT)** |  | 2024-09-27 A |  | 99% → 100% | 32417d → none |  |  |
| 1784 | Central Party (Avanade) UIT environment Regression Testing | 2024-07-31 A | 2024-07-31 A |  | 0% → 100% | 32459d → none |  |  |
| 1791 | **SI Environments (UIT)** |  | 2025-07-04 → 2024-09-30 (-277d) | 688d → 489d | 71% → 99% | 32217d → 843d |  |  |
| 1827 | **SIT PPs Early Sandbox Testing Execution (SIT-A)** | 2025-08-08 → 2025-07-21 (-18d) |  | 56d → 70d |  | 32137d → 564d |  |  |
| 1828 | SIT PPs E2E Sandbox Testing Start | 2025-08-08 → 2025-07-21 (-18d) | 2025-08-08 → 2025-07-21 (-18d) |  |  | 32192d → 634d | 1822FS+5d, 1606 → 1822FS+5d, 1605 | constraint start no earlier than 2025-02-10 → start no earlier than 2025-07-21; baseline start 2025-08-08 → 2025-08-11; baseline finish 2025-08-08 → 2025-08-11 |
| 1829 | SIT PPs E2E Sandbox Testing Execution | 2025-08-08 → 2025-07-21 (-18d) |  | 56d → 70d |  | 32137d → 564d |  | constraint start no earlier than 2024-11-04 → start no earlier than 2025-07-21; baseline start 2025-02-07 → 2025-08-11; baseline finish 2026-04-24 → 2025-10-24 |
| 1831 | **System Integration Testing - Tier 1 Milestones** | 2025-02-28 → 2024-05-28 A (-276d) |  | 214d? → 411d? | 0% → 99% | 31727d → 521d |  |  |
| 1832 | **M10 Checkpoint 1** | 2025-02-28 → 2025-01-06 A (-53d) | 2025-02-28 → 2025-04-02 A (+33d) | 1d? → 63d? | 0% → 100% | 32307d → none | 1891FS-149d → none | was named M10 Checkpoint |
| 1891 | Central systems ready for migrating MPANs (M10) |  |  |  |  | 31578d → 5d | 1716FS+20d, 3156, 2838FS+2d, 2835, 2853, 2813, 2821 → 1716FS+20d, 3156, 2838FS+2d, 2835, 2853, 2813, 2821, 2820 |  |
| 1903 | **NON SIT LDSO QUALIFICATION** |  | 2025-09-19 → 2025-08-22 (-28d) | 489d? → 469d? | 63% → 92% | 32162d → 609d |  |  |
| 1949 | **Test Data** |  |  |  | 65% → 84% | 32252d → 679d |  |  |
| 1956 | Test Data Loaded |  | 2024-12-06 A |  | 90% → 100% | 32252d → none |  |  |
| 1957 | Test Data Signed Off | 2024-12-06 A | 2024-12-06 A |  | 0% → 100% | 32252d → none |  |  |
| 1958 | Test Execution Data Support | 2024-12-09 A |  |  | 0% → 50% | 32252d → 679d |  |  |
| 1963 | **Pre-Integration Testing** |  | 2025-01-24 → 2025-01-31 (+7d) | 258d → 263d | 78% → 97% | 32332d → 754d |  |  |
| 1967 | PIT Execution (Functional and Migration) |  | 2024-11-29 A |  | 36% → 100% |  |  |  |
| 1968 | PIT Execution (Non-Functional and Operational) |  | 2025-01-24 → 2025-01-31 (+7d) | 90d → 95d | 21% → 85% | 32332d → 754d |  | constraint none → finish no earlier than 2025-01-31; baseline finish 2025-01-24 → 2025-01-31 |
| 1969 | Non-SIT LDSO Participants have submitted functional PIT Test Completion Report & evidence for QT Entry​ | 2024-11-29 A | 2024-11-29 A |  | 0% → 100% | 32372d → none |  |  |
| 1970 | Non-SIT LDSO Participants have submitted non-functional PIT Test Completion Report | 2025-01-24 → 2025-01-31 (+7d) | 2025-01-24 → 2025-01-31 (+7d) |  |  | 32332d → 754d |  | baseline start 2025-01-27 → 2025-01-31; baseline finish 2025-01-27 → 2025-01-31 |
| 1990 | **Test Readiness** |  | 2024-12-20 A |  | 90% → 100% | 32357d → none |  |  |
| 1993 | LDSO Update Readiness Report & Final Assurance by Programme |  | 2024-12-12 A |  | 95% → 100% | 7d → none |  |  |
| 1994 | Final Test Readiness Report Submitted to MHHS Programme | 2024-12-13 A | 2024-12-13 A |  | 0% → 100% | 32357d → none |  |  |
| 1995 | Final Programme Assurance of LDSO Test Readiness | 2024-12-13 A | 2024-12-20 A |  | 0% → 100% | 7d → none |  |  |
| 1996 | Qualification Testing for Non-SIT LDSOs (Functional, Migration, NFT, Operational) Programme Test Readiness confirmed | 2024-12-20 A | 2024-12-20 A |  | 0% → 100% | 32357d → none |  |  |
| 1997 | Qualification Testing for Non-SIT LDSOs (Functional, Migration, NFT, Operational) Test Readiness Confirmed (Final Test Readiness Review for LDSO) | 2024-12-20 A | 2024-12-20 A |  | 0% → 100% | 7d → none |  |  |
| 1998 | **Test Window** | 2025-01-06 A |  |  | 0% → 87% | 7d → 609d |  |  |
| 1999 | **All Non-SIT LDSOs Qualification Testing** | 2025-01-06 A |  |  | 0% → 95% |  |  |  |
| 2000 | Non-SIT LDSO QT Test Execution Starts | 2025-01-06 A | 2025-01-06 A |  | 0% → 100% | 7d → none |  |  |
| 2001 | LDSO Alpha | 2025-01-06 A |  |  | 0% → 97% |  |  |  |
| 2002 | LDSO Bravo | 2025-01-06 A | 2025-03-27 → 2025-05-05 (+39d) | 59d → 86d | 0% → 99% | 36d → 9d |  | constraint none → finish no earlier than 2025-05-05; baseline finish 2025-03-27 → 2025-05-05 |
| 2003 | LDSO Charlie | 2025-01-06 A |  |  | 0% → 96% |  |  |  |
| 2004 | LDSO Delta | 2025-01-06 A |  |  | 0% → 93% |  |  |  |
| 2005 | LDSO Echo | 2025-01-06 A | 2025-04-10 A |  | 0% → 100% | 26d → none |  |  |
| 2006 | LDSO Foxtrot | 2025-01-20 A | 2025-03-20 → 2025-05-15 (+56d) | 44d → 84d | 0% → 72% | 41d → 1d |  | constraint none → finish no earlier than 2025-05-15; baseline finish 2025-03-20 → 2025-05-15 |
| 2007 | LDSO Golf | 2025-01-06 A | 2025-04-07 → 2025-04-25 A (+18d) | 66d → 80d | 0% → 100% | 29d → none |  | constraint none → finish no earlier than 2025-04-25; baseline finish 2025-04-07 → 2025-04-25 |
| 2008 | LDSO Hotel | 2025-01-06 A | 2025-03-07 → 2025-05-05 A (+59d) | 45d → 86d | 0% → 100% | 50d → none |  | constraint none → finish no earlier than 2025-05-05; baseline finish 2025-03-07 → 2025-05-05 |
| 2009 | LDSO India | 2025-01-06 A |  |  | 0% → 99% |  |  |  |
| 2012 | **Test Result Assurance** | 2025-04-21 → 2025-04-04 A (-17d) | 2025-05-29 → 2025-05-16 (-13d) | 29d → 30d | 0% → 43% | 31622d → 649d |  |  |
| 2013 | Test Reports Reviewed By MHHS & Code Bodies & Finalised | 2025-05-16 → 2025-04-04 A (-42d) | 2025-05-29 → 2025-05-16 (-13d) | 10d → 30d | 0% → 43% | 32223d → 649d | LDSOs Develop & Submit Test Report (QT Test Completion Report) → 2010FF | baseline start 2025-05-16 → 2025-04-04; baseline finish 2025-05-29 → 2025-05-16 |
| 2014 | Non-SIT LDSOs submission deadline for their QT Test Completion Report to MHHS Programme | 2025-05-29 → 2025-05-16 (-13d) | 2025-05-29 → 2025-05-16 (-13d) |  |  | 32223d → 649d |  | baseline start 2025-05-29 → 2025-05-16; baseline finish 2025-05-29 → 2025-05-16 |
| 2015 | **Non-SIT LDSO Qualification Closure** | 2025-08-25 → 2025-05-16 (-101d) | 2025-09-19 → 2025-06-27 (-84d) | 20d → 31d |  | 32162d → 649d |  |  |
| 2016 | Non-SIT LDSO Qualification Learned Captured | 2025-08-25 → 2025-05-16 (-101d) | 2025-09-12 → 2025-05-29 (-106d) | 15d → 10d |  | 32162d → 670d | 2014, 2108 → 2014 | constraint none → start no earlier than 2025-04-16; baseline start 2025-05-30 → 2025-05-16; baseline finish 2025-06-19 → 2025-05-29 |
| 2018 | Non-SIT LDSO Qualification Closure Down | 2025-09-15 → 2025-06-23 (-84d) | 2025-09-19 → 2025-06-27 (-84d) |  |  | 32162d → 649d | 2016 → 2017 | constraint none → finish no earlier than 2025-06-26; baseline start 2025-06-20 → 2025-06-23; baseline finish 2025-06-26 → 2025-06-27 |
| 2019 | **S & A QUALIFICATION** |  |  |  | 51% → 62% | 31808d → 235d |  |  |
| 2020 | **MHHS Qualification - Qualification Deliverables** |  | 2025-08-14 → 2025-10-17 (+64d) | 463d → 509d | 94% → 95% | 32178d → 305d |  |  |
| 2048 | **Qualification Assessment Document** |  | 2025-04-18 → 2025-10-17 (+182d) | 346d → 476d | 85% → 88% | 32262d → 305d |  |  |
| 2067 | **Qualification Assessment Document Portal** |  | 2025-04-18 → 2025-10-17 (+182d) | 315d → 445d | 72% → 78% | 32262d → 305d |  |  |
| 2073 | SIT Participant QAD Application Creation in Portal |  | 2024-12-20 A |  | 60% → 100% | 32347d → none |  |  |
| 2074 | Non-SIT LDSO Participant QAD Application Creation in Portal |  | 2024-12-20 A |  | 60% → 100% | 32346d → none |  |  |
| 2075 | QT Wave 1 Participant QAD Application Creation in Portal | 2025-04-07 → 2025-04-21 A (+14d) | 2025-04-18 → 2025-05-02 (+14d) |  | 0% → 20% | 31579d → 420d | 2071FS+205d → 2071FS+215d | baseline start 2025-04-07 → 2025-04-21; baseline finish 2025-04-18 → 2025-05-02 |
| 2076 | QT Wave 2 Participant QAD Application Creation in Portal | 2024-10-28 → 2025-05-26 (+210d) | 2024-11-08 → 2025-06-06 (+210d) |  |  | 31578d → 386d | 2071FS+90d → 2071FS+240d | baseline start 2024-10-28 → 2025-05-26; baseline finish 2024-11-08 → 2025-06-06 |
| 2077 | QT Wave 3 Participant QAD Application Creation in Portal | 2024-12-30 → 2025-07-28 (+210d) | 2025-01-10 → 2025-08-08 (+210d) |  |  | 31582d → 355d | 2071FS+135d → 2071FS+285d | baseline start 2024-12-30 → 2025-07-28; baseline finish 2025-01-10 → 2025-08-08 |
| 2078 | QT Wave 4 Participant QAD Application Creation in Portal | 2025-02-24 → 2025-10-06 (+224d) | 2025-03-07 → 2025-10-17 (+224d) |  |  | 31573d → 235d | 2071FS+175d → 2071FS+335d | baseline start 2025-02-24 → 2025-10-06; baseline finish 2025-03-07 → 2025-10-17 |

| ID | Task | Start | Finish | Duration | Complete | Total float | Predecessors | Other |
| --- | --- | --- | --- | --- | --- | --- | --- | --- |
| 2081 | **MHHS Qualification - SIT Participants** | 2025-01-06 A | 2025-12-18 → 2025-12-17 (-1d) | 249d → 248d | 0% → 32% | 31633d → 505d |  |  |
| 2082 | Initial QAD Submission Window opens | 2025-01-06 A | 2025-01-06 A |  | 0% → 100% | 32347d → none |  |  |
| 2083 | SIT Participants submit Initial QAD | 2025-01-06 A | 2025-02-14 A |  | 0% → 100% | 31633d → none |  |  |
| 2084 | Code Bodies review Initial QAD | 2025-02-14 A | 2025-04-04 A |  | 0% → 100% | 31633d → none |  |  |
| 2085 | Completion of Code Bodies review of Initial QAD | 2025-04-04 A | 2025-04-04 A |  | 0% → 100% | 31633d → none |  |  |
| 2086 | **MHHS Qualification - SIT MVC Participants** | 2025-04-07 A |  |  | 0% → 14% | 31578d → 5d |  |  |
| 2087 | Final QAD Submission Window (MVC) opens | 2025-04-07 A | 2025-04-07 A |  | 0% → 100% | 31633d → none |  |  |
| 2088 | SIT MVC Participants submit Final QAD (exc Test Reports) | 2025-04-07 A |  |  | 0% → 25% | 31633d → 60d |  |  |
| 2092 | **MHHS Qualification - SIT Non-MVC Participants** |  | 2025-12-18 → 2025-12-17 (-1d) | 154d → 153d |  | 31602d → 505d |  |  |
| 2093 | Final QAD Submission Window (Non-MVC) opens |  |  |  |  | 31711d → 613d |  | constraint none → start no earlier than 2025-04-07 |
| 2096 | QAD Sign Off Deadline (Non-MVC) | 2025-11-28 → 2025-11-27 (-1d) | 2025-11-28 → 2025-11-27 (-1d) |  |  | 31602d → 505d |  |  |
| 2097 | REC Code Manager / BSC PAB Approval of Qualification (Non-MVC) | 2025-12-18 → 2025-12-17 (-1d) | 2025-12-18 → 2025-12-17 (-1d) |  |  | 31602d → 505d |  | baseline start 2025-12-22 → 2025-12-17; baseline finish 2025-12-22 → 2025-12-17 |
| 2098 | **MHHS Qualification - Non-SIT LDSO** | 2025-01-06 A |  |  | 0% → 60% | 31631d → 9d |  |  |
| 2099 | Initial QAD Submission window opens | 2025-01-06 A | 2025-01-06 A |  | 0% → 100% | 32346d → none |  |  |
| 2100 | Non-SIT LDSO Participants submit initial QAD | 2025-01-06 A | 2025-02-14 A |  | 0% → 100% | 31631d → none |  |  |
| 2101 | Non-SIT LDSO QT Participants have submitted their initial QAD | 2025-02-14 A | 2025-02-14 A |  | 0% → 100% | 31631d → none |  |  |
| 2102 | Code Bodies review of Non-SIT LDSO participants Initial QAD | 2025-02-17 A | 2025-04-04 A |  | 0% → 100% | 31631d → none |  |  |
| 2103 | Completion of Code Bodies review of Initial QAD | 2025-04-04 A | 2025-04-04 A |  | 0% → 100% | 31631d → none |  |  |
| 2104 | Final QAD Submission window opens | 2025-04-07 A | 2025-04-07 A |  | 0% → 100% | 31631d → none |  |  |
| 2105 | Non-SIT LDSO Participants submit Final QAD | 2025-04-21 → 2025-04-07 A (-14d) |  | 25d → 35d | 0% → 20% | 31622d → 49d | LDSOs Develop & Submit Test Report (QT Test Completion Report)SS, 2104SS → 2104SS-1d |  |
| 2110 | **MHHS Qualification - Qualification Waves** |  |  |  | 48% → 57% | 31808d → 235d |  |  |
| 2111 | **Qualification Wave Prep** |  | 2026-01-08 → 2026-02-06 (+29d) | 539d? → 560d? | 76% → 94% | 32083d → 489d |  |  |
| 2143 | **QT Functional (inc NF and Operational) Test Scenarios and Test Cases** |  | 2025-01-30 → 2025-02-20 A (+21d) | 63d → 77d | 40% → 100% | 32309d → none |  |  |
| 2145 | Issue Batch 3 for Consultation | 2024-12-03 A | 2024-12-16 A |  | 0% → 100% | 32309d → none |  |  |
| 2146 | Update Batch 3 Post Consultation | 2024-12-17 A | 2025-01-13 A |  | 0% → 100% | 32309d → none |  |  |
| 2147 | QWG Endorsement of Batch 3 | 2025-01-22 → 2025-02-11 A (+20d) | 2025-01-22 → 2025-02-11 A (+20d) |  | 0% → 100% | 32309d → none | 2146FS+7d → 2146FS+21d | baseline start 2025-01-22 → 2025-02-11; baseline finish 2025-01-22 → 2025-02-11 |
| 2148 | QAG Approval of QT Functional Test Scenarios and Test Cases Batches 3 | 2025-01-30 → 2025-02-20 A (+21d) | 2025-01-30 → 2025-02-20 A (+21d) |  | 0% → 100% | 32309d → none |  | constraint none → start no earlier than 2025-02-20; baseline start 2025-01-30 → 2025-02-20; baseline finish 2025-01-30 → 2025-02-20 |
| 2149 | **Qualification Testing Framework (Test Stubs and Supporting UI)** |  | 2026-01-08 → 2026-02-06 (+29d) | 509d? → 530d? | 74% → 93% | 32083d → 489d |  |  |
| 2163 | QTF Test Cases DBT Refinement, Execution and Results Validation, Defect Management, Error Handling |  | 2025-01-31 → 2025-02-20 A (+20d) | 64d → 77d | 30% → 100% | 32308d → none |  | baseline finish 2025-01-31 → 2025-02-20 |
| 2164 | **Environments** |  |  |  | 98% → 100% | 32198d → none |  |  |
| 2182 | **QTF Deployment into Production** | 2025-02-03 → 2025-02-20 A (+17d) | 2025-02-27 → 2025-03-18 A (+19d) |  | 0% → 100% | 32308d → none |  |  |
| 2183 | App Deployment | 2025-02-03 → 2025-02-20 A (+17d) | 2025-02-07 → 2025-02-26 A (+19d) |  | 0% → 100% | 32308d → none |  | baseline start 2025-02-03 → 2025-02-20; baseline finish 2025-04-25 → 2025-02-26 |
| 2184 | Smoke Test | 2025-02-10 → 2025-02-27 A (+17d) | 2025-02-11 → 2025-02-28 A (+17d) |  | 0% → 100% | 32308d → none |  | baseline start 2025-02-03 → 2025-02-27; baseline finish 2025-02-04 → 2025-02-28 |
| 2185 | PEN Test | 2025-02-12 → 2025-03-03 A (+19d) | 2025-02-13 → 2025-03-04 A (+19d) |  | 0% → 100% | 32308d → none |  | baseline start 2025-02-05 → 2025-03-03; baseline finish 2025-02-06 → 2025-03-04 |
| 2186 | Regression Test | 2025-02-14 → 2025-03-05 A (+19d) | 2025-02-27 → 2025-03-18 A (+19d) |  | 0% → 100% | 32308d → none |  | baseline start 2025-02-07 → 2025-03-05; baseline finish 2025-02-20 → 2025-03-18 |
| 2215 | **MPANs, DIP Messages, Settlement, Consumption, Reference** |  |  |  | 45% → 81% |  |  |  |
| 2235 | **BETA Testing 1 - Test Data** |  |  |  | 50% → 100% |  |  |  |
| 2245 | **BETA Testing 2 - Test Data** | 2025-01-08 A | 2025-01-22 A |  | 0% → 100% |  |  |  |
| 2246 | Provide Example MPAN File | 2025-01-08 A | 2025-01-10 A |  | 0% → 100% | 32334d → none |  |  |
| 2247 | Load Example MPAN File | 2025-01-13 A | 2025-01-20 A |  | 0% → 100% | 32334d → none |  |  |
| 2248 | Industry Standing Data (ISD) | 2025-01-08 A | 2025-01-15 A |  | 0% → 100% | 32338d → none |  |  |
| 2249 | Market Domain Data (MDD) | 2025-01-08 A | 2025-01-15 A |  | 0% → 100% | 32338d → none |  |  |
| 2250 | Load ISD / MDD Data | 2025-01-16 A | 2025-01-16 A |  | 0% → 100% | 32338d → none |  |  |
| 2251 | Create QTC sets and Test MPANs via QTF | 2025-01-21 A | 2025-01-21 A |  | 0% → 100% | 32334d → none |  |  |
| 2252 | Create QTC sets in ADO via QTF | 2025-01-21 A | 2025-01-21 A |  | 0% → 100% | 32335d → none |  |  |
| 2253 | Provide Test MPANs (Suppliers only) allocated to specfic QTC's | 2025-01-21 A | 2025-01-21 A |  | 0% → 100% | 32334d → none |  |  |
| 2254 | Load Test MPANs | 2025-01-22 A | 2025-01-22 A |  | 0% → 100% | 32334d → none |  |  |
| 2256 | Test Data Request + Templates Completed | 2025-04-21 → 2025-06-02 (+42d) | 2025-05-12 → 2025-06-06 (+25d) | 16d → 5d |  | 32226d → 440d |  | constraint finish no earlier than 2025-05-12 → start no earlier than 2025-06-02; baseline start 2025-04-21 → 2025-06-02; baseline finish 2025-05-12 → 2025-06-06 |
| 2257 | Test Data Generated | 2025-05-21 → 2025-06-09 (+19d) | 2025-06-03 → 2025-06-13 (+10d) | 10d → 5d |  | 32220d → 440d |  | baseline start 2025-05-21 → 2025-06-09; baseline finish 2025-06-03 → 2025-06-13 |
| 2258 | Test Data Loaded into QP Systems | 2025-06-04 → 2025-06-16 (+12d) | 2025-07-01 → 2025-07-04 (+3d) | 20d → 15d |  | 32220d → 440d |  | baseline start 2025-06-04 → 2025-06-16; baseline finish 2025-07-01 → 2025-07-04 |
| 2259 | Test Data Loaded into QTF + ADO | 2025-06-04 → 2025-07-07 (+33d) | 2025-06-30 → 2025-07-25 (+25d) | 19d → 15d |  | 32221d → 440d | 2257 → 2257, 2258 | baseline start 2025-06-04 → 2025-07-07; baseline finish 2025-06-30 → 2025-07-25 |
| 2261 | Test Data Request + Templates Completed | 2025-06-16 → 2025-07-28 (+42d) | 2025-07-07 → 2025-08-01 (+25d) | 16d → 5d |  | 32190d → 407d |  | constraint finish no earlier than 2025-07-07 → start no earlier than 2025-07-28; baseline start 2025-06-16 → 2025-07-28; baseline finish 2025-07-07 → 2025-08-01 |
| 2262 | Test Data Generated | 2025-07-16 → 2025-08-04 (+19d) | 2025-07-29 → 2025-08-08 (+10d) | 10d → 5d |  | 32184d → 407d |  | baseline start 2025-07-16 → 2025-08-04; baseline finish 2025-07-29 → 2025-08-08 |
| 2263 | Test Data Loaded into QP Systems | 2025-07-30 → 2025-08-11 (+12d) | 2025-08-20 → 2025-08-29 (+9d) | 16d → 15d |  | 32184d → 407d |  | baseline start 2025-07-30 → 2025-08-11; baseline finish 2025-08-20 → 2025-08-29 |
| 2264 | Test Data Loaded into QTF + ADO | 2025-07-30 → 2025-09-01 (+33d) | 2025-08-20 → 2025-09-19 (+30d) | 16d → 15d |  | 32184d → 407d | 2262 → 2262, 2263 | baseline start 2025-07-30 → 2025-09-01; baseline finish 2025-08-20 → 2025-09-19 |
| 2266 | Test Data Request + Templates Completed | 2025-08-19 → 2025-10-20 (+62d) | 2025-09-08 → 2025-10-24 (+46d) | 15d → 5d |  | 32141d → 376d |  | constraint finish no earlier than 2025-09-08 → start no earlier than 2025-10-20; baseline start 2025-08-19 → 2025-10-20; baseline finish 2025-09-08 → 2025-10-24 |
| 2267 | Test Data Generated | 2025-09-16 → 2025-10-27 (+41d) | 2025-09-29 → 2025-10-31 (+32d) | 10d → 5d |  | 32136d → 376d |  | baseline start 2025-09-16 → 2025-10-27; baseline finish 2025-09-29 → 2025-10-31 |
| 2268 | Test Data Loaded into QP Systems | 2025-09-30 → 2025-11-03 (+34d) | 2025-10-27 → 2025-11-21 (+25d) | 20d → 15d |  | 32136d → 376d |  | baseline start 2025-09-30 → 2025-11-03; baseline finish 2025-10-27 → 2025-11-21 |
| 2269 | Test Data Loaded into QTF + ADO | 2025-09-30 → 2025-11-24 (+55d) | 2025-10-27 → 2025-12-12 (+46d) | 20d → 15d |  | 32136d → 376d | 2267 → 2267, 2268 | baseline start 2025-09-30 → 2025-11-24; baseline finish 2025-10-27 → 2025-12-12 |
| 2271 | Test Data Request + Templates Completed | 2025-10-17 → 2025-12-15 (+59d) | 2025-11-06 → 2025-12-19 (+43d) | 15d → 5d |  | 32098d → 256d |  | constraint finish no earlier than 2025-11-06 → start no earlier than 2025-12-15; baseline start 2025-10-17 → 2025-12-15; baseline finish 2025-11-06 → 2025-12-19 |
| 2272 | Test Data Generated | 2025-11-14 → 2025-12-22 (+38d) | 2025-11-27 → 2025-12-26 (+29d) | 10d → 5d |  | 32093d → 256d |  | baseline start 2025-11-14 → 2025-12-22; baseline finish 2025-11-27 → 2025-12-26 |
| 2273 | Test Data Loaded into QP Systems | 2025-11-28 → 2025-12-29 (+31d) | 2025-12-25 → 2026-01-16 (+22d) | 20d → 15d |  | 32093d → 256d |  | baseline start 2025-11-28 → 2025-12-29; baseline finish 2025-12-25 → 2026-01-16 |
| 2274 | Test Data Loaded into QTF + ADO | 2025-11-28 → 2026-01-19 (+52d) | 2025-12-25 → 2026-02-06 (+43d) | 20d → 15d |  | 32093d → 256d | 2272 → 2272, 2273 | baseline start 2025-11-28 → 2026-01-19; baseline finish 2025-12-25 → 2026-02-06 |
| 2275 | **Governance** |  | 2025-03-28 A |  | 6% → 100% | 32287d → none |  |  |
| 2276 | Onboarding Strategy and Develop Training Requirements & Materials Inc. Day in the Life | 2024-07-01 A | 2024-12-13 A |  | 0% → 100% | 32362d → none |  |  |
| 2278 | Knowledge Transfer, Training, Demonstrations, Documentation, Governance | 2024-08-30 A | 2024-12-17 A |  | 0% → 100% | 32360d → none |  |  |
| 2279 | BETA Testing | 2024-11-01 A | 2024-12-17 A |  | 0% → 100% | 32302d → none |  |  |
| 2280 | BETA Testing 2 | 2025-01-08 A | 2025-03-28 A |  | 0% → 100% | 32287d → none |  |  |
| 2281 | Qualification Testing Framework Readiness Confirmed | 2025-03-28 A | 2025-03-28 A |  | 0% → 100% | 32287d → none |  |  |
| 2293 | Initial QAD Submission window opens |  |  |  |  | 31579d → 420d | 2290, 2075FS+11d → 2290, 2075FS+1d |  |

| ID | Task | Start | Finish | Duration | Complete | Total float | Predecessors | Other |
| --- | --- | --- | --- | --- | --- | --- | --- | --- |
| 2311 | Qualification Wave 1 QT Execution Start |  |  |  |  | 31578d → 419d | 2310, 2307, 1613FS+6d → 2310, 2307, 1613FS+6d, 2259 |  |
| 2323 | Initial QAD Submission window opens |  |  |  |  | 31578d → 386d | 2076FS+151d → 2076FS+1d |  |
| 2341 | Qualification Wave 2 Execution Start |  |  |  |  | 31578d → 386d | 2340FS+1d, 2337 → 2340FS+1d, 2337, 2264 |  |
| 2353 | Initial QAD Submission window opens |  |  |  |  | 31582d → 355d | 2077FS+151d → 2077FS+1d |  |
| 2371 | Qualification Wave 3 Execution Start |  |  |  |  | 31582d → 355d | 2370FS+16d, 2367FS+1d → 2370FS+16d, 2367FS+1d, 2269 |  |
| 2381 | **Qualification Wave 4** | 2025-10-20 → 2025-01-23 A (-270d) |  | 334d → 526d |  | 31573d → 235d |  |  |
| 2383 | Initial QAD Submission window opens |  |  |  |  | 31573d → 235d | 2078FS+161d → 2078FS+1d |  |
| 2401 | Qualification Wave 4 QT Execution Start |  |  |  |  | 31573d → 235d | 2400FS+1d, 2397 → 2400FS+1d, 2397, 2274 |  |
| 2563 | **Deliver MHHS Code Changes** |  |  |  | 84% → 93% | 32094d → 521d |  |  |
| 2564 | **Releases** |  | 2025-12-24 → 2025-02-27 A (-300d) | 292d → 78d | 84% → 100% | 32094d → none |  |  |
| 2565 | Impacted codes make resourcing provisions and prepare to implement new Code via internal code body change processes |  | 2025-02-27 A |  | 90% → 100% | 32308d → none |  |  |
| 2578 | **Main Code Release** | 2025-09-17 → 2025-09-15 (-2d) |  | 71d → 73d |  | 32094d → 521d |  |  |
| 2579 | Release preparation (e.g. preparing release documentation) | 2025-09-17 → 2025-09-15 (-2d) | 2025-09-24 → 2025-09-22 (-2d) |  |  | 32159d → 588d |  |  |
| 2580 | Implement new code on day of code release | 2025-09-24 → 2025-09-22 (-2d) | 2025-09-24 → 2025-09-22 (-2d) |  |  | 32159d → 588d |  |  |
| 2581 | Code changes delivered (M8) | 2025-09-24 → 2025-09-22 (-2d) | 2025-09-24 → 2025-09-22 (-2d) |  |  | 32094d → 521d | 2561, 2540, 1891SS → 2561, 2540, 1891SS-3d, 2577 | constraint none → finish no earlier than 2025-09-22; baseline start 2025-09-24 → 2025-09-22; baseline finish 2025-09-24 → 2025-09-22 |
| 2582 | Code changes delivered (M8*) late exit |  |  |  |  | 32094d → 521d | 2581FS+65d → 2581FS+67d |  |
| 2587 | **MIGRATION** |  |  |  | 36% → 58% | 31671d → 98d |  |  |
| 2588 | **Regulatory Governance** |  | 2025-01-01 → 2025-06-27 (+177d) | 198d → 325d | 47% → 73% | 32349d → 649d |  |  |
| 2589 | Incentive Mods Created |  | 2024-08-30 A |  | 85% → 100% | 32349d → none |  |  |
| 2590 | Incentives Implemented | 2024-09-02 → 2025-03-31 A (+210d) | 2025-01-01 → 2025-06-27 (+177d) | 88d → 65d | 0% → 26% | 32349d → 649d |  | constraint start no earlier than 2024-07-02 → start no earlier than 2025-03-31; baseline start 2024-09-02 → 2025-03-31; baseline finish 2025-01-01 → 2025-06-27 |
| 2591 | **Migration Framework Agreed and Implemented** |  | 2025-05-07 → 2025-04-29 (-8d) | 330d? → 324d? | 52% → 99% | 32259d → 692d |  |  |
| 2606 | **Consultation 3 - Parameters** |  | 2025-02-25 A | 72d → 71d | 40% → 100% | 32222d → none |  |  |
| 2608 | Industry Consultation |  | 2025-01-17 A |  | 5% → 100% | 32222d → none |  |  |
| 2609 | Triage Response | 2025-01-20 A | 2025-01-31 A |  | 0% → 100% | 32222d → none |  |  |
| 2611 | MWG Recommendation | 2025-02-21 → 2025-02-13 A (-8d) | 2025-02-21 → 2025-02-13 A (-8d) |  | 0% → 100% | 32222d → none | Industry Assurance ReviewFS+8d → 2610FS+6d |  |
| 2612 | MCAG Paper Day | 2025-02-25 → 2025-02-18 A (-7d) | 2025-02-25 → 2025-02-18 A (-7d) |  | 0% → 100% | 32222d → none | 2611FS+2d → 2611FS+3d |  |
| 2613 | MCAG Approval of Consultation 3 | 2025-02-25 A | 2025-02-25 A |  | 0% → 100% | 32222d → none | Supplier Submissions, 2611, 2612 → 2611, 2612 | was named MCAG Approval of Migration Framework Artefacts (Baselined); constraint none → start no earlier than 2025-02-25 |
| 2614 | **Consultation 4** | 2025-01-07 → 2025-01-20 A (+13d) | 2025-05-07 → 2025-04-29 (-8d) | 87d? → 72d? | 0% → 99% | 32259d → 692d |  |  |
| 2615 | Agree Consultation 4 Plan | 2025-01-07 → 2025-01-20 A (+13d) | 2025-05-07 → 2025-02-07 A (-89d) | 87d? → 15d | 0% → 100% | 32259d → none |  | was named Prepare Artefacts; baseline start 2025-01-07 → 2025-01-20; baseline finish 2025-05-07 → 2025-02-07 |
| 2620 | Industry Consultation | 2025-03-12 → 2025-03-03 A (-9d) | 2025-03-25 → 2025-03-14 A (-11d) |  | 0% → 100% | 32270d → none | none → 2617 | constraint start no earlier than 2025-03-12 → finish no earlier than 2025-03-14 |
| 2621 | Comment responses by PPs | 2025-03-26 → 2025-03-17 A (-9d) | 2025-04-08 → 2025-03-28 A (-11d) |  | 0% → 100% | 32270d → none |  | was named Triage Response; constraint none → finish no earlier than 2025-03-28 |
| 2623 | Assurance meeting | 2025-04-09 → 2025-04-22 A (+13d) | 2025-04-22 A | 10d? → 0d | 0% → 100% | 32270d → none | 2621 → 2622FS+5d | was named Assurance and MCAG Approval; constraint none → finish no earlier than 2025-04-22 |
| 2625 | MCAG Approval of Consultation 4 | 2025-04-22 → 2025-04-29 (+7d) | 2025-04-22 → 2025-04-29 (+7d) |  |  | 32270d → 692d | 2623 → 2624FS+5d | was named Consultation 4 Approved; constraint none → finish no earlier than 2025-04-29; baseline start 2025-04-22 → 2025-04-29; baseline finish 2025-04-22 → 2025-04-29 |
| 2626 | Framework Baselined at MCAG | 2025-04-22 → 2025-04-29 (+7d) | 2025-04-22 → 2025-04-29 (+7d) |  |  | 32270d → 692d |  | constraint none → finish no earlier than 2025-04-29; baseline start 2025-04-22 → 2025-04-29; baseline finish 2025-04-22 → 2025-04-29 |
| 2627 | **Migration Schedule Agreed and Maintained** |  | 2025-07-18 → 2024-12-20 A (-210d) | 275d? → 125d? | 44% → 100% | 32207d → none |  | baseline start 2024-07-01 → 2022-10-31; baseline finish 2026-01-30 → 2024-12-20 |
| 2628 | Schedule Production | 2024-11-18 → 2024-07-01 A (-140d) | 2024-12-20 A | 25d? → 125d? | 0% → 100% | 32357d → none |  | was named Schedule Production v1; baseline start 2024-11-18 → 2024-07-01 |
| 2632 | V1.0 of Migration Schedule Baseline Approved at MCAG | 2025-07-18 → 2025-07-22 (+4d) | 2025-07-18 → 2025-07-22 (+4d) |  |  | 31932d → 632d | Schedule Production v2 → 2631FS+81d | baseline start 2025-07-18 → 2025-07-22; baseline finish 2025-07-18 → 2025-07-22 |
| 2647 | **MCC Stood up** | 2024-11-18 A |  |  | 0% → 40% |  |  |  |
| 2648 | Migration Planning Management Tool Delivery | 2024-11-18 A |  | 265d? → 265d | 0% → 40% |  |  | was named MPMT Delivered |
| 2649 | **MCC Operational** | 2024-11-18 → 2025-04-23 (+156d) | 2024-11-18 → 2025-08-29 (+284d) | 1d? → 93d |  | 32381d → 604d |  | was named MCC Stood up complete; baseline start 2024-11-18 → 2025-04-18; baseline finish 2024-11-18 → 2025-08-29 |
| 2667 | **SIT Participant's Prepared for Migration** |  | 2025-05-01 → 2025-04-30 (-1d) | 219d → 218d | 23% → 49% | 32222d → 691d |  | was named PP's Prepared for Migration |
| 2668 | Prep for Envelope Webinar |  |  |  |  |  | Indicative Envelopes IssuedSS → none |  |
| 2670 | Guides Creation | 2025-02-28 → 2025-02-27 A (-1d) | 2025-05-01 → 2025-04-24 (-7d) | 45d → 41d | 0% → 34% | 32222d → 695d |  | constraint none → finish no earlier than 2025-04-24; baseline start 2025-01-28 → 2025-02-27; baseline finish 2025-03-31 → 2025-04-30 |
| 2671 | Support Channels | 2025-02-28 → 2025-02-27 A (-1d) | 2025-05-01 → 2025-04-30 (-1d) |  | 0% → 31% | 32222d → 691d |  | baseline start 2025-01-28 → 2025-02-27; baseline finish 2025-03-31 → 2025-04-30 |
| 2672 | **Migration Artefact Development and Publication** |  | 2025-10-15 → 2026-10-28 (+378d) | 773d → 1043d | 88% → 60% | 32144d → 301d |  |  |
| 2715 | **Data Cleanse Plan** |  |  |  | 80% → 90% | 32144d → 571d |  |  |
| 2719 | Monitor Programme Participant adherence to Data Cleanse Plan |  | 2025-03-28 A |  | 76% → 100% | 32287d → none |  |  |
| 2720 | **MTDs** |  | 2025-01-24 → 2025-07-18 (+175d) | 115d → 240d | 95% → 70% | 32332d → 634d |  |  |
| 2721 | **ESME ID** |  | 2024-12-20 → 2025-05-16 (+147d) | 90d → 195d | 94% → 85% | 32357d → 679d |  |  |
| 2724 | Suppliers complete investigation of exceptions and resolution of exceptions | 2024-12-20 A | 2024-12-20 A |  | 0% → 100% | 32357d → none |  |  |
| 2726 | ESME ID Complete | 2024-12-20 → 2025-05-16 (+147d) | 2024-12-20 → 2025-05-16 (+147d) |  |  | 32357d → 679d | 2724 → 2725 | baseline start 2024-12-20 → 2025-05-16; baseline finish 2024-12-20 → 2025-05-16 |
| 2727 | **Meter Location and Number of Displayed Register Digits** |  | 2025-01-24 → 2025-07-18 (+175d) | 96d → 221d | 96% → 57% | 32332d → 634d |  |  |
| 2730 | Suppliers complete investigation of exceptions and resolution of exceptions | 2025-01-24 A | 2025-01-24 A |  | 0% → 100% | 32332d → none |  |  |
| 2732 | Meter Location and Number of Displayed Register Digits Complete | 2025-01-24 → 2025-07-18 (+175d) | 2025-01-24 → 2025-07-18 (+175d) |  |  | 32332d → 634d | 2730 → 2730, 2731 | baseline start 2025-01-31 → 2025-07-18; baseline finish 2025-01-31 → 2025-07-18 |
| 2742 | **Domestic Premises Indicator** | 2025-09-19 → 2025-09-05 (-14d) |  | 19d → 29d |  | 32144d → 571d |  |  |
| 2743 | The DCC to extract Domestic Premises Indicator from the CSS and provide a file to each LDSO and EES. | 2025-09-19 → 2025-09-05 (-14d) | 2025-09-22 → 2025-09-08 (-14d) |  |  | 32144d → 597d | 1891FS-4d → 1891FS-14d | constraint start no earlier than 2025-08-08 → start no earlier than 2025-09-05; baseline start 2025-09-19 → 2025-09-05; baseline finish 2025-09-22 → 2025-09-08 |
| 2744 | Each LDSO notifies the MHHS Programme SI of any exceptions which have occurred because of the data load and the reason for that exception | 2025-09-23 → 2025-09-24 (+1d) | 2025-09-23 → 2025-09-24 (+1d) |  |  | 32144d → 586d |  | was named Each LDSO notifies the DCC of any exceptions; constraint none → start no earlier than 2025-09-24; baseline start 2025-09-23 → 2025-09-24; baseline finish 2025-09-23 → 2025-09-24 |
| 2745 | Each LDSO and DCC completes investigation and resolution of exceptions |  |  |  |  | 32144d → 571d | 2743FS+15d, 2744FS+15d → none | constraint none → start no earlier than 2025-10-15 |
| 2746 | Domestic Premises Indicator Complete | 2025-10-15 → 2025-09-24 (-21d) | 2025-10-15 → 2025-09-24 (-21d) |  |  | 32144d → 586d | 2745 → 2744 | constraint none → finish no earlier than 2025-09-24; baseline start 2025-10-15 → 2025-09-24; baseline finish 2025-10-15 → 2025-09-24 |
| 2775 | **Export / Import MPANs** |  | 2024-10-18 A → 2025-08-13 (+299d) | 151d → 363d | 100% → 99% | none → 617d |  |  |
| 2805 | **Preparation for Cutover to Live** |  | 2025-10-17 → 2027-05-05 (+565d) | 341d → 744d | 0% → 3% | 32142d → 166d |  |  |
| 2806 | **Central Systems Prepare for Cutover to Live** |  |  |  | 0% → 7% | 32157d → 584d |  |  |
| 2808 | **Development of Comms Approach and Declaration Guidance** | 2025-04-28 A |  |  | 0% → 3% | 31607d → 34d |  |  |
| 2809 | Draft Cutover Comms Approach | 2025-04-28 A |  |  | 0% → 5% | 31607d → 34d |  |  |
| 2814 | **Development of Cutover Plan requirements with Participants** | 2025-04-28 → 2025-04-11 A (-17d) | 2025-09-04 → 2025-08-22 (-13d) | 94d → 96d | 0% → 10% | 31592d → 609d |  |  |
| 2815 | Development of Central Parties Cutover Plans | 2025-04-28 → 2025-04-11 A (-17d) | 2025-07-17 → 2025-05-16 (-62d) | 59d → 26d | 0% → 31% | 31592d → 659d |  | was named Development of SIT Participant Cutover Plans; constraint start no earlier than 2025-04-28 → start no earlier than 2025-04-11 |
| 2816 | Development of Programme Participant Cutover Plans | 2025-07-17 → 2025-04-11 A (-97d) | 2025-07-17 → 2025-06-27 (-20d) | 0d → 56d | 0% → 14% | 31592d → 33d | 2815 → 2815SS | was named SIT Participant Cutover Plans Ready; constraint none → finish no earlier than 2025-06-27 |
| 2821 | Programme SIT Participant Cutover Plan Assurance | 2025-07-18 → 2025-06-30 (-18d) | 2025-09-04 → 2025-08-15 (-20d) |  |  | 31592d → 33d |  |  |
| 2840 | **Cutover Governance M10** | 2025-09-10 → 2025-09-01 (-9d) |  | 11d → 17d |  | 31581d → 7d |  |  |
| 2843 | Confirmation that Pre-migration Data Cleanse Activities have successfully taken place |  |  |  |  | 31583d → 10d | none → 2842 |  |

| ID | Task | Start | Finish | Duration | Complete | Total float | Predecessors | Other |
| --- | --- | --- | --- | --- | --- | --- | --- | --- |
| 2845 | Confirmation of Helix E2E Settlement Testing Complete |  |  |  |  | 31580d → 5d | none → 2844 |  |
| 2852 | TORWG (Recommendation from TORWG that the Programme should enter M10) |  |  |  |  | 31578d → 5d | 2843FS+1d, 2847FS+1d, 2849FS+1d, 2823FS+1d, 2824FS+1d, 3005FS+1d, 2845FS+1d, 2846FS+1d, 2848FS+1d, 2850, 2851 → 2843FS+1d, 2847FS+1d, 2849FS+3d, 2823FS+1d, 2824FS+1d, 3005FS+1d, 2845FS+3d, 2846FS+3d, 2848FS+3d, 2850, 2851 |  |
| 2860 | **Cutover Governance M11** |  | 2025-10-17 → 2025-10-22 (+5d) | 16d → 19d |  | 31581d → 5d |  |  |
| 2861 | Confirmation of Qualified Parties from Code Bodies |  | 2025-10-10 → 2025-10-14 (+4d) | 11d → 13d |  | 31581d → 7d | 2859FS+1d → 2859FS+1d, 2430 | baseline finish 2025-10-10 → 2025-10-14 |
| 2862 | Self-Declaration that MHHS Functionality will be deployed to Production by Qualified parties | 2025-10-10 → 2025-10-14 (+4d) | 2025-10-10 → 2025-10-14 (+4d) |  |  | 31581d → 7d |  | constraint none → finish no earlier than 2025-10-14; baseline start 2025-10-10 → 2025-10-14; baseline finish 2025-10-10 → 2025-10-14 |
| 2863 | Production Service Activation Activities have taken place | 2025-10-10 → 2025-10-14 (+4d) | 2025-10-10 → 2025-10-14 (+4d) |  |  | 31581d → 7d |  | constraint none → finish no earlier than 2025-10-14; baseline start 2025-10-10 → 2025-10-14; baseline finish 2025-10-10 → 2025-10-14 |
| 2864 | TORWG (Confirmation of Qualified Parties from TORWG) | 2025-10-13 → 2025-10-17 (+4d) | 2025-10-13 → 2025-10-17 (+4d) |  |  | 31581d → 5d |  | constraint none → finish no earlier than 2025-10-17; baseline start 2025-10-13 → 2025-10-17; baseline finish 2025-10-13 → 2025-10-17 |
| 2865 | MCAG (Provide recommendation to PSG on M11 decision) | 2025-10-15 → 2025-10-20 (+5d) | 2025-10-15 → 2025-10-20 (+5d) |  |  | 31581d → 5d | 2864FS+2d → 2864FS+1d | constraint none → finish no earlier than 2025-10-20; baseline start 2025-10-15 → 2025-10-20; baseline finish 2025-10-15 → 2025-10-20 |
| 2866 | PSG (OFGEM and PSG Decision to Confirm M11 and M12) | 2025-10-17 → 2025-10-22 (+5d) | 2025-10-17 → 2025-10-22 (+5d) |  |  | 31581d → 5d |  | baseline start 2025-10-17 → 2025-10-22; baseline finish 2025-10-17 → 2025-10-22 |
| 2970 | Full transition complete (M15) |  |  |  |  | 31573d → 0d | SIT MVC UMS / Advanced Migration, SIT Non-MVC UMS / Advanced Migration, Wave 1 UMS / Advanced Migration, Wave 2 UMS / Advanced Migration, Wave 3 UMS / Advanced Migration, Wave 4 UMS / Advanced Migration, SIT MVC Smart / Non-Smart Migration, SIT Non-MVC Smart / Non-Smart Migration, Wave 1 Smart / Non-Smart Migration, Wave 2 Smart / Non-Smart Migration, Wave 3 Smart / Non-Smart Migration, Wave 4 Smart / Non-Smart MigrationFS+1d → 2949FS+2d |  |
| 2972 | **BUSINESS & OPERATIONAL READINESS** |  |  |  | 6% → 11% | 31573d → 0d |  |  |
| 2973 | **Service Management** | 2023-09-19 A → 2022-10-31 A (-323d) | 2027-06-24 → 2026-01-14 (-526d) | 983d → 838d | 26% → 42% | 31703d → 506d |  |  |
| 2978 | **Early Life Support Model** |  | 2024-07-30 → 2025-04-29 (+273d) | 110d → 305d | 82% → 99% | 32460d → 692d |  |  |
| 2979 | Draft Document |  | 2024-06-10 → 2025-02-13 A (+248d) | 74d → 252d | 96% → 100% | 32460d → none |  | constraint none → finish no earlier than 2025-02-13 |
| 2980 | Share Document with SRO | 2024-06-11 → 2025-02-14 A (+248d) | 2024-06-11 → 2025-02-14 A (+248d) |  | 0% → 100% | 32460d → none |  | was named Share document with SRO |
| 2981 | Industry Consultation | 2024-06-18 → 2025-02-21 A (+248d) | 2024-07-02 → 2025-03-07 A (+248d) |  | 0% → 100% | 32460d → none |  |  |
| 2982 | Assurance Meeting | 2024-07-16 → 2025-04-03 A (+261d) | 2024-07-16 → 2025-04-03 A (+261d) |  | 0% → 100% | 32460d → none |  | constraint none → finish no earlier than 2025-04-03; baseline start 2024-07-16 → 2025-04-03; baseline finish 2024-07-16 → 2025-04-03 |
| 2983 | MCAG Approval of Early Life Support Model | 2024-07-30 → 2025-04-29 (+273d) | 2024-07-30 → 2025-04-29 (+273d) |  |  | 32460d → 692d |  | constraint none → finish no earlier than 2025-04-29; baseline start 2024-07-30 → 2025-04-29; baseline finish 2024-07-30 → 2025-04-29 |
| 2984 | **Service Management Arrangements Implementation** | 2025-09-25 → 2022-10-31 (-1060d) | 2027-06-24 → 2026-01-14 (-526d) | 456d → 838d |  | 31703d → 506d |  |  |
| 2986 | Monitor Elexon implementation of Service Management arrangements | 2025-10-23 → 2022-10-31 (-1088d) | 2027-06-24 → 2024-07-01 (-1088d) |  |  | 31703d → 908d | SIT MVC UMS / Advanced MigrationSS, SIT MVC Smart / Non-Smart MigrationSS → none |  |
| 3023 | **SIT Non-MVC** |  | 2026-01-19 → 2026-01-16 (-3d) | 841d? → 840d? |  | 32076d → 504d |  |  |
| 3027 | **SIT Non-MVC Service Activation Implementation** | 2025-12-19 → 2025-12-18 (-1d) | 2025-12-29 → 2025-12-26 (-3d) |  |  | 31602d → 505d |  |  |
| 3028 | Add EDF to DIP | 2025-12-19 → 2025-12-18 (-1d) | 2025-12-19 → 2025-12-18 (-1d) |  |  | 31602d → 505d |  |  |
| 3029 | DIP Promoted to Production | 2025-12-22 → 2025-12-19 (-3d) | 2025-12-22 → 2025-12-19 (-3d) |  |  | 31602d → 505d |  |  |
| 3030 | SIT non-MVC S&As Create Certificates and Test Connectivity | 2025-12-23 → 2025-12-22 (-1d) | 2025-12-23 → 2025-12-22 (-1d) |  |  | 32095d → 523d |  | baseline start none → 2025-12-23; baseline finish none → 2025-12-23 |
| 3031 | Create M16 in Customer Solution | 2025-12-23 → 2025-12-22 (-1d) | 2025-12-24 → 2025-12-23 (-1d) |  |  | 31602d → 505d |  |  |
| 3032 | Publish ISD | 2025-12-25 → 2025-12-24 (-1d) | 2025-12-26 → 2025-12-25 (-1d) |  |  | 31602d → 505d |  |  |
| 3033 | SIT non-MVC S&As to update systems with ISD | 2025-12-29 → 2025-12-26 (-3d) | 2025-12-29 → 2025-12-26 (-3d) |  |  | 32091d → 519d |  | baseline start none → 2025-12-29; baseline finish none → 2025-12-29 |
| 3034 | SIT Non-MVC Service Activation Implementation Complete | 2025-12-26 → 2025-12-25 (-1d) | 2025-12-26 → 2025-12-25 (-1d) |  |  | 31602d → 520d |  |  |
| 3035 | **SIT Non-MVC Service Activation Implementation MDD** | 2025-12-29 → 2025-12-26 (-3d) | 2026-01-16 → 2026-01-15 (-1d) |  |  | 32077d → 505d |  |  |
| 3036 | MDD Manual Load | 2025-12-29 → 2025-12-26 (-3d) | 2026-01-06 → 2026-01-05 (-1d) |  |  | 32077d → 505d |  |  |
| 3037 | MDD Update | 2026-01-07 → 2026-01-06 (-1d) | 2026-01-16 → 2026-01-15 (-1d) |  |  | 32077d → 505d |  |  |
| 3038 | SIT Non-MVC Service Activation Implementation MDD Complete | 2026-01-16 → 2026-01-15 (-1d) | 2026-01-16 → 2026-01-15 (-1d) |  |  | 32077d → 505d |  |  |
| 3039 | **Non-SIT MVC Service Activation Hypercare** | 2025-12-19 → 2025-12-18 (-1d) | 2026-01-19 → 2026-01-16 (-3d) |  |  | 32076d → 504d |  |  |
| 3040 | Service& Process Monitoring | 2025-12-19 → 2025-12-18 (-1d) | 2026-01-13 → 2026-01-12 (-1d) |  |  | 32080d → 508d |  |  |
| 3041 | Daily Reporting | 2025-12-19 → 2025-12-18 (-1d) | 2026-01-13 → 2026-01-12 (-1d) |  |  | 32080d → 508d |  |  |
| 3042 | Issue Management | 2025-12-19 → 2025-12-18 (-1d) | 2026-01-13 → 2026-01-12 (-1d) |  |  | 32080d → 508d |  |  |
| 3043 | SA Hypercare Close Down Activities | 2025-12-19 → 2025-12-18 (-1d) | 2026-01-13 → 2026-01-12 (-1d) |  |  | 32076d → 504d |  |  |
| 3044 | Handover to MHHSP | 2026-01-14 → 2026-01-13 (-1d) | 2026-01-19 → 2026-01-16 (-3d) |  |  | 32076d → 504d |  |  |
| 3045 | Non-SIT MVC Service Activation Hypercare Complete (M) | 2026-01-19 → 2026-01-16 (-3d) | 2026-01-19 → 2026-01-16 (-3d) |  |  | 32076d → 504d |  |  |
| 3180 | Central Parties BCDRs in Place |  |  |  |  | 32159d → 586d | 2581FS-40d → 2581FS-38d |  |
| 3257 | **Readiness Assessment 5 / 6 - Start of Qualification and Participant Readiness for M10 and M11 and CP3/CP4 check** | 2025-04-21 → 2025-04-28 (+7d) | 2025-06-24 → 2025-07-01 (+7d) |  |  | 32225d → 647d |  |  |
| 3258 | Launch Readiness Assessment survey | 2025-04-21 → 2025-04-28 (+7d) | 2025-04-21 → 2025-04-28 (+7d) |  |  | 32225d → 647d |  | constraint start no earlier than 2025-04-21 → start no earlier than 2025-04-28; baseline start 2025-04-21 → 2025-04-28; baseline finish 2025-04-21 → 2025-04-28 |
| 3259 | PPs submit survey responses | 2025-04-21 → 2025-04-28 (+7d) | 2025-05-09 → 2025-05-16 (+7d) |  |  | 32225d → 647d |  | baseline start 2025-04-21 → 2025-04-28; baseline finish 2025-05-09 → 2025-05-16 |
| 3260 | Analyse survey responses | 2025-05-12 → 2025-05-19 (+7d) | 2025-05-30 → 2025-06-06 (+7d) |  |  | 32225d → 647d |  | baseline start 2025-05-12 → 2025-05-19; baseline finish 2025-05-30 → 2025-06-06 |
| 3261 | Conduct deep-dive interviews (sample of PPs) | 2025-05-12 → 2025-05-19 (+7d) | 2025-05-30 → 2025-06-06 (+7d) |  |  | 32225d → 647d |  | baseline start 2025-05-12 → 2025-05-19; baseline finish 2025-05-30 → 2025-06-06 |
| 3262 | Produce Readiness Assessment Reports (Overall Report & Individual Participant Reports) | 2025-06-02 → 2025-06-09 (+7d) | 2025-06-20 → 2025-06-27 (+7d) |  |  | 32225d → 647d |  | baseline start 2025-06-02 → 2025-06-09; baseline finish 2025-06-20 → 2025-06-27 |
| 3263 | Readiness Assessment 5 / 6 - Start of Qualification and Participant Readiness for M10 and M11 and CP3/CP4 check (incl. Readiness Assessment Report approval) Completed | 2025-06-24 → 2025-07-01 (+7d) | 2025-06-24 → 2025-07-01 (+7d) |  |  | 32225d → 647d |  | baseline start 2025-06-24 → 2025-07-01; baseline finish 2025-06-24 → 2025-07-01 |
| 3285 | **Readiness Assessments - Tier 1 Milestones** | 2025-06-24 → 2025-07-01 (+7d) |  | 517d → 512d |  | 31708d → 135d |  |  |
| 3286 | Readiness Assessment 6 - Start of Migration - Completed (incl. Readiness Assessment Report approval) | 2025-06-24 → 2025-07-01 (+7d) | 2025-06-24 → 2025-07-01 (+7d) |  |  | 32225d → 647d |  | baseline start 2025-06-24 → 2025-07-01; baseline finish 2025-06-24 → 2025-07-01 |
| 3308 | **MILESTONE RANGE CHECKPOINTS** | 2022-10-31 → 2025-07-31 (+1004d) |  | 1160d? → 442d |  | 31757d → 184d |  |  |
| 3315 | **M16 milestone checkpoint** | 2022-10-31 → 2027-04-12 (+1624d) |  | 1160d? → 0d |  | 31757d → 184d |  |  |

## Version 4 (data date 2025-06-04, saved 2025-06-04, file MHHS-DEL1139 - MHHS Plan v6.26.mpp)

Last finish stays 2027-12-23. Complete tasks 1756 → 1930.

Added:

| ID | Task | Duration | Start | Finish | Predecessors | Constraint |
| --- | --- | --- | --- | --- | --- | --- |
| 1599 | eSITAG decision point on end of SIT A testing | 0d | 2025-06-11 | 2025-06-11 |  | finish no earlier than 2025-06-11 |
| 1611 | Programme drafts Functional & Migration PP Exit Report | 20d | 2025-04-28 A | 2025-05-23 | 1564 |  |
| 1612 | SRO Review PP Exit Reports | 2d | 2025-05-22 | 2025-05-23 | 1611SS | start no earlier than 2025-05-22 |
| 1613 | Functional & Migration PP Exit Reports shared with PPs | 0d | 2025-05-23 | 2025-05-23 | 1612 | finish no earlier than 2025-05-23 |
| 1614 | PPs complete and return Exit Reports | 10d | 2025-05-26 | 2025-06-06 | 1613 | start no earlier than 2025-05-26 |
| 1615 | PPs Exit Report submission deadline | 0d | 2025-06-06 | 2025-06-06 | 1614 | start no earlier than 2025-06-06 |
| 1616 | Programme drafts SI SIT Functional & Migration Overarching Exit Report | 13d | 2025-05-26 | 2025-06-11 | 1613, 1615FF | start no earlier than 2025-05-26 |
| 1617 | SITWG Review status of SI SIT Functional & Migration Overarching Exit Report | 0d | 2025-06-05 | 2025-06-05 | 1616SS | start no earlier than 2025-06-05 |
| 1618 | SRO Review SI SIT Functional & Migration Overarching Exit Report | 5d | 2025-06-02 | 2025-06-06 | 1616SS | start no earlier than 2025-06-02 |
| 1619 | SITAG endorses the SI SIT Functional & Migration Overarching Test Exit Report | 0d | 2025-06-18 | 2025-06-18 | 1616FS+3d, 1617 | finish no earlier than 2025-06-18 |
| 1620 | **SIT Settlement and Regression Test Exit Report** | 38d | 2025-06-30 | 2025-08-20 |  |  |
| 1621 | Programme drafts Settlement and Regression PP Exit Reports (when Participant completes Regression testing) | 30d | 2025-06-30 | 2025-08-08 | 1605SS | start no earlier than 2025-06-30 |
| 1622 | All Settlement and Regression PP Exit Reports shared with PPs | 0d | 2025-08-08 | 2025-08-08 | 1621 |  |
| 1623 | PPs complete and return Exit Reports | 25d | 2025-07-07 | 2025-08-08 | 1621SS, 1708SS | start no earlier than 2025-07-07 |
| 1624 | PPs Exit Report and Regression Exit Decleration submission deadline | 0d | 2025-08-08 | 2025-08-08 | 1623 | finish no earlier than 2025-08-08 |
| 1625 | Programme drafts SI SIT Settlement and Regression Overarching Exit Report | 25d | 2025-07-07 | 2025-08-08 | 1623SS, 1710SS |  |
| 1626 | SRO Review SI SIT Settlement and Regression Overarching Exit Report | 5d | 2025-08-04 | 2025-08-08 | 1625SS | start no earlier than 2025-08-04 |
| 1627 | SITWG Review status of SI SIT Settlement and Regression Overarching Exit Report | 0d | 2025-08-12 | 2025-08-12 | 1625 | finish no earlier than 2025-08-12 |
| 1629 | SITAG Approves SI SIT Functional & Migration (Post-Regression) Overarching Test Exit Report | 0d | 2025-08-20 | 2025-08-20 | 1625, 1627, 1608 | finish no earlier than 2025-08-20 |
| 1698 | Programme drafts Functional & Migration PP Exit Report | 20d | 2025-04-28 A | 2025-05-23 | 1688 | finish no earlier than 2025-05-16 |
| 1699 | SRO Review PP Exit Reports | 2d | 2025-05-22 | 2025-05-23 | 1698SS | start no earlier than 2025-05-22 |
| 1700 | Functional & Migration PP Exit Reports shared with PPs | 0d | 2025-05-23 | 2025-05-23 | 1699 | start no earlier than 2025-05-16 |
| 1701 | PPs complete and return Exit Reports | 10d | 2025-05-26 | 2025-06-06 | 1700 | finish no earlier than 2025-05-30 |
| 1702 | PPs Exit Report submission deadline | 0d | 2025-06-06 | 2025-06-06 | 1701 | start no earlier than 2025-05-30 |
| 1703 | Programme drafts SI SIT Functional & Migration Overarching Exit Report | 13d | 2025-05-26 | 2025-06-11 | 1700, 1701FF | start no earlier than 2025-05-26 |
| 1704 | SITWG Review status of Functional & Migration Overarching Completion Report | 0d | 2025-06-05 | 2025-06-05 | 1703SS | start no earlier than 2025-06-05 |
| 1705 | SRO Review SI SIT Functional & Migration Overarching Exit Report | 5d | 2025-06-02 | 2025-06-06 | 1703SS | finish no earlier than 2025-06-06 |
| 1706 | SITAG endorses the SI SIT Functional & Migration Overarching Test Exit Report | 0d | 2025-06-18 | 2025-06-18 | 1703FS+3d, 1704 | finish no earlier than 2025-06-18 |
| 1707 | **SIT Settlement and Regression Test Exit Report** | 38d | 2025-06-30 | 2025-08-20 |  |  |
| 1708 | Programme drafts Settlement and Regression PP Exit Report (when Participant completes Regression testing) | 30d | 2025-06-30 | 2025-08-08 | 1692SS | finish no earlier than 2025-08-08 |
| 1709 | All Settlement and Regression PP Exit Reports shared with PPs | 0d | 2025-08-08 | 2025-08-08 | 1708 | start no earlier than 2025-08-08 |
| 1710 | PPs complete and return PP Exit Reports | 25d | 2025-07-07 | 2025-08-08 | 1708SS | start no earlier than 2025-07-07 |
| 1711 | PPs Exit Report and Regression Exit Deceleration submission deadline | 0d | 2025-08-08 | 2025-08-08 | 1710 | finish no earlier than 2025-08-08 |
| 1712 | Programme drafts SI SIT Settlement and Regression Overarching Exit Report | 25d | 2025-07-07 | 2025-08-08 | 1710SS | start no earlier than 2025-07-07 |
| 1713 | SRO Review SI SIT Settlement and Regression Overarching Exit Report | 5d | 2025-08-04 | 2025-08-08 | 1712SS | start no earlier than 2025-08-04 |
| 1714 | SITWG Review status of SI SIT Settlement and Regression Overarching Exit Report | 0d | 2025-08-12 | 2025-08-12 |  | finish no earlier than 2025-08-12 |
| 1717 | SITAG Approves SI SIT Functional & Migration (Post-Regression) Overarching Test Exit Report | 0d | 2025-08-20 | 2025-08-20 | 1712 | finish no earlier than 2025-08-20 |
| 1725 | Programme drafts Non-Functional PP Exit Report | 15d | 2025-05-26 | 2025-06-13 | 1723 |  |
| 1726 | Non-Functional PP Exit Reports shared with PPs | 0d | 2025-06-13 | 2025-06-13 | 1725 | start no earlier than 2025-06-09 |
| 1727 | PPs complete and return PP Exit Reports | 10d | 2025-06-16 | 2025-06-27 | 1725SS | finish no earlier than 2025-06-27 |
| 1728 | PPs Exit Report submission deadline | 0d | 2025-06-27 | 2025-06-27 | 1727 |  |
| 1729 | Programme drafts SI SIT Non-Functional Overarching Exit Report | 15d | 2025-06-16 | 2025-07-04 | 1727SS | start no earlier than 2025-06-16 |
| 1730 | SRO Review SI SIT Non-Functional Overarching Exit Report | 5d | 2025-06-23 | 2025-06-27 | 1729SS | start no earlier than 2025-06-23 |
| 1731 | SITWG Review status of SI SIT Non-Functional Overarching Exit Report | 0d | 2025-07-03 | 2025-07-03 |  | start no earlier than 2025-07-03 |
| 1733 | SITAG Approves SI SIT Non-Functional Overarching Test Exit Report | 0d | 2025-07-16 | 2025-07-16 | 1729FS+3d | start no earlier than 2025-07-16 |
| 1743 | **SIT Operational Testing Re-test Theme 3 (Batch 1)** | 30d | 2025-05-05 A | 2025-06-13 |  |  |
| 1744 | SRO Review of re-testing approach | 10d | 2025-05-05 A | 2025-05-16 A |  | start no earlier than 2025-05-05 |
| 1745 | Scripts uploaded to ADO / Project Created | 5d | 2025-05-19 A | 2025-05-23 A | 1744 |  |
| 1746 | SIT Operational Testing Re-test Execution Theme 3 (Batch 1) | 5d | 2025-06-09 | 2025-06-13 | 1745 | start no earlier than 2025-06-09 |
| 1749 | Programme drafts PP Exit Report (when Participant completes Operational testing) | 30d | 2025-06-02 | 2025-07-11 | 1740SS | start no earlier than 2025-06-02 |
| 1750 | All Operational Completion PP Exit Reports have been shared with PPs | 0d | 2025-07-11 | 2025-07-11 | 1749 |  |
| 1751 | PPs complete and return PP Exit Reports | 31d | 2025-06-13 | 2025-07-25 | 1749SS | start no earlier than 2025-06-13 |
| 1752 | PPs Exit Report submission deadline | 0d | 2025-07-25 | 2025-07-25 | 1751 |  |
| 1753 | Programme drafts SI SIT Operational Overarching Exit Report | 30d | 2025-06-23 | 2025-08-01 | 1751SS | start no earlier than 2025-06-23 |
| 1754 | SITWG Review status of SI SIT Operational Overarching Exit Report | 0d | 2025-07-03 | 2025-07-03 |  | start no earlier than 2025-07-03 |
| 1755 | SRO Review SI SIT Operational Overarching Exit Report | 5d | 2025-07-21 | 2025-07-25 | 1753SS | start no earlier than 2025-07-21 |
| 1757 | SITAG Approves SI SIT Operational Testing Test Exit Report | 0d | 2025-08-06 | 2025-08-06 | 1753FS+3d | start no earlier than 2025-08-06 |
| 1867 | **Sandbox Testing Execution (UIT) - LDSO Participants** | 169d | 2025-06-02 | 2026-01-22 |  |  |
| 1868 | Sandbox Testing Start (UIT) - LDSO Participants | 0d | 2025-06-02 | 2025-06-02 | 1862 | finish no earlier than 2025-06-02 |
| 1869 | Sandbox Testing Execution (UIT) - LDSO Participants | 169d | 2025-06-02 | 2026-01-22 | 1868SS-1d | start no earlier than 2024-11-04 |
| 1870 | Sandbox Testing End (UIT) - LDSO Participants | 0d | 2026-01-22 | 2026-01-22 | 1869 |  |
| 1936 | M10 Acceptance Criteria Ratification | 0d | 2025-09-24 | 2025-09-24 | 1935FS+2d |  |
| 2064 | **HELIX / ELEXON M10 READINESS** | 869d? | 2024-04-02 A | 2027-07-30 |  |  |
| 2065 | **Service Management - M10 Readiness** | 630d | 2025-03-03 A | 2027-07-30 |  |  |
| 2066 | **Service Model Design (Cross Party Service Desk)** | 105d | 2025-03-03 A | 2025-07-25 |  |  |
| 2067 | **Cross Party Service Desk** | 55d | 2025-03-03 A | 2025-05-19 A |  |  |
| 2068 | Cross Party Service Desk Definition and Design | 24d | 2025-03-03 A | 2025-04-03 A |  |  |
| 2069 | Cross Party Service Desk Design Document MHHS Review | 0d | 2025-04-03 A | 2025-04-03 A | 2068 | start no earlier than 2025-04-03 |
| 2070 | Cross Party Service Desk Model Issued | 0d | 2025-04-07 A | 2025-04-07 A | 2069 | start no earlier than 2025-04-07 |
| 2071 | Cross Party Service Desk Model Reissued | 0d | 2025-04-15 A | 2025-04-15 A | 2070 | start no earlier than 2025-04-15 |
| 2072 | **Cross Party Service Desk Consultation** | 30d | 2025-04-07 A | 2025-05-19 A |  |  |
| 2073 | Cross Party Service Desk Consultation | 16d | 2025-04-07 A | 2025-04-28 A | 2069, 2071FF | finish no earlier than 2025-04-28 |
| 2074 | Cross Party Service Desk Consultation Completed | 0d | 2025-04-28 A | 2025-04-28 A | 2073 | start no earlier than 2025-03-28 |
| 2075 | Cross Party Service Desk Model Updates (Feedback Review) | 8d | 2025-04-29 A | 2025-05-08 A | 2074 | start no earlier than 2025-04-23 |
| 2076 | Cross Party Service Desk Model Spotlight at Elexon Service Management Steering Group | 0d | 2025-05-07 A | 2025-05-07 A | 2075FF-1d | start no earlier than 2025-05-07 |
| 2077 | Updated Consultation Documents Shared with MHHS and Industry | 0d | 2025-05-08 A | 2025-05-08 A | 2075 | start no earlier than 2025-04-14 |
| 2078 | TORWG Post-Consultation Update (CPSD) | 0d | 2025-05-14 A | 2025-05-14 A | 2077 | start no earlier than 2025-05-14 |
| 2079 | Updated Consultation Documents Released to Industry for eTORWG | 0d | 2025-05-16 A | 2025-05-16 A | 2078FS+3d |  |
| 2080 | CPSD, Operating Hours & Triage Updates Endorsement (eTORWG) | 0d | 2025-05-19 A | 2025-05-19 A | 2079 | start no earlier than 2025-05-19 |
| 2081 | Cross Party Service Desk Model Completed | 0d | 2025-05-19 A | 2025-05-19 A | 2080 | start no earlier than 2025-03-28 |
| 2082 | **Service Documentation** | 64d | 2025-04-29 A | 2025-07-25 |  |  |
| 2083 | Operations Manual and LLSD Updates Post-Consultation | 13d | 2025-04-29 A | 2025-05-15 A | 2074 | start no earlier than 2025-04-23 |
| 2084 | Service User LLSD Version 1.2 | 0d | 2025-05-15 A | 2025-05-15 A | 2083 |  |
| 2085 | Operations Manual Version 1.3 | 0d | 2025-05-15 A | 2025-05-15 A | 2083 |  |
| 2086 | ORT version of LLSD SOM CPSD | 0d | 2025-06-04 A | 2025-06-04 A |  | start no earlier than 2025-06-04 |
| 2087 | ORT version brought to TORWG | 0d | 2025-06-11 | 2025-06-11 | 2086FS+5d | start no earlier than 2025-06-11 |
| 2088 | Post-ORT Operations Manual and LLSD Updates | 10d | 2025-07-14 | 2025-07-25 | 2084, 2085 | start no earlier than 2025-07-14 |
| 2089 | M10 Operations Manual Version 2.0 & LLSD ORT Learning | 0d | 2025-07-25 | 2025-07-25 | 2088 | start no earlier than 2025-04-01 |
| 2090 | **Operational Readiness Testing** | 130d | 2025-03-03 A | 2025-08-29 |  |  |
| 2091 | **ORT Design** | 72d | 2025-03-03 A | 2025-06-10 |  |  |
| 2092 | ORT Test Scope and Approach | 25d | 2025-03-03 A | 2025-04-04 A | 2068FF | start no earlier than 2025-03-03 |
| 2093 | ORT Test Approach Shared with MHHS (Initial Review) | 0d | 2025-04-02 A | 2025-04-02 A | 2092FS-3d | start no earlier than 2025-04-02 |
| 2094 | ORT Test Scenarios Shared with MHHS (Initial Review) | 0d | 2025-04-02 A | 2025-04-02 A | 2092FS-3d | start no earlier than 2025-04-02 |
| 2095 | ORT Test Scope and Approach Documents Shared with Industry | 0d | 2025-04-07 A | 2025-04-07 A | 2094 | start no earlier than 2025-04-07 |
| 2096 | **ORT Test Scope and Approach Consultation (Test Scope and Approach & Test Scripts)** | 29d | 2025-04-08 A | 2025-05-19 A |  |  |
| 2097 | ORT Test Scope and Approach Consultation | 15d | 2025-04-08 A | 2025-04-28 A | 2095 | finish no earlier than 2025-04-28 |
| 2098 | ORT Test Scope and Approach Consultation Completed | 0d | 2025-04-28 A | 2025-04-28 A | 2097 | start no earlier than 2025-03-28 |
| 2099 | ORT Test Scope and Approach Updates (Feedback Review) | 8d | 2025-04-29 A | 2025-05-08 A | 2098 | start no earlier than 2025-04-14 |
| 2100 | Updated ORT Test Scope and Approach Documents Shared with MHHS and Industry | 0d | 2025-05-08 A | 2025-05-08 A | 2099 | start no earlier than 2025-04-14 |
| 2101 | TORWG Post-Consultation Update (ORT Approach) | 0d | 2025-05-14 A | 2025-05-14 A | 2100 | start no earlier than 2025-05-14 |
| 2102 | Updated ORT Test Scope and Approach Documents Released to Industry for eSITWG | 0d | 2025-05-16 A | 2025-05-16 A | 2100, 2101 | start no earlier than 2025-05-16 |
| 2103 | ORT Test Scope and Approach Endorsement (eSITWG) | 0d | 2025-05-19 A | 2025-05-19 A | 2102 | start no earlier than 2025-05-19 |
| 2104 | ORT Test Script Production and Updates | 23d | 2025-04-08 A | 2025-05-08 A | 2098FF, 2099FF, 2073FF | start no earlier than 2025-04-07 |
| 2105 | ORT Test Scripts Shared | 0d | 2025-05-08 A | 2025-05-08 A | 2104 | start no earlier than 2025-05-07 |
| 2106 | **ORT Test Scripts Consultation** | 25d | 2025-05-07 A | 2025-06-10 |  |  |
| 2107 | ORT Spotlight (Test Approach) at Elexon Service Management Helix Steering Group | 0d | 2025-05-07 A | 2025-05-07 A |  | start no earlier than 2025-05-07 |
| 2108 | ORT Test Scripts Consultation | 6d | 2025-05-09 A | 2025-05-16 A | 2104, 2105 | start no earlier than 2025-05-01 |
| 2109 | ORT Test Scripts Consultation Completed | 0d | 2025-05-16 A | 2025-05-16 A | 2108 | start no earlier than 2025-03-28 |
| 2110 | ORT Test Scripts Updates (Feedback Review) | 4d | 2025-05-19 A | 2025-05-22 A | 2109 | start no earlier than 2025-04-02 |
| 2111 | ORT Test Scipts Updates Shared with MHHS and Industry | 0d | 2025-05-22 A | 2025-05-22 A | 2110 | start no earlier than 2025-04-14 |
| 2112 | Industry Assurance Review Session Post-Consultation Update (ORT Test Scripts) | 0d | 2025-05-30 A | 2025-05-30 A | 2111FS+6d | start no earlier than 2025-04-14 |
| 2113 | Updated ORT Test Script Consultation Documents Released to industry for eSITWG | 0d | 2025-06-03 A | 2025-06-03 A | 2112FS+2d | start no earlier than 2025-04-04 |
| 2114 | ORT Test Scripts and Readiness Spotlight at Elexon Service Management Steering Group | 0d | 2025-06-04 A | 2025-06-04 A | 2113FS+1d | start no earlier than 2025-04-22 |
| 2115 | ORT Test Scipt Updates Endorsement (eSITWG) | 0d | 2025-06-10 | 2025-06-10 | 2113FS+5d | start no earlier than 2025-04-14 |
| 2116 | **ORT Preparation** | 32d | 2025-05-01 A | 2025-06-13 |  |  |
| 2117 | ORT Participant/User Scheduling | 24d | 2025-05-01 A | 2025-06-03 A |  | start no earlier than 2025-05-01 |
| 2118 | ORT Participant/User Scheduling Completed | 0d | 2025-06-03 A | 2025-06-03 A | 2117 | start no earlier than 2025-03-28 |
| 2119 | ORT Training and Preparation | 6d | 2025-06-04 A | 2025-06-11 | 2097, 2104, 2107, 2111 | start no earlier than 2025-06-04 |
| 2120 | ORT DITL Session | 0d | 2025-06-12 | 2025-06-12 | 2109FS+2d, 2112 | start no earlier than 2025-06-12 |
| 2121 | ORT Orientation (JiT) | 0d | 2025-06-13 | 2025-06-13 | 2119FS+2d | start no earlier than 2025-05-30 |
| 2122 | **ORT Execution** | 20d | 2025-06-16 | 2025-07-11 |  |  |
| 2123 | ORT Execution | 20d | 2025-06-16 | 2025-07-11 | 2119, 2121, 2103 | start no earlier than 2025-06-02 |
| 2124 | ORT Execution Completed | 0d | 2025-07-11 | 2025-07-11 | 2123 | start no earlier than 2025-03-28 |
| 2125 | **ORT Exit** | 14d | 2025-07-14 | 2025-07-31 | 2103, 2110, 2113, 2117 |  |
| 2126 | ORT Wrap Up | 5d | 2025-07-14 | 2025-07-18 | 2124 | start no earlier than 2025-04-22 |
| 2127 | ORT Exit Report | 10d | 2025-07-14 | 2025-07-25 | 2124 | start no earlier than 2025-04-02 |
| 2128 | ORT Exit Report Shared with Participants | 0d | 2025-07-25 | 2025-07-25 | 2127 | start no earlier than 2025-04-22 |
| 2129 | ORT eSITAG Exit Report Endorsement | 0d | 2025-07-31 | 2025-07-31 | 2128FS+4d | start no earlier than 2025-04-02 |
| 2130 | **Codification of Service** | 81d | 2025-05-09 A | 2025-08-29 |  |  |
| 2131 | OFGEM Review Meeting | 0d | 2025-05-09 A | 2025-05-09 A |  | start no earlier than 2025-04-04 |
| 2132 | Codification Update at TORWG | 0d | 2025-05-14 A | 2025-05-14 A | 2131 | start no earlier than 2025-05-14 |
| 2133 | "Codify Service Management" Item Preparation | 36d | 2025-05-14 A | 2025-07-02 | 2132 |  |
| 2134 | "Codify Service Management" - Item raised | 0d | 2025-07-02 | 2025-07-02 | 2133 | start no earlier than 2025-07-02 |
| 2135 | Committee Views Ahead of Panel | 6d | 2025-07-03 | 2025-07-10 | 2134 |  |
| 2136 | Initial Panel Committee Views | 0d | 2025-07-10 | 2025-07-10 | 2135 | start no earlier than 2025-07-10 |
| 2137 | Consultation on Codify Service Management | 10d | 2025-07-14 | 2025-07-25 | 2136FS+1d | finish no earlier than 2025-07-25 |
| 2138 | Committee Views Ahead of Final Panel | 14d | 2025-07-28 | 2025-08-14 | 2137 |  |
| 2139 | Final Panel Committee Views | 0d | 2025-08-14 | 2025-08-14 | 2138 | start no earlier than 2025-08-14 |
| 2140 | Submission for Decision to Ofgem ("Codify Service Management") | 0d | 2025-08-18 | 2025-08-18 | 2139FS+1d | start no earlier than 2025-08-18 |
| 2141 | "Codify Service Management" Final Decision Process | 10d | 2025-08-18 | 2025-08-29 | 2140 |  |
| 2142 | "Codify Service Management" Decision Due (TBC and Indicitavely by End of Aug) | 0d | 2025-08-29 | 2025-08-29 | 2141 | start no earlier than 2025-08-29 |
| 2143 | **Service Go-Live** | 522d | 2025-07-31 | 2027-07-30 |  |  |
| 2144 | Service Management Go/No Go Decision | 0d | 2025-07-31 | 2025-07-31 | 2091, 2097, 2120, 2126 | start no earlier than 2025-07-31 |
| 2145 | Helix Service Management Live | 0d | 2025-07-31 | 2025-07-31 | 2144 |  |
| 2146 | Registration of LDSOs into ServiceNow | 3d | 2025-07-31 | 2025-08-04 | 2145 |  |
| 2147 | Helix Service Management Live for LDSO DIP Onboarding | 0d | 2025-08-04 | 2025-08-04 | 2146 | start no earlier than 2025-08-04 |
| 2148 | Helix Service Management Live for MHHS Enduring Arrangements | 500d | 2025-09-01 | 2027-07-30 | 2151 | start no earlier than 2025-09-01 |
| 2149 | **Business Readiness (inc DIP)** | 436d? | 2024-04-02 A | 2025-12-02 |  |  |
| 2150 | Knowledge Transfer triage | 35d? | 2025-04-28 A | 2025-06-13 |  | start no earlier than 2025-04-28 |
| 2151 | Elexon Leading Triage | 55d | 2025-06-16 | 2025-08-29 | 2150 | start no earlier than 2025-06-16 |
| 2152 | MHHS Transition (Knowledge Transfer) | 64d | 2025-05-06 A | 2025-08-01 |  | start no earlier than 2025-05-06 |
| 2153 | Artefact Handshake with MHHS | 0d | 2025-08-01 | 2025-08-01 | 2152 |  |
| 2154 | Operational Control Centre (OCC) Development | 85d | 2025-04-07 A | 2025-08-01 |  | start no earlier than 2025-04-07 |
| 2155 | Operational Control Centre (OCC) Live | 0d | 2025-08-04 | 2025-08-04 | 2154FS+1d |  |
| 2156 | **Service Activation Readiness** | 436d? | 2024-04-02 A | 2025-12-02 |  |  |
| 2158 | **Business Service Activation Governance, Planning & Scope** | 128d | 2024-04-04 A | 2024-09-30 A |  |  |
| 2159 | Create and Confirm SA Scope | 9d | 2024-06-03 A | 2024-06-13 A |  | finish no earlier than 2024-06-13 |
| 2160 | POAP Service Activation | 13d | 2024-06-03 A | 2024-06-19 A |  | finish no earlier than 2024-06-19 |
| 2161 | Service Activation Working Group | 62d | 2024-04-04 A | 2024-06-28 A |  | finish no earlier than 2024-06-28 |
| 2162 | Business Readiness Governance Framework | 42d | 2024-08-02 A | 2024-09-30 A |  | finish no earlier than 2024-09-30 |
| 2163 | Service Activation Governance Framework Completed | 0d | 2024-09-30 A | 2024-09-30 A | 2159, 2160, 2161, 2162 | finish no earlier than 2024-06-28 |
| 2164 | **Service Activation High Level Process Models** | 109d | 2024-04-02 A | 2024-08-31 A |  |  |
| 2165 | Transition Process Model | 70d | 2024-04-02 A | 2024-07-08 A |  | finish no earlier than 2024-07-08 |
| 2166 | Migration Process Model | 14d | 2024-08-13 A | 2024-08-30 A |  | finish no earlier than 2024-08-31 |
| 2167 | Enduring Process Model | 44d | 2024-06-03 A | 2024-08-01 A |  | start no earlier than 2024-06-01 |
| 2168 | Service Activation High Level Process Models Completed | 0d | 2024-08-31 A | 2024-08-31 A | 2165, 2166, 2167 | start no earlier than 2024-08-31 |
| 2169 | **Target Operating Model for Service Activation** | 83d | 2024-06-21 A | 2024-10-15 A |  |  |
| 2170 | MHHSP Engagement Team understanding | 25d | 2024-06-21 A | 2024-07-25 A |  | finish no earlier than 2024-07-25 |
| 2171 | Define and produce organisation model for Service Activation in Elexon | 83d | 2024-06-21 A | 2024-10-15 A |  | finish no earlier than 2024-10-15 |
| 2172 | Implement Target Operating model | 1d | 2024-10-15 A | 2024-10-15 A |  | start no earlier than 2024-10-15 |
| 2173 | Target Operating Model for Service Activation Completed | 0d | 2024-10-15 A | 2024-10-15 A | 2170, 2171, 2172 | start no earlier than 2024-10-15 |
| 2174 | **SIT Operational Testing for Service Activation** | 5d? | 2024-08-12 A | 2024-08-16 A |  |  |
| 2175 | Review and validate test cases | 5d | 2024-08-12 A | 2024-08-16 A |  | finish no earlier than 2024-08-16 |
| 2176 | SIT Operational Testing for Service Activation Completed | 1d? | 2024-08-16 A | 2024-08-16 A |  | start no earlier than 2024-08-16 |
| 2177 | **Operational Training for Service Activation** | 182d | 2024-11-13 A | 2025-07-25 |  |  |
| 2178 | Training Execution [Placeholder] | 153d | 2024-11-13 A | 2025-06-13 |  | start no earlier than 2024-11-13 |
| 2179 | Service Activation Training Completed | 0d | 2025-07-25 | 2025-07-25 |  | start no earlier than 2025-07-25 |
| 2180 | **Service Activation Readiness** | 7d | 2025-08-04 | 2025-08-12 |  |  |
| 2181 | Dress Rehearsal 1 | 2d | 2025-08-04 | 2025-08-05 | 2163, 2168, 2173, 2179 | start no earlier than 2025-08-04 |
| 2182 | Dress Rehearsal 1 Complete | 0d | 2025-08-05 | 2025-08-05 | 2181 | start no earlier than 2025-01-22 |
| 2183 | Dress Rehearsal 2 | 2d | 2025-08-11 | 2025-08-12 | 2182FS+3d | start no earlier than 2025-08-04 |
| 2184 | Dress Rehearsal 2 Complete | 0d | 2025-08-12 | 2025-08-12 | 2183 | start no earlier than 2025-01-22 |
| 2185 | **Service Activation Go / No Go** | 8d | 2025-08-13 | 2025-08-22 |  |  |
| 2186 | **Final Service Activation Go/No Go Decision** | 7d | 2025-08-13 | 2025-08-22 |  |  |
| 2187 | DIP Team Ready | 1d | 2025-08-13 | 2025-08-13 | 2184, 2182 |  |
| 2188 | DIP Technical Onboarding Processes Completed | 0d | 2025-08-22 | 2025-08-22 |  | start no earlier than 2025-08-22 |
| 2189 | PM Team Ready | 0d | 2025-08-22 | 2025-08-22 | 2182, 2184 | start no earlier than 2025-08-22 |
| 2190 | Operational Support Ready (Ops Control Centre, Account Managers) | 0d | 2025-08-22 | 2025-08-22 |  | start no earlier than 2025-08-22 |
| 2191 | Service Management Activity Completed (Resolver Groups) | 0d | 2025-08-22 | 2025-08-22 |  | start no earlier than 2025-08-22 |
| 2192 | Process 1.1.1 ISD and Related LWIs Completed | 0d | 2025-08-22 | 2025-08-22 | 2191 |  |
| 2193 | Service Activation Go / No Go | 0d | 2025-08-22 | 2025-08-22 | 2188FF, 2189FF, 2190FF, 2191FF, 2155FF, 2192FF | finish no earlier than 2025-08-22 |
| 2194 | **SOLR Consultation** | 122d | 2025-04-10 A | 2025-09-26 | 2193 |  |
| 2195 | SOLR workshop 1 | 1d | 2025-04-10 A | 2025-04-10 A | 2193SF | start no earlier than 2025-04-10 |
| 2196 | SOLR workshop 2 | 1d | 2025-04-29 A | 2025-04-29 A | 2193SF | start no earlier than 2025-04-29 |
| 2197 | SOLR consultation | 23d | 2025-08-27 | 2025-09-26 | 2193SF | finish no earlier than 2025-09-26 |
| 2198 | SOLR comms to MHHS for review | 1d | 2025-08-26 | 2025-08-26 |  | finish no earlier than 2025-08-26 |
| 2199 | **MDR Process** | 77d | 2025-04-16 A | 2025-07-31 |  |  |
| 2200 | MDR workshop 1 | 1d | 2025-04-16 A | 2025-04-16 A |  | start no earlier than 2025-04-16 |
| 2201 | MDR workshop 2 | 1d | 2025-04-30 A | 2025-04-30 A |  | start no earlier than 2025-04-30 |
| 2202 | MDR workshop | 1d | 2025-05-27 A | 2025-05-27 A |  | start no earlier than 2025-05-27 |
| 2203 | MDR consultation | 12d | 2025-05-06 A | 2025-05-21 A |  | start no earlier than 2025-05-06 |
| 2204 | MDR consultation ongoing actions | 62d | 2025-05-07 A | 2025-07-31 |  | start no earlier than 2025-05-07 |
| 2205 | **Phase 2 - Implementation** | 388d? | 2024-06-07 A | 2025-12-02 |  |  |
| 2206 | **Non-SIT LDSO & SIT MVC Data Loading (M10 Ready)** | 6d | 2024-06-07 A | 2024-06-14 A |  |  |
| 2207 | Define Non-SIT LDSO Upfront Activities | 6d | 2024-06-07 A | 2024-06-14 A |  | finish no earlier than 2024-06-15 |
| 2208 | **M10-Ready Activation Preparation Tasks** | 11d? | 2025-08-25 | 2025-09-08 | 2207 |  |
| 2209 | Identify Resources | 1d | 2025-08-25 | 2025-08-25 |  | start no earlier than 2025-08-25 |
| 2210 | Confirmation from Qualification of Wave Participants Complete | 0d | 2025-08-25 | 2025-08-25 |  | start no earlier than 2025-08-25 |
| 2211 | Agree & Understand Support Model | 1d | 2025-08-26 | 2025-08-26 |  | start no earlier than 2025-08-26 |
| 2212 | Confirm Training complete | 0d | 2025-08-27 | 2025-08-27 |  | start no earlier than 2025-08-27 |
| 2213 | Confirm IDNOs gobal sigin comleted prior to M10 | 1d | 2025-08-28 | 2025-08-28 |  | start no earlier than 2025-08-28 |
| 2214 | Engagement / Communications with Participants | 1d | 2025-08-29 | 2025-08-29 |  | start no earlier than 2025-08-29 |
| 2215 | **Internal Communications** | 1d | 2025-09-01 | 2025-09-01 |  |  |
| 2216 | Agree Content for Livewire | 1d | 2025-09-01 | 2025-09-01 |  | start no earlier than 2025-09-01 |
| 2217 | Publish Content for Livewire | 0d | 2025-09-01 | 2025-09-01 |  | start no earlier than 2025-09-01 |
| 2220 | Publish the guidence with Parties | 1d | 2025-09-04 | 2025-09-04 |  | start no earlier than 2025-09-04 |
| 2221 | Provide LWIs | 1d? | 2025-09-05 | 2025-09-05 | 2220 |  |
| 2223 | M10-Ready Participants Service Activation Preparation Completed | 0d | 2025-09-08 | 2025-09-08 | 2209, 2211, 2212, 2213, 2214, 2215, 2218, 2219, 2220, 2222 | start no earlier than 2025-09-05 |
| 2224 | **M10-Ready (Inlcuding Non-SIT LDSOs) Service Activation Implementation** | 31d? | 2025-08-06 | 2025-09-19 |  |  |
| 2225 | MHHSP Enabled Confirmation | 0d | 2025-09-10 | 2025-09-10 | 2418, 2421, 2424 | start no earlier than 2025-09-08 |
| 2226 | PAB Approval Completed | 0d | 2025-09-10 | 2025-09-10 |  | start no earlier than 2025-09-10 |
| 2227 | Add EFD (ISD Calendar Date) to DIP | 1d | 2025-09-11 | 2025-09-11 | 2218, 2219, 2222, 2225, 2226 | start no earlier than 2025-09-11 |
| 2229 | Create M16 in Customer Solution Started | 0d | 2025-09-11 | 2025-09-11 |  | start no earlier than 2025-09-11 |
| 2231 | DIP Production Success Checks | 1d? | 2025-09-12 | 2025-09-12 | 2227, 2230 |  |
| 2232 | 1st ISD Publish Started | 0d | 2025-09-11 | 2025-09-11 |  | start no earlier than 2025-09-11 |
| 2233 | 1st ISD Publish | 6d | 2025-09-11 | 2025-09-18 | 2227SS, 2232SS | start no earlier than 2025-09-11 |
| 2234 | Go Live ISD | 1d? | 2025-09-18 | 2025-09-18 |  | start no earlier than 2025-09-18 |
| 2235 | M10-Ready Service Activation Implementation Completed | 0d | 2025-09-19 | 2025-09-19 | 2225, 2226, 2227, 2228, 2230, 2233, 2234 | start no earlier than 2025-09-19 |
| 2236 | Non-SIT LDSO Service Activation Data Loading Completed | 0d | 2025-08-06 | 2025-08-06 |  | finish no earlier than 2025-08-06 |
| 2237 | **M10-Ready Service Activation Implementation MDD** | 7d | 2025-09-10 | 2025-09-19 |  |  |
| 2238 | MDD Final Circular Completed | 0d | 2025-09-10 | 2025-09-10 | 2222 | finish no earlier than 2025-09-10 |
| 2239 | MDD Manual Update | 3d | 2025-09-11 | 2025-09-15 | 2238FF | finish no earlier than 2025-09-15 |
| 2240 | MDD Publish | 6d | 2025-09-11 | 2025-09-18 | 2239SF | finish no earlier than 2025-09-18 |
| 2241 | MDD Go Live | 0d | 2025-09-18 | 2025-09-18 | 2240 | finish no earlier than 2025-09-18 |
| 2242 | Non-SIT LDSO & SIT MVC Service Activation Implementation MDD Completed | 0d | 2025-09-18 | 2025-09-18 | 2238, 2239, 2240, 2241 | finish no earlier than 2025-09-18 |
| 2243 | Non-SIT LDSO & SIT MVC Service Activation Implementation MDD Completed | 0d | 2025-09-19 | 2025-09-19 | 2242 | finish no earlier than 2025-09-19 |
| 2244 | **Non-SIT LDSO & SIT MVC Service Activation Hypercare (M10 Ready)** | 54d | 2025-09-18 | 2025-12-02 |  |  |
| 2245 | Monitoring | 54d | 2025-09-18 | 2025-12-02 |  | finish no earlier than 2025-12-02 |
| 2246 | Reporting | 54d | 2025-09-18 | 2025-12-02 |  | start no earlier than 2025-09-18 |
| 2248 | Closed Down Activities | 1d | 2025-09-19 | 2025-09-19 | 2245SS, 2246SS, 2247SS | finish no earlier than 2025-09-19 |
| 2249 | Inform MHHSP | 1d | 2025-09-19 | 2025-09-19 | 2248SS | finish no earlier than 2025-09-19 |
| 2250 | **DIP Guidance Notes** | 55d | 2025-05-05 A | 2025-07-18 |  |  |
| 2251 | GN/LWI creation & publication | 55d | 2025-05-05 A | 2025-07-18 |  | start no earlier than 2025-05-05 |
| 2252 | Tranche 1 GN/LWI created & published (critical for M10) | 0d | 2025-06-20 | 2025-06-20 |  | start no earlier than 2025-06-20 |
| 2253 | Tranche 2 GN/LWI created & published | 0d | 2025-07-04 | 2025-07-04 |  | start no earlier than 2025-07-04 |
| 2254 | Tranche 3 GN/LWI created & published | 0d | 2025-07-18 | 2025-07-18 |  | start no earlier than 2025-07-18 |
| 2255 | DIP Reporting (M11) | 65d | 2025-05-12 A | 2025-08-08 |  | start no earlier than 2025-05-12 |
| 2256 | Functional Training Execution | 85d | 2025-05-05 A | 2025-08-29 |  | start no earlier than 2025-05-05 |
| 2257 | **Operational Readiness E2E Testing** | 64d | 2025-05-13 A | 2025-08-08 |  |  |
| 2258 | Phase 1 Test Execution (Service Activation and Participant Management) | 34d | 2025-05-13 A | 2025-06-27 |  | start no earlier than 2025-05-13 |
| 2259 | Phase 2 Test Execution (S&I) | 25d | 2025-06-03 A | 2025-07-07 |  | start no earlier than 2025-06-03 |
| 2260 | Phase 3 Test Execution (Assurance & mop-up) | 23d | 2025-06-30 | 2025-07-30 |  | start no earlier than 2025-06-30 |
| 2261 | E2E Operational Testing Completed | 0d | 2025-08-08 | 2025-08-08 | 2258, 2259, 2260 | finish no earlier than 2025-08-08 |
| 2262 | **Helix Solution Build** | 254d? | 2024-08-19 A | 2025-08-07 |  |  |
| 2263 | M10 Build | 32d | 2025-04-28 A | 2025-06-10 |  | start no earlier than 2025-04-28 |
| 2264 | Helix Code Uplifts (TBC) | 40d? | 2025-06-11 | 2025-08-05 | 2263 |  |
| 2265 | **Helix E2E Settlement Assurance Testing (SAT)** | 254d? | 2024-08-19 A | 2025-08-07 |  |  |
| 2266 | **Test design** | 125d | 2024-09-02 A | 2025-02-21 A |  |  |
| 2267 | SAT tests (Review and finalise) | 95d | 2024-09-02 A | 2025-01-10 A |  | start no earlier than 2024-09-02 |
| 2268 | Test Automation and Supporting Tools | 80d | 2024-11-04 A | 2025-02-21 A |  | start no earlier than 2024-11-04 |
| 2269 | SAT tests batch 3 | 50d | 2024-12-16 A | 2025-02-21 A |  | start no earlier than 2024-12-16 |
| 2270 | **Data and environment** | 120d? | 2024-08-19 A | 2025-01-31 A |  |  |
| 2271 | Data and environment requirements | 55d | 2024-08-19 A | 2024-11-01 A |  | start no earlier than 2024-08-19 |
| 2272 | Data sourcing | 95d | 2024-09-02 A | 2025-01-10 A |  | start no earlier than 2024-09-02 |
| 2273 | Environment data check | 15d? | 2025-01-13 A | 2025-01-31 A | 2272 |  |
| 2274 | **Execution** | 194d? | 2024-11-11 A | 2025-08-07 |  |  |
| 2275 | Trial test runs | 50d | 2024-11-11 A | 2025-01-17 A |  | start no earlier than 2024-11-11 |
| 2276 | Test planning prioritisation | 14d | 2025-01-20 A | 2025-02-06 A | 2275 |  |
| 2277 | Programme agreement to start SAT testing | 0d | 2025-02-06 A | 2025-02-06 A | 2276 |  |
| 2278 | SAT Testing Start | 0d | 2025-02-06 A | 2025-02-06 A | 2277 |  |
| 2279 | **SAT Cycle 1** | 114d? | 2025-02-07 A | 2025-07-16 | 2278 |  |
| 2280 | **Legacy** | 99d | 2025-02-07 A | 2025-06-25 |  |  |
| 2281 | GMT | 89d | 2025-02-07 A | 2025-06-11 |  |  |
| 2282 | P0210 file shared for NESO Validation | 0d | 2025-05-23 A | 2025-05-23 A |  | start no earlier than 2025-05-23 |
| 2283 | NESO Validation Period (GMT) | 5d | 2025-05-28 A | 2025-06-03 A | 2282 | start no earlier than 2025-05-28 |
| 2284 | Long | 13d | 2025-05-28 | 2025-06-13 |  | start no earlier than 2025-05-28 |
| 2285 | Helix SAT Confidence Check 1 | 0d | 2025-06-10 | 2025-06-10 |  | finish no earlier than 2025-06-10 |
| 2286 | P0210 file shared for NESO Validation | 0d | 2025-06-13 | 2025-06-13 | 2284 | start no earlier than 2025-06-13 |
| 2287 | Helix SAT Confidence Check 2 | 0d | 2025-06-13 | 2025-06-13 |  | finish no earlier than 2025-06-13 |
| 2288 | NESO Validation Period (Long) | 5d | 2025-06-16 | 2025-06-20 | 2286 | start no earlier than 2025-06-16 |
| 2289 | SAT Confidence Assessment | 0d | 2025-06-13 A | 2025-06-13 |  | start no earlier than 2025-06-13 |
| 2290 | BST | 13d | 2025-06-02 | 2025-06-18 |  | start no earlier than 2025-06-02 |
| 2291 | P0210 file shared for NESO Validation | 0d | 2025-06-18 | 2025-06-18 | 2290 |  |
| 2292 | NESO Validation Period (BST) | 5d | 2025-06-19 | 2025-06-25 |  | start no earlier than 2025-06-19 |
| 2293 | Trading Dispute | 3d | 2025-06-18 | 2025-06-20 |  | start no earlier than 2025-06-18 |
| 2294 | **Transition** | 36d? | 2025-05-28 A | 2025-07-16 |  |  |
| 2295 | GMT | 19d | 2025-05-28 A | 2025-06-23 |  | start no earlier than 2025-05-28 |
| 2296 | P0210 file shared for NESO Validation | 1d? | 2025-06-13 | 2025-06-13 |  | finish no earlier than 2025-06-13 |
| 2297 | NESO Validation Period (GMT) | 5d | 2025-06-17 | 2025-06-23 | 2296 | finish no earlier than 2025-06-23 |
| 2298 | Long | 4d | 2025-06-24 | 2025-06-27 |  | start no earlier than 2025-06-24 |
| 2299 | P0210 file shared for NESO Validation | 0d | 2025-06-27 | 2025-06-27 | 2298 |  |
| 2300 | NESO Validation Period (Long) | 5d | 2025-06-30 | 2025-07-04 | 2299 | start no earlier than 2025-06-30 |
| 2301 | BST | 4d | 2025-06-26 | 2025-07-01 |  | start no earlier than 2025-06-26 |
| 2302 | P0210 file shared for NESO Validation | 0d | 2025-07-01 | 2025-07-01 | 2301 |  |
| 2303 | NESO Validation Period (BST) | 5d | 2025-07-03 | 2025-07-09 | 2302 | finish no earlier than 2025-07-09 |
| 2304 | Short | 3d | 2025-07-01 | 2025-07-03 |  | start no earlier than 2025-07-01 |
| 2305 | P0210 file shared for NESO Validation | 0d | 2025-07-03 | 2025-07-03 | 2304 |  |
| 2306 | NESO Validation Period (Short) | 5d | 2025-07-04 | 2025-07-10 | 2305 | start no earlier than 2025-07-04 |
| 2307 | DCP MPAN Mig | 3d | 2025-07-01 A | 2025-07-03 A |  | start no earlier than 2025-07-01 |
| 2308 | ISD | 3d | 2025-07-01 | 2025-07-03 |  | start no earlier than 2025-07-01 |
| 2309 | Data Agg | 6d | 2025-07-04 | 2025-07-11 |  | start no earlier than 2025-07-04 |
| 2310 | M16 | 3d | 2025-07-14 | 2025-07-16 |  | start no earlier than 2025-07-14 |
| 2311 | End of Cycle 1 | 0d | 2025-07-16 | 2025-07-16 |  | start no earlier than 2025-07-16 |
| 2312 | **SAT Cycle 2** | 12d | 2025-07-17 | 2025-08-01 |  |  |
| 2313 | **Legacy** | 12d | 2025-07-17 | 2025-08-01 |  |  |
| 2314 | Pre-M10 | 1d | 2025-07-17 | 2025-07-17 |  | start no earlier than 2025-07-17 |
| 2315 | GMT & BST & Long | 6d | 2025-07-18 | 2025-07-25 |  | start no earlier than 2025-07-18 |
| 2316 | NESO Validation Period (GMT & BST & Long) | 5d | 2025-07-28 | 2025-08-01 | 2315 |  |
| 2317 | Trading Dispute | 2d | 2025-07-28 | 2025-07-29 |  | start no earlier than 2025-07-28 |
| 2318 | **Transition** | 4d | 2025-07-24 | 2025-07-29 |  |  |
| 2319 | ISD | 4d | 2025-07-24 | 2025-07-29 |  | start no earlier than 2025-07-24 |
| 2320 | Data Agg | 3d | 2025-07-24 | 2025-07-28 |  | start no earlier than 2025-07-24 |
| 2321 | End of Cycle 2 | 0d | 2025-08-01 | 2025-08-01 |  | start no earlier than 2025-08-01 |
| 2322 | SAT Exit Report | 5d | 2025-08-01 | 2025-08-07 | 2321 |  |
| 2323 | SAT Complete | 0d | 2025-08-01 | 2025-08-01 |  | start no earlier than 2025-08-01 |
| 2324 | DR Testing | 30d | 2025-04-28 | 2025-06-06 |  | start no earlier than 2025-04-28 |
| 2325 | Pen Testing | 40d? | 2025-04-28 | 2025-06-20 |  | start no earlier than 2025-04-28 |
| 2326 | Post Environment Build | 24d | 2025-06-30 | 2025-07-31 |  | finish no earlier than 2025-07-31 |
| 2327 | Production Environment Base Platform Sign-off | 0d | 2025-07-31 | 2025-07-31 | 2326FF | start no earlier than 2025-07-31 |
| 2328 | **Implementation (Helix & DIP)** | 116d | 2025-04-28 | 2025-10-06 |  |  |
| 2329 | Go / No-Go (DIP & SM) | 0d | 2025-07-31 | 2025-07-31 |  | start no earlier than 2025-07-31 |
| 2330 | Implementation Readiness (inc Technical Readiness, Approach and Runbook, Walkthrough / Rehearsals | 69d | 2025-04-28 | 2025-07-31 |  | start no earlier than 2025-04-28 |
| 2331 | M10 Implementation Approach & Go-Live Runbook | 30d | 2025-04-28 | 2025-06-06 |  | start no earlier than 2025-04-28 |
| 2332 | DIP Production Build | 15d | 2025-06-09 | 2025-06-27 |  | start no earlier than 2025-06-09 |
| 2333 | Final Production Deployment | 15d | 2025-07-07 | 2025-07-25 |  | start no earlier than 2025-07-07 |
| 2334 | DIP Portal Available | 0d | 2025-08-04 | 2025-08-04 | 2333FS+6d |  |
| 2335 | DIP Technical Onboarding for LDSOs | 36d | 2025-08-05 | 2025-09-23 | 2333, 2334, 2147, 2329 |  |
| 2336 | ISD Dress Rehearsals | 25d | 2025-07-07 | 2025-08-08 |  | start no earlier than 2025-07-07 |
| 2337 | Go / No-Go (Helix Central Systems) | 0d | 2025-08-11 | 2025-08-11 | 2323, 1608, 2327 | start no earlier than 2025-08-11 |
| 2338 | Service Activation Implementation | 8d | 2025-08-15 | 2025-08-26 | 2337FS+4d |  |
| 2339 | ISD Data Migration | 8d | 2025-08-15 | 2025-08-26 | 2337FS+4d, 2322 |  |
| 2340 | DAH & ISD Dark Mode | 0d | 2025-08-26 | 2025-08-26 | 2339 |  |
| 2341 | Dual Run (Pre-Prod) | 15d | 2025-08-27 | 2025-09-16 | 2340 |  |
| 2342 | DIP Technical Onboarding for LDSOs | 26d | 2025-08-04 | 2025-09-08 | 2147FS-1d | start no earlier than 2025-08-04 |
| 2343 | M10 Cutover Weekend | 1d | 2025-09-22 | 2025-09-22 | 2341FS+3d |  |
| 2344 | Post Implementation Review | 1d | 2025-10-06 | 2025-10-06 | 2343FS+9d |  |
| 2416 | **SIT / LDSO Pathway 1** | 16d | 2025-07-23 | 2025-08-13 |  |  |
| 2419 | **SIT / LDSO Pathway 2** | 16d | 2025-08-07 | 2025-08-28 |  |  |
| 2420 | QAD Sign Off Deadline + Test Reports | 0d | 2025-08-07 | 2025-08-07 | 2415, 1692FF | start no earlier than 2025-08-07 |
| 2421 | REC Code Manager / BSC PAB Approval of Qualification (M10-Ready) | 0d | 2025-08-28 | 2025-08-28 | 2420FS+16d |  |
| 2422 | **SIT / LDSO Pathway 3** | 13d | 2025-08-22 | 2025-09-10 |  |  |
| 2423 | QAD Sign Off Deadline + Test Reports | 0d | 2025-08-22 | 2025-08-22 | 2415, 1758, 1692FF |  |
| 2424 | REC Code Manager / BSC PAB Approval of Qualification (M10-Ready) | 2d | 2025-09-09 | 2025-09-10 | 2423FS+11d |  |
| 2425 | M10-Ready SIT Participants are qualified | 0d | 2025-09-10 | 2025-09-10 | 2424 |  |
| 2426 | **MHHS Qualification - M11-Ready** | 137d? | 2025-04-07 A | 2025-10-15 |  |  |
| 2427 | Final QAD Submission Window opens | 0d | 2025-04-07 A | 2025-04-07 A | 2410, 2406, 2411FS+1d |  |
| 2428 | SIT M11-ready Participants submit Final QAD (exc Test Reports) | 44d | 2025-04-08 A | 2025-06-06 | 2427 |  |
| 2429 | Completion of Code Bodies review of Final QAD (M11-Ready) | 20d? | 2025-06-09 | 2025-07-04 | 2428 |  |
| 2430 | **SIT Pathway 4** | 16d | 2025-09-04 | 2025-09-25 |  |  |
| 2431 | QAD Sign Off Deadline + Test Reports | 0d | 2025-09-04 | 2025-09-04 | 2429, 1692FF | start no earlier than 2025-09-04 |
| 2432 | REC Code Manager / BSC PAB Approval of Qualification (M11-Ready) | 0d | 2025-09-25 | 2025-09-25 | 2431FS+16d |  |
| 2433 | **SIT Pathway 5** | 16d | 2025-09-24 | 2025-10-15 |  |  |
| 2434 | QAD Sign Off Deadline + Test Reports | 0d | 2025-09-24 | 2025-09-24 | 2429, 1692FF | start no earlier than 2025-09-24 |
| 2435 | REC Code Manager / BSC PAB Approval of Qualification | 0d | 2025-10-15 | 2025-10-15 | 2434FS+16d |  |
| 2436 | 'M11-Ready SIT Participants are qualified' | 0d | 2025-10-15 | 2025-10-15 | 2435 |  |
| 2441 | **SIT Pathway 6** | 15d | 2025-11-27 | 2025-12-17 |  |  |
| 2454 | QAD Finalisation | 45d | 2025-06-23 | 2025-08-22 | 2453 |  |
| 2993 | Drop-in session 4 | 0d | 2025-06-18 | 2025-06-18 | 2992FS+5d | start no earlier than 2025-06-18 |
| 3003 | Test Scripts shared with Participants | 0d | 2025-06-02 A | 2025-06-02 A |  | start no earlier than 2025-06-02 |
| 3004 | Dress rehearsal 1 start | 0d | 2025-06-09 | 2025-06-09 |  | start no earlier than 2025-06-09 |
| 3005 | Supplier Schedule Submission #2 complete | 1d | 2025-06-20 | 2025-06-20 |  | start no earlier than 2025-06-20 |
| 3006 | Consolidate baseline schedule | 15d | 2025-06-23 | 2025-07-11 | 3005 |  |
| 3007 | Consolidated baseline schedule published to industry | 0d | 2025-07-11 | 2025-07-11 | 3006 |  |
| 3008 | Baselined Schedule available for download | 1d | 2025-07-14 | 2025-07-14 | 3007 |  |
| 3012 | MCAG approval of Baseline Migration schedule | 0d | 2025-07-22 | 2025-07-22 | 3011 | finish no earlier than 2025-07-22 |
| 3022 | M11 Readiness Checkpoint | 45d | 2025-07-28 | 2025-09-26 |  | finish no earlier than 2025-09-26 |
| 3335 | **Phase 1 - Preparation** | 1d? | 2022-10-31 A | 2022-10-31 |  |  |
| 3336 | **Business Service Activation Governance, Planning & Scope** | 1d | 2022-10-31 | 2022-10-31 |  |  |
| 3337 | Create and Confirm SA Scope | 9d | 2024-06-03 A | 2024-06-13 A |  | start no earlier than 2024-06-03 |
| 3338 | POAP Service Activation | 13d | 2024-06-03 A | 2024-06-19 A |  | start no earlier than 2024-06-03 |
| 3339 | Service Activation Working Group | 62d | 2024-04-04 A | 2024-06-28 A |  | start no earlier than 2024-04-04 |
| 3340 | Business Readiness Governance Framework | 42d | 2024-08-02 A | 2024-09-30 A |  | start no earlier than 2024-08-02 |
| 3341 | Service Activation Governance Framework Completed | 0d | 2024-09-30 A | 2024-09-30 A | 3337, 3338, 3339, 3340 |  |
| 3342 | **Service Activation High Level Process Models** | 1d | 2022-10-31 | 2022-10-31 |  |  |
| 3343 | Transition Process Model | 70d | 2024-04-02 A | 2024-07-08 A |  | start no earlier than 2024-04-02 |
| 3344 | Migration Process Model | 14d | 2024-08-13 A | 2024-08-30 A |  | start no earlier than 2024-08-13 |
| 3345 | Enduring Process Model | 44d | 2024-06-03 A | 2024-08-01 A |  | start no earlier than 2024-06-03 |
| 3346 | Service Activation High Level Process Models Completed | 0d | 2024-08-30 A | 2024-08-30 A | 3343, 3344, 3345 |  |
| 3347 | **Target Operating Model for Service Activation** | 1d? | 2022-10-31 | 2022-10-31 |  |  |
| 3348 | MHHSP Engagement Team understanding | 25d | 2024-06-21 A | 2024-07-25 A |  | start no earlier than 2024-06-21 |
| 3349 | Define and produce organisation model for Service Activation in Elexon | 83d | 2024-06-21 A | 2024-10-15 A |  | start no earlier than 2024-06-21 |
| 3350 | Implement Target Operating model | 1d | 2024-10-15 A | 2024-10-15 A |  | start no earlier than 2024-10-15 |
| 3351 | Target Operating Model for Service Activation Completed | 0d | 2024-10-15 A | 2024-10-15 A | 3348, 3349, 3350 |  |
| 3352 | **SIT Operational Testing for Service Activation** | 5d | 2024-08-12 A | 2024-08-16 A |  |  |
| 3353 | Review and validate test cases | 5d | 2024-08-12 A | 2024-08-16 A |  | start no earlier than 2024-08-12 |
| 3354 | SIT Operational Testing for Service Activation Completed | 0d | 2024-08-16 A | 2024-08-16 A | 3353 |  |
| 3355 | **Operational Readiness E2E Testing** | 1d | 2022-10-31 | 2022-10-31 |  |  |
| 3356 | Define Service Activation Scenarios & Scripts | 25d | 2024-07-29 A | 2024-08-30 A |  | start no earlier than 2024-07-29 |
| 3357 | Define Service Activation Test plan | 10d | 2024-08-19 A | 2024-08-30 A |  | start no earlier than 2024-08-19 |
| 3358 | Test Execution [Placeholder] | 26d | 2025-04-01 | 2025-05-06 |  | start no earlier than 2025-04-01 |
| 3359 | Service Activation Test Scenarios Completed | 0d | 2025-05-06 | 2025-05-06 | 3358 |  |
| 3360 | **Operational Training for Service Activation** | 1d | 2022-10-31 | 2022-10-31 |  |  |
| 3361 | Training Execution [Placeholder] | 153d | 2024-11-13 | 2025-06-13 |  | start no earlier than 2024-11-13 |
| 3362 | Service Activation Training Completed | 0d | 2025-07-25 | 2025-07-25 |  | start no earlier than 2025-07-25 |
| 3363 | **Service Activation Readiness** | 1d | 2022-10-31 | 2022-10-31 |  |  |
| 3364 | Dress Rehearsal 1 | 2d | 2025-08-04 | 2025-08-05 | 3341, 3346, 3359, 3362, 3354 | start no earlier than 2025-08-04 |
| 3365 | Dress Rehearsal 1 Complete | 0d | 2025-08-05 | 2025-08-05 | 3364 |  |
| 3366 | Dress Rehearsal 2 | 2d | 2025-08-11 | 2025-08-12 | 3365FS+3d |  |
| 3367 | Dress Rehearsal 2 Complete | 0d | 2025-08-12 | 2025-08-12 | 3366 |  |
| 3368 | **Service Activation Go / No Go** | 1d? | 2022-10-31 | 2022-10-31 |  |  |
| 3369 | **Final Service Activation Go/No Go Decision** | 1d? | 2022-10-31 | 2022-10-31 |  |  |
| 3370 | DIP Team Ready | 1d? | 2025-08-22 | 2025-08-22 | 3364, 3366 | start no earlier than 2025-08-22 |
| 3371 | DIP Technical Onboarding Processes Completed | 0d | 2025-08-22 | 2025-08-22 |  | start no earlier than 2025-08-22 |
| 3372 | PM Team Ready | 1d? | 2025-08-21 | 2025-08-22 | 3364, 3366 | finish no earlier than 2025-08-22 |
| 3373 | Operational Support Ready (Ops Control Centre, Account Managers) | 1d? | 2025-08-21 | 2025-08-22 |  | finish no earlier than 2025-08-22 |
| 3374 | Service Management Activity Completed (Resolver Groups) | 1d? | 2025-08-21 | 2025-08-22 |  | finish no earlier than 2025-08-22 |
| 3375 | Process 1.1.1 ISD and Related LWIs Completed | 0d | 2025-08-22 | 2025-08-22 |  | start no earlier than 2025-08-22 |
| 3376 | Service Activation Go / No Go | 0d | 2025-08-22 | 2025-08-22 | 3371, 3375 |  |
| 3377 | **SOLR Consultation** | 1d | 2022-10-31 | 2022-10-31 | 3376 |  |
| 3378 | SOLR workshop 1 | 1d | 2024-04-10 A | 2024-04-10 A |  | start no earlier than 2024-04-10 |
| 3379 | SOLR workshop 2 | 1d | 2024-04-29 A | 2024-04-29 A |  | start no earlier than 2024-04-29 |
| 3380 | SOLR consultation | 23d | 2024-04-30 | 2024-05-30 |  | start no earlier than 2024-04-30 |
| 3381 | SOLR comms to MHHS for review | 0d | 2024-05-07 | 2024-05-07 |  | start no earlier than 2024-05-07 |
| 3382 | **MDR Process** | 1d | 2022-10-31 | 2022-10-31 |  |  |
| 3383 | MDR workshop 1 | 1d | 2025-04-16 A | 2025-04-16 A |  | start no earlier than 2024-04-16 |
| 3384 | MDR workshop 2 | 1d | 2025-04-30 A | 2025-04-30 A |  | start no earlier than 2024-04-30 |
| 3385 | MDR consultation | 18d | 2025-05-07 A | 2025-05-30 |  | start no earlier than 2024-05-07 |
| 3386 | **Phase 2 - Implementation** | 751d? | 2022-10-31 A | 2025-09-15 |  |  |
| 3387 | **Non-SIT LDSO & SIT MVC Data Loading (M10 Ready)** | 317d | 2024-06-07 A | 2025-08-25 |  |  |
| 3388 | Define Non-SIT LDSO Upfront Activities | 6d | 2024-06-07 A | 2024-06-14 A |  | finish no earlier than 2024-06-15 |
| 3389 | **Perform Non-SIT LDSO Activities (M10 Ready)** | 7d | 2025-08-15 | 2025-08-25 |  |  |
| 3390 | Create Entity Forms in Customer Solution | 2d | 2025-08-22 | 2025-08-25 |  | start no earlier than 2025-08-22 |
| 3391 | DIP - Add EFD to DIP | 2d | 2025-08-15 | 2025-08-18 |  | start no earlier than 2025-08-15 |
| 3392 | DIP - Promote to production Environment | 2d | 2025-08-19 | 2025-08-20 | 3391 |  |
| 3393 | DIP - Enable Technology capabilities for participants | 2d | 2025-08-15 | 2025-08-18 |  | start no earlier than 2025-08-15 |
| 3394 | ISD - Replicate Entity Forms from CS | 2d | 2025-08-15 | 2025-08-18 |  | start no earlier than 2025-08-15 |
| 3395 | ISD - Replicate Entity Forms from CS Completed | 0d | 2025-08-18 | 2025-08-18 | 3394, 3393 |  |
| 3396 | MDD - Load MHHS roles | 2d | 2025-08-15 | 2025-08-18 |  | start no earlier than 2025-08-15 |
| 3397 | Non-SIT LDSO Service Activation Data Loading Completed | 0d | 2025-08-25 | 2025-08-25 | 3394, 3395, 3396, 3389, 3391, 3392 |  |
| 3398 | **Non-SIT LDSO & SIT MCV Activation Preparation Tasks (M10 Ready)** | 1d? | 2022-10-31 | 2022-10-31 | 3390, 3392, 3393, 3397 |  |
| 3399 | Identify Resources | 1d | 2025-08-25 | 2025-08-25 | 3388, 3397FS-1d | start no earlier than 2025-08-25 |
| 3400 | Confirmation from Qualification of Wave Participants Complete | 0d | 2025-08-25 | 2025-08-25 |  | start no earlier than 2025-08-25 |
| 3401 | Agree & Understand Support Model | 1d | 2025-08-26 | 2025-08-26 |  | start no earlier than 2025-08-26 |
| 3402 | Confirm Training complete | 0d | 2025-08-27 | 2025-08-27 |  | start no earlier than 2025-08-27 |
| 3403 | Confirm IDNOs gobal sigin comleted prior to M10 | 1d | 2025-08-28 | 2025-08-28 |  | start no earlier than 2025-08-28 |
| 3404 | Engagement / Communications with Participants | 1d | 2025-08-29 | 2025-08-29 |  | start no earlier than 2025-08-29 |
| 3405 | **Internal Communications** | 1d | 2022-10-31 | 2022-10-31 |  |  |
| 3406 | Agree Content for Livewire | 1d | 2025-09-01 | 2025-09-01 |  | start no earlier than 2025-09-01 |
| 3407 | Publish Content for Livewire | 0d | 2025-09-01 | 2025-09-01 |  | start no earlier than 2025-09-01 |
| 3408 | Validate User Access | 1d | 2025-09-02 | 2025-09-02 |  | start no earlier than 2025-09-02 |
| 3409 | Target Systems and Environments Ready | 1d | 2025-09-03 | 2025-09-03 |  | start no earlier than 2025-09-03 |
| 3410 | Publish the guidence with Parties | 1d | 2025-09-04 | 2025-09-04 |  | start no earlier than 2025-09-04 |
| 3411 | Provide LWIs | 1d? | 2025-09-05 | 2025-09-05 |  | start no earlier than 2025-09-05 |
| 3412 | Business Readiness Governance Approval | 1d | 2025-09-05 | 2025-09-05 |  | start no earlier than 2025-09-05 |
| 3413 | Non-SIT LDSO & SIT MVC Service Activation Preparation Completed | 2d | 2025-09-05 | 2025-09-08 | 3399, 3401, 3402, 3403, 3404, 3405, 3408, 3409, 3410, 3412FS-1d |  |
| 3414 | **Non-SIT LDSO & SIT MVC Service Activation Implementation (M10 Ready Pathway 1)** | 1d? | 2022-10-31 | 2022-10-31 |  |  |
| 3415 | PAB Approval Completed | 0d | 2025-08-13 | 2025-08-13 | 2418 |  |
| 3416 | MHHSP Enabled Confirmation | 0d | 2025-08-13 | 2025-08-13 | 3415 |  |
| 3417 | Add EFD (ISD Calendar Date) to DIP | 1d | 2025-09-08 | 2025-09-08 | 3408, 3409, 3412, 3415, 3416, 3411 |  |
| 3419 | Create M16 in Customer Solution Started | 0d | 2022-10-31 | 2022-10-31 |  |  |
| 3421 | DIP Production Success Checks | 1d? | 2022-10-31 | 2022-10-31 |  |  |
| 3422 | 1st ISD Publish Started | 0d | 2022-10-31 | 2022-10-31 |  |  |
| 3423 | 1st ISD Publish | 6d | 2025-09-08 | 2025-09-15 | 3417SS, 3422SS |  |
| 3424 | Go-Live ISD | 1d? | 2022-10-31 | 2022-10-31 |  |  |
| 3425 | Non-SIT LDSO SIT MVC Service Activation Implementation Completed | 0d | 2025-09-15 | 2025-09-15 | 3415, 3417, 3418, 3420, 3423 |  |
| 3426 | **Non-SIT LDSO & SIT MVC Service Activation Implementation MDD (M10 Ready)** | 1d | 2022-10-31 | 2022-10-31 | 3425 |  |
| 3427 | MDD Final Circular Completed | 0d | 2022-10-31 | 2022-10-31 |  |  |
| 3428 | MDD Manual Update | 3d | 2022-10-31 | 2022-11-02 | 3427SF |  |
| 3429 | MDD Publish | 6d | 2022-10-31 | 2022-11-07 | 3428SF |  |
| 3430 | MDD Go Live | 0d | 2022-11-07 | 2022-11-07 | 3429 |  |
| 3431 | Non-SIT LDSO & SIT MVC Service Activation Implementation MDD Completed | 0d | 2022-11-07 | 2022-11-07 | 3427, 3428, 3429, 3430 |  |
| 3432 | **Non-SIT LDSO & SIT MVC Service Activation Hypercare (M10 Ready)** | 1d | 2022-10-31 | 2022-10-31 | 3415, 3431 |  |
| 3433 | Monitoring | 54d | 2022-11-08 | 2023-01-20 | 3431 |  |
| 3434 | Reporting | 54d | 2022-11-08 | 2023-01-20 | 3431 |  |
| 3436 | Closed Down Activities | 1d | 2022-11-08 | 2022-11-08 | 3433SS, 3434SS, 3435SS |  |
| 3437 | Inform MHHSP | 1d | 2022-11-08 | 2022-11-08 | 3436SS |  |
| 3438 | Non-SIT LDSO Service &SIT MVC Activation Hypercare Completed | 0d | 2023-01-20 | 2023-01-20 | 3433, 3434, 3435, 3436, 3437 |  |
| 3439 | **Non-SIT LDSO & SIT MVC Service Activation Retro and Go/No-Go (M11 Ready)** | 1d | 2022-10-31 | 2022-10-31 |  |  |
| 3440 | Review | 0d | 2023-01-20 | 2023-01-20 | 3438 |  |
| 3441 | Lessons Learned | 5d | 2023-01-23 | 2023-01-27 | 3440 |  |
| 3442 | SIT Non-MVC Service Activation Readiness Review Against Entry/Exit Criteria | 5d | 2023-01-30 | 2023-02-03 | 3441 |  |
| 3443 | **SIT Non-MVC Service Activation Preparation Tasks (M11 Not Ready)** | 1d | 2022-10-31 | 2022-10-31 |  |  |
| 3444 | Review Entry/Exit Criteria & Lessons Learned | 0d | 2022-10-31 | 2022-10-31 |  |  |
| 3445 | Identify Resources | 1d | 2022-10-31 | 2022-10-31 |  |  |
| 3446 | Confirmation from Qualification of Wave Participants Complete | 0d | 2022-10-31 | 2022-10-31 |  |  |
| 3447 | Agree & Understand Support Model | 2d | 2022-10-31 | 2022-11-01 |  |  |
| 3448 | Confirm Training complete | 1d | 2022-10-31 | 2022-10-31 |  |  |
| 3449 | Engagement / Communications with Participants | 1d | 2022-10-31 | 2022-10-31 |  |  |
| 3450 | **Internal Communications** | 1d | 2022-10-31 | 2022-10-31 |  |  |
| 3451 | Agree Content for Livewire | 1d | 2022-10-31 | 2022-10-31 |  |  |
| 3452 | Publish Content for Livewire | 0d | 2022-10-31 | 2022-10-31 |  |  |
| 3453 | Validate User Access | 1d | 2022-10-31 | 2022-10-31 |  |  |
| 3454 | Target Systems and Environments Ready | 1d | 2022-10-31 | 2022-10-31 |  |  |
| 3455 | Provide LWIs | 1d | 2022-10-31 | 2022-10-31 |  |  |
| 3456 | Business Readiness Governance Approval | 1d | 2022-10-31 | 2022-10-31 |  |  |
| 3457 | SIT Non-MVC Service Activation Preparation Tasks Completed | 0d | 2022-11-01 | 2022-11-01 | 3445, 3447, 3448, 3449, 3450, 3453, 3454, 3455, 3456 |  |
| 3458 | **SIT Non-MVC Service Activation Implementation (M11 Not Ready)** | 1d | 2022-10-31 | 2022-10-31 |  |  |
| 3459 | MHHSP Enabled Confirmation | 1d | 2022-10-31 | 2022-10-31 |  |  |
| 3460 | PAB Approval | 0d | 2022-10-31 | 2022-10-31 |  |  |
| 3461 | Add EFD(ISD Calendar Date) to DIP | 2d | 2022-11-01 | 2022-11-02 | 3453, 3454, 3455, 3456, 3459, 3460 |  |
| 3462 | DIP Promoted to Production | 1d | 2022-11-01 | 2022-11-01 | 3461SS |  |
| 3463 | Create M16 in Customer Solution | 1d | 2022-10-31 | 2022-10-31 |  |  |
| 3464 | DIP Production Success Checks | 7d | 2022-11-03 | 2022-11-11 | 3461, 3463 |  |
| 3466 | Go Live ISD | 0d | 2022-11-07 | 2022-11-07 | 3465 |  |
| 3467 | SIT Non-MVC Service Activation Implementation Completed | 0d | 2022-11-11 | 2022-11-11 | 3459, 3460, 3461, 3462, 3463, 3464, 3465, 3466 |  |
| 3468 | **SIT Non-MVC Service Activation Implementation MDD (M11 Not Ready)** | 1d | 2022-10-31 | 2022-10-31 |  |  |
| 3469 | MDD Final Circular | 0d | 2022-10-31 | 2022-10-31 | 3460 |  |
| 3470 | MDD Manual Update | 3d | 2022-10-31 | 2022-11-02 | 3469SF |  |
| 3471 | MDD Publish | 5d | 2022-10-31 | 2022-11-04 | 3470SF |  |
| 3472 | MDD Go Live | 0d | 2022-11-04 | 2022-11-04 | 3471 |  |
| 3473 | SIT Non-MVC Service Activation Implementation MDD Completed | 0d | 2022-11-04 | 2022-11-04 | 3469, 3472 |  |
| 3474 | **SIT Non-MVC Service Activation Hypercare (M11 Not Ready)** | 1d | 2022-10-31 | 2022-10-31 |  |  |
| 3475 | Monitoring | 11d | 2022-10-31 | 2022-11-14 |  |  |
| 3476 | Reporting | 11d | 2022-10-31 | 2022-11-14 |  |  |
| 3477 | Issue Management | 11d | 2022-10-31 | 2022-11-14 |  |  |
| 3478 | Closed Down Activities | 3d | 2022-10-31 | 2022-11-02 | 3475SS, 3476SS, 3477SS |  |
| 3479 | Inform MHHSP | 2d | 2022-10-31 | 2022-11-01 | 3478SS |  |
| 3480 | Non-SIT LDSO Service Activation Hypercare Completed | 0d | 2022-11-14 | 2022-11-14 | 3475, 3476, 3477, 3478, 3479 |  |
| 3481 | **SIT Non-MVC Service Activation Retro & Go/No Go (M11 Not Ready)** | 1d | 2022-10-31 | 2022-10-31 |  |  |
| 3482 | Review | 0d | 2022-10-31 | 2022-10-31 |  |  |
| 3483 | Lessons Learned | 5d | 2022-10-31 | 2022-11-04 | 3482SS |  |
| 3484 | Wave 1 - Service Activation Readiness Review Against Entry/Exit Criteria | 5d | 2022-11-07 | 2022-11-11 | 3483 |  |

Removed: 1609 Assurance of PPs Test Completion Reports; 1611 Develop document; 1612 Review & agree document; 1682 Develop document; 1683 Review & agree document; 1686 Assurance of PPs Test Completion Reports; 1693 Assurance of PPs Test Completion Reports; 1695 Develop document; 1696 Review & agree document; 1708 Assurance of PPs Test Completion Reports; 1710 Develop document; 1711 Review & agree document; 1713 SIT MVC Test Exit Report; 1714 Develop document; 1715 Review & agree document; 1762 Submit proposed version to QWG; 1763 Discuss document at QWG; 2667 SIT Participant's Prepared for Migration; 2668 Prep for Envelope Webinar; 2669 Envelope/Submission Webinar; 2670 Guides Creation; 2671 Support Channels; 2745 Each LDSO and DCC completes investigation and resolution of exceptions; 2811 Development of Implementation Group; 2812 Implementation Group Established; 2821 Programme SIT Participant Cutover Plan Assurance; 2989 SIT MVC; 2990 SIT MVC Service Activation Preparation Tasks; 2991 Identify operational resources; 2992 Define and approve operational support model; 2993 Confirm SA Training completed; 2994 Participant Engagement / Communications; 2995 Internal Communications; 2998 Provide opeartional resources with LWIs; 3000 SIT MVC Service Activation Preparation Tasks Complete; 3001 MHHSP Confirms SIT MVC PPs MHHS Enabled; 3002 SIT MVC Service Activation Implementation; 3003 Add EFD to DIP; 3005 SIT LDSOs Create Certificates and Test Connectivity; 3006 SIT MVC S&As Create Certificates and Test Connectivity; 3009 SIT LDSOs to update systems with ISD; 3010 SIT MVC S&As to update systems with ISD; 3011 SIT MVC Service Activation Implementation Complete; 3012 SIT MVC Service Activation Implementation MDD; 3013 MDD Manual Load; 3014 MDD Update; 3015 SIT MVC Service Activation Implementation MDD Complete; 3016 SIT MVC Service Activation Hypercare; 3017 Service & Process Monitoring; 3018 Daily Reporting; 3020 SA Hypercare Close Down Activities; 3021 Handover to MHHSP; 3022 SIT MVC Service Activation Hypercare Complete; 3023 SIT Non-MVC; 3024 SIT Non-MVC Service Activation Preparation Tasks; 3025 Helix Preparatory Activities Complete; 3026 MHHSP Confirms SIT Non-MVC PPs MHHS Enabled; 3027 SIT Non-MVC Service Activation Implementation; 3028 Add EDF to DIP; 3030 SIT non-MVC S&As Create Certificates and Test Connectivity; 3032 Publish ISD; 3033 SIT non-MVC S&As to update systems with ISD; 3034 SIT Non-MVC Service Activation Implementation Complete; 3035 SIT Non-MVC Service Activation Implementation MDD; 3036 MDD Manual Load; 3037 MDD Update; 3038 SIT Non-MVC Service Activation Implementation MDD Complete; 3039 Non-SIT MVC Service Activation Hypercare; 3040 Service& Process Monitoring; 3041 Daily Reporting; 3043 SA Hypercare Close Down Activities; 3044 Handover to MHHSP; 3045 Non-SIT MVC Service Activation Hypercare Complete (M)

Changed:

| ID | Task | Start | Finish | Duration | Complete | Total float | Predecessors | Other |
| --- | --- | --- | --- | --- | --- | --- | --- | --- |
| 1 | **PROGRAMME PLAN.** |  |  |  | 66% → 67% |  |  |  |
| 113 | Publish updated baselined artefacts |  | 2023-06-12 A → 2023-06-06 A (-6d) |  |  |  |  |  |
| 545 | **SYSTEMS INTEGRATION TESTING (SIT)** |  |  |  | 78% → 77% |  |  |  |
| 546 | **SIT Preparation** |  | 2025-05-16 → 2025-05-23 (+7d) | 665d? → 670d? |  | 679d → 674d |  |  |
| 627 | **SIT Stage-Specific Preparation** |  | 2025-05-16 → 2025-05-23 (+7d) | 665d? → 670d? |  | 679d → 674d |  |  |
| 639 | Development of test scenarios |  | 2023-04-28 A → 2023-01-02 A (-116d) |  |  |  |  |  |
| 640 | Review test scenarios with SIT Working Group |  | 2023-08-09 A → 2023-02-15 A (-175d) |  |  |  |  |  |
| 1194 | **SIT Operational Preparation** |  | 2025-04-25 → 2025-05-23 (+28d) | 650d? → 670d? | 97% → 98% | 694d → 674d |  |  |
| 1363 | **SIT Operational Programme RTTM (Theme 1, 2 & 3 (Batch 2))** |  | 2025-04-25 → 2025-05-23 (+28d) | 80d → 100d | 56% → 75% | 694d → 674d |  |  |
| 1366 | DIP Manager / Code Bodies / Full SRO to review |  |  |  | 26% → 90% |  |  |  |
| 1369 | SIT Operational (Theme 1, 2 & 3 (Batch 2)) RTTM Complete | 2025-04-25 → 2025-05-23 (+28d) | 2025-04-25 → 2025-05-23 (+28d) |  |  | 694d → 674d |  | constraint start no earlier than 2025-03-28 → finish no earlier than 2025-05-23 |
| 1432 | **Regression Test Preparation** |  |  |  | 90% → 100% |  |  |  |
| 1445 | **Regression Core Test Pack** |  | 2025-04-24 A |  | 99% → 100% | 7d → none |  |  |
| 1465 | SITAG (inc SRO) Approval of regression Core Pack | 2025-04-24 A | 2025-04-24 A |  | 0% → 100% | 7d → none |  |  |
| 1466 | SIT Regression Approval | 2025-04-24 A | 2025-04-24 A |  | 0% → 100% | 7d → none |  |  |
| 1467 | **Regression Test Data Load Window (SIT Functional and Migration) - SIT A** |  |  |  | 50% → 100% |  |  |  |
| 1468 | Data Load preparation activities |  | 2025-04-25 A |  | 85% → 100% | 6d → none |  |  |
| 1469 | Regression Test Data Load Start | 2025-04-28 A | 2025-04-28 A |  | 0% → 100% | 5d → none |  |  |
| 1470 | Regression Test Data Load Window | 2025-04-29 A | 2025-05-16 A |  | 0% → 100% | 5d → none |  |  |
| 1537 | **SIT** |  |  |  |  |  |  | was named SIT - Minimum Viable Cohort (MVC) |
| 1538 | **SIT Functional Testing (MVC)** |  | 2025-08-15 → 2025-08-20 (+5d) | 375d? → 378d? | 71% → 66% | 614d → 611d |  |  |
| 1540 | **SIT Functional Testing Execution (Minimum Viable Cohort)** |  |  | 296d? → 295d? |  |  |  |  |
| 1564 | SIT Functional Cycle 3 Complete |  |  | 1d? → 0d |  |  |  |  |
| 1565 | **SIT Scope Traceability** |  | 2025-04-24 A |  | 99% → 100% | 695d → none |  |  |
| 1575 | SITAG approve SIT Scope Traceability document | 2025-04-24 A | 2025-04-24 A |  | 0% → 100% | 695d → none |  |  |
| 1576 | SIT Scope Traceability Approved | 2025-04-24 A | 2025-04-24 A |  | 0% → 100% | 695d → none |  |  |
| 1577 | **SIT Functional Settlement Testing** |  |  |  | 36% → 35% |  |  |  |
| 1596 | **SIT-A Settlement Testing** | 2025-05-19 A | 2025-06-16 → 2025-06-13 (-3d) |  | 0% → 40% | 5d → 659d |  |  |
| 1597 | SIT-A Settlement Testing Start | 2025-05-19 A | 2025-05-19 A |  | 0% → 100% | 5d → none |  |  |
| 1598 | SIT-A Settlement Testing | 2025-05-20 → 2025-05-19 A (-1d) | 2025-06-16 → 2025-06-13 (-3d) |  | 0% → 40% | 5d → 19d |  |  |
| 1600 | SIT-A Settlement Decision Point Exit Criteria |  |  |  |  | 5d → 4d | 1598FS-2d → 1598FS-1d |  |
| 1602 | **SIT Functional Regression Testing (code freeze)** |  |  |  |  | 5d → 19d |  | was named SIT Functional MVC Regression Testing (code freeze) |
| 1608 | Regression Contingency Week |  |  |  |  | 5d → 4d | 1607 → 1607, 1621FF |  |
| 1609 | SIT Functional Testing End |  |  |  |  | 5d → 619d |  | was named SIT Functional Testing End (Minimum Viable Cohort) (incl. confirmation that PPs have submitted their Test Completion Reports to Programme for assurance) |
| 1610 | **SIT Functional & Migration Overarching Exit Report** | 2025-07-21 → 2025-04-28 A (-84d) | 2025-08-15 → 2025-06-18 (-58d) | 20d → 38d | 0% → 36% | 5d → 656d |  | was named SIT Functional Test Completion Report (Minimum Viable Cohort) |
| 1628 | SI SIT Functional Testing Test Exit Report Approved | 2025-08-15 → 2025-08-20 (+5d) | 2025-08-15 → 2025-08-20 (+5d) |  |  | 5d → 12d | Review & agree documentFF → 1625, 1627, 1608 | was named SIT Functional Testing Test Completion Report (Minimum Viable Cohort) Approved; constraint none → start no earlier than 2025-08-20; baseline start 2025-08-15 → 2025-08-20; baseline finish 2025-08-15 → 2025-08-20 |
| 1662 | **SIT Migration Testing** |  | 2025-08-22 → 2025-08-20 (-2d) | 380d? → 378d? | 77% → 67% | 609d → 611d |  | was named SIT Migration Testing (MVC) |
| 1664 | **SIT Migration Testing Execution** |  | 2025-08-22 → 2025-08-20 (-2d) | 380d? → 378d? | 77% → 67% | 609d → 611d |  | was named SIT Migration Testing Execution (Minimum Viable Cohort) |
| 1689 | **SIT Migration Regression Testing (code freeze)** |  |  |  |  | 614d → 619d |  | was named SIT Migration MVC Regression Testing (code freeze) |
| 1690 | Regression Test Execution Start |  |  |  |  | 614d → 26d | 1601FS+2d → 1601FS+2d, 2263 |  |
| 1695 | Regression Contingency Week |  |  |  |  |  | 1694 → 1694, 1708FF |  |
| 1696 | SIT Migration Testing End (incl. confirmation that PPs have submitted their Test Completion Reports to Programme for assurance) |  |  |  |  |  |  | was named SIT Migration Testing End (Minimum Viable Cohort) (incl. confirmation that PPs have submitted their Test Completion Reports to Programme for assurance) |
| 1697 | **SIT Functional & Migration Test Exit Report** | 2025-07-14 → 2025-04-28 A (-77d) | 2025-08-15 → 2025-06-18 (-58d) | 25d → 38d | 0% → 36% | 609d → 656d |  | was named SIT Migration Test Completion Report (Minimum Viable Cohort) |
| 1715 | SIT Migration Testing Test Exit Report Approved | 2025-08-15 → 2025-08-20 (+5d) | 2025-08-15 → 2025-08-20 (+5d) |  |  | 609d → 11d | Review & agree documentFS+5d → none | was named SIT Migration Testing Test Completion Report (Minimum Viable Cohort) Approved; constraint none → finish no earlier than 2025-08-20; baseline start 2025-08-15 → 2025-08-20; baseline finish 2025-08-15 → 2025-08-20 |
| 1716 | SIT Migration Testing End (incl. confirmation that PPs have submitted their Test Exit Reports to Programme for assurance) |  |  |  |  | 609d → 614d | Develop documentFF, 1715 → 1712 | was named SIT Migration Testing End (Minimum Viable Cohort) (incl. confirmation that PPs have submitted their Test Completion Reports to Programme for assurance); constraint start no earlier than 2025-03-14 → finish no earlier than 2025-08-15 |
| 1718 | **SIT Non-Functional Testing (all SIT PPs)** |  | 2025-06-06 → 2025-07-16 (+40d) | 70d? → 98d? | 37% → 55% | 60d → 636d |  |  |
| 1722 | Theme 2 & 3 SIT Non-Functional Testing Execution |  | 2025-05-23 A |  | 50% → 100% | 60d → none |  |  |
| 1723 | SIT Non-Functional Testing Execution End (all SIT PPs) | 2025-05-23 A | 2025-05-23 A |  | 0% → 100% | 60d → none |  | was named SIT Non-Functional Testing End (all SIT PPs) (incl. confirmation that PPs have submitted their Test Completion Reports to Programme for assurance) |
| 1724 | **SIT Non-Functional Testing Test Exit Report (all SIT PPs)** | 2025-05-05 → 2025-05-26 (+21d) | 2025-05-30 → 2025-07-16 (+47d) | 20d → 38d |  | 60d → 56d |  | was named SIT Non-Functional Testing Test Completion Report (all SIT PPs) |
| 1732 | SIT Non-Functional Testing Test Exit Report (all SIT PPs) Approved | 2025-06-06 → 2025-07-16 (+40d) | 2025-06-06 → 2025-07-16 (+40d) |  |  | 60d → 36d | Review & agree documentFF+5d → 1729FS+3d | was named SIT Non-Functional Testing Test Completion Report (all SIT PPs) Approved; constraint none → finish no earlier than 2025-07-16; baseline start 2025-06-06 → 2025-07-16; baseline finish 2025-06-06 → 2025-07-16 |
| 1734 | **SIT Operational Testing (all SIT PPs)** |  | 2025-07-18 → 2025-08-06 (+19d) | 120d? → 133d? | 24% → 47% | 30d → 621d |  |  |
| 1738 | **SIT B Testing** |  |  |  | 18% → 67% | 30d → 644d |  |  |
| 1740 | SIT Operational Testing Execution Theme 1 |  |  |  | 35% → 75% | 30d → 644d |  |  |
| 1741 | SIT Operational Testing Execution Theme 2 | 2025-05-05 A |  |  | 0% → 80% | 30d → 644d |  |  |
| 1747 | SIT Operational Testing End (all SIT PPs) (incl. confirmation that PPs have submitted their Test Completion Reports to Programme for assurance) |  |  |  |  | 30d → 644d | 1737, 1740, 1741, 1742 → 1737, 1740, 1741, 1742, 1746 |  |
| 1748 | **SIT Operational Testing Test Exit Report (all SIT PPs)** | 2025-06-16 → 2025-06-02 (-14d) | 2025-07-11 → 2025-08-06 (+26d) | 20d → 48d |  | 30d → 36d |  | was named SIT Operational Testing Test Completion Report (all SIT PPs) |
| 1756 | SIT Operational Testing Test Exit Report (all SIT PPs) Approved | 2025-07-18 → 2025-08-06 (+19d) | 2025-07-18 → 2025-08-06 (+19d) |  |  | 30d → 6d | Review & agree documentFF+5d → 1753FS+3d | was named SIT Operational Testing Test Completion Report (all SIT PPs) Approved; baseline start 2025-07-25 → 2025-08-06; baseline finish 2025-07-25 → 2025-08-06 |
| 1758 | SIT Complete (SIT Test Exit Report Approved) |  |  |  |  | 5d → 9d | 1536, 1628FS+5d, 1732, 1756 → 1536, 1628, 1732, 1756, 1715, 1757, 1733, 1629 | was named SIT Minimum Viable Cohort Complete (SIT Minimum Viable Cohort Test Exit Report Approved); constraint none → finish no earlier than 2025-08-22 |
| 1759 | **SIT (Contingency)** |  |  |  |  | 505d → 526d |  | was named SIT (non-MVC) |
| 1760 | **SIT Functional Testing (Contingency)** |  |  |  |  | 505d → 526d |  | was named SIT Functional Testing (non-MVC) |
| 1761 | **SIT Functional Testing Execution (Contingency)** |  |  |  |  | 505d → 526d |  | was named SIT Functional Testing Execution (non-MVC) |
| 1763 | SIT Functional Testing End (Contingency) (incl. confirmation that PPs have submitted their Test Exit Reports to Programme for assurance) |  |  |  |  | 505d → 526d |  | was named SIT Functional Testing End (non-MVC) (incl. confirmation that PPs have submitted their Test Completion Reports to Programme for assurance) |
| 1764 | Assurance of PPs Test Exit Reports |  |  |  |  | 505d → 526d |  | was named Assurance of PPs Test Completion Reports |
| 1765 | **SIT Functional Testing Test Completion Report (Contingency)** |  |  |  |  | 505d → 526d |  | was named SIT Functional Testing Test Completion Report (non-MVC) |
| 1768 | SIT Functional Testing Test Exit Report (Contingency) Approved |  |  |  |  | 505d → 526d |  | was named SIT Functional Testing Test Completion Report (non-MVC) Approved |
| 1769 | **SIT Migration Testing (Contingency)** |  |  |  |  | 505d → 526d |  | was named SIT Migration Testing (non-MVC) |
| 1771 | SIT Migration Testing End (Contingency) (incl. confirmation that PPs have submitted their Test Exit Reports to Programme for assurance) |  |  |  |  | 505d → 526d |  | was named SIT Migration Testing End (non-MVC) (incl. confirmation that PPs have submitted their Test Completion Reports to Programme for assurance) |
| 1772 | Assurance of PPs Test Exit Reports |  |  |  |  | 505d → 526d |  | was named Assurance of PPs Test Completion Reports |
| 1773 | **SIT Migration Testing Test Completion Report (Contingency)** |  |  |  |  | 505d → 526d |  | was named SIT Migration Testing Test Completion Report (non-MVC) |
| 1776 | SIT Migration Testing Test Exit Report (Contingency) Approved |  |  |  |  | 505d → 526d |  | was named SIT Migration Testing Test Completion Report (non-MVC Approved) |

| ID | Task | Start | Finish | Duration | Complete | Total float | Predecessors | Other |
| --- | --- | --- | --- | --- | --- | --- | --- | --- |
| 1777 | **SIT Contingency Test Exit Report** |  |  |  |  | 505d → 526d |  | was named SIT non-MVC Test Exit Report |
| 1780 | SIT Contingency Complete |  |  |  |  | 505d → 526d |  | was named SIT non-MVC Complete |
| 1781 | **UIT Environment Preparation** |  | 2025-06-06 → 2025-06-19 (+13d) | 680d? → 689d | 52% → 53% | 664d → 655d |  |  |
| 1782 | **Test Artefact Development** |  | 2025-04-17 → 2025-06-19 (+63d) | 557d? → 602d | 74% → 96% | 700d → 655d |  |  |
| 1783 | **E2E Sandbox Guidance** |  | 2025-04-17 → 2025-06-19 (+63d) | 557d? → 602d | 96% → 99% | 700d → 655d |  |  |
| 1787 | Update E2E Sandbox guidance to reflect CR055 | 2025-01-13 A → 2025-03-17 A (+63d) | 2025-03-14 A → 2025-05-16 A (+63d) |  |  |  |  | constraint finish no earlier than 2025-03-14 → finish no earlier than 2025-05-16; baseline start 2025-01-13 → 2025-03-17; baseline finish 2025-03-14 → 2025-05-16 |
| 1788 | Internal SI review | 2025-03-17 A → 2025-05-19 A (+63d) | 2025-03-21 A → 2025-05-23 A (+63d) |  |  |  |  | baseline start 2025-03-17 → 2025-05-19; baseline finish 2025-03-21 → 2025-05-23 |
| 1789 | SRO / Code Bodies review | 2025-03-24 A → 2025-05-19 A (+56d) | 2025-03-28 → 2025-05-23 A (+56d) |  | 40% → 100% | 713d → none | 1788 → none | constraint finish no earlier than 2025-03-28 → finish no earlier than 2025-05-23; baseline start 2025-03-24 → 2025-05-19; baseline finish 2025-03-28 → 2025-05-23 |
| 1790 | Submit version to QWG | 2025-04-01 → 2025-06-03 (+63d) | 2025-04-01 → 2025-06-03 (+63d) |  |  | 711d → 667d | 1789 → none | constraint finish no earlier than 2025-04-01 → finish no earlier than 2025-06-03; baseline start 2025-04-01 → 2025-06-03; baseline finish 2025-04-01 → 2025-06-03 |
| 1791 | Artefact Recommendation for Approval (via QWG) | 2025-04-08 → 2025-06-10 (+63d) | 2025-04-08 → 2025-06-10 (+63d) |  |  | 706d → 662d |  | constraint finish no earlier than 2025-04-08 → finish no earlier than 2025-06-10; baseline start 2025-04-08 → 2025-06-10; baseline finish 2025-04-08 → 2025-06-10 |
| 1792 | Final Document updates post QWG review | 2025-04-09 → 2025-06-11 (+63d) | 2025-04-09 → 2025-06-11 (+63d) | 1d → 0d |  | 706d → 661d |  | constraint start no earlier than 2025-04-09 → finish no earlier than 2025-06-11; baseline start 2025-04-09 → 2025-06-11; baseline finish 2025-04-09 → 2025-06-11 |
| 1793 | Submit final version to QAG | 2025-04-10 → 2025-06-12 (+63d) | 2025-04-10 → 2025-06-12 (+63d) | 1d? → 0d |  | 701d → 657d |  | constraint finish no earlier than 2025-04-10 → finish no earlier than 2025-06-12; baseline start 2025-04-10 → 2025-06-12; baseline finish 2025-04-10 → 2025-06-12 |
| 1794 | E2E Sandbox guidance update approved at QAG | 2025-04-17 → 2025-06-19 (+63d) | 2025-04-17 → 2025-06-19 (+63d) | 1d? → 0d |  | 700d → 655d |  | constraint finish no earlier than 2025-04-17 → finish no earlier than 2025-06-19; baseline start 2025-04-17 → 2025-06-19; baseline finish 2025-04-17 → 2025-06-19 |
| 1795 | **E2E Sandbox Test Data Approach & Plan** | 2025-01-13 A → 2025-03-10 A (+56d) | 2025-04-16 → 2025-06-17 (+62d) | 68d → 72d | 23% → 86% | 701d → 657d |  |  |
| 1801 | Develop document | 2025-01-13 → 2025-04-10 A (+87d) | 2025-02-18 → 2025-05-16 A (+87d) |  | 0% → 100% | 701d → none |  | constraint start no earlier than 2025-01-13 → finish no earlier than 2025-05-16; baseline start 2025-01-13 → 2025-04-10; baseline finish 2025-02-18 → 2025-05-16 |
| 1802 | Internal SI review and updates | 2025-02-19 → 2025-05-19 A (+89d) | 2025-02-25 → 2025-05-23 A (+87d) |  | 0% → 100% | 701d → none |  | baseline start 2025-02-19 → 2025-05-19; baseline finish 2025-02-25 → 2025-05-23 |
| 1803 | SRO / Code Bodies review | 2025-02-26 → 2025-05-19 A (+82d) | 2025-03-04 → 2025-05-23 A (+80d) |  | 0% → 100% | 701d → none | 1802 → 1802SS | baseline start 2025-02-26 → 2025-05-19; baseline finish 2025-03-04 → 2025-05-23 |
| 1804 | Final updates prior to consultation | 2025-03-12 → 2025-05-26 A (+75d) | 2025-03-17 → 2025-05-26 A (+70d) | 4d → 1d | 0% → 100% | 701d → none | Discuss document at QWG → 1803 | baseline start 2025-03-12 → 2025-05-26; baseline finish 2025-03-17 → 2025-05-26 |
| 1805 | Industry Consultation for E2E Sandbox Test Data Approach and Plan document | 2025-03-18 → 2025-05-27 A (+70d) | 2025-03-31 → 2025-06-06 (+67d) | 10d → 9d | 0% → 22% | 701d → 664d | 1804 → 1804SS | baseline start 2025-03-18 → 2025-05-26; baseline finish 2025-03-31 → 2025-06-06 |
| 1806 | Document updates post Industry Consultation | 2025-04-01 → 2025-06-06 (+66d) | 2025-04-03 → 2025-06-09 (+67d) | 3d → 2d |  | 701d → 663d | 1805 → 1805SS | constraint finish no earlier than 2024-04-22 → finish no earlier than 2025-06-09; baseline start 2025-04-01 → 2025-06-07; baseline finish 2025-04-03 → 2025-06-09 |
| 1807 | Submit Proposed Version to QWG | 2025-04-04 → 2025-06-10 (+67d) | 2025-04-08 → 2025-06-10 (+63d) | 3d → 0d |  | 701d → 660d | 1806 → none | constraint none → finish no earlier than 2025-06-10; baseline start 2025-04-04 → 2025-06-10; baseline finish 2025-04-08 → 2025-06-10 |
| 1808 | Artefact Approval (via QWG) | 2025-04-08 → 2025-06-10 (+63d) | 2025-04-08 → 2025-06-10 (+63d) |  |  | 701d → 660d |  | constraint none → finish no earlier than 2025-06-10; baseline start 2025-04-08 → 2025-06-10; baseline finish 2025-04-08 → 2025-06-10 |
| 1809 | Final Document updates post QWG review | 2025-04-09 → 2025-06-11 (+63d) | 2025-04-09 → 2025-06-11 (+63d) |  |  | 701d → 660d |  | baseline start 2025-04-09 → 2025-06-11; baseline finish 2025-04-09 → 2025-06-11 |
| 1810 | Submit final version to QAG | 2025-04-10 → 2025-06-12 (+63d) | 2025-04-10 → 2025-06-12 (+63d) |  |  | 701d → 660d | 1809FS+1d → 1809FS+1d, 1806 | baseline start 2025-04-10 → 2025-06-12; baseline finish 2025-04-10 → 2025-06-12 |
| 1811 | E2E Sandbox Test Data Approach and Plan Approved at QAG | 2025-04-16 → 2025-06-17 (+62d) | 2025-04-16 → 2025-06-17 (+62d) |  |  | 701d → 657d | 1810FS+4d → 1810 | was named E2E Sandbox Test Data Approach and Plan; constraint start no earlier than 2024-05-09 → finish no earlier than 2025-06-17 |
| 1863 | **Sandbox Testing Execution (UIT) - Supplier & Agent Participants** |  |  |  |  |  |  | was named Sandbox Testing Execution (UIT) |
| 1864 | Sandbox Testing Start (UIT) - Supplier & Agent Participants |  |  |  |  |  |  | was named Sandbox Testing Start (UIT) |
| 1865 | Sandbox Testing Execution (UIT) - Supplier & Agent Participants |  |  |  |  |  |  | was named Sandbox Testing Execution (UIT) |
| 1866 | Sandbox Testing End (UIT) - Supplier & Agent Participants |  |  |  |  |  |  | was named Sandbox Testing End (UIT) |
| 1871 | **SIT PPs Early Sandbox Testing Execution (SIT-A)** |  |  |  |  |  |  | baseline start 2025-02-07 → 2025-07-21; baseline finish 2026-04-24 → 2025-10-24 |
| 1872 | SIT PPs E2E Sandbox Testing Start |  |  |  |  |  |  | baseline start 2025-08-11 → 2025-07-21; baseline finish 2025-08-11 → 2025-07-21 |
| 1873 | SIT PPs E2E Sandbox Testing Execution |  |  |  |  |  |  | baseline start 2025-08-11 → 2025-07-21 |
| 1900 | M10 Checkpoint 1 complete |  |  |  |  |  | 1935FS-126d, 1899 → 1899 |  |
| 1905 | Non-SIT LDSO Qualification Testing complete | 2025-05-16 A | 2025-05-16 A |  | 0% → 100% | 679d → none |  |  |
| 1912 | Migration Schedule approved |  |  |  |  |  | none → 2979 |  |
| 1913 | Migration Framework approved | 2025-04-30 A | 2025-04-30 A |  | 0% → 100% | 691d → none |  |  |
| 1914 | Migration Control Centre (MCC) delegation of authority approved | 2025-04-30 A | 2025-04-30 A |  | 0% → 100% | 691d → none |  |  |
| 1915 | Migration incentives implemented | 2025-04-30 A | 2025-04-30 A |  | 0% → 100% | 691d → none |  |  |
| 1916 | MCC tested and ready to operate |  |  |  |  |  | none → 3020 |  |
| 1919 | Early Life Support Model defined | 2025-04-29 A | 2025-04-29 A |  | 0% → 100% | 692d → none |  |  |
| 1922 | M10/M11 Cutover Plan in place | 2024-05-28 A | 2024-05-28 A |  | 0% → 100% | 932d → none |  |  |
| 1935 | Central systems ready for migrating MPANs (M10) | 2025-09-24 → 2025-09-22 (-2d) | 2025-09-24 → 2025-09-22 (-2d) |  |  | 5d → 7d | 1758FS+20d, 3595, 3185FS+2d, 3182, 3200, 3161, Programme SIT Participant Cutover Plan Assurance, 3168 → 1758FS+18d, 3595, 3185, 3182, 3200, 3161, 3168 | constraint none → start no earlier than 2025-09-22; baseline start 2025-09-24 → 2025-09-22; baseline finish 2025-09-24 → 2025-09-22 |
| 1937 | Central systems ready for migrating MPANs (M10*) - Late Exit |  |  |  |  |  | 1935FS+65d → 1935FS+67d |  |
| 1948 | **NON SIT LDSO QUALIFICATION** |  |  |  | 92% → 96% |  |  |  |
| 1994 | **Test Data** |  | 2025-05-16 A |  | 84% → 100% | 679d → none |  |  |
| 2003 | Test Execution Data Support |  | 2025-05-16 A |  | 50% → 100% | 679d → none |  |  |
| 2043 | **Test Window** |  |  |  | 87% → 92% |  |  |  |
| 2044 | **All Non-SIT LDSOs Qualification Testing** |  | 2025-05-16 A |  | 95% → 100% | 1d → none |  |  |
| 2046 | LDSO Alpha |  | 2025-05-05 A |  | 97% → 100% | 9d → none |  |  |
| 2047 | LDSO Bravo |  | 2025-05-05 A |  | 99% → 100% | 9d → none |  |  |
| 2048 | LDSO Charlie |  | 2025-05-07 A |  | 96% → 100% | 7d → none |  |  |
| 2049 | LDSO Delta |  | 2025-04-30 A |  | 93% → 100% | 12d → none |  |  |
| 2051 | LDSO Foxtrot |  | 2025-05-15 A |  | 72% → 100% | 1d → none |  |  |
| 2054 | LDSO India |  | 2025-05-05 A |  | 99% → 100% | 9d → none |  |  |
| 2055 | Qualification Testing for Non-SIT LDSOs (Functional, Migration, NFT, Operational) 1 End | 2025-05-16 A | 2025-05-16 A |  | 0% → 100% | 1d → none |  |  |
| 2056 | Potential for non-SIT LDSO QT Regression for Qualification | 2025-05-19 A |  |  | 0% → 10% |  |  |  |
| 2057 | **Test Result Assurance** |  | 2025-05-16 A |  | 43% → 100% | 649d → none |  |  |
| 2058 | Test Reports Reviewed By MHHS & Code Bodies & Finalised |  | 2025-05-16 A |  | 43% → 100% | 649d → none |  |  |
| 2059 | Non-SIT LDSOs submission deadline for their QT Test Completion Report to MHHS Programme | 2025-05-16 A | 2025-05-16 A |  | 0% → 100% | 649d → none | 2058, 2044 → 2058, 2044, 2055 |  |
| 2060 | **Non-SIT LDSO Qualification Closure** | 2025-05-16 A |  |  | 0% → 46% |  |  |  |
| 2061 | Non-SIT LDSO Qualification Learned Captured | 2025-05-16 A | 2025-05-29 A |  | 0% → 100% | 670d → none |  |  |
| 2062 | Non-SIT LDSO Regression Testing | 2025-05-16 A |  |  | 0% → 35% |  |  |  |
| 2157 | **Phase 1 - Preparation** | 2022-10-31 → 2024-04-02 A (+519d) | 2026-01-16 → 2025-09-26 (-112d) | 840d? → 389d? | 0% → 70% | 504d → 584d |  |  |
| 2218 | Validate User Access | 2025-02-17 → 2025-09-02 (+197d) | 2025-02-21 → 2025-09-02 (+193d) | 5d → 1d |  | 739d → 596d |  | constraint finish no earlier than 2025-02-21 → start no earlier than 2025-09-02; baseline start 2025-02-17 → none; baseline finish 2025-02-21 → none |
| 2219 | Target Systems and Environments Ready | 2025-02-20 → 2025-09-03 (+195d) | 2025-02-24 → 2025-09-03 (+191d) | 3d → 1d |  | 738d → 595d |  | constraint finish no earlier than 2025-02-24 → start no earlier than 2025-09-03; baseline start 2025-02-20 → none; baseline finish 2025-02-24 → none |
| 2222 | Business Readiness Governance Approval | 2025-02-17 → 2025-09-08 (+203d) | 2025-02-19 → 2025-09-08 (+201d) | 3d → 1d |  | 741d → 592d | none → 2221 | constraint finish no earlier than 2025-02-19 → start no earlier than 2025-09-05; baseline start 2025-02-17 → none; baseline finish 2025-02-19 → none |
| 2228 | DIP Promoted to Production | 2025-09-15 → 2025-09-12 (-3d) | 2025-09-15 → 2025-09-12 (-3d) | 1d? → 1d |  | 5d → 594d | Add EFD to DIP → 2227 | constraint none → start no earlier than 2025-09-12; baseline start 2025-09-15 → none; baseline finish 2025-09-15 → none |
| 2230 | Create M16 in Customer Solution | 2025-09-16 → 2025-09-11 (-5d) | 2025-09-17 → 2025-09-11 (-6d) | 2d → 1d |  | 5d → 594d | 2228 → 2229SS, 2233SS | constraint finish no earlier than 2025-03-07 → start no earlier than 2025-09-11; baseline start 2025-09-16 → none; baseline finish 2025-09-17 → none |
| 2247 | Issue Management | 2025-09-12 → 2025-09-18 (+6d) | 2025-10-07 → 2025-12-02 (+56d) | 18d → 54d |  | 577d → 537d | Add EFD to DIPSS → none | constraint finish no earlier than 2025-03-26 → finish no earlier than 2025-12-02; baseline start 2025-03-03 → none; baseline finish 2025-03-26 → none |
| 2345 | **S & A QUALIFICATION** |  |  |  | 62% → 64% |  |  |  |

| ID | Task | Start | Finish | Duration | Complete | Total float | Predecessors | Other |
| --- | --- | --- | --- | --- | --- | --- | --- | --- |
| 2346 | **MHHS Qualification - Qualification Deliverables** |  |  |  | 95% → 96% |  |  |  |
| 2374 | **Qualification Assessment Document** |  |  |  | 88% → 91% |  |  |  |
| 2393 | **Qualification Assessment Document Portal** |  |  |  | 78% → 84% |  |  |  |
| 2401 | QT Wave 1 Participant QAD Application Creation in Portal |  | 2025-05-02 A |  | 20% → 100% | 420d → none |  |  |
| 2402 | QT Wave 2 Participant QAD Application Creation in Portal | 2025-05-26 A |  |  | 0% → 20% |  |  |  |
| 2407 | **MHHS Qualification - SIT Participants** |  |  | 248d → 248d? | 32% → 46% | 505d → 526d |  |  |
| 2412 | **MHHS Qualification - M10-Ready** |  | 2025-09-11 → 2025-09-10 (-1d) | 114d → 113d | 14% → 79% | 5d → 596d |  | was named MHHS Qualification - SIT MVC Participants |
| 2413 | Final QAD Submission Window opens |  |  |  |  |  |  | was named Final QAD Submission Window (MVC) opens |
| 2414 | SIT M10-ready Participants submit Final QAD (exc Test Reports) |  | 2025-05-09 A |  | 25% → 100% | 60d → none |  | was named SIT MVC Participants submit Final QAD (exc Test Reports) |
| 2415 | Completion of Code Bodies review of Final QAD (M10-Ready) | 2025-05-12 A |  |  | 0% → 60% | 60d → 642d |  | was named Completion of Code Bodies review of Final QAD (MVC) |
| 2417 | QAD Sign Off Deadline + Test Reports | 2025-08-22 → 2025-07-23 (-30d) | 2025-08-22 → 2025-07-23 (-30d) |  |  | 5d → 610d | 1758, 2415, 1747 → 2415, 1692FF | was named QAD Sign Off Deadline (MVC) + Test Reports; constraint start no earlier than 2025-07-11 → start no earlier than 2025-07-23; baseline start 2025-08-22 → 2025-07-23; baseline finish 2025-08-22 → 2025-07-23 |
| 2418 | REC Code Manager / BSC PAB Approval of Qualification | 2025-09-11 → 2025-08-13 (-29d) | 2025-09-11 → 2025-08-13 (-29d) |  |  | 5d → 610d | 2417FS+14d → 2417FS+16d | was named REC Code Manager / BSC PAB Approval of Qualification (MVC); baseline start 2025-09-11 → 2025-08-13; baseline finish 2025-09-11 → 2025-08-13 |
| 2437 | **MHHS Qualification - Not M11-Ready** | 2025-05-19 A |  |  | 0% → 1% | 505d → 526d |  | was named MHHS Qualification - SIT Non-MVC Participants; baseline finish 2025-12-22 → 2025-12-17 |
| 2438 | Final QAD Submission Window opens | 2025-05-19 A | 2025-05-19 A |  | 0% → 100% | 613d → none |  | was named Final QAD Submission Window (Non-MVC) opens |
| 2439 | SIT Not M11-Ready Participants submit Final QAD | 2025-05-19 A |  |  | 0% → 1% | 524d → 545d |  | was named SIT Non-MVC Participants submit Final QAD |
| 2440 | Completion of Code Bodies review of Final QAD (Not M11-Ready) |  |  |  |  | 524d → 545d |  | was named Completion of Code Bodies review of Final QAD (Non-MVC) |
| 2442 | QAD Sign Off Deadline (Not M11-Ready) |  |  |  |  | 505d → 526d |  | was named QAD Sign Off Deadline (Non-MVC); baseline start 2025-11-28 → 2025-11-27; baseline finish 2025-11-28 → 2025-11-27 |
| 2443 | SIT Participants are Qualified |  |  |  |  | 505d → 526d |  | was named REC Code Manager / BSC PAB Approval of Qualification (Non-MVC) |
| 2444 | **MHHS Qualification - Non-SIT LDSO (M10-Ready)** |  |  |  |  |  |  | was named MHHS Qualification - Non-SIT LDSO; baseline finish 2025-09-11 → 2025-09-10 |
| 2451 | Non-SIT LDSO Participants submit Final QAD |  |  |  | 20% → 95% | 49d → 9d | 2450SS-1d → 2450SS-1d, 2055 | constraint none → finish no earlier than 2025-05-23 |
| 2455 | QAD Sign Off Deadline (Non-SIT LDSOs) |  |  |  |  |  | 2453FS+5d, 1758, 2055 → 2453FS+5d, 1758, 2055, 2454 |  |
| 2457 | **MHHS Qualification - Qualification Waves** |  |  |  | 57% → 59% |  |  |  |
| 2458 | **Qualification Wave Prep** |  | 2026-02-06 → 2026-02-19 (+13d) | 560d? → 569d? | 94% → 96% | 489d → 480d |  |  |
| 2496 | **Qualification Testing Framework (Test Stubs and Supporting UI)** |  | 2026-02-06 → 2026-02-19 (+13d) | 530d? → 539d? | 93% → 96% | 489d → 480d |  |  |
| 2562 | **MPANs, DIP Messages, Settlement, Consumption, Reference** |  |  |  | 81% → 88% |  |  |  |
| 2603 | Test Data Request + Templates Completed | 2025-06-02 → 2025-07-14 (+42d) | 2025-06-06 → 2025-07-15 (+39d) | 5d → 2d |  | 440d → 426d |  | constraint start no earlier than 2025-06-02 → start no earlier than 2025-07-14; baseline start 2025-06-02 → 2025-07-14; baseline finish 2025-06-06 → 2025-07-15 |
| 2604 | Test Data Generated | 2025-06-09 → 2025-07-16 (+37d) | 2025-06-13 → 2025-07-17 (+34d) | 5d → 2d |  | 440d → 426d |  | baseline start 2025-06-09 → 2025-07-16; baseline finish 2025-06-13 → 2025-07-17 |
| 2605 | Test Data Loaded into QP Systems | 2025-06-16 → 2025-07-18 (+32d) | 2025-07-04 → 2025-08-07 (+34d) |  |  | 440d → 426d |  | baseline start 2025-06-16 → 2025-07-18; baseline finish 2025-07-04 → 2025-08-07 |
| 2606 | Test Data Loaded into QTF + ADO | 2025-07-07 → 2025-08-11 (+35d) | 2025-07-25 → 2025-08-15 (+21d) | 15d → 5d |  | 440d → 425d |  | constraint finish no earlier than 2025-06-17 → finish no earlier than 2025-08-15; baseline start 2025-07-07 → 2025-08-11; baseline finish 2025-07-25 → 2025-08-15 |
| 2608 | Test Data Request + Templates Completed | 2025-07-28 → 2025-09-17 (+51d) | 2025-08-01 → 2025-09-18 (+48d) | 5d → 2d |  | 407d → 387d |  | constraint start no earlier than 2025-07-28 → start no earlier than 2025-09-17; baseline start 2025-07-28 → 2025-09-17; baseline finish 2025-08-01 → 2025-09-18 |
| 2609 | Test Data Generated | 2025-08-04 → 2025-09-19 (+46d) | 2025-08-08 → 2025-09-22 (+45d) | 5d → 2d |  | 407d → 387d |  | baseline start 2025-08-04 → 2025-09-19; baseline finish 2025-08-08 → 2025-09-22 |
| 2610 | Test Data Loaded into QP Systems | 2025-08-11 → 2025-09-23 (+43d) | 2025-08-29 → 2025-10-13 (+45d) |  |  | 407d → 387d |  | baseline start 2025-08-11 → 2025-09-23; baseline finish 2025-08-29 → 2025-10-13 |
| 2611 | Test Data Loaded into QTF + ADO | 2025-09-01 → 2025-10-14 (+43d) | 2025-09-19 → 2025-10-17 (+28d) | 15d → 4d |  | 407d → 387d |  | baseline start 2025-09-01 → 2025-10-14; baseline finish 2025-09-19 → 2025-10-17 |
| 2613 | Test Data Request + Templates Completed | 2025-10-20 → 2025-11-10 (+21d) | 2025-10-24 → 2025-11-11 (+18d) | 5d → 2d |  | 376d → 377d |  | constraint start no earlier than 2025-10-20 → start no earlier than 2025-11-10; baseline start 2025-10-20 → 2025-11-10; baseline finish 2025-10-24 → 2025-11-11 |
| 2614 | Test Data Generated | 2025-10-27 → 2025-11-12 (+16d) | 2025-10-31 → 2025-11-13 (+13d) | 5d → 2d |  | 376d → 377d |  | baseline start 2025-10-27 → 2025-11-12; baseline finish 2025-10-31 → 2025-11-13 |
| 2615 | Test Data Loaded into QP Systems | 2025-11-03 → 2025-11-14 (+11d) | 2025-11-21 → 2025-12-04 (+13d) |  |  | 376d → 377d |  | baseline start 2025-11-03 → 2025-11-14; baseline finish 2025-11-21 → 2025-12-04 |
| 2616 | Test Data Loaded into QTF + ADO | 2025-11-24 → 2025-12-05 (+11d) | 2025-12-12 → 2025-12-11 (-1d) | 15d → 5d |  | 376d → 377d |  | baseline start 2025-11-24 → 2025-12-05; baseline finish 2025-12-12 → 2025-12-11 |
| 2618 | Test Data Request + Templates Completed | 2025-12-15 → 2026-01-19 (+35d) | 2025-12-19 → 2026-01-20 (+32d) | 5d → 2d |  | 256d → 247d |  | constraint start no earlier than 2025-12-15 → start no earlier than 2026-01-19; baseline start 2025-12-15 → 2026-01-19; baseline finish 2025-12-19 → 2026-01-20 |
| 2619 | Test Data Generated | 2025-12-22 → 2026-01-21 (+30d) | 2025-12-26 → 2026-01-22 (+27d) | 5d → 2d |  | 256d → 247d |  | baseline start 2025-12-22 → 2026-01-21; baseline finish 2025-12-26 → 2026-01-22 |
| 2620 | Test Data Loaded into QP Systems | 2025-12-29 → 2026-01-23 (+25d) | 2026-01-16 → 2026-02-12 (+27d) |  |  | 256d → 247d |  | baseline start 2025-12-29 → 2026-01-23; baseline finish 2026-01-16 → 2026-02-12 |
| 2621 | Test Data Loaded into QTF + ADO | 2026-01-19 → 2026-02-13 (+25d) | 2026-02-06 → 2026-02-19 (+13d) | 15d → 5d |  | 256d → 247d |  | baseline start 2026-01-19 → 2026-02-13; baseline finish 2026-02-06 → 2026-02-19 |
| 2638 | **Qualification Wave 1** | 2025-05-05 A |  |  | 0% → 7% |  |  |  |
| 2639 | **Qualification Wave 1 QAD Prep** | 2025-05-05 A |  |  | 0% → 29% | 420d → 419d |  |  |
| 2640 | Initial QAD Submission window opens | 2025-05-05 A | 2025-05-05 A |  | 0% → 100% | 420d → none |  |  |
| 2641 | Qualification Wave 1 Participants Submit Initial QAD | 2025-05-05 A |  |  | 0% → 46% | 420d → 419d |  |  |
| 2645 | **Qualification Wave 1 Test Prep** | 2025-05-26 A |  |  | 0% → 8% |  |  |  |
| 2646 | Confirmation from Qualification Wave 1 Participants that DIP onboarding has commenced | 2025-05-26 A | 2025-05-26 A |  | 0% → 100% | 445d → none |  |  |
| 2647 | Qualification Wave 1 Participants DIP Onboarding Window | 2025-05-26 A |  |  | 0% → 23% | 445d → 444d |  |  |
| 2658 | Qualification Wave 1 QT Execution Start |  |  |  |  |  | 2657, 2654, 1628FS+6d, 2606 → 2657FS+1d, 2654, 2606 |  |
| 2767 | PAB293 | 2025-04-24 A | 2025-04-24 A |  | 0% → 100% | 696d → none |  |  |
| 2768 | PAB294 | 2025-05-14 A | 2025-05-14 A |  | 0% → 100% | 682d → none |  |  |
| 2769 | PAB295 | 2025-05-29 A | 2025-05-29 A |  | 0% → 100% | 671d → none |  |  |
| 2928 | Code changes delivered (M8) |  |  |  |  |  | 2908, 2887, 1935SS-3d, 2924 → 2908, 2887, 1935SS-3d, 2924, 2142 |  |
| 2934 | **MIGRATION** |  |  |  | 58% → 66% |  |  |  |
| 2935 | **Regulatory Governance** |  |  |  | 73% → 90% |  |  |  |
| 2937 | Incentives Implemented |  |  |  | 26% → 72% |  |  |  |
| 2938 | **Migration Framework Agreed and Implemented** |  | 2025-04-29 A |  | 99% → 100% | 692d → none |  |  |
| 2961 | **Consultation 4** |  | 2025-04-29 A |  | 99% → 100% | 692d → none |  |  |
| 2972 | MCAG Approval of Consultation 4 | 2025-04-29 A | 2025-04-29 A |  | 0% → 100% | 692d → none |  |  |
| 2973 | Framework Baselined at MCAG | 2025-04-29 A | 2025-04-29 A |  | 0% → 100% | 692d → none |  |  |
| 2982 | Supplier submission issued | 2025-04-25 A | 2025-04-25 A |  | 0% → 100% | 632d → none |  |  |
| 2986 | **Supplier Submission Support** | 2025-04-25 A | 2025-06-04 → 2025-06-18 (+14d) | 29d? → 38d? | 0% → 99% | 666d → 657d |  |  |
| 2987 | Support guides issued | 2025-04-25 A | 2025-04-25 A |  | 0% → 100% | 666d → none |  |  |
| 2988 | Envelope webinar | 2025-05-02 A | 2025-05-02 A |  | 0% → 100% | 666d → none |  |  |
| 2989 | De-minimus webinar | 2025-05-02 A | 2025-05-02 A |  | 0% → 100% | 666d → none |  |  |
| 2990 | Drop-in session 1 | 2025-05-14 A | 2025-05-14 A |  | 0% → 100% | 666d → none |  |  |
| 2991 | Drop-in session 2 | 2025-05-28 A | 2025-05-28 A |  | 0% → 100% | 666d → none |  |  |
| 2992 | Drop-in session 3 | 2025-06-04 → 2025-06-11 (+7d) | 2025-06-04 → 2025-06-11 (+7d) |  |  | 666d → 657d |  | constraint none → start no earlier than 2025-06-11; baseline start 2025-06-04 → 2025-06-11; baseline finish 2025-06-04 → 2025-06-11 |
| 2994 | Q+A documents from sessions published | 2025-06-04 → 2025-06-18 (+14d) | 2025-06-04 → 2025-06-18 (+14d) |  |  | 666d → 657d | 2992 → 2993 | baseline start 2025-06-04 → 2025-06-18; baseline finish 2025-06-04 → 2025-06-18 |
| 2995 | **MCC Stood up** |  |  |  | 40% → 50% |  |  |  |

| ID | Task | Start | Finish | Duration | Complete | Total float | Predecessors | Other |
| --- | --- | --- | --- | --- | --- | --- | --- | --- |
| 2996 | Migration Planning Management Tool Delivery |  |  |  | 40% → 54% |  |  |  |
| 2997 | **MCC Operational** | 2025-04-23 A |  |  |  |  |  |  |
| 2998 | **MCC Dress Rehersal 1 - Initialise Schedule (Weekly) Drop 1, 2** | 2025-04-23 A | 2025-07-15 → 2025-07-22 (+7d) | 60d → 65d |  | 637d → 632d |  |  |
| 2999 | Issue Dress Rehearsal support information to all Suppliers (SIT & Non-SIT) | 2025-04-23 A | 2025-04-23 A |  | 0% → 100% | 637d → none |  | was named Issue Dress Rehearsal support information to Participants |
| 3000 | Kestrel Webinar 1 | 2025-04-23 A | 2025-04-23 A |  | 0% → 100% | 637d → none |  |  |
| 3001 | Onboard and connectivity testing - Dress Rehearsal with Suppliers (All SIT and Wave 1 mandatory) | 2025-04-25 A | 2025-04-25 A |  | 0% → 100% | 637d → none |  |  |
| 3002 | Dress rehearsal start | 2025-04-28 A | 2025-04-28 A |  | 0% → 100% | 637d → none |  |  |
| 3010 | Dress rehearsal completion report |  |  |  |  |  | 3009 → 3009, 3006 |  |
| 3023 | **Migration Artefact Development and Publication** |  |  |  | 60% → 73% |  |  |  |
| 3066 | **Data Cleanse Plan** |  | 2025-10-15 → 2025-09-24 (-21d) | 685d → 670d | 90% → 95% | 571d → 586d |  |  |
| 3071 | **MTDs** |  |  |  | 70% → 86% |  |  |  |
| 3072 | **ESME ID** |  | 2025-05-16 A |  | 85% → 100% | 679d → none |  |  |
| 3076 | Suppliers complete Work Off plans |  | 2025-05-16 A |  | 83% → 100% | 679d → none |  |  |
| 3077 | ESME ID Complete | 2025-05-16 A | 2025-05-16 A |  | 0% → 100% | 679d → none |  |  |
| 3078 | **Meter Location and Number of Displayed Register Digits** |  |  |  | 57% → 75% |  |  |  |
| 3082 | Suppliers complete Work Off plans |  |  |  | 49% → 70% |  |  |  |
| 3084 | **Registration Data** |  | 2025-10-15 → 2025-09-24 (-21d) | 289d → 274d | 81% → 85% | 571d → 586d |  |  |
| 3093 | **Domestic Premises Indicator** |  | 2025-10-15 → 2025-09-24 (-21d) | 29d → 14d |  | 571d → 586d |  |  |
| 3094 | The DCC to extract Domestic Premises Indicator from the CSS and provide a file to each LDSO and EES. |  |  |  |  |  | 1935FS-14d → none |  |
| 3097 | **Connection Type and Meter Type Misalignments** |  |  |  | 24% → 47% |  |  |  |
| 3098 | **Traditional Meters installed on Current Transformers** |  |  |  | 7% → 15% |  |  |  |
| 3099 | Suppliers investigate all MPANs with Traditional Meters installed on a Current Transformer Connection Type |  | 2025-05-30 A |  | 57% → 100% | 301d → none |  |  |
| 3100 | Suppliers to raise the relevant SDEP cases with LDSOs in pot 3 | 2025-05-30 A | 2025-05-30 A |  | 0% → 100% | 629d → none |  |  |
| 3101 | Suppliers to have ensured that Meter Operators have sent the necessary D0312s for MPANs in pot 2 | 2025-06-02 A |  |  | 0% → 14% |  |  |  |
| 3102 | LDSOs will be required to have corrected all of these Connection Types in pot 3 | 2025-06-02 A |  |  | 0% → 8% |  |  |  |
| 3103 | Suppliers to have completed meter exchanges for those MPANs in pot 1 | 2025-06-02 A |  |  | 0% → 1% |  |  |  |
| 3105 | **CHECK Meters** |  | 2025-06-02 A |  | 57% → 100% | 668d → none |  |  |
| 3106 | Suppliers and their appointed Meter Operator investigate MPANs within their portfolio that have incorrectly populated meters with the Meter Type CHECK within MPRS. Meter Operators are required to send a D0312 to remove the CHECK meter from MPRS. |  | 2025-05-30 A |  | 57% → 100% | 669d → none |  |  |
| 3107 | Once CHECK meters are either removed from MPRS or the Meter Type is changed to a valid Meter Type, the LDSO should check that the Connection Type assigned to the MPAN is still valid. |  | 2025-05-30 A |  | 57% → 100% | 669d → none |  |  |
| 3108 | Suppliers confirm to the Programme that they have completed this activity | 2025-06-02 A | 2025-06-02 A |  | 0% → 100% | 668d → none |  |  |
| 3109 | CHECK Meters complete | 2025-06-02 A | 2025-06-02 A |  | 0% → 100% | 668d → none |  |  |
| 3110 | **Smart Meter Types installed on CT Connection Types** |  |  |  | 24% → 59% |  |  |  |
| 3112 | LDSOs investigate Connection Type misalignments and correct where appropriate |  | 2025-05-30 A |  | 44% → 100% | 629d → none |  |  |
| 3113 | LDSOs raise SDEP queries with Suppliers where they believe there is an issue | 2025-05-30 A | 2025-05-30 A |  | 0% → 100% | 629d → none |  |  |
| 3114 | Suppliers resolve all issues | 2025-06-02 A |  |  | 0% → 8% |  |  |  |
| 3116 | **Linked Import / Export MPANs** |  |  |  | 30% → 65% |  |  |  |
| 3117 | LDSOs review and correct linked Import / Export MPANs with Different Connection Types |  |  |  | 30% → 65% |  |  |  |
| 3118 | LDSOs, Import and Export Suppliers review and correct linked Import / Export MPANs with meters in the Advanced and Traditional or Smart Meter Groups |  |  |  | 30% → 65% |  |  |  |
| 3120 | **Related MPANs** |  |  |  | 35% → 65% |  |  |  |
| 3121 | LDSOs review and correct related MPANs with different Connection Types |  |  |  | 46% → 85% |  |  |  |
| 3123 | Suppliers should investigate Related MPANs within different meter groups and verify that they are correct or request that their Meter Operators update the Meter Types where they are incorrect |  |  |  | 35% → 65% |  |  |  |
| 3155 | **Preparation for Cutover to Live** | 2024-06-28 A → 2022-10-31 A (-606d) |  | 744d → 1178d | 3% → 18% |  |  |  |
| 3156 | **Central Systems Prepare for Cutover to Live** | 2024-06-28 A → 2022-10-31 A (-606d) |  | 326d → 760d | 7% → 51% |  |  |  |
| 3158 | **Development of Comms Approach and Declaration Guidance** |  |  |  | 3% → 39% |  |  | baseline start 2025-03-03 → 2025-04-28; baseline finish 2025-06-19 → 2025-08-14 |
| 3159 | Draft Cutover Comms Approach |  |  |  | 5% → 39% |  |  |  |
| 3161 | Finalised Cutover Comms Approach shared |  |  |  |  |  | 3160FS+20d, Implementation Group EstablishedFS+20d → 3160FS+20d |  |
| 3162 | **Development of Cutover Plan requirements with Participants** |  |  |  | 10% → 55% |  |  |  |
| 3163 | Development of Central Parties Cutover Plans |  | 2025-05-16 A |  | 31% → 100% | 659d → none |  | baseline start 2025-04-28 → 2025-04-11; baseline finish 2025-07-17 → 2025-05-16 |
| 3164 | Development of Programme Participant Cutover Plans |  | 2025-06-27 → 2025-06-30 (+3d) | 56d → 57d | 14% → 68% | 33d → 67d |  | baseline start 2025-07-17 → 2025-04-11; baseline finish 2025-07-17 → 2025-06-30 |
| 3165 | Central Party Cutover Plan Assurance |  |  |  | 16% → 73% |  |  |  |
| 3166 | Consolidated MHHS Cutover Plan Developed | 2025-05-19 A |  |  | 0% → 65% |  |  |  |
| 3169 | **M10/M11 Cutover Activities** | 2025-09-05 → 2022-10-31 A (-1040d) |  | 15d → 760d |  | 12d → 584d |  |  |
| 3172 | Completion of the pre-M10 MHHS Data Cleanse | 2025-09-24 → 2025-09-22 (-2d) | 2025-09-24 → 2025-09-22 (-2d) |  |  | 586d → 588d |  |  |
| 3173 | Market-wide Participant MHHS Supporting Functionality Ready - Confirmation from Code Bodies | 2025-09-15 → 2022-10-31 A (-1050d) | 2025-09-15 → 2022-10-31 A (-1050d) |  | 0% → 100% | 594d → none | 1935FS-8d → none |  |
| 3174 | Market-wide Participant MHHS Supporting Functionality Ready |  |  |  |  | 589d → 588d | 1935FS-3d → 1935 |  |
| 3191 | Confirmation that Market Segment has been populated for 95% of LDSO portfolios |  |  |  |  | 5d → 7d |  | baseline start none → 2025-09-12; baseline finish none → 2025-09-12 |
| 3199 | TORWG (Recommendation from TORWG that the Programme should enter M10) |  |  |  |  | 5d → 7d | 3190FS+1d, 3194FS+1d, 3196FS+3d, 3170FS+1d, 3171FS+1d, SIT LDSOs Create Certificates and Test ConnectivityFS+1d, 3192FS+3d, 3193FS+3d, 3195FS+3d, 3197, 3198 → 3190FS+1d, 3194FS+1d, 3196FS+3d, 3170FS+1d, 3171FS+1d, 3192FS+3d, 3193FS+3d, 3195FS+3d, 3197, 3198 |  |
| 3200 | MCAG (Confirm that the Programme can Enter M10) |  |  |  |  | 5d → 7d | 3199FS+2d, SIT MVC Service Activation Implementation Complete → 3199FS+2d |  |
| 3205 | Recommendation from TORWG that PSG should approve M10 |  |  |  |  |  | 3201FS+1d, 3202FS+1d, 3203FS+1d, 3204FS+1d, SIT LDSOs to update systems with ISD → 3201FS+1d, 3202FS+1d, 3203FS+1d, 3204FS+1d |  |
| 3211 | TORWG (Confirmation of Qualified Parties from TORWG) |  |  |  |  |  | 3208FS+1d, 3209FS+1d, 3210FS+1d, 3186, SIT MVC S&As Create Certificates and Test Connectivity, SIT MVC S&As to update systems with ISD → 3208FS+1d, 3209FS+1d, 3210FS+1d, 3186 |  |
| 3221 | Sprint Execution Start |  |  |  |  |  | 3220FS+5d, SIT MVC Service Activation Implementation Complete, 3313 → 3220FS+5d, 3313 |  |
| 3308 | Assurance of DCC capacity upgrade to ensure suitability to support migration |  |  |  |  |  | 1935FF-23d → 1935FF-21d |  |
| 3310 | **Migration - Tier 1 Milestones** | 2025-09-24 → 2025-09-22 (-2d) |  | 488d → 490d |  | 25d → 27d |  |  |
| 3311 | Load Shaping Service switched on (M13) | 2025-09-24 → 2025-09-22 (-2d) | 2025-09-24 → 2025-09-22 (-2d) |  |  | 25d → 27d |  |  |
| 3312 | Load Shaping Service switched on (M13*) - Late Exit |  |  |  |  |  | 3311FS+65d → 3311FS+67d |  |
| 3313 | Start of 18-month migration for UMS / Advanced (M11) |  |  |  |  |  | 3311, 3212, 3213, SIT MVC Service Activation Implementation Complete, 1935FS+20d → 3311, 3212, 3213, 1935FS+20d |  |
| 3315 | Start of 18-month migration for Smart / Non-smart (M12) |  |  |  |  |  | 3311, 1935FS+20d → 3311, 1935FS+22d |  |
| 3319 | **BUSINESS & OPERATIONAL READINESS** |  |  |  | 11% → 38% |  |  |  |
| 3325 | **Early Life Support Model** |  | 2025-04-29 A |  | 99% → 100% | 692d → none |  |  |
| 3330 | MCAG Approval of Early Life Support Model | 2025-04-29 A | 2025-04-29 A |  | 0% → 100% | 692d → none |  |  |

| ID | Task | Start | Finish | Duration | Complete | Total float | Predecessors | Other |
| --- | --- | --- | --- | --- | --- | --- | --- | --- |
| 3332 | Hypercare post M10 | 2025-09-25 → 2025-09-23 (-2d) |  | 80d → 82d |  |  |  |  |
| 3334 | **Service Activation** | 2022-10-31 A |  |  | 0% → 23% |  |  |  |
| 3418 | DIP Promoted to Production | 2025-12-19 → 2025-09-09 (-101d) | 2025-12-19 → 2025-09-09 (-101d) |  |  | 505d → 597d | Add EDF to DIP → 3417 | constraint finish no earlier than 2025-06-05 → none; baseline start 2025-12-25 → none; baseline finish 2025-12-26 → none |
| 3420 | Create M16 in Customer Solution | 2025-12-22 → 2025-09-08 (-105d) | 2025-12-23 → 2025-09-08 (-106d) | 2d → 1d |  | 505d → 598d | 3418 → 3419SS, 3423SS | constraint finish no earlier than 2025-06-06 → none; baseline start 2025-12-29 → none; baseline finish 2025-12-30 → none |
| 3435 | Issue Management | 2025-12-18 → 2022-11-08 (-1136d) | 2026-01-12 → 2023-01-20 (-1088d) | 18d → 54d |  | 508d → 1274d | Add EDF to DIPSS → 3431 | constraint finish no earlier than 2025-06-25 → none; baseline start 2025-06-02 → none; baseline finish 2025-06-25 → none |
| 3465 | Publish ISD | 2025-09-18 → 2022-11-01 (-1052d) | 2025-09-19 → 2022-11-07 (-1047d) | 2d → 5d |  | 5d → 1338d | 2230 → 3461SS | constraint finish no earlier than 2025-03-07 → none; baseline start 2025-09-18 → none; baseline finish 2025-09-19 → none |
| 3491 | MHHSP Enabled Confirmation |  |  |  |  |  | MHHSP Confirms SIT Non-MVC PPs MHHS Enabled → none |  |
| 3625 | **PP Business Change** | 2025-02-03 A | 2025-07-31 A |  | 0% → 100% | 625d → none |  |  |
| 3626 | Plan stakeholder management | 2025-02-03 A | 2025-07-31 A |  | 0% → 100% | 625d → none |  |  |
| 3627 | Manage stakeholders | 2025-02-03 A | 2025-07-31 A |  | 0% → 100% | 625d → none |  |  |
| 3628 | Develop & implement changes to KPIs, organisation & people management | 2025-02-03 A | 2025-07-31 A |  | 0% → 100% | 625d → none |  |  |
| 3629 | Develop & test changes to business processes | 2025-02-03 A | 2025-07-31 A |  | 0% → 100% | 625d → none |  |  |
| 3630 | Develop and deliver training | 2025-02-03 A | 2025-07-31 A |  | 0% → 100% | 625d → none |  |  |
| 3631 | Programme support for PP Business Change activities | 2025-02-03 A | 2025-07-31 A |  | 0% → 100% | 625d → none |  |  |
| 3688 | **READINESS ASSESSMENTS** |  |  |  | 23% → 33% |  |  |  |
| 3696 | **Readiness Assessment 5 / 6 - Start of Qualification and Participant Readiness for M10 and M11 and CP3/CP4 check** | 2025-04-28 A |  |  | 0% → 46% |  |  |  |
| 3697 | Launch Readiness Assessment survey | 2025-04-28 A | 2025-04-28 A |  | 0% → 100% | 647d → none |  |  |
| 3698 | PPs submit survey responses | 2025-04-28 A | 2025-05-16 A |  | 0% → 100% | 647d → none |  |  |
| 3699 | Analyse survey responses | 2025-05-19 A | 2025-06-06 → 2025-06-27 (+21d) | 15d → 30d | 0% → 43% | 647d → 649d |  | baseline finish 2025-06-06 → 2025-06-27 |
| 3700 | Conduct deep-dive interviews (sample of PPs) | 2025-05-19 A | 2025-06-06 → 2025-06-27 (+21d) | 15d → 30d | 0% → 43% | 647d → 649d | 3698 → none | constraint none → start no earlier than 2025-05-19; baseline finish 2025-06-06 → 2025-06-27 |
| 3701 | Produce Readiness Assessment Reports (Overall Report & Individual Participant Reports) |  |  |  |  |  | 3699, 3700 → none | constraint none → start no earlier than 2025-06-09 |
| 3702 | Readiness Assessment 5 / 6 - Start of Qualification and Participant Readiness for M10 and M11 and CP3/CP4 check (incl. Readiness Assessment Report approval) Completed |  |  |  |  |  |  | constraint none → finish no earlier than 2025-07-01 |
| 3738 | Control Point 3/4 - Readiness for Migration (incl. Control Point Report approval) |  |  |  |  |  | 1935FS-5d → 1935FS-3d |  |
